# 3GPP_Release-2000

Schedule from MS Project, 1999-01-01 to 2012-09-17, A marks actual dates.

## Calendars

- Standard: Mon-Fri 08:00-12:00, 13:00-17:00; Sat-Sun off. Exceptions (off unless hours are given): 2000-01-15 08:00-12:00, 13:00-17:00, 2009-05-30 08:00-12:00, 13:00-17:00.

## Resources

| Resource |
| --- |
| NP |
| N1 |
| N2 |
| N3 |
| N4 |
| N5 |
| TP |
| T1 |
| T2 |
| T3 |
| RP |
| R1 |
| R2 |
| R3 |
| R4 |
| SP |
| S1 |
| S2 |
| S3 |
| S4 |
| S5 |
| PCG |
| GP |
| No |
| CN4 |
| ? |
| WG G2 |
| G2 |
| G1 |
| G4 |
| G3 |
| All |
| Generic |
| MLST |
| G5 |
| S3, G2 |
| WG T2 |
| GP,G1 |
| G4,G5 |
| OMA |
| GP-G2 |
| Yes |
| GP, |
| N4, |
| GP, N1 |
| CT5 |
| C5 |
| C1 |
| C4 |
| C3 |
| C6 |
| G1, |
| 4 |
| ct |
| c,s,r |
| CT,RAN,SA |
| G2, |
| G1, G3 |
| CT6 |
| CT1 |
| CT1, CT3, CT4 |
| C1, C3, C4 |
| CP |
| R5 |
| C |
| Rel-8 |
| GP, G2 |
| R1,R4 |
| S5,C1 |
| CT,RAN,SA,GERAN |
| S3,C1,C4 |
| 5 |
| S1,C1,C3,C4,S5 |
| S1,C1,C3,C5 |
| S1,C1,C3,C4 |
| S1,S5 |
| S2,S3 |
| RAN,SA |
| RP,S5 |
| S2,CT |
| S1,CT |
| S1,CT,GERAN |
| S1,C5 |
| S3,CT |
| S4,CT |
| C1,SA |
| S1,S2 |
| S1,S4 |
| S2,S2,S3,CT |
| S2,S3,CT |
| S1,CT,GX |
| S1,S4,CT |
| S2,S2,S3,S5,CT |
| S1,S2,CT |
| S1,S2,S3,CT |
| S1,S2,S3,S5CT |
| S1,S2,S3,S5,CT |
| S2,S5,CT |
| S4,S3 |
| S1,C1 |
| CP,C1 |
| C1,C3 |
| C1,C3,C4 |
| S1,S5,CT |
| C4,C3 |
| CP,RAN,SA,GERAN |
| S1,S2,S3,S5,CP |
| S2,S3,CP |
| S2,CP |
| S1,CP,GX |
| S1,CP |
| S1,S4,CP |
| S1,S2,CP |
| S1,S2,S3,CP |
| S2,S5,CP |
| S3,CP |
| S1,S5,CP |
| RAN,SA,GERAN |
| S1,S2,S3,S5,C1,C3,C4,C6 |
| S2,S3,C1,C3,C4 |
| S2,C4 |
| S2,C1,C3,C4 |
| S2,C1,C4 |
| S2,S3,C1,C4 |
| S1,C1,C4,G2 |
| C1,C4 |
| S1,C1,C3 |
| S1,S4,C1,C3,C4 |
| S1,S2,S3,C1,C3,C4 |
| S2,S5,C3 |
| S1,S2,C1,C4 |
| S2,C1 |
| S2,C1,C3 |
| S3,C1,C3,C4 |
| S1,S5,C1,C3,C4 |
| S2,C3,C4 |
| C3,C1 |
| R2,R4 |
| R2,R5 |
| RP,R5 |
| RP,S5,R5 |
| R1,R5 |
| S1,C1,R5 |
| S1,C1,S4,R5 |
| GERAN |
| G3new |
| G1, G3new |
| C4,C1,C3 |
| R1.R4 |
| R1, R4 |
| R2,R3 |
| C3,C4 |
| S4,C3 |
| S4,C3,C1,C4 |
| S1,S2,C1 |
| S1,S2<C1,C3,C4 |
| S1,S2,C1,C3,C4 |
| S5,C1,C3,C4 |
| GP,C4 |
| C4,C1 |
| S2,S1 |
| RP,SP,GP |
| RP,SP,CP,GP |
| CP,GP,RP,SP |
| GP,C4,S4 |
| S1,C1,C4 |
| S1,S2,C3,C1 |
| R2,R4,R3 |
| CP,GP, RP,SP |
| S2,S1,C1,S5 |
| S2,S1,C1 |
| S1,C1,S4 |
| S1,S2,GP,C4,R2 |
| S1,GP,R2 |
| S1,C6 |
| S1,S2,C1,S4 |
| S2,S3,S5,C1,C3,C4 |
| S2,S5,C1 |
| S2,S3,S5 |
| CP,GP, RP,SP,TP |
| S2,C4,C1 |
| S1,C1,C4,S3 |
| S2,S5 |
| S3,C1 |
| S3,C4 |
| S1,C4 |
| S2,S5,C3,C1 |
| S2,S1,S5,C1,C4 |
| S1,R1,C3 |
| S1,C1,R2 |
| S2,S1,C1,C4 |
| S1,C1,C6 |
| GP,S4,C4,C1,C3 |
| C3,C1,C4 |
| S1,C4,C1 |
| S1,S3 |
| S1,S2,S5,C3,C4 |
| R4,G1 |
| G1,R4 |
| RP,GP |
| R4,GP |
| R3,R2 |
| C6,RP,SP |
| R5,C6 |
| CP,RP,SP |
| RP,SP,CP |
| R3,S5 |
| S1,S2,RP |
| S1,S2,S5,RP |
| S2,S1,RP |
| Rel-9 |
| S3,C6 |
| S1,S2,S3,S5,RP |
| S2,S1,S3 |
| S1,S2,S3 |
| S1,S2,S3,S5 |
| C6,R5 |
| S1,S2,RP,GP |
| S1,S2,S4,S5,RP,GP |
| GP,G2 |
| GP,GP, N1 |
| GP,S2,G1,G2 |
| GP,R2,R3,S2,G1,G2 |
| GP,S2,S5,R2,R3,G2,G1 |
| GP,R3 |
| N4,S2 |
| GP,RP |
| GP,S2,RP |
| G5,G4 |
| G4,R3 |
| S2,R2,R4 |
| S1,S2,R2,R4 |
| GP,S5 |
| S1,S2,S5 |
| R4,R5 |
| R4,R2,R3,R5 |
| S2,S5,N4,RP |
| S1,S2,S3,S5,NP |
| S2,S4,S5 |
| T2,S1,S4,S5 |
| SP,RP |
| S2,RP |
| S1,S2,CP,G2 |
| CP,SP |
| S1,G2 |
| SP,CP |
| S1,S2,S5,C3 |
| S1,C1,S3 |
| G1,G3new |
| C4, C3, C1C4 |
| C4,C3,C1 |
| S1,S2,S3,S5,R2,R3,R4 |
| S1,S2,S3,R2 |
| S2,S3,S5,C4,R2 |
| S1,S5,C1 |
| S1,S2,S3,C1,C3,C4,R2 |
| Ggp |
| S3,S2,C1,C4,G2 G3new |
| R1,R2,R3,R4 |
| R4,R1,R2,R3 |
| R4,R2,R3 |
| S1,C1,C4,R2 |
| R4,R2 |
| S2,C4,R2,R4 |
| S2,C4,R2 |
| S2,S3,S5,C3,C4,R2 |
| S1,S2,S4,T2 |
| S1,S2,S4 |
| S1,S2,S4,R5 |
| S3,S2,C1,C4,G2,G3new |
| GP,C1 |
| S1,S5,C4 |
| S1,S2,S3,S5,R2,R3,R4,GP |
| GP,C4,C3,C1 |
| SMG9 |
| SMG1 |
| SMG2 |
| N3,R5 |
| N1, N2, N4, G1, G2, R3, S1, SMG2 |
| S1,SMG1 |
| SMG1,N4 |
| N1,C1,N4,S1,T2,G2,SMG1,SMG2,SMG3,SMG7,SMG9 |
| SMG1,N2 |
| S1,S2,N2,N4 |
| N4,N2 |
| G1,G2 |
| G1,G2,C1 |
| G1,G2,N1 |
| SMG2, SMG1, SMG3, SMG4, SMG7, SMG9, SMG10, G1, G2, G3, N1, N3, T2 |
| SMG2,G1 |
| S1,G1,G2 |
| SMG1,N1,G1,G2 |
| G2,G1 |
| G1,G2,G3,S1,S2,SMG1,SMG2,SMG7,N1,N2,N3,N4,T2 |
| 23.003, 23.008, 29.060 |
| S1, S2, SMG1, SMG2, SMG12, G2, N1, N2, N4 |
| S1,S2,SMG1,SMG2,SMG12,G2,N1,N2,N4 |
| S1,SMG2,N1,N2,N4 |
| SMG1,T2 |
| S1,N1,N2,N4 |
| S1,S2,N5 |
| SMG2,SMG7,G2,T2 |
| S3,N1,N2,N3 |
| S3,N1,N2,N4 |
| SMG9,T3 |
| SMG2,SMG3,SMG7,G2,N2 |
| SMG2,N1,G1,G2 |
| S1,N2 |
| N1,N3 |
| S2,N1 |
| N1,N2,N4 |
| N2,N1,N4 |
| N2,N4 |
| S1,T3 |
| T2,N3 |
| S3,N2 |
| T2,S1 |
| S1,N4 |
| SMG1,SMG2,SMG7 |
| N1,S1,T1 |
| SMG1,SMG3 |
| N4,S2,N1 |
| S1,S2,SMG1,SMG2,SMG7,G1,G2,G3,N1,N2,N3,N4,T2 |
| SMG1,N3 |
| S1,N3 |
| CP,SP,SMG |
| CP,SP,TP,GP,SMG |
| NP,SP,TP,GP,SMG |
| NP,GP, RP,SP,TP |
| SMG2,SMG1,SMG3,SMG4,SMG7,SMG9,SMG10,G1,G2,G3,N1,N3,T2 |
| S1,N2,N4 |
| S1,S2,S3,C1,C3,C4,R2,R3 |
| R2,R3,R1,R4 |
| R2,R3,R4 |
| R2,R1,R3,R4 |
| S2,C4,R2,R3,R4 |
| S2,C4,R2,R1,R3,R4 |
| S2,S3,S5,C3,C4,R2,R3,R4 |
| R1,R2,R4 |
| R3,R1,R4 |
| S2, |
| S2,G2, |
| S1,S2,G2, |
| S1,S2,G2,R2,R3, |
| S1,S2,C4,G2,R2,R3 |
| S1,S2,N4,G2,R2,R3 |
| S1,S2,SMG1,SMG2,SMG12,G2,N1,N2,N4,R2,R3 |
| S1,SMG1,T2 |
| S1,SMG1,S2 |
| S1,N4,N2 |
| T2,N1,N3 |
| S3,N2,N4 |
| SMG1,SMG2,SMG3,SMG7,SMG9,N1,C1,N4,S1,T2,G2 |
| SMG1,N2,N4 |
| S2,T2,N1,N2,N4 |
| S1,T2 |
| S1,S2,C4 |
| S1,S2,N4,RP |
| S2,N4 |
| S1,S2,N3,N4,RP |
| S1,S2,SMG1,SMG2,SMG12,T2,G2,N1,N2,N4,R2,R3 |
| S1,T2,N1,N3 |
| S1,S2,SMG1,SMG2,SMG12,T2,G2,N1,N2,N3,N4,R2,R3 |
| S1,S2,S3,SMG1,SMG2,SMG12,G2,N1,N2,N4,R2,R3 |
| S1,S2,SMG,G1,G2,G3,N1,N2,N3,N4,T2 |
| S1,S2,SMG,T2,G2,N1,N2,N3,N4,R2,R3 |
| S1,S3,SMG,G1,G2,G3,N1,N2,N3,N4,T2 |
| S1,S3,T2,N2,N4 |
| S1,S2,SMG,T2,G1,G2,G3,N1,N2,N3,N4 |
| G2,S2 |
| T1,R5 |
| R5,T1 |
| S1,S2,S4,T1,R5 |
| S1,S2,S4,S5,T1,RP,GP |
| S1,S2,S3,S5,R2,R3,R4,GP,C1 |
| S1,S2,S3,SMG1,SMG2,SMG12,N1,N2,N4,R2,R3 |
| S1,S2,SMG,T2,N1,N2,N3,N4,R2,R3 |
| NP,SP,TP,SMG |
| S1,S2,SMG,T2,N1,N2,N3,N4 |
| SMG,N1 |
| SMG |
| S1,S2,SMG1,SMG2,SMG7,N1,N2,N3,N4,T2 |
| SMG2,SMG1,SMG3,SMG4,SMG7,SMG9,SMG10,N1,N3,T2 |
| S1,SMG |
| SMG2,SMG7,T2 |
| SMG2,S2 |
| N1,N2,N4,R3,S1,SMG |
| SMG2,SMG3,SMG7,N2 |
| SMG1,SMG2,SMG3,SMG7,SMG9,N1,C1,N4,S1,T2 |
| S1,S2,SMG,N3,N4,RP |
| S1,S2,S4,SMG,N3,N4,RP |
| S2,C1,C4,R2,R1,R3,R4 |
| R2,S2,S4 |
| G3new,R5 |
| GP,R4 |
| S2,S4,R2 |
| SP,GP |
| RP,SP |
| S2,S1,S3,S5 |
| S3,S1 |
| N4,N1,N2,S2 |

## Schedule

| ID | WBS | Task | Type | Duration | Start | Finish | Complete | Remaining | Baseline start | Baseline finish | Baseline duration | Total slack | Constraint | Resources | Work | Actual work | Text6 | Text1 | Text2 | Text4 | Text5 | Text7 | Text8 | Text9 | Text12 |
| --- | --- | --- | --- | --- | --- | --- | --- | --- | --- | --- | --- | --- | --- | --- | --- | --- | --- | --- | --- | --- | --- | --- | --- | --- | --- |
| 1 | 1 | Version 2009 Oct 15 |  | 3318d? | 2000-01-03 | 2012-09-17 |  |  | 2000-01-03 | 2012-09-17 | 3318d? | 0d | start no earlier than 2000-01-03 |  |  |  |  |  |  |  |  |  |  |  |  |
| 2 | 2 | SA3 Rel-9 Stage 2 exceptions to 12/2009 |  | 1d? | 2000-01-03 | 2000-01-03 |  |  | 2000-01-03 | 2000-01-03 | 1d? | 3317d |  |  |  |  |  |  |  |  |  |  |  |  |  |
| 3 | 3 | "CTRL + a" to display all the 3GPP fields |  | 1d | 2000-01-03 | 2000-01-03 |  |  | 2000-01-03 | 2000-01-03 | 1d | 3317d |  |  |  |  |  |  |  |  |  |  |  |  |  |
| 5 | 4 | Gantt: dark blue=done; light blue=to be done; grey: previous values; black=summary |  | 1d? | 2000-01-03 | 2000-01-03 |  |  | 2000-01-03 | 2000-01-03 | 1d? | 3317d | start no earlier than 2000-01-01 |  |  |  |  |  |  |  |  |  |  |  |  |
| 7 | 5 | Release 10 Features | milestone | 0d? | 2000-01-01 | 2000-01-01 |  |  | 2000-01-01 | 2000-01-01 | 0d? | 3318d |  | RP,SP |  |  | Rel-10 |  |  |  |  |  |  |  |  |
| 8 | 6 | **Enhanced Home NodeB / eNodeB continuation of Rel-9** |  | 395d? | 2008-12-11 A | 2010-06-15 | 35% | 256.75d? | 2008-12-11 | 2010-06-15 | 395d? | 589d |  | S2 | 6312h | 2209.2h | Rel-10 | eEHNB | PCG-23 | Alcatel-Lucent | Nicolas Drevon | SP-44 | Maurice |  |  |
| 9 | 6.1 | IMS aspects of Architecture for Home NodeB |  | 394d? | 2008-12-11 A | 2010-06-15 | 35% | 256.1d? | 2008-12-11 | 2010-06-15 | 394d? | 589d | finish no earlier than 2010-06-15 | S2 | 3152h | 1103.2h | Rel-10 | EHNB-IMS | PCG-22 | Alcatel-Lucent | Nicolas Drevon | SP-42 | Maurice |  |  |
| 10 | 7 | H(e)NB enhancements |  | 126d? | 2009-09-24 | 2010-03-18 |  |  | 2009-09-24 | 2010-03-18 | 126d? | 652d | finish no earlier than 2010-03-18 | S1 | 1008h |  | Rel-10 | EHNBF | PCG-23 | NEC | joerg.swetina@nw.neclab.eu | SP-45 | Alain |  |  |
| 11 | 8 | **Registration in Densely-populated area (RED)** |  | 665d? | 2007-03-12 A | 2009-09-24 A | 100% |  | 2007-03-12 | 2009-09-24 | 665d? |  |  | S1 | 9544h | 9544h | Rel-10 | RED |  | NTT DoCoMo | tanakai@nttdocomo.co.jp | SP-35 | Alain |  |  |
| 12 | 8.1 | Stage 1 for RED |  | 4d? | 2007-03-12 A | 2007-03-15 A | 100% |  | 2007-03-12 | 2007-03-15 | 4d? |  | start no earlier than 2007-03-12 | S1 | 32h | 32h | Rel-10 | RED |  | NTT DoCoMo | takakurat@s1.nttdocomo.co.jp | SP-35 | Alain |  |  |
| 13 | 8.2 | Deleted - Stage 2 for RED |  | 524d? | 2007-09-25 A | 2009-09-24 A | 100% |  | 2007-09-25 | 2009-09-24 | 524d? |  | finish no earlier than 2009-09-24 | S2 | 4192h | 4192h | Rel-10 | RED |  | NTT DoCoMo | tanakai@nttdocomo.co.jp | SP-37 | Maurice | PCG-23 | SP-45 |
| 14 | 9 | **Network Improvements for Machine-Type Communications** |  | 452d? | 2008-09-18 A | 2010-06-10 | 38% | 280.1d? | 2008-09-18 | 2010-06-10 | 452d? | 592d |  | S1,S2 | 7680h | 2920.82h | Rel-10 | NIMTC | PCG-21 | KPN | Toon Norp (toon.norp AT tno.nl) | SP-41 | Alain |  |  |
| 15 | 9.1 | Stage 1 for NIMTC |  | 322d? | 2008-09-18 A | 2009-12-10 | 60% | 128.8d? | 2008-09-18 | 2009-12-10 | 322d? | 722d | finish no earlier than 2009-12-10 | S1 | 2576h | 1545.6h | Rel-10 | NIMTC | PCG-21 | KPN | Toon Norp (toon.norp AT tno.nl) | SP-41 | Alain |  |  |
| 16 | 9.2 | Stage 2 for NIMTC |  | 186d? | 2009-09-24 | 2010-06-10 |  |  | 2009-09-24 | 2010-06-10 | 186d? | 592d | finish no earlier than 2010-06-10 | S2 | 1488h |  | Rel-10 | NIMTC | PCG-23 | Samsung | Erik Guttman (erik.guttman@partner.samsung.com) | SP-45 | Maurice |  |  |
| 17 | 10 | **GTP-based S8 chaining** |  | 262d? | 2008-12-11 A | 2009-12-10 | 35% | 170.3d? | 2008-12-11 | 2009-12-10 | 262d? | 722d |  | S2 | 4192h | 1467.2h | Rel-10 | GTPchaining | PCG-22 | Huawei | Haining Wang (wanghaining@huawei.com) | SP-42 | Maurice |  |  |
| 18 | 10.1 | Stage 2 for GTPchaining |  | 262d? | 2008-12-11 A | 2009-12-10 | 35% | 170.3d? | 2008-12-11 | 2009-12-10 | 262d? | 722d | finish no earlier than 2009-12-10 | S2 | 2096h | 733.6h | Rel-10 | GTPchaining | PCG-22 | Huawei | Haining Wang (wanghaining@huawei.com) | SP-42 | Maurice |  |  |
| 19 | 11 | Multi Access PDN Connectivity |  | 263d? | 2009-03-13 A | 2010-03-15 | 75% | 65.75d? | 2009-03-13 | 2010-03-15 | 263d? | 655d | finish no earlier than 2010-03-15 | S2 | 2104h | 1578h | Rel-10 | MAPCON | PCG-22 | Telecom Italia | ivano.guardini@telecomitalia.it | SP-43 | Maurice |  |  |
| 20 | 12 | **IMS Service Continuity – Inter Device Transfer enhancements** |  | 266d? | 2009-06-04 A | 2010-06-10 | 38% | 164.89d? | 2009-06-04 | 2010-06-10 | 266d? | 592d |  | S1,S2 | 4704h | 1619.2h | Rel-10 | IMS_SC_eIDT | PCG-23 | Huawei | Amar Deol (adeol@huawei.com) | SP-44 | Alain |  |  |
| 21 | 12.1 | Stage 1 for IMS_SC_eIDT |  | 136d? | 2009-06-04 A | 2009-12-10 | 90% | 13.6d? | 2009-06-04 | 2009-12-10 | 136d? | 722d | start no earlier than 2009-06-04 | S1 | 1088h | 979.2h | Rel-10 | IMS_SC_eIDT | PCG-23 | Huawei | Amar Deol (adeol@huawei.com) | SP-44 | Alain |  |  |
| 22 | 12.2 | IMS Inter-UE Transfer enhancements (Stage 2) |  | 186d? | 2009-09-24 | 2010-06-10 |  |  | 2009-09-24 | 2010-06-10 | 186d? | 592d | finish no earlier than 2010-06-10 | S2 | 1488h |  | Rel-10 | IMS_SC_eIDT | PCG-23 | Huawei | HengLiang Zhang (hl_zhang@huawei.com) | SP-45 | Maurice |  |  |
| 23 | 13 | **IP-Short-Message-Gateway enhancements for CPM-SMS Interworking** |  | 186d? | 2009-09-24 A | 2010-06-10 | 19% | 151.44d? | 2009-09-24 | 2010-06-10 | 186d? | 592d |  | S1,S2 | 3416.8h | 358.4h | Rel-10 | CPM-SMS | PCG-23 | China Mobile | Qing Huang | SP-45 | Alain |  |  |
| 24 | 13.1 | Stage 1 for CPM-SMS |  | 56d? | 2009-09-24 A | 2009-12-10 | 80% | 11.2d? | 2009-09-24 | 2009-12-10 | 56d? | 722d | finish no earlier than 2009-12-10 | S1 | 448h | 358.4h | Rel-10 | CPM-SMS | PCG-23 | China Mobile | Qing Huang | SP-45 | Alain |  |  |
| 25 | 13.2 | Stage 2 for CPM-SMS |  | 185.1d? | 2009-09-24 | 2010-06-10 |  |  | 2009-09-24 | 2010-06-10 | 185.1d? | 592d | finish no earlier than 2010-06-10 | S2 | 1480.8h |  | Rel-10 | CPM-SMS | PCG-23 | Orange | Antoine Mouquet | SP-45 | Maurice |  |  |
| 26 | 14 | **Completion of Communications on Not Logged-in** |  | 1d? | 2009-09-24 A | 2009-09-24 A | 100% |  | 2009-09-24 | 2009-09-24 | 1d? |  |  | S1 | 16h | 16h | Rel-10 | CCNL | PCG-23 | Deutsche Telekom | Kurt Bischinger | SP-45 | Alain |  |  |
| 27 | 14.1 | Stage 1 for CCNL |  | 1d? | 2009-09-24 A | 2009-09-24 A | 100% |  | 2009-09-24 | 2009-09-24 | 1d? |  | start no earlier than 2009-09-24 | S1 | 8h | 8h | Rel-10 | CCNL | PCG-23 | Deutsche Telekom | Kurt Bischinger | SP-45 | Alain |  |  |

Notes:
- 1: -
- 2: -
- 3: -
- 5: -
- 7: -
- 8: SP#44 Umbrella Feature created to host WIs moved out of Rel-9
- 9: SP#45 completion 12/09=>06/10. SP#44 Moved from Rel-9 to Rel-10 / Text3: 23.832, 23.232
- 10: Items beyond Rel-9 UID_400035 Enhanced Home NodeB / eNodeB (EHNB) / Text3: 22.220
- 11: SP#35 Stage 1 completed. SP#40 SA2 moved to Rel-9. SP#43 moved to Rel-10. SP#45 Stage 2 work stopped/abandoned. / Text3: WID identifies also impacted CT1 24.008, RAN2 25.331
- 12: SP#35 completed. / Text3: 22.101 CR#0207
- 13: SP#45 Stage 2 work stopped/abandoned. SP#40 SA2 moved to Rel-9. SP#43 moved to Rel-10. / Text3: draft TR 23.880 withdrawn, 23.002, 23.060, 23.221, 23.236
- 14: SP#45 updated WID SP-080649=>SP-090658 (added Stage 2). TS 22.368v100 for Information. Stage 1 completion 09/09=>12/09. Triggered by Rel-8 UID_7027 Study on Facilitating Machine to Machine Communication in GSM and UMTS (FS_M2M) TR 22.868
- 15: SP#45 TS 22.368v100 for Information. Stage 1 completion 09/09=>12/09 / Text3: 22.368
- 16: SP#45 updated WID SP-080649=>SP-090658 (added SA2 part) / Text3: 23.888 (Architectural Enhancements for machine-type communications)
- 17: Stage 1 in UID_320022 Rel-8 Requirements for evolution of the 3GPP system architecture (AIPN-SAE): 22.278, 22.011, 22.246
- 18: - / Text3: 23.402 (Chaining GTP-S8 based architecture and procedures)
- 19: SP#45 WID updated SP-090100=>SP-090659. Completion 12/09=>03/10. Triggered by TR 23.861 UID_410043 FS_MAPIM. Stage 1 in Rel-9 22.278 (6.2 - IP session control) / Text3: 23.401, 23.402, 23.237
- 20: Rel-9 set Inter-Device Transfer requirements UID_410033 (IMS_SCC-IDT). Add additional scenarios and requirements for IDT.
- 21: - / Text3: 22.228
- 22: - / Text3: 23.237, 23.292, new TR 23.8ab (IMS Inter-UE transfer enhancements)
- 23: IP-SM-GW enhancements for interworking with OMA CPM. External requirements (Stage 1 in OMA-RD-CPM-V1_0-20090310-C)
- 24: External requirements (Stage 1 in OMA-RD-CPM-V1_0-20090310-C) / Text3: 22.340 (IMS messaging)
- 25: - / Text3: 23.204 (Support of SMS over generic 3GPP IP access), new TR 23.824 (IP-SM-GW enhancements for interworking with OMA CPM)
- 26: SP#45 WID approved. Stage 1 completed
- 27: SP#45 WID approved. Stage 1 completed / Text3: 22.173 CR#0056r1 Call Completion on Not Logged in (CCNL)

| ID | WBS | Task | Type | Duration | Start | Finish | Complete | Remaining | Baseline start | Baseline finish | Baseline duration | Total slack | Constraint | Resources | Work | Actual work | Text1 | Text2 | Text4 | Text6 | Text7 | Text8 | Text11 | Text9 | Text12 |
| --- | --- | --- | --- | --- | --- | --- | --- | --- | --- | --- | --- | --- | --- | --- | --- | --- | --- | --- | --- | --- | --- | --- | --- | --- | --- |
| 28 | 15 | **Local IP Access and Selected Internet IP Traffic Offload** |  | 256d? | 2009-09-24 A | 2010-09-16 | 3% | 247.81d? | 2009-09-24 | 2010-09-16 | 256d? | 522d |  | S2,S1,S3,S5 | 9608h | 242h | LIPA_SIPTO | PCG-23 | Huawei, China Mobile | Rel-10 | SP-45 | Maurice |  |  |  |
| 29 | 15.1 | TR on LIPA_SIPTO |  | 121d? | 2009-09-24 | 2010-03-11 |  |  | 2009-09-24 | 2010-03-11 | 121d? | 657d | finish no earlier than 2010-03-11 | S2 | 968h |  | LIPA_SIPTO | PCG-23 | Huawei, China Mobile | Rel-10 | SP-45 | Maurice |  |  |  |
| 30 | 15.2 | Stage 1 for LIPA_SIPTO |  | 121d? | 2009-09-24 A | 2010-03-11 | 25% | 90.75d? | 2009-09-24 | 2010-03-11 | 121d? | 657d | finish no earlier than 2010-03-11 | S1 | 968h | 242h | LIPA_SIPTO | PCG-23 | Huawei, China Mobile | Rel-10 | SP-45 | Alain |  |  |  |
| 31 | 15.3 | Stage 2 for LIPA_SIPTO |  | 191d? | 2009-09-24 | 2010-06-17 |  |  | 2009-09-24 | 2010-06-17 | 191d? | 587d | finish no earlier than 2010-06-17 | S2 | 1528h |  | LIPA_SIPTO | PCG-23 | Huawei, China Mobile | Rel-10 | SP-45 | Maurice |  |  |  |
| 32 | 15.4 | Security for LIPA_SIPTO |  | 256d? | 2009-09-24 | 2010-09-16 |  |  | 2009-09-24 | 2010-09-16 | 256d? | 522d | finish no earlier than 2010-09-16 | S3 | 2048h |  | LIPA_SIPTO | PCG-23 | Huawei, Qualcomm Europe | Rel-10 | SP-45 | Dionisio |  |  |  |
| 33 | 15.5 | OAM&P for LIPA_SIPTO |  | 256d? | 2009-09-24 | 2010-09-16 |  |  | 2009-09-24 | 2010-09-16 | 256d? | 522d | finish no earlier than 2010-09-16 | S5 | 2048h |  | LIPA_SIPTO | PCG-23 | nn | Rel-10 | SP-45 | Dionisio |  |  |  |
| 34 | 16 | **IP Flow Mobility and seamless WLAN offload** |  | 186d? | 2009-09-24 A | 2010-06-10 |  | 185.85d? | 2009-09-24 | 2010-06-10 | 186d? | 592d |  | S2,S1 | 3960h | 3.2h | IFOM | PCG-23 | Qualcomm Europe | Rel-10 | SP-45 | Maurice |  |  |  |
| 35 | 16.1 | Stage 1 for IFOM |  | 123d? | 2009-09-24 A | 2010-03-15 |  | 122.75d? | 2009-09-24 | 2010-03-15 | 123d? | 655d | finish no earlier than 2010-03-15 | S1 | 984h | 2h | IFOM | PCG-23 | Qualcomm Europe | Rel-10 | SP-45 | Alain |  |  |  |
| 36 | 16.2 | Stage 2 for IFOM |  | 186d? | 2009-09-24 | 2010-06-10 |  |  | 2009-09-24 | 2010-06-10 | 186d? | 592d | finish no earlier than 2010-06-10 | S2 | 1488h |  | IFOM | PCG-23 | Qualcomm Europe | Rel-10 | SP-45 | Maurice |  |  |  |
| 37 | 17 | **Enabling Coder Selection and Rate Adaptation for UTRAN and E-UTRAN for Load Adaptive Applications** |  | 186d? | 2009-09-24 | 2010-06-10 |  |  | 2009-09-24 | 2010-06-10 | 186d? | 592d |  | S2 | 4464h |  | ECSRA_LAA | PCG-23 | Qualcomm Europe | Rel-10 | SP-45 | Maurice |  |  |  |
| 38 | 17.1 | TR on ECSRA_LAA |  | 186d? | 2009-09-24 | 2010-06-10 |  |  | 2009-09-24 | 2010-06-10 | 186d? | 592d | finish no earlier than 2010-06-10 | S2 | 1488h |  | ECSRA_LAA | PCG-23 | Qualcomm Europe | Rel-10 | SP-45 | Maurice |  |  |  |
| 39 | 17.2 | Stage 2 for ECSRA_LAA |  | 186d? | 2009-09-24 | 2010-06-10 |  |  | 2009-09-24 | 2010-06-10 | 186d? | 592d | finish no earlier than 2010-06-10 | S2 | 1488h |  | ECSRA_LAA | PCG-23 | Qualcomm Europe | Rel-10 | SP-45 | Maurice |  |  |  |
| 40 | 18 | EEA3 and EIA3 (new Encryption & Integrity EPS security algorithms) |  | 266d? | 2009-06-04 | 2010-06-10 |  |  | 2009-06-04 | 2010-06-10 | 266d? | 592d | finish no earlier than 2010-06-10 | S3 | 2128h |  | EEA3_EIA3 | PCG-23 | CATR | Rel-10 | SP-44 | Dionisio |  |  |  |
| 41 | 19 | 1.28 Mcps TDD Repeater |  | 659d? | 2007-12-04 A | 2010-06-11 | 50% | 329.5d? | 2007-12-04 | 2010-06-11 | 659d? | 591d | finish no earlier than 2010-06-11 | R4 | 5272h | 2636h | RANimp-Repeaters1.28TDD | PCG-21 | RITT | Rel-10 | RP-38 | Stefania | RP-090691 |  |  |
| 42 | 20 | 1.28 Mcps TDD Multi-carrier HSUPA |  | 316d? | 2009-09-18 | 2010-12-03 |  |  | 2009-09-18 | 2010-12-03 | 316d? | 466d | finish no earlier than 2010-12-03 | R1,R2,R3,R4 | 2528h |  | TDD_MC_HSUPA | PCG-23 | CATR | Rel-10 | RP-45 | Patrick |  |  |  |
| 43 | 21 | A-GNSS Minimum Performance for UTRAN |  | 261d? | 2009-09-18 | 2010-09-17 |  |  | 2009-09-18 | 2010-09-17 | 261d? | 521d | finish no earlier than 2010-09-17 | R4 | 2088h |  | AGNSSPerf_UTRAN | PCG-23 | Thales | Rel-10 | RP-45 | Stefania |  |  |  |
| 44 | 22 | UE Over The Air (Antenna) conformance testing methodology - Laptop mounted equipment Free Space test |  | 521d? | 2009-09-18 | 2011-09-16 |  |  | 2009-09-18 | 2011-09-16 | 521d? | 261d | finish no earlier than 2011-09-16 | R4 | 4168h |  | UEAnt_FSTest | PCG-23 | CATR | Rel-10 | RP-45 | Stefania |  |  |  |
| 45 | 23 | (Small) Technical Enhancements and Improvements for Rel-10 |  | 136d? | 2009-06-04 | 2009-12-10 |  |  | 2009-06-04 | 2009-12-10 | 136d? | 722d | finish no earlier than 2009-12-10 | All | 1088h |  | TEI10 | PCG-23 | ALL | Rel-10 | SP-44 |  |  |  |  |
| 46 | 24 | **Deleted - Network Selection for non-3GPP Access** |  | 471d? | 2007-12-07 A | 2009-09-24 A | 100% |  | 2007-12-07 | 2009-09-24 | 471d? |  |  | S1,C6 | 10452.8h | 10452.8h | N3GtoNSP | PCG-21 | Telefonica O2 | Rel-10 | SP-38 | Alain |  | PCG-23 | SP-45 |
| 47 | 24.1 | Deleted - Stage 1 for N3GtoNSP |  | 471d? | 2007-12-07 A | 2009-09-24 A | 100% |  | 2007-12-07 | 2009-09-24 | 471d? |  | finish no earlier than 2009-12-10 | S1 | 3768h | 3768h | N3GtoNSP | PCG-21 | Telefonica O2 | Rel-10 | SP-38 | Alain |  | PCG-23 | SP-45 |
| 48 | 24.2 | Deleted - CT6 issues for N3GtoNSP |  | 471d? | 2007-12-07 A | 2009-09-24 A | 100% |  | 2007-12-07 | 2009-09-24 | 471d? |  | finish no earlier than 2009-12-04 | C6 | 3768h | 3768h | N3GtoNSP | PCG-21 | Telefonica O2 | Rel-10 | CP-38 | Xavier |  | PCG-23 | CP-45 |
| 49 | 25 | Release 10 Studies | milestone | 0d? | 2000-01-01 | 2000-01-01 |  |  | 2000-01-01 | 2000-01-01 | 0d? | 3318d | start no earlier than 2000-01-01 | RP,SP |  |  |  |  |  | Rel-10 |  |  |  |  |  |
| 50 | 26 | Study on Haptic Services |  | 262d? | 2009-03-12 A | 2010-03-11 | 50% | 131d? | 2009-03-12 | 2010-03-11 | 262d? | 657d | finish no earlier than 2010-03-11 | S1 | 2088h | 1040h | FS_Haptics | PCG-22 | SK Telecom | Rel-10 | SP-43 | Alain |  |  |  |
| 51 | 27 | Study on advanced requirements for IP interconnect |  | 528d? | 2007-12-04 A | 2009-12-10 | 80% | 105.6d? | 2007-12-04 | 2009-12-10 | 528d? | 722d | finish no earlier than 2009-12-10 | S1 | 4224h | 3379.2h | FS_IPXS | PCG-21 | Telefonica O2 | Rel-10 | SP-38 | Alain |  |  |  |
| 52 | 28 | Study on Unauthenticated PS Emergency Calls |  | 396d? | 2008-06-05 A | 2009-12-10 | 20% | 316.8d? | 2008-06-05 | 2009-12-10 | 396d? | 722d | finish no earlier than 2009-12-10 | S1 | 3168h | 633.6h | FS_UAPSEC | PCG-21 | Nokia Siemens Networks | Rel-10 | SP-40 | Alain |  |  |  |
| 53 | 29 | Study on Personal Broadcast Service |  | 322d? | 2008-09-18 A | 2009-12-10 | 90% | 32.2d? | 2008-09-18 | 2009-12-10 | 322d? | 722d | finish no earlier than 2009-12-10 | S1 | 2568h | 2310.4h | FS_PBS | PCG-21 | ETRI | Rel-10 | SP-41 | Alain |  |  |  |
| 54 | 30 | Study on LCS support in SAE for non-3GPP accesses |  | 322d? | 2008-09-18 A | 2009-12-10 | 70% | 96.3d? | 2008-09-18 | 2009-12-10 | 322d? | 722d | finish no earlier than 2009-12-10 | S1 | 2568h | 1797.6h | FS_LCS_n3GPP | PCG-21 | SK Telecom | Rel-10 | SP-41 | Alain |  |  |  |
| 55 | 31 | Study on System enhancements for the use of IMS services in Local BreakOut and Optimal Routing of Media |  | 575d? | 2007-10-01 A | 2009-12-10 | 80% | 115d? | 2007-10-01 | 2009-12-10 | 575d? | 722d | finish no earlier than 2009-12-10 | S2 | 4600h | 3680h | FS_IMS_LBO_ORM |  | Telecom Italia, BT | Rel-10 | SP-37 | Maurice |  |  |  |
| 56 | 32 | Study on Intra Domain Connection of RAN Nodes to Multiple CN Nodes |  | 525d? | 2008-03-12 A | 2010-03-15 | 30% | 367.5d? | 2008-03-12 | 2010-03-15 | 525d? | 655d | finish no earlier than 2010-03-15 | S2 | 4200h | 1260h | FS_IDC | PCG-21 | China Mobile | Rel-10 | SP-39 | Maurice |  |  |  |
| 57 | 33 | Study on IMS Evolution |  | 389d? | 2008-09-18 A | 2010-03-15 | 60% | 155.6d? | 2008-09-18 | 2010-03-15 | 389d? | 655d | finish no earlier than 2010-03-15 | S2 | 3112h | 1867.2h | FS_eIMS | PCG-21 | China Mobile | Rel-10 | SP-41 | Maurice |  |  |  |
| 58 | 34 | Study on enhancements to IMS border functions for IMS Interconnection of services |  | 455d? | 2008-09-18 A | 2010-06-15 | 20% | 364d? | 2008-09-18 | 2010-06-15 | 455d? | 589d | finish no earlier than 2010-06-15 | S2 | 3640h | 728h | FS_eIMS_IBCF | PCG-21 | Starent Networks | Rel-10 | SP-41 | Maurice |  |  |  |
| 59 | 35 | Study on Multi Access PDN connectivity and IP flow Mobility |  | 389d? | 2008-09-18 A | 2010-03-15 | 85% | 58.35d? | 2008-09-18 | 2010-03-15 | 389d? | 655d | finish no earlier than 2010-03-15 | S2,S1 | 3112h | 2645.2h | FS_MAPIM | PCG-21 | Qualcomm Europe | Rel-10 | SP-41 | Maurice |  |  |  |
| 60 | 36 | Study on Policy solutions and enhancements |  | 338d? | 2009-06-04 A | 2010-09-20 | 15% | 287.3d? | 2009-06-04 | 2010-09-20 | 338d? | 520d | finish no earlier than 2010-09-20 | S2,S1 | 2704h | 405.6h | FS_PP | PCG-23 | AT&T | Rel-10 | SP-44 | Maurice |  |  |  |
| 61 | 37 | Study on IPv6 Migration |  | 269d? | 2009-06-04 A | 2010-06-15 | 10% | 242.1d? | 2009-06-04 | 2010-06-15 | 269d? | 589d | finish no earlier than 2010-06-15 | S2 | 2152h | 215.2h | FS_IP6M | PCG-23 | China Mobile | Rel-10 | SP-44 | Maurice |  |  |  |
| 62 | 38 | Study on SR-VCC Enhancements |  | 338d? | 2009-06-04 A | 2010-09-20 | 6% | 317.4d? | 2009-06-04 | 2010-09-20 | 338d? | 520d | finish no earlier than 2010-09-20 | S2 | 2704h | 164.8h | FS_eSRVCC | PCG-23 | China Mobile | Rel-10 | SP-44 | Maurice |  |  |  |
| 63 | 39 | Study on Uplink Tx Diversity for HSPA |  | 218.4d? | 2009-08-18 | 2010-06-18 |  |  | 2009-08-18 | 2010-06-18 | 218.4d? | 586d | finish no earlier than 2010-06-18 | R4 | 1747.2h |  | FS_UL-TxDiv-HSPA | PCG-23 | Qualcomm Europe | Rel-10 | RP-45 | Stefania |  |  |  |
| 64 | 40 | Study on RAN improvements for Machine-Type Communications |  | 196d? | 2009-09-18 | 2010-06-18 |  |  | 2009-09-18 | 2010-06-18 | 196d? | 586d | finish no earlier than 2010-06-18 | R2,R1,R3,R4 | 1568h |  | FS_NIMTC-RAN | PCG-23 | Huawei | Rel-10 | RP-45 | Joern |  |  |  |
| 65 | 41 | Study on IMS based Peer-to-Peer Content Distribution Services |  | 196d? | 2009-09-24 | 2010-06-24 |  |  | 2009-09-24 | 2010-06-24 | 196d? | 582d | finish no earlier than 2010-06-24 | S1,S2 | 1568h |  | FS_IMS_PP-CDS | PCG-23 | China Mobile | Rel-10 | SP-45 | Alain |  |  |  |
| 66 | 42 | Release 9 Features | milestone | 0d? | 2000-01-01 | 2000-01-01 |  |  | 2000-01-01 | 2000-01-01 | 0d? | 3318d |  | CP,GP,RP,SP |  |  |  |  |  | Rel-9 |  |  |  |  |  |

Notes:
- 28: UID_400035 Enhanced Home NodeB/eNodeB (EHNB) has formerly covered Local IP Access to Internet and Local access to Home Network from the Home NodeB/eNodeB Features now covered by this WI. / Text5: patrice.hede@huawei.com, Tao Sun (suntao@chinamobile.com)
- 29: - / Text3: 23.829 (Local IP Access & Selected IP Traffic Offload) / Text5: patrice.hede@huawei.com, Tao Sun (suntao@chinamobile.com)
- 30: - / Text3: 22.101, 22.220 / Text5: Amar Deol (adeolf@huawei.com), Gang Li (ligangyf@chinamobile.com)
- 31: - / Text3: 23.060, 23.203, 23.401 / Text5: patrice.hede@huawei.com, Tao Sun (suntao@chinamobile.com)
- 32: - / Text3: 33.102, 33.107, 33.108, 33.320, 33.401 / Text5: Marcus Wong (mwong@huawei.com), Brian Rosenberg (bmr@qualcomm.com)
- 33: - / Text3: 32.101, 32.102, 32.405, 32.425, 32.452, 32.453, 32.581, 32.582, 32.583, 32.584, 32.591, 32.592, 32.593, 32.594, 32.64x, 32.76x / Text5: nn
- 34: Triggered by Rel-10 TR 23.861 (UID_410043 Study on Multi Access PDN connectivity and IP flow mobility - MAPIM). Charging aspects are to be considered for IP Flow Mobility and WLAN offloading. / Text5: Gerardo Giaretta (gerardo@qualcomm.com)
- 35: Service requirements for IP Flow Mobility partially in 22.278 and additional aspects in TR 23.861. 22.278 needs updating to capture aspects currently only in TR 23.861. / Text3: 22.278 / Text5: David Williams (dwilliam@qualcomm.com)
- 36: - / Text3: 23.203, 23.402, new TS 23.261 (IP Flow Mobility) / Text5: Gerardo Giaretta (gerardo@qualcomm.com)
- 37: Rel-10 Rate Adaptation. Triggered by Rel-9 RAN2 (UID_440013 Vocoder rate adaptation for LTE (LTEimp-Vocoder). Enhance existing (pre Rel-10) codec selection/rate adaptation based on network loading conditions and operator policies over UTRA/E-UTRA / Text5: AC Mahendran (ac@qualcomm.com)
- 38: Needs Liaison with SA4, RAN2 / Text3: new TR 23.abc (Enabling Encoder Selection and Rate Adaptation for UTRAN and E-UTRAN) / Text5: AC Mahendran (ac@qualcomm.com)
- 39: - / Text3: 23.060, 23.203, 23.228, 23.401 / Text5: AC Mahendran (ac@qualcomm.com)
- 40: develop new EPS algorithms acceptable to regions such as China / Text3: 35.xxx (EEA3 & EIA3 Algorithm Specification, Implementers’ test data, Design and evaluation report, Final project report), 33.401 (SAE Security Architecture) / Text5: Yuan Qi, yuanqi@mail.ritt.com.cn
- 41: RP#45 completion 12/09=>06/10 / Text3: 25.113, new 25.116, 25.153 (testing) / Text5: qinyan@chinattl.com
- 42: - / Text3: 25.102, 25.105, 25.123, 25.221, 25.222, 25.223, 25.224, 25.225, 25.306, 25.319, 25.321, 25.331, 25.423, 25.427, 25.433 / Text5: Aihui Song (songaihui@mail.ritt.com.cn)
- 43: Triggered by Rel-7 UID_20050 (GNSS in UTRAN) and Rel-8 UID_400051 (Support for Additional NSS). Linked to GERAN Rel-8 UID_38002 (A-GNSS Performances and Testing Procedures) / Text3: 25.171, 34.108, 34.123, 34.171, 34.109 / Text5: Michel.monnerat@thalesaleniaspace.com
- 44: - / Text3: 25.144, 25.914, 34.114 / Text5: Guo Lin (guolin@emcite.com)
- 45: -
- 46: SP#45 work stopped/abandoned / Text5: chris.friel@O2.com
- 47: SP#45 work stopped/abandoned / Text3: 22.011 / Text5: chris.friel@O2.com
- 48: SP#45 work stopped/abandoned / Text3: 22.234, 21.111, 31.101, 31.102, 31.103 / Text5: chris.friel@O2.com
- 49: -
- 50: SP#45 updated WID SP-090222=>SP-090664 (IMS extension, removed Mobile to also cover Fixed/Cordless/etc terminal). Haptic (human-machine tactile communication) extend service offering & richness of user experience beyond current visual & auditory senses / Text3: 22.987 / Text5: Jinhan Song
- 51: SP#45 TR 22.893 for Information. Linked to Rel-8 Feature UID_380060 IP Interconnection of Services (IPinterc) / Text3: 22.893 / Text5: chris.friel@O2.com
- 52: SP#44/45 stagnating at 20% / Text3: 22.984 / Text5: Juergen Merkel
- 53: SP#45 TR 22.947 for Information / Text3: 22.947 / Text5: Jaihyung Cho
- 54: SP#44 TR 22.913 for Information / Text3: 22.913 / Text5: Donghee Shim
- 55: SP#43 TR 23.894 for Information (Common and IP-CAN aspects). Linked to Study on Multimedia Session Continuity UID_350051, Study on Centralized IMS Service Control UID_330012, IMS inter-operator service interconnection interface UID_360011 / Text3: 23.894 / Text5: mario.madella@telecomitalia.it, victor.kueh@bt.com
- 56: SP#45 TR 23.823 for Information. Completion 12/09=>03/10. Linked to 23.236 / Text3: 23.823 / Text5: LIU HONG (liuhongyfw@chinamobile.com)
- 57: - / Text3: 23.812 / Text5: Li Gang (ligangyf@chinamobile.com), Yu Qing (yuqing@chinamobile.com)
- 58: SP#45 completion 12/09=>06/10 / Text3: 23.848 / Text5: Rajat Ghai (rghai@starentnetworks.com)
- 59: SP#45 completion 09/09=>03/10 (SA1 completed). Spin-off UID_430035 MAPCON and UID_450041 IFOM / Text3: 23.861 / Text5: Gerardo Giaretta (gerardog@qualcomm.com)
- 60: SP#45 completion 12/09=>09/10. Study an evolved policy solution through enhancement of 3GPP policy framework (Stage 2). Consider aspects such as DPI, traffic steering, enhancing service policies. / Text3: 23.813 / Text5: farooq.bari@att.com
- 61: Study how to migrate from IPv4 to IPv6-only with the help of transition mechanisms defined in IETF, and how to handle scenarios where not all services are provided via IPv6. Some of these solutions may have impacts on 3GPP network elements and terminals. / Text3: 23.975 / Text5: Li Lianyuan (lilianyuan@chinamobile.com), Liu Hong (liuhongyfw@chinamobile.com)
- 62: SP#45 completion 03/10=>09/10. Analyze current performance of SR-VCC solution in Rel-8 from E-UTRAN/HSPA to UTRAN/GERAN, and then evaluate additional mechanisms to improve user experience. Study if SR-VCC performance needs to be enhanced. / Text3: 23.856 / Text5: Hou zhiqiang (houzhiqiang@chinamobile.com), Jiang Yi (jiangyi@chinamobile.com)
- 63: - / Text3: 25.8xx / Text5: Heechoon Lee
- 64: Triggered by UID_7027 Study on Facilitating Machine to Machine Communication in GSM and UMTS (M2M) TR 22.868 and Rel-10 UID_410030 Network Improvements for Machine-Type Communications (NIMTC) / Text3: TR on RAN Improvements for Machine-type Communications / Text5: arnaud.meylan@huawei.com
- 65: Linked to OMA work? / Text3: 22.8xy / Text5: Li Gang (ligangyf@chinamobile.com)
- 66: -

| ID | WBS | Task | Duration | Start | Finish | Complete | Remaining | Baseline start | Baseline finish | Baseline duration | Total slack | Constraint | Resources | Work | Actual work | Text1 | Text2 | Text4 | Text5 | Text6 | Text7 | Text8 | Text11 |
| --- | --- | --- | --- | --- | --- | --- | --- | --- | --- | --- | --- | --- | --- | --- | --- | --- | --- | --- | --- | --- | --- | --- | --- |
| 67 | 43 | **Enhanced Home NodeB / eNodeB** | 397d? | 2008-06-05 A | 2009-12-10 | 54% | 182.02d? | 2008-06-05 | 2009-12-10 | 397d? | 722d |  | S1,S2,S3,S5,R2,R3,R4,GP,C1 | 23128h | 12520.7h | EHNB | PCG-21 | T-Mobile | michael.kurz@t-mobile.at | Rel-9 | SP-40 | Alain |  |
| 68 | 43.1 | Stage 1 for EHNB | 261d? | 2008-06-05 A | 2009-06-04 A | 100% |  | 2008-06-05 | 2009-06-04 | 261d? |  | finish no earlier than 2009-06-04 | S1 | 2088h | 2088h | EHNB | PCG-21 | T-Mobile | michael.kurz@t-mobile.at | Rel-9 | SP-40 | Alain |  |
| 69 | 43.2 | Architecture aspects of EHNB | 266d? | 2008-09-18 A | 2009-09-24 A | 100% |  | 2008-09-18 | 2009-09-24 | 266d? |  | finish no earlier than 2009-09-22 | S2 | 2128h | 2128h | EHNB | PCG-21 | T-Mobile | Sebastian Speicher | Rel-9 | SP-41 | Maurice |  |
| 70 | 43.3 | Security aspects of Enhanced Home NodeB / eNodeB | 262d? | 2008-12-11 A | 2009-12-10 | 60% | 104.8d? | 2008-12-11 | 2009-12-10 | 262d? | 722d | finish no earlier than 2009-12-10 | S3 | 2096h | 1257.6h | EHNB-Sec | PCG-22 | Huawei | Marcus Wong (mwong@huawei.com) | Rel-9 | SP-42 | Dionisio |  |
| 71 | 43.4 | CT1 aspects - Support of Home NB and Home eNB enhancements | 56d? | 2009-09-18 A | 2009-12-04 | 50% | 28d? | 2009-09-18 | 2009-12-04 | 56d? | 726d | finish no earlier than 2009-12-04 | C1 | 448h | 224h | EHNB-CT1 | PCG-23 | Qualcomm Europe | Ramachandran Subramanian (rsubrama@qualcomm.com) | Rel-9 | CP-45 | Frederic |  |
| 72 | 43.5 | CT6 aspects - Support of Home NB and Home eNB enhancements | 56d? | 2009-09-18 | 2009-12-04 |  |  | 2009-09-18 | 2009-12-04 | 56d? | 726d | finish no earlier than 2009-12-04 | C6 | 448h |  | EHNB-CT6 | PCG-23 | Qualcomm Europe | Ramachandran Subramanian (rsubrama@qualcomm.com) | Rel-9 | CP-45 | Xavier |  |
| 73 | 43.6 | 3G HNB Gateway and LTE HeNB Gateway OAM&P | 261d? | 2008-12-11 A | 2009-12-10 | 50% | 130.5d? | 2008-12-11 | 2009-12-10 | 261d? | 722d | finish no earlier than 2009-12-10 | S5 | 2088h | 1044h | HNB-OAM_GW | PCG-22 | China Mobile | GangChen (chengang@chinamobile.com) | Rel-9 | SP-42 | Dionisio |  |
| 74 | 43.7 | 3G HNB and LTE HeNB OAM&P Type 1 Interface | 197d? | 2009-03-12 A | 2009-12-10 | 45% | 108.35d? | 2009-03-12 | 2009-12-10 | 197d? | 722d | finish no earlier than 2009-12-10 | S5 | 1568h | 701.2h | HNB_eHNB-OAM_Type1 | PCG-22 | Huawei | Zou Lan (zlan@huawei.com) | Rel-9 | SP-43 | Dionisio |  |
| 75 | 43.8 | 3G HNB and LTE HeNB OAM&P Type 2 Interface | 150d? | 2009-05-15 A | 2009-12-10 | 20% | 120d? | 2009-05-15 | 2009-12-10 | 150d? | 722d | finish no earlier than 2009-12-10 | S5 | 1200h | 240h | HNB_eHNB-OAM_Type2 | PCG-23 | Ericsson | edwin.tse@ericsson.com | Rel-9 | SP-44 | Dionisio |  |
| 76 | 43.9 | LTE FDD Home eNodeB RF Requirements | 261d? | 2008-12-05 A | 2009-12-04 | 40% | 156.6d? | 2008-12-05 | 2009-12-04 | 261d? | 726d | finish no earlier than 2009-12-04 | R4 | 2088h | 835.2h | HeNB-RF_FDD | PCG-22 | Motorola | Ying Cai (yingcai@motorola.com) | Rel-9 | RP-42 | Stefania | RP-090705 |
| 77 | 43.10 | LTE TDD Home eNodeB RF Requirements | 196d? | 2009-03-06 A | 2009-12-04 | 50% | 98d? | 2009-03-06 | 2009-12-04 | 196d? | 726d | finish no earlier than 2009-12-04 | R4 | 1568h | 784h | HeNB-RF_TDD | PCG-22 | China Mobile | Nan Li (linan@chinamobile.com) | Rel-9 | RP-43 | Stefania | RP-090706 |
| 78 | 43.11 | Home NB and Home eNB enhancements - RAN3 aspects | 197d? | 2009-03-06 A | 2009-12-04 | 35% | 128.05d? | 2009-03-06 | 2009-12-04 | 197d? | 726d | finish no earlier than 2009-12-04 | R3 | 1576h | 551.6h | EHNB-RAN3 | PCG-22 | Alcatel-Lucent | Martin Warner (mw15@alcatel-lucent.com) | Rel-9 | RP-43 | Juha | RP-090708 |
| 79 | 43.12 | Home NB and Home eNB enhancements - RAN2 aspects | 196d? | 2009-03-06 A | 2009-12-04 | 50% | 98d? | 2009-03-06 | 2009-12-04 | 196d? | 726d | finish no earlier than 2009-12-04 | R2 | 1568h | 784h | EHNB-RAN2 | PCG-22 | Huawei | Yang Xudong (yangxudong@huawei.com) | Rel-9 | RP-43 | Joern | RP-090707 |
| 80 | 43.13 | Home NB and Home eNB enhancements - GERAN aspects | 136d? | 2009-05-18 A | 2009-11-20 | 15% | 115.6d? | 2009-05-18 | 2009-11-20 | 136d? | 736d | finish no earlier than 2009-11-20 | GP | 1088h | 163.2h | EHNB-GERAN | PCG-23 | Nokia Siemens Networks | Leonardo Provvedi | Rel-9 | GP-42 | Paolo |  |
| 81 | 44 | **Services Alignment and Migration** | 467d? | 2006-12-06 A | 2008-09-18 A | 100% |  | 2006-12-06 | 2008-09-18 | 467d? |  |  | S1 | 7472h | 7472h | ServAl |  | China Mobile | fenglingjuan@chinamobile.com | Rel-9 | SP-33 | Alain |  |
| 82 | 44.1 | Stage 1 for ServAl | 467d? | 2006-12-06 A | 2008-09-18 A | 100% |  | 2006-12-06 | 2008-09-18 | 467d? |  | finish no earlier than 2008-12-11 | S1 | 3736h | 3736h | ServAl | PCG-21 | China Mobile | fenglingjuan@chinamobile.com | Rel-9 | SP-33 | Alain |  |
| 83 | 45 | **Value-Added Services for Short Message Service** | 586d? | 2007-09-10 A | 2009-12-04 | 50% | 291.04d? | 2007-09-10 | 2009-12-04 | 586d? | 726d |  | S1,C4,C1 | 10888h | 4180.8h | VAS4SMS |  | China Mobile | Wu Bin (wubin@chinamobile.com) | Rel-9 | SP-37 | Alain |  |
| 84 | 45.1 | Stage 1 for VAS4SMS | 133d? | 2007-09-10 A | 2008-03-12 A | 100% |  | 2007-09-10 | 2008-03-12 | 133d? |  | finish no earlier than 2008-03-21 | S1 | 1064h | 1064h | VAS4SMS |  | China Mobile | Wu Bin (wubin@chinamobile.com) | Rel-9 | SP-37 | Alain |  |
| 85 | 45.2 | VAS4SMS Interface and Signalling Flow - CT4 aspects | 322d? | 2008-09-12 A | 2009-12-04 | 80% | 64.4d? | 2008-09-12 | 2009-12-04 | 322d? | 726d | finish no earlier than 2009-12-04 | C4 | 2568h | 2052.8h | VAS4SMS | PCG-21 | China Mobile | Wu Bin (wubin@chinamobile.com) | Rel-9 | CP-41 | Kimmo |  |
| 86 | 45.3 | VAS4SMS Interface and Signalling Flow - CT1 aspects | 321d? | 2008-09-09 | 2009-12-04 |  |  | 2008-09-09 | 2009-12-04 | 321d? | 726d | finish no earlier than 2009-12-04 | C1 | 2568h |  | VAS4SMS | PCG-21 | China Mobile | Wu Bin (wubin@chinamobile.com) | Rel-9 | CP-41 | Frederic |  |
| 87 | 46 | **End-User Identity** | 334d? | 2007-09-03 A | 2008-12-11 A | 100% |  | 2007-09-03 | 2008-12-11 | 334d? |  |  | S1 | 5344h | 5344h | EUI |  | Nokia Siemens Networks | Juergen.Merkel@NSN.com | Rel-9 | SP-38 | Alain |  |
| 88 | 46.1 | Definition of EUI | 334d? | 2007-09-03 A | 2008-12-11 A | 100% |  | 2007-09-03 | 2008-12-11 | 334d? |  | finish no earlier than 2008-12-11 | S1 | 2672h | 2672h | EUI | PCG-21 | Nokia Siemens Networks | Juergen.Merkel@NSN.com | Rel-9 | SP-38 | Alain |  |
| 89 | 47 | **Customized Ringing Signal** | 522d? | 2007-12-06 A | 2009-12-03 | 81% | 97.13d? | 2007-12-06 | 2009-12-03 | 522d? | 727d |  | S1,C1 | 7120h | 4473.6h | CRS | PCG-21 | SK Telecom, China Mobile | Donghee Shim (SK Telecom), Jianping Zheng (China Mobile) | Rel-9 | SP-38 | Alain |  |
| 90 | 47.1 | Stage 1 for CRS | 266d? | 2007-12-06 A | 2008-12-11 A | 100% |  | 2007-12-06 | 2008-12-11 | 266d? |  | finish no earlier than 2008-12-11 | S1 | 2128h | 2128h | CRS | PCG-21 | SK Telecom, China Mobile | Donghee Shim (SK Telecom), Jianping Zheng (China Mobile) | Rel-9 | SP-38 | Alain |  |
| 91 | 47.2 | Stage 3 for IMS CRS Service | 136d? | 2009-05-29 A | 2009-12-03 | 45% | 74.8d? | 2009-05-29 | 2009-12-03 | 136d? | 727d | start no earlier than 2009-05-29 | C1 | 816h | 217.6h | CRS | PCG-23 | China Mobile | wangzhao | Rel-9 | CP-44 | Frederic |  |

Notes:
- 67: SP#43 WID updated SP-080791=>SP-090197 to include RAN items/BBs
- 68: SP#44 completed / Text3: 22.220, 22.011
- 69: SP#45 completed. TR 23.830 for Approval / Text3: 23.830, 23.401, 23.402, 23.060
- 70: SP#45 Stage 2 exception to 12/09. TS 33.320 for Information / Text3: new 33.320
- 71: Roaming aspects for manual CSG selection, Support of temporary users and CSG membership changes, Support of user controlled and operator controlled lists / Text3: 23.122, 24.008, 24.285, 24.301
- 72: Storing of CSG related data items on the USIM / Text3: 31.102
- 73: SP#45 for Information TS 32.771, 32.772, 32.781, 32.452 / Text3: 32.771, 32.772, 32.773, 32.775, 32.781, 32.782, 32.783, 32.785, 32.452, 32.453, 32.632, 32.633, 32.635
- 74: SP#45 for Information TS 32.593. Network Manager to Element Manager for H(e)NB / Text3: 32.591, 32.592, 32.593, 32.594, 32.581, 32.582, 32.583, 32.584
- 75: Network Manager to Element Manager for H(e)NB / Text3: 32.xxx Home NB and Home eNB OAM&P concepts and requirements (for interface Type 2), 32.xxy Home NB and Home eNB OAM&P Stage 2 (for interface Type 2)
- 76: - / Text3: 36.104, 36.141
- 77: - / Text3: 36.9xx (LTE TDD Home eNodeB RF Requirements WI TR), 36.104, 36.141
- 78: - / Text3: new 25.444 (UTRAN Iuh interface data transport and transport signalling), 25.413, 25.467, 25.467, 25.468, 25.469, 25.469, 36.401, 36.413
- 79: - / Text3: 25.304, 25.331, 25.367, 36.300, 36.304, 36.331
- 80: GP#42 WID approved / Text3: 43.055, 43.129, 44.018, 44.060, 45.008, 48.008, 48.018
- 81: SP#41 Stage 1 completed. Triggered by Study UID_370086 (FSServAl).
- 82: SP#41 completed / Text3: 22.182
- 83: SP#43 Feature moved to Rel-9. Stage 1 TS 22.142 promoted to Rel-9 and dismissed the Rel-8 version.
- 84: SP#39 completed. SP#43 Feature moved to Rel-9. Stage 1 TS 22.142 promoted to Rel-9 and dismissed the Rel-8 version. / Text3: 22.142
- 85: CP#43 moved to Rel-9. WID updated CP-080721=>CP-090021 / Text3: 23.142, 29.002
- 86: CP#43 moved to Rel-9. WID updated CP-080721=>CP-090021 / Text3: 23.040
- 87: SP#44 WID updated SP-070651=>SP-090380 (reduced scope of the work)
- 88: SP#44 WID updated SP-070651=>SP-090380 (reduced scope of the work) / Text3: 21.905
- 89: SP#42 Stage 1 completed (need for Input in SA2). SP#41 WID updated SP-070875=>SP-080502
- 90: SP#42 completed. / Text3: 22.183, 22.173
- 91: - / Text3: 24.173, 24.183

| ID | WBS | Task | Type | Duration | Start | Finish | Complete | Remaining | Baseline start | Baseline finish | Baseline duration | Total slack | Constraint | Resources | Work | Actual work | Text1 | Text2 | Text4 | Text6 | Text7 | Text8 | Text11 |
| --- | --- | --- | --- | --- | --- | --- | --- | --- | --- | --- | --- | --- | --- | --- | --- | --- | --- | --- | --- | --- | --- | --- | --- |
| 92 | 48 | **Public Warning System** |  | 523d? | 2007-12-06 A | 2009-12-04 | 65% | 182.33d? | 2007-12-06 | 2009-12-04 | 523d? | 726d |  | S1,C1,C4,R2 | 10232h | 5569.22h | PWS | PCG-21 | T-Mobile | Rel-9 | SP-38 | Alain |  |
| 93 | 48.1 | Stage 1 for PWS |  | 266d? | 2007-12-06 A | 2008-12-11 A | 100% |  | 2007-12-06 | 2008-12-11 | 266d? |  | finish no earlier than 2008-12-11 | S1 | 2128h | 2128h | PWS | PCG-21 | T-Mobile | Rel-9 | SP-38 | Alain |  |
| 94 | 48.2 | **Stage 3 for PWS** |  | 137d? | 2009-05-29 A | 2009-12-04 | 25% | 102.37d? | 2009-05-29 | 2009-12-04 | 137d? | 726d |  | C1,C4 | 3272h | 821.01h | PWS-St3 | PCG-23 | Qualcomm Europe | Rel-9 | CP-44 | Frederic |  |
| 95 | 48.2.1 | CT1 aspects of PWS-St3 |  | 137d? | 2009-05-29 A | 2009-12-04 | 50% | 68d? | 2009-05-29 | 2009-12-04 | 137d? | 726d | finish no earlier than 2009-12-04 | C1 | 1088h | 544h | PWS-St3 | PCG-23 | Qualcomm Europe | Rel-9 | CP-44 | Frederic |  |
| 96 | 48.2.2 | CT4 aspects of PWS-St3 |  | 136d? | 2009-05-30 | 2009-12-04 |  |  | 2009-05-30 | 2009-12-04 | 136d? | 726d | finish no earlier than 2009-12-04 | C4 | 1088h |  | PWS-St3 | PCG-23 | Qualcomm Europe | Rel-9 | CP-44 | Kimmo |  |
| 97 | 48.3 | Public Warning System (PWS) – RAN aspects |  | 81d? | 2009-05-30 A | 2009-12-04 | 85% | 12.15d? | 2009-05-30 | 2009-12-04 | 81d? | 726d | finish no earlier than 2009-12-04 | R2,R3 | 648h | 550.8h | PWS-RAN | PCG-23 | AT&T | Rel-9 | RP-44 | Joern | RP-090710 |
| 98 | 49 | **Enhancements to Multimedia Priority Service** |  | 584d? | 2006-03-13 A | 2008-06-05 A | 100% |  | 2006-03-13 | 2008-06-05 | 584d? |  |  | S1 | 4672h | 4672h | ePRIOR | PCG-21 | Telcordia | Rel-9 | SP-39 | Alain |  |
| 99 | 49.1 | Stage 1 for ePRIOR |  | 584d? | 2006-03-13 A | 2008-06-05 A | 100% |  | 2006-03-13 | 2008-06-05 | 584d? |  | start no earlier than 2006-03-12 | S1 | 4672h | 4672h | ePRIOR | PCG-21 | Telcordia | Rel-9 | SP-39 | Alain |  |
| 100 | 50 | **Support of Personal Area Networks and Enhancements to Personal Network Management** |  | 393d? | 2008-06-05 A | 2009-12-04 | 40% | 235.8d? | 2008-06-05 | 2009-12-04 | 393d? | 726d |  | S1,C1 | 6280h | 2512h | PAN_EPNM | PCG-21 | Vodafone | Rel-9 | SP-40 | Alain |  |
| 101 | 50.1 | Stage 1 for PAN_EPNM | milestone | 0d? | 2008-06-05 A | 2008-06-05 A | 100% |  | 2008-06-05 | 2008-06-05 | 0d? |  | finish no earlier than 2008-06-05 | S1 |  |  | PAN_EPNM | PCG-21 | Vodafone | Rel-9 | SP-40 | Alain |  |
| 102 | 50.2 | Stage 2 for PAN_EPNM |  | 196d? | 2009-03-06 A | 2009-12-04 | 80% | 39.2d? | 2009-03-06 | 2009-12-04 | 196d? | 726d | finish no earlier than 2009-12-04 | C1 | 1568h | 1254.4h | PAN_EPNM | PCG-22 | Huawei | Rel-9 | CP-43 | Frederic |  |
| 103 | 50.3 | Stage 3 for PAN_EPNM |  | 196d? | 2009-03-09 | 2009-12-04 |  |  | 2009-03-09 | 2009-12-04 | 196d? | 726d | finish no earlier than 2009-12-04 | C1 | 1568h |  | PAN_EPNM | PCG-22 | Huawei | Rel-9 | CP-43 | Frederic |  |
| 104 | 51 | **Multi-Media Telephony Service enhancements** |  | 397d? | 2008-06-05 A | 2009-12-10 | 69% | 124.03d? | 2008-06-05 | 2009-12-10 | 397d? | 722d |  | S1,S5,C1 | 8488h | 5833.8h | eMMTel | PCG-21 | France Telecom | Rel-9 | SP-40 | Alain |  |
| 105 | 51.1 | Stage 1 for eMMTel |  | 136d? | 2008-06-05 A | 2008-12-11 A | 100% |  | 2008-06-05 | 2008-12-11 | 136d? |  | start no earlier than 2008-06-05 | S1 | 1088h | 1088h | eMMTel | PCG-21 | France Telecom | Rel-9 | SP-40 | Alain |  |
| 106 | 51.2 | Multimedia Telephony (MMTel) Service and Supplementary Services - Online Charging and completion for Offline Charging (all supplementary services) |  | 197d? | 2009-03-12 A | 2009-12-10 | 65% | 68.95d? | 2009-03-12 | 2009-12-10 | 197d? | 722d | finish no earlier than 2009-12-10 | S5 | 1568h | 1016.4h | eMMTel-SS-CH | PCG-22 | Alcatel-Lucent | Rel-9 | SP-43 | Dionisio |  |
| 107 | 51.3 | Support of Real-time Transfer of Tariff Information (RTTI) in IMS charging |  | 196d? | 2009-03-12 A | 2009-12-10 | 50% | 98d? | 2009-03-12 | 2009-12-10 | 196d? | 722d | finish no earlier than 2009-12-10 | S5 | 1568h | 784h | IMSTSS-RTTI-CH | PCG-22 | Orange | Rel-9 | SP-43 | Dionisio |  |
| 108 | 51.4 | Stage 3 - Enhancements for Completion of Communications Supplementary service |  | 136d? | 2009-05-30 A | 2009-12-04 | 70% | 40.8d? | 2009-05-30 | 2009-12-04 | 136d? | 726d | finish no earlier than 2009-12-04 | C1 | 1088h | 761.6h | eMMTel-CC | PCG-23 | France Telecom | Rel-9 | CP-44 | Frederic |  |
| 109 | 52 | **User Data Convergence** |  | 456d? | 2008-06-05 A | 2010-03-03 | 39% | 278.15d? | 2008-06-05 | 2010-03-03 | 456d? | 663d |  | S1,S5,C4 | 10512h | 3866.02h | UDC | PCG-21 | China Mobile | Rel-9 | SP-40 | Alain |  |
| 110 | 52.1 | Stage 1 for UDC |  | 136d? | 2008-06-05 A | 2008-12-11 A | 100% |  | 2008-06-05 | 2008-12-11 | 136d? |  | start no earlier than 2008-06-05 | S1 | 1088h | 1088h | UDC | PCG-21 | China Mobile | Rel-9 | SP-40 | Alain |  |
| 111 | 52.2 | UDC Technical Realization (Stage 2) |  | 196d? | 2009-03-06 A | 2009-12-04 | 50% | 98d? | 2009-03-06 | 2009-12-04 | 196d? | 726d | finish no earlier than 2009-12-04 | C4 | 1568h | 784h | UDC-CN | PCG-22 | Ericsson | Rel-9 | CP-43 | Kimmo |  |
| 112 | 52.3 | UDC Protocol Description |  | 118d? | 2009-09-18 | 2010-03-03 |  |  | 2009-09-18 | 2010-03-03 | 118d? | 663d | finish no earlier than 2010-03-03 | C4 | 944h |  | UDC-CN | PCG-23 | China Mobile, Ericsson | Rel-9 | CP-45 | Kimmo |  |
| 113 | 52.4 | **User Data Convergence - Modelling and Management** |  | 136d? | 2009-06-04 A | 2009-12-10 | 18% | 112.2d? | 2009-06-04 | 2009-12-10 | 136d? | 722d |  | S5 | 3264h | 571.2h | UDC-MMAN | PCG-23 | T-Mobile, China Mobile, Ericsson | Rel-9 | SP-44 | Dionisio |  |
| 114 | 52.4.1 | UDC – Framework for Model Handling and Management |  | 136d? | 2009-06-04 A | 2009-12-10 | 15% | 115.6d? | 2009-06-04 | 2009-12-10 | 136d? | 722d | start no earlier than 2009-06-04 | S5 | 1088h | 163.2h | UDC-MMAN-MFRM | PCG-23 | T-Mobile | Rel-9 | SP-44 | Dionisio |  |
| 115 | 52.4.2 | UDC – Common Baseline Information Model |  | 136d? | 2009-06-04 A | 2009-12-10 | 20% | 108.8d? | 2009-06-04 | 2009-12-10 | 136d? | 722d | start no earlier than 2009-06-04 | S5 | 1088h | 217.6h | UDC-MMAN-CBIM | PCG-23 | China Mobile, Ericsson | Rel-9 | SP-44 | Dionisio |  |

Notes:
- 92: SP#42 Stage 1 completed. Larger scope than Rel-8 Feature UID_370051 (ETWS). Triggered by TR 22.968 Study UID_320025 (FS_PWS). / Text5: Mark.Younge@t-mobile.com
- 93: SP#42 completed. / Text3: 22.268 / Text5: Mark.Younge@t-mobile.com
- 94: - / Text5: Ramachandran Subramanian (rsubrama@qualcomm.com)
- 95: - / Text3: 23.041 / Text5: Ramachandran Subramanian (rsubrama@qualcomm.com)
- 96: CP#45 may be no changes needed to 29.168 / Text3: 29.168 (may be no changes needed) / Text5: Ramachandran Subramanian (rsubrama@qualcomm.com)
- 97: Extend Warning System support of E-UTRA/E-UTRAN beyond Rel-8 ETWS by providing support for multiple parallel Warning Notifications, etc. RP#45 Rapporteur recommended WI closure as completion >85% / Text3: 36.300, 36.331, 36.413 / Text5: don.zelmer@att.com
- 98: SP#40 Stage 1 completed. Continuation of Rel-8 Feature PRIOR UID_340044. / Text5: jgarraha@telcordia.com
- 99: SP#40 completed / Text3: 22.153, 22.278 / Text5: jgarraha@telcordia.com
- 100: SP#40 WID approved & Stage 1 completed / Text5: armin.toepfer@vodafone.com
- 101: SP#40 Stage 1 completed / Text3: 22.259 / Text5: armin.toepfer@vodafone.com
- 102: CP#45 completion 09/09=>12/09. CP#44 WID updated CP-090113=>CP-090435 Removed: Mechanism for a PNE without a (U)SIM capable of discovering PNEs with a (U)SIM in its proximity / Text3: 23.259 / Text5: Lili Yang (kadyyang@huawei.com)
- 103: CP#44 WID updated CP-090113=>CP-090435 Removed: Mechanism for a PNE without a (U)SIM capable of discovering PNEs with a (U)SIM in its proximity / Text3: 24.259 / Text5: Lili Yang (kadyyang@huawei.com)
- 104: SP#42 Stage 1 completed. SP#41 WID updated SP-080324=>SP-080503 / Text5: Philippe Lottin
- 105: SP#42 completed. SP#41 WID updated SP-080324=>SP-080503 / Text3: 22.173 / Text5: Philippe Lottin
- 106: - / Text3: 32.275, 32.298, 32.299 / Text5: Maryse.Gardella@alcatel-lucent.fr
- 107: SP#44 WID updated SP-090055=>SP-090306. Linked to SA5 Rel-8 UID_380042 AoC support in IMS Charging (IMSTSS). SA3/CT3 coordination need on 29.658 (SIP transfer of tariff information) / Text3: 32.27x, 32.240, 32.280, 32.298, 32.299 / Text5: Jean-Luc Garcia (jl.garcia@orange-ftgroup.com)
- 108: - / Text3: 24.642 / Text5: Youssef.chadli@orange-ftgroup.com
- 109: SP#42 Stage 1 completed / Text5: lansizhong@chinamobile.com
- 110: SP#42 completed / Text3: 22.985, 22.101 / Text5: lansizhong@chinamobile.com
- 111: - / Text3: 23.335 User Data Convergence (UDC); Technical Realization and Information Flows / Text5: Emiliano Merino (emiliano.merino@ericsson.com)
- 112: - / Text3: 29.335 / Text5: Lan Si Zhong (lansizhong@chinamobile.com), emiliano.merino@ericsson.com
- 113: develop UDC information models / Text5: Istvan Aba, Lan Si Zhong, Miguel Garcia
- 114: - / Text3: 32.172, new 32.181 / Text5: istvan.aba <at> t-mobile.at
- 115: develop UDC information models) / Text3: 32.172, new 32.182 / Text5: Istvan Aba, Lan Si Zhong, Miguel Garcia

| ID | WBS | Task | Duration | Start | Finish | Complete | Remaining | Baseline start | Baseline finish | Baseline duration | Total slack | Constraint | Resources | Work | Actual work | Text1 | Text2 | Text4 | Text5 | Text6 | Text7 | Text8 | Text11 |
| --- | --- | --- | --- | --- | --- | --- | --- | --- | --- | --- | --- | --- | --- | --- | --- | --- | --- | --- | --- | --- | --- | --- | --- |
| 116 | 53 | **IMS Services Centralization and Continuity** | 318d? | 2008-09-18 A | 2009-12-04 | 70% | 96.93d? | 2008-09-18 | 2009-12-04 | 318d? | 726d |  | S1,S2,C1 | 9760h | 5327.6h | IMS_SCC | PCG-21 | NEC | Joerg Swetina (joerg.swetina@nw.neclab.eu) | Rel-9 | SP-41 | Alain |  |
| 117 | 53.1 | Stage 1 - Inter-Device Transfer – Requirements | 61d? | 2008-09-18 A | 2008-12-11 A | 100% |  | 2008-09-18 | 2008-12-11 | 61d? |  | finish no earlier than 2009-06-18 | S1 | 488h | 488h | IMS_SCC-IDT | PCG-21 | NEC | Joerg Swetina (joerg.swetina@nw.neclab.eu) | Rel-9 | SP-41 | Alain |  |
| 118 | 53.2 | Stage 2 - IMS Service Continuity Enhancements: Service, Policy and Interactions | 186d? | 2008-09-18 A | 2009-06-04 A | 100% |  | 2008-09-18 | 2009-06-04 | 186d? |  | finish no earlier than 2009-06-04 | S2 | 1488h | 1488h | IMS_SCC-SPI | PCG-21 | Huawei | HengLiang Zhang (hl_zhang@huawei.com) | Rel-9 | SP-41 | Maurice |  |
| 119 | 53.3 | Stage 3 - IMS Service Continuity Enhancements: Service, Policy, Interactions and Inter UE Transfer | 137d? | 2009-05-29 A | 2009-12-04 | 10% | 123.4d? | 2009-05-29 | 2009-12-04 | 137d? | 726d | finish no earlier than 2009-12-04 | C1 | 1096h | 108.8h | IMS_SCC-SPI | PCG-23 | Qualcomm Europe | Roozbeh Atarius (ratarius@qualcomm.com) | Rel-9 | CP-44 | Frederic |  |
| 120 | 53.4 | Stage 2 - IMS Centralized Services | 186d? | 2008-09-18 A | 2009-06-04 A | 100% |  | 2008-09-18 | 2009-06-04 | 186d? |  | finish no earlier than 2009-06-04 | S2 | 1488h | 1488h | IMS_SCC-ICS | PCG-21 | Alcatel-Lucent | Andy Bennett (andybennett@alcatel-lucent.com) | Rel-9 | SP-41 | Maurice |  |
| 121 | 53.5 | Stage 3 - Enhancements to IMS Centralized Services | 137d? | 2009-05-29 A | 2009-12-04 | 75% | 34.25d? | 2009-05-29 | 2009-12-04 | 137d? | 726d | start no earlier than 2009-05-29 | C1 | 1088h | 814h | IMS_SCC-ICS | PCG-23 | Nokia Siemens Networks | Peter.Leis@nsn.com | Rel-9 | CP-44 | Frederic |  |
| 122 | 53.6 | Stage 3 - IMS Centralized Services support via I1 interface | 196d? | 2009-03-06 A | 2009-12-04 | 40% | 117.6d? | 2009-03-06 | 2009-12-04 | 196d? | 726d | finish no earlier than 2009-12-04 | C1 | 1568h | 627.2h | IMS_SCC-ICS_I1 | PCG-22 | Huawei | Lili Yang(kadyyang@huawei.com) | Rel-9 | CP-43 | Frederic |  |
| 123 | 54 | **Service Specific Access Control in EPS** | 258d? | 2008-12-11 A | 2009-12-04 | 30% | 179.85d? | 2008-12-11 | 2009-12-04 | 258d? | 726d |  | S1,C1 | 3168h | 342.4h | SSAC | PCG-22 | NTT DoCoMo | Frederic Thepot (thepot@docomolab-euro.com) | Rel-9 | SP-42 | Alain |  |
| 124 | 54.1 | Stage 1 for SSAC | 1d? | 2008-12-11 A | 2008-12-11 A | 100% |  | 2008-12-11 | 2008-12-11 | 1d? |  | start no earlier than 2008-12-11 | S1 | 8h | 8h | SSAC | PCG-22 | NTT DoCoMo | Frederic Thepot (thepot@docomolab-euro.com) | Rel-9 | SP-42 | Alain |  |
| 125 | 54.2 | Stage 3 for SSAC | 137d? | 2009-05-29 A | 2009-12-04 | 30% | 96.2d? | 2009-05-29 | 2009-12-04 | 137d? | 726d | finish no earlier than 2009-12-04 | C1 | 1096h | 326.4h | SSAC | PCG-23 | NTT DoCoMo | Hideyuki Yamashita (yamashitahi@s1.nttdocomo.co.jp) | Rel-9 | CP-44 | Frederic |  |
| 126 | 55 | **Support for IMS Emergency Calls over GPRS and EPS** | 500d? | 2008-01-14 A | 2009-12-10 | 81% | 93.47d? | 2008-01-14 | 2009-12-10 | 500d? | 722d |  | S1,S2,S3,C1,C3,C4,R2,R3 | 23843.7h | 16500.6h | IMS_EMER_GPRS_EPS | PCG-21 | Alcatel-Lucent | Deborah Barclay | Rel-9 | SP-38 | Maurice |  |
| 127 | 55.1 | Stage 1 of IMS_EMER_GPRS_EPS | 239d? | 2008-01-14 A | 2008-12-11 A | 100% |  | 2008-01-14 | 2008-12-11 | 239d? |  | finish no earlier than 2008-12-11 | S1 | 1912h | 1912h | IMS_EMER_GPRS_EPS | PCG-21 | Alcatel-Lucent | Deborah Barclay | Rel-9 | SP-38 | Alain |  |
| 128 | 55.2 | Stage 2 of IMS_EMER_GPRS_EPS | 364d? | 2008-01-14 A | 2009-06-04 A | 100% |  | 2008-01-14 | 2009-06-04 | 364d? |  | finish no earlier than 2009-06-04 | S2 | 2912h | 2912h | IMS_EMER_GPRS_EPS | PCG-21 | Alcatel-Lucent | Deborah Barclay | Rel-9 | SP-38 | Maurice |  |
| 129 | 55.3 | Security aspects of IMS_EMER_GPRS_EPS | 261d? | 2008-12-12 A | 2009-12-10 | 80% | 52.2d? | 2008-12-12 | 2009-12-10 | 261d? | 722d | finish no earlier than 2009-12-10 | S3 | 2088h | 1670.4h | IMS_EMER_GPRS_EPS-Sec | PCG-22 | Alcatel-Lucent | Deborah Barclay | Rel-9 | SP-42 | Dionisio |  |
| 130 | 55.4 | **Stage 3 of IMS_EMER_GPRS_EPS** | 137d? | 2009-05-29 A | 2009-12-04 | 85% | 21.09d? | 2009-05-29 | 2009-12-04 | 137d? | 726d |  | C1,C3,C4 | 3939.68h | 2441.55h | IMS_EMER_GPRS_EPS | PCG-23 | Alcatel-Lucent | Frank Alfano (falfano@alcatel-lucent.com) | Rel-9 | CP-44 | Frederic |  |
| 131 | 55.4.1 | CT1 aspects - Stage 3 of IMS_EMER_GPRS_EPS | 137d? | 2009-05-29 A | 2009-12-04 | 80% | 27.4d? | 2009-05-29 | 2009-12-04 | 137d? | 726d | finish no earlier than 2009-12-04 | C1 | 1096h | 876.8h | IMS_EMER_GPRS_EPS | PCG-23 | Alcatel-Lucent | Frank Alfano (falfano@alcatel-lucent.com) | Rel-9 | CP-44 | Frederic |  |
| 132 | 55.4.2 | CT3 aspects - Stage 3 of IMS_EMER_GPRS_EPS | 82d? | 2009-05-29 A | 2009-09-18 A | 100% |  | 2009-05-29 | 2009-09-18 | 82d? |  | start no earlier than 2009-05-29 | C3 | 651.68h | 651.68h | IMS_EMER_GPRS_EPS | PCG-23 | Alcatel-Lucent | Frank Alfano (falfano@alcatel-lucent.com) | Rel-9 | CP-44 | Gwiho |  |
| 133 | 55.4.3 | CT4 aspects - Stage 3 of IMS_EMER_GPRS_EPS | 137d? | 2009-05-29 A | 2009-12-04 | 80% | 27.4d? | 2009-05-29 | 2009-12-04 | 137d? | 726d | finish no earlier than 2009-12-04 | C4 | 1096h | 876.8h | IMS_EMER_GPRS_EPS | PCG-23 | Alcatel-Lucent | Frank Alfano (falfano@alcatel-lucent.com) | Rel-9 | CP-44 | Kimmo |  |
| 134 | 55.5 | Support for IMS Emergency Calls over LTE | 206d? | 2008-12-05 A | 2009-09-18 A | 100% |  | 2008-12-05 | 2009-09-18 | 206d? |  |  | R2,R3 | 1648h | 1648h | IMS_EMER_LTE | PCG-22 | Alcatel-Lucent | Sudeep Palat (spalat@alcatel-lucent.com) | Rel-9 | RP-42 | Joern | RP-090698 |
| 135 | 55.6 | **SRVCC support for IMS Emergency Calls** | 322d? | 2008-09-18 A | 2009-12-10 | 55% | 146.41d? | 2008-09-18 | 2009-12-10 | 322d? | 722d |  | S2,C1,C4 | 7344h | 4004.7h | IMS_EMER_GPRS_EPS-SRVCC | PCG-21 | China Mobile | Yu Qing (Yuqing@chinamobile.com) | Rel-9 | SP-41 | Maurice |  |
| 136 | 55.6.1 | SRVCC support for IMS Emergency Calls | 322d? | 2008-09-18 A | 2009-12-10 | 50% | 161d? | 2008-09-18 | 2009-12-10 | 322d? | 722d | finish no earlier than 2009-12-10 | S2 | 2576h | 1288h | IMS_EMER_GPRS_EPS-SRVCC | PCG-21 | China Mobile | Yu Qing (Yuqing@chinamobile.com) | Rel-9 | SP-41 | Maurice |  |
| 137 | 55.6.2 | CT1 aspects of SRVCC support for IMS Emergency Calls | 137d? | 2009-05-29 A | 2009-12-04 | 80% | 27.4d? | 2009-05-29 | 2009-12-04 | 137d? | 726d | finish no earlier than 2009-12-04 | C1 | 1096h | 876.8h | IMS_EMER_GPRS_EPS-SRVCC | PCG-23 | China Mobile | jiangyi@chinamobile.com | Rel-9 | CP-44 | Frederic |  |
| 138 | 55.6.3 | CT4 aspects of SRVCC support for IMS Emergency Calls | 137d? | 2009-05-29 A | 2009-12-04 | 40% | 82.6d? | 2009-05-29 | 2009-12-04 | 137d? | 726d | finish no earlier than 2009-12-04 | C4 | 1096h | 435.2h | IMS_EMER_GPRS_EPS-SRVCC | PCG-23 | China Mobile | jiangyi@chinamobile.com | Rel-9 | CP-44 | Kimmo |  |
| 139 | 56 | **LCS for LTE and EPS** | 393d? | 2008-06-05 A | 2009-12-04 | 50% | 197.25d? | 2008-06-05 | 2009-12-04 | 393d? | 726d |  | S2,C1,C4,R2,R1,R3,R4 | 14232h | 7217.6h | LCS_LTE_EPS | PCG-22 |  |  | Rel-9 | SP-43 | Maurice |  |
| 140 | 56.1 | **LCS Control Plane Solution for EPS** | 393d? | 2008-06-05 A | 2009-12-04 | 54% | 181.15d? | 2008-06-05 | 2009-12-04 | 393d? | 726d |  | S2,C4,C1 | 7424h | 4002.02h | LCS_EPS-CPS | PCG-21 | Polaris Wireless | Robert Gross | Rel-9 | SP-40 | Maurice |  |
| 141 | 56.1.1 | Stage 2 for LCS_CPS_EPS | 261d? | 2008-06-05 A | 2009-06-04 A | 100% |  | 2008-06-05 | 2009-06-04 | 261d? |  | finish no earlier than 2009-06-04 | S2 | 2088h | 2088h | LCS_EPS-CPS | PCG-21 | Polaris Wireless | Robert Gross | Rel-9 | SP-40 | Maurice |  |
| 142 | 56.1.2 | CT4 aspects - Control Plane LCS in the EPC | 137d? | 2009-05-29 A | 2009-12-04 | 20% | 109.6d? | 2009-05-29 | 2009-12-04 | 137d? | 726d | finish no earlier than 2009-12-04 | C4 | 1096h | 219.2h | LCS_EPS-CPS | PCG-23 | Polaris Wireless | Robert Gross | Rel-9 | CP-44 | Kimmo |  |
| 143 | 56.1.3 | CT1 aspects - Control Plane LCS in the EPC | 137d? | 2009-05-29 | 2009-12-04 |  |  | 2009-05-29 | 2009-12-04 | 137d? | 726d | finish no earlier than 2009-12-04 | C1 | 1096h |  | LCS_EPS-CPS | PCG-23 | Polaris Wireless | Robert Gross | Rel-9 | CP-44 | Frederic |  |
| 144 | 56.2 | Positioning Support for LTE | 262d? | 2008-12-05 A | 2009-12-04 | 60% | 104.8d? | 2008-12-05 | 2009-12-04 | 262d? | 726d |  | R2,R1,R3,R4 | 2096h | 1257.6h | LCS_LTE | PCG-22 | Qualcomm Europe | Nathan Tenny (ntenny@qualcomm.com) | Rel-9 | RP-42 | Joern | RP-090699 |
| 145 | 56.3 | Network-Based Positioning Support in LTE | 196d? | 2009-03-06 A | 2009-12-04 | 25% | 147d? | 2009-03-06 | 2009-12-04 | 196d? | 726d |  | R2,R3,R4 | 1568h | 392h | LCS_LTE-NBPS | PCG-22 | TruePosition | Terry Brooks (terri.brooks@trueposition.com) | Rel-9 | RP-43 | Joern | RP-090700 |

Notes:
- 116: SP#42 Stage 1 completed.
- 117: SP#42 completed / Text3: 22.101, 22.228
- 118: SP#44 completed. TR 23.838 for Approval / Text3: 23.838, 23.237, 23.292, 23.216
- 119: - / Text3: 24.216, 24.229, 24.237
- 120: SP#44 completed. TR 23.883 for Information + Approval / Text3: 23.883, 23.292
- 121: - / Text3: 24.292, 24.604, 24.605, 24.606, 24.607, 24.608, 24.610, 24.611, 24.615, 24.616, 24.623, 24.629, 24.642
- 122: CP#45 updated WID CP-090114=>CP-090640 / Text3: 24.237, 24.292, new 24.294
- 123: SP#42 Stage 1 completed (need for SA2 input). Triggered by Study UID_400036 on Service Specific Access Control in EPS (FS_SSAC)
- 124: SP#42 completed / Text3: 22.011 CR0136
- 125: - / Text3: 23.122, 24.173?
- 126: SP#42 Stage 1 completed. WID updated SP-070820=>SP-080352=>SP-080844 (Add SA3 task).
- 127: SP#42 completed / Text3: 22.101
- 128: SP#44 completed / Text3: 23.869, 23.060, 23.167, 23.203, 23.221, 23.228, 23.271, 23.401, 23.402
- 129: SP#42 WID updated SP-080352=>SP-080844 (Added SA3 task) / Text3: 33.401, 33.402
- 130: CP#45 WID updated CP-090441=>CP-090564
- 131: CP#45 WID updated CP-090441=>CP-090564 / Text3: 23.122, 24.008, 24.229, 24.301, 24.302
- 132: CP#45 completed / Text3: 29.212, 29.213, 29.214, 29.215
- 133: CP#45 WID updated CP-090441=>CP-090564 / Text3: 23.003, 23.008, 29.060, 29.272, 29.273, 29.274, 29.275, 29.276
- 134: RP#45 completed / Text3: 36.331, 36.413
- 135: SP#43 TR 23.870 for Information. WID updated SP-080562=>SP-090099 (added location continuity aspects)
- 136: SP#44 TR 23.870 for Approval / Text3: 23.870, 23.216, 23.237
- 137: Stage 3 / Text3: 24.237
- 138: Stage 3 / Text3: 29.280
- 139: -
- 140: Triggered by abandoned Study UID_380068 (FS_LCS_EPS). Linked to UID_380064 Feature IMS_EMER_GPRS_EPS.
- 141: SP#44 completed (Some alignments might be needed later on based on RAN progress) / Text3: 23.891, 23.271, 23.401, 23.402
- 142: CP#45 WID update CP-090317=>CP-090518. Supports stage 3 definition of SLs and SLg interfaces. Supports transport of positioning messages between the E-SMLC and MME in the scope of UID_420006 (Positioning Support for LTE) / Text3: 29.002, 29.171, 29.172, 29.173 (Definition of SLs, SLg and Diameter-based Lh interface for Control Plane LCS)
- 143: CP#45 WID update CP-090317=>C4-092688. Supports stage 3 definition of SLs and SLg interfaces. Supports transport of positioning messages between the E-SMLC and MME in the scope of UID_420006 (Positioning Support for LTE) / Text3: 24.007, 24.301, new 24.171
- 144: RP#45 TS 36.305-200 for Approval. UID_400038 (LCS Control Plane Solution for EPS) depends on this WI / Text3: 36.133, 36.211, 36.214, 36.300, 36.331, new 36.305, new 36.355 (LTE Positioning Protocol - LPP), 36.413
- 145: - / Text3: new 36.xxx (Performance Requirements for LMU), 36.300, 36.331, 36.355, 36.413

| ID | WBS | Task | Duration | Start | Finish | Complete | Remaining | Baseline start | Baseline finish | Baseline duration | Total slack | Constraint | Resources | Work | Actual work | Text1 | Text2 | Text4 | Text5 | Text6 | Text7 | Text8 | Text11 |
| --- | --- | --- | --- | --- | --- | --- | --- | --- | --- | --- | --- | --- | --- | --- | --- | --- | --- | --- | --- | --- | --- | --- | --- |
| 146 | 57 | **MBMS support in EPS** | 397d? | 2008-06-05 A | 2009-12-10 | 67% | 131.22d? | 2008-06-05 | 2009-12-10 | 397d? | 722d |  | S2,S3,S5,C3,C4,R2,R3,R4 | 12704h | 8503.44h | MBMS_EPS | PCG-21 | China Mobile | Liu Hong (liuhongyfw@chinamobile.com) | Rel-9 | SP-40 | Maurice |  |
| 147 | 57.1 | Stage 2 for MBMS_EPS | 261d? | 2008-06-05 A | 2009-06-04 A | 100% |  | 2008-06-05 | 2009-06-04 | 261d? |  | finish no earlier than 2009-06-04 | S2 | 2088h | 2088h | MBMS_EPS | PCG-21 | China Mobile | Liu Hong (liuhongyfw@chinamobile.com) | Rel-9 | SP-40 | Maurice |  |
| 148 | 57.2 | Security for MBMS_EPS | 261d? | 2008-12-11 A | 2009-12-10 | 50% | 130.5d? | 2008-12-11 | 2009-12-10 | 261d? | 722d | finish no earlier than 2009-12-10 | S3 | 2088h | 1044h | MBMS_EPS | PCG-22 | China Mobile | Liu Hong (liuhongyfw@chinamobile.com) | Rel-9 | SP-42 | Dionisio |  |
| 149 | 57.3 | MBMS Charging in EPS | 201d? | 2009-03-06 A | 2009-12-10 | 55% | 90.45d? | 2009-03-06 | 2009-12-10 | 201d? | 722d | finish no earlier than 2009-12-10 | S5 | 1600h | 877.63h | MBMS_EPS | PCG-22 | ZTE | guo.wenjie1@zte.com.cn | Rel-9 | SP-43 | Dionisio |  |
| 150 | 57.4 | CT4 aspects of MBMS support in EPS | 137d? | 2009-05-29 A | 2009-12-04 | 75% | 34.25d? | 2009-05-29 | 2009-12-04 | 137d? | 726d | finish no earlier than 2009-12-04 | C4 | 1096h | 822h | MBMS_EPS | PCG-23 | China Mobile, ZTE | wangjingyf@chinamobile.com, lu.fei1@zte.com.cn | Rel-9 | CP-44 | Kimmo |  |
| 151 | 57.5 | CT3 aspects of MBMS support in EPS | 136d? | 2009-05-29 A | 2009-12-03 | 70% | 40.8d? | 2009-05-29 | 2009-12-03 | 136d? | 727d | start no earlier than 2009-05-29 | C3 | 1088h | 761.6h | MBMS_EPS | PCG-23 | ZTE, China Mobile | zhou.xiaoyun@zte.com.cn, wangjingyf@chinamobile.com | Rel-9 | CP-44 | Gwiho |  |
| 152 | 57.6 | MBMS support in LTE | 196d? | 2009-03-06 A | 2009-12-04 | 50% | 98d? | 2009-03-06 | 2009-12-04 | 196d? | 726d |  | R2,R3,R4 | 1568h | 784h | MBMS_LTE | PCG-22 | Huawei | arnaud.meylan@huawei.com | Rel-9 | RP-43 | Joern | RP-090701 |
| 153 | 58 | **Access Network Discovery and Selection Function enhancements** | 326d? | 2008-12-11 A | 2010-03-10 | 50% | 161.7d? | 2008-12-11 | 2010-03-10 | 326d? | 658d |  | S2,S1,S3 | 4608h | 2322.43h | eANDSF | PCG-22 | Motorola | Apostolis Salkintzis (salki@motorola.com) | Rel-9 | SP-42 | Maurice |  |
| 154 | 58.1 | Stage 2 for eANDSF | 126d? | 2008-12-11 A | 2009-06-04 A | 100% |  | 2008-12-11 | 2009-06-04 | 126d? |  | finish no earlier than 2009-06-04 | S2 | 1008h | 1008h | eANDSF | PCG-22 | Motorola | Apostolis Salkintzis (salki@motorola.com) | Rel-9 | SP-42 | Maurice |  |
| 155 | 58.2 | CT1 aspects - eANDSF | 124d? | 2009-09-18 | 2010-03-10 |  |  | 2009-09-18 | 2010-03-10 | 124d? | 658d | finish no earlier than 2010-03-10 | C1 | 992h |  | eANDSF | PCG-23 | Panasonic | benjamin.limck@sg.panasonic.com | Rel-9 | CP-45 | Frederic |  |
| 156 | 59 | **Multiple PDN Connection to the Same APN for PMIP-based Interfaces** | 192d? | 2009-03-13 A | 2009-12-04 | 35% | 124.3d? | 2009-03-13 | 2009-12-04 | 192d? | 726d |  | S2,C4,C1 | 2920h | 976h | MUPSAP | PCG-22 | Samsung | erik.guttman@partner.samsung.com | Rel-9 | SP-43 | Maurice |  |
| 157 | 59.1 | Stage 2 for MUPSAP | 61d? | 2009-03-13 A | 2009-06-04 A | 100% |  | 2009-03-13 | 2009-06-04 | 61d? |  | finish no earlier than 2009-06-04 | S2 | 488h | 488h | MUPSAP | PCG-22 | Samsung | erik.guttman@partner.samsung.com | Rel-9 | SP-43 | Maurice |  |
| 158 | 59.2 | MUPSAP - CT4 aspects | 56d? | 2009-09-18 | 2009-12-04 |  |  | 2009-09-18 | 2009-12-04 | 56d? | 726d | finish no earlier than 2009-12-04 | C4 | 448h |  | MUPSAP | PCG-23 | Samsung | Surjyakanta Mohapatra (surjya.kanta@samsung.com) | Rel-9 | CP-45 | Kimmo |  |
| 159 | 59.3 | MUPSAP - CT1 aspects | 56d? | 2009-09-18 | 2009-12-04 |  |  | 2009-09-18 | 2009-12-04 | 56d? | 726d | finish no earlier than 2009-12-04 | C1 | 448h |  | MUPSAP | PCG-23 | Samsung | Surjyakanta Mohapatra (surjya.kanta@samsung.com) | Rel-9 | CP-45 | Frederic |  |
| 160 | 60 | Access Security Enhancements | 505d? | 2007-07-02 A | 2009-06-04 A | 100% |  | 2007-07-02 | 2009-06-04 | 505d? |  | finish no earlier than 2009-06-03 | S3 | 4040h | 4040h | ACCSEC2 |  | Ericsson | Bengt.Sahlin@ericsson.com | Rel-9 | SP-26 | Dionisio |  |
| 161 | 61 | **Protection against Unsolicited Communication for IMS (PUCI)** | 322d? | 2008-09-18 A | 2009-12-10 | 58% | 135.36d? | 2008-09-18 | 2009-12-10 | 322d? | 722d |  | S3,S1 | 5640h | 2264h | PUCI | PCG-21 | NEC | Anand R. Prasad (anand@bq.jp.nec.com) | Rel-9 | SP-41 | Alain |  |
| 162 | 61.1 | Stage 1 for PUCI | 61d? | 2008-09-18 A | 2008-12-11 A | 100% |  | 2008-09-18 | 2008-12-11 | 61d? |  | finish no earlier than 2009-06-18 | S1 | 488h | 488h | PUCI | PCG-21 | NEC | Anand R. Prasad (anand@bq.jp.nec.com) | Rel-9 | SP-41 | Alain |  |
| 163 | 61.2 | SA3 work on PUCI | 322d? | 2008-09-18 A | 2009-12-10 | 50% | 161d? | 2008-09-18 | 2009-12-10 | 322d? | 722d | finish no earlier than 2009-12-10 | S3 | 2576h | 1288h | PUCI | PCG-21 | NEC | Anand R. Prasad (anand@bq.jp.nec.com) | Rel-9 | SP-41 | Dionisio |  |
| 164 | 62 | **IMS Media Plane Security** | 260d? | 2009-03-13 A | 2010-03-10 | 34% | 171.63d? | 2009-03-13 | 2010-03-10 | 260d? | 658d |  | S3,C1,C4 | 4848h | 1881.6h | MEDIASEC | PCG-22 | Vodafone | Peter.Howard@vodafone.com | Rel-9 | SP-43 | Dionisio |  |
| 165 | 62.1 | SA3 aspects - MEDIASEC | 196d? | 2009-03-13 A | 2009-12-10 | 60% | 78.4d? | 2009-03-13 | 2009-12-10 | 196d? | 722d | finish no earlier than 2009-12-10 | S3 | 1568h | 940.8h | MEDIASEC | PCG-22 | Vodafone | Peter.Howard@vodafone.com | Rel-9 | SP-43 | Dionisio |  |
| 166 | 62.2 | CT1 aspects - MEDIASEC | 26d? | 2009-09-18 | 2010-03-10 |  |  | 2009-09-18 | 2010-03-10 | 26d? | 658d | finish no earlier than 2010-03-10 | C1 | 208h |  | MEDIASEC_CORE | PCG-23 | Vodafone | peter.dawes@vodafone.com | Rel-9 | CP-45 | Frederic |  |
| 167 | 62.3 | CT4 aspects - MEDIASEC | 124d? | 2009-09-18 | 2010-03-10 |  |  | 2009-09-18 | 2010-03-10 | 124d? | 658d | start no earlier than 2009-09-18 | C4 | 992h |  | MEDIASEC_CORE | PCG-23 | Vodafone | peter.dawes@vodafone.com | Rel-9 | CP-45 | Kimmo |  |
| 168 | 63 | **GBAPush enhancements (Generic push layer)** | 458d? | 2008-03-12 A | 2009-12-10 | 75% | 114.5d? | 2008-03-12 | 2009-12-10 | 458d? | 722d |  | S3 | 7328h | 5496h | eGBAPush | PCG-23 | Ericsson | Rolf Blom | Rel-9 | SP-44 | Dionisio |  |
| 169 | 63.1 | SA3 part of eGBAPush (Generic push layer) | 458d? | 2008-03-12 A | 2009-12-10 | 75% | 114.5d? | 2008-03-12 | 2009-12-10 | 458d? | 722d | finish no earlier than 2009-12-10 | S3 | 3664h | 2748h | eGBAPush | PCG-21 | Ericsson | Rolf Blom | Rel-9 | SP-39 | Dionisio |  |
| 170 | 64 | Extended Identity Management | 136d? | 2009-06-04 A | 2009-12-10 | 70% | 40.8d? | 2009-06-04 | 2009-12-10 | 136d? | 722d | finish no earlier than 2009-12-10 | S3,C4 | 1088h | 761.6h | GBA-IdM | PCG-23 | Nokia | Silke.Holtmanns at nokia.com | Rel-9 | SP-44 | Dionisio |  |

Notes:
- 146: SP#42 WID updated SP-080442=>SP-080737 (add SA3 task)
- 147: SP#44 completed / Text3: 23.246
- 148: SP#45 completion 09/09=>12/09 / Text3: 33.246
- 149: - / Text3: 32.273, 32.251, 32.298, 32.299
- 150: Stage 3 / Text3: 29.274, 29.281, 23.007, 23.008
- 151: Stage 3 / Text3: 29.061
- 152: RP#44 updated WID RP-090350=>RP-090619. Stage 2/3 / Text3: 36.101, 36.104, 36.141, 36.300, 36.304, 36.321, 36.322, 36.323, 36.331, 36.440, 36.441, 36.442, 36.444, 36.445, 36.446
- 153: SP#44 Stage 2 completed. No new Rel-9 use cases defined. Implement service requirements not covered in Rel-8 / Text3: SA1 22.278, SA3 33.402 CR#0055
- 154: SP#44 completed / Text3: 23.402, 23.002
- 155: - / Text3: 24.302, 24.312
- 156: SP#44 Stage 2 completed. Continues Rel-8 SAES Stage 2 UID_320005. Stage 1 in 22.278 (EPS Service requirements) / Text3: 23.060, 23.203, 23.401, 23.402
- 157: SP#44 completed. Continues Rel-8 SAES Stage 2 UID_320005. Stage 1 in 22.278 (EPS Service requirements) / Text3: 23.060, 23.203, 23.401, 23.402
- 158: Leadership CT4 / Text3: 29.275, 23.008, 29.282
- 159: Leadership CT4 / Text3: 24.302
- 160: SP#44 completed. Stopped TR 33.801. CRs 33.102,43.020 on A5/2 removal done long time ago. A5/4 introduction CRs will be done under UID_440057 128 bit encryption for GSM and GPRS. SP#26 approved WID (improved GERAN security) / Text3: 33.102, 43.020, Stopped TR 33.801 “Access security review” (Reason: draft contained useful material for planning A5/2 removal and A5/4 introduction. Completion would require significant effort)
- 161: SP#42 Stage 1 completed. SP#41 SA3 WID approved (Stage 1 commitment in SA1 LS in SP-080523). Check related work in OMA Categorization Based Content Screening
- 162: SP#42 completed / Text3: 22.228
- 163: SP#45 completion 09/09=>12/09. SP#44 TR 33.837 for Information. No TS started yet. Bring revised WID reflecting only Rel-9 and New WID for TS work / Text3: 33.837
- 164: SP#45 Stage 2 exception to 12/09. SP#43 Stage 1 to be defined by SA3 in consultation with SA1
- 165: SP#45 Stage 2 exception to 12/09. TR 33.828 2nd time for Information. TS 33.328v100 for Information (currently 3 solutions / decide in Dec 2009 subject of progress) / Text3: new 33.828, 33.328
- 166: Leadership CT1 / Text3: 23.218, 24.229
- 167: Leadership CT1 / Text3: 23.334, 29.334
- 168: SP#45 TS 33.224 for Approval. Completion 09/09=>12/09. SP#44 WID approved. Develop a generic push layer using GAA protection. SP#43 Umbrella Feature created to host 33.224, moved from Rel-8 to Rel-9 / Text3: 33.224
- 169: SP#45 TS 33.224 for Approval. Completion 09/09=>12/09. Develop a generic push layer using GAA protection. SP#42 TS 33.224 moved to Rel-9 (33.223 completed as Rel-8 under UID_390146) / Text3: 33.224
- 170: SP#45 Stage 2 exception to 12/09. TR 33.924 for Information. Stage 2 (Stage 1 not identified: GBA Liberty Interworking has been outlined and GBAOpenID interworking is analogous) / Text3: new 33.924, CP#45 CT4 completed (Added service code in 29.109)

| ID | WBS | Task | Duration | Start | Finish | Complete | Remaining | Baseline start | Baseline finish | Baseline duration | Total slack | Constraint | Resources | Work | Actual work | Text1 | Text2 | Text4 | Text6 | Text7 | Text8 | Text9 | Text12 |
| --- | --- | --- | --- | --- | --- | --- | --- | --- | --- | --- | --- | --- | --- | --- | --- | --- | --- | --- | --- | --- | --- | --- | --- |
| 171 | 65 | **Network Domain Security (NDS) enhancements to support backhaul security** | 136d? | 2009-06-04 | 2009-12-10 |  |  | 2009-06-04 | 2009-12-10 | 136d? | 722d |  | S3,C4 | 3264h |  | NDS_Backhaul | PCG-23 | Vodafone | Rel-9 | SP-44 | Dionisio |  |  |
| 172 | 65.1 | SA3 part of NDS_Backhaul | 136d? | 2009-06-04 | 2009-12-10 |  |  | 2009-06-04 | 2009-12-10 | 136d? | 722d | finish no earlier than 2009-12-10 | S3 | 1088h |  | NDS_Backhaul | PCG-23 | Vodafone | Rel-9 | SP-44 | Dionisio |  |  |
| 173 | 65.2 | CT4 part of NDS_Backhaul | 136d? | 2009-06-04 | 2009-12-10 |  |  | 2009-06-04 | 2009-12-10 | 136d? | 722d | finish no earlier than 2009-12-10 | C4 | 1088h |  | NDS_Backhaul | PCG-23 | Vodafone | Rel-9 | SP-44 | Kimmo |  |  |
| 174 | 66 | **128 bit encryption for GSM and GPRS** | 136d? | 2009-06-04 A | 2009-12-10 | 36% | 86.57d? | 2009-06-04 | 2009-12-10 | 136d? | 722d |  | S3,S2,C1,C4,G2,G3new | 6040h | 2195.47h | A5/4-GEA4 | PCG-23 | Ericsson | Rel-9 | SP-44 | Dionisio |  |  |
| 175 | 66.1 | SA3 part of A5/4-GEA4 | 136d? | 2009-06-04 | 2009-12-10 |  |  | 2009-06-04 | 2009-12-10 | 136d? | 722d | start no earlier than 2009-06-04 | S3 | 1088h |  | A5/4-GEA4 | PCG-23 | Ericsson | Rel-9 | SP-44 | Dionisio |  |  |
| 176 | 66.2 | CT1 part of A5/4-GEA4 | 77d? | 2009-06-04 A | 2009-09-18 A | 100% |  | 2009-06-04 | 2009-09-18 | 77d? |  | start no earlier than 2009-06-04 | C1 | 616h | 616h | A5/4-GEA4 | PCG-23 | Ericsson | Rel-9 | SP-44 | Frederic |  |  |
| 177 | 66.3 | CT4 part of A5/4-GEA4 | 136d? | 2009-06-04 | 2009-12-10 |  |  | 2009-06-04 | 2009-12-10 | 136d? | 722d | start no earlier than 2009-06-04 | C4 | 1088h |  | A5/4-GEA4 | PCG-23 | Ericsson | Rel-9 | SP-44 | Kimmo |  |  |
| 178 | 66.4 | GERAN2 part of A5/4-GEA4 | 67d? | 2009-06-04 A | 2009-09-04 A | 100% |  | 2009-06-04 | 2009-09-04 | 67d? |  | finish no earlier than 2009-09-04 | G2 | 536h | 536h | A5/4-GEA4 | PCG-23 | Ericsson | Rel-9 | SP-44 | Gert |  |  |
| 179 | 66.5 | GERAN3new (testing) part of A5/4-GEA4 | 122d? | 2009-06-04 | 2009-11-20 |  |  | 2009-06-04 | 2009-11-20 | 122d? | 736d | finish no earlier than 2009-11-20 | G3new | 976h |  | A5/4-GEA4 | PCG-23 | Ericsson | Rel-9 | SP-44 | Ingbert |  |  |
| 180 | 66.6 | Deleted - SA2 part of A5/4-GEA4 | 81d? | 2009-06-04 A | 2009-09-24 A | 100% |  | 2009-06-04 | 2009-09-24 | 81d? |  | finish no earlier than 2009-09-24 | S2 | 648h | 648h | A5/4-GEA4 | PCG-23 | Ericsson | Rel-9 | SP-44 | Maurice | PCG-23 | SP-45 |
| 181 | 67 | Lawful Interception in the 3GPP Rel-9 | 136d? | 2009-06-04 A | 2009-12-10 | 20% | 108.8d? | 2009-06-04 | 2009-12-10 | 136d? | 722d | finish no earlier than 2009-12-10 | S3 | 1088h | 217.6h | LI9 | PCG-23 | BMWi, Nortel | Rel-9 | SP-44 | Dionisio |  |  |
| 182 | 68 | Timed Graphics | 262d? | 2008-12-11 A | 2009-12-10 | 35% | 170.3d? | 2008-12-11 | 2009-12-10 | 262d? | 722d |  | S4 | 2096h | 733.6h | TG | PCG-22 | Ericsson | Rel-9 | SP-42 | Paolo |  |  |
| 183 | 69 | Managing MTSI Media Adaptation | 196d? | 2009-03-12 A | 2009-12-10 | 70% | 58.8d? | 2009-03-12 | 2009-12-10 | 196d? | 722d | finish no earlier than 2009-12-10 | S4 | 1568h | 1097.6h | M3A | PCG-22 | Samsung | Rel-9 | SP-43 | Paolo |  |  |
| 184 | 70 | **PSS and MBMS Aspects** | 197d? | 2009-03-12 A | 2009-12-10 | 40% | 118.2d? | 2009-03-12 | 2009-12-10 | 197d? | 722d |  | S4 | 4712h | 1884.8h | PMA | PCG-23 | Ericsson, Nokia | Rel-9 | SP-44 | Paolo |  |  |
| 185 | 70.1 | PSS and MBMS extensions | 196d? | 2009-03-12 A | 2009-12-10 | 40% | 117.6d? | 2009-03-12 | 2009-12-10 | 196d? | 722d | finish no earlier than 2009-12-10 | S4 | 1568h | 627.2h | PMA-MBS_Ext | PCG-22 | Ericsson | Rel-9 | SP-43 | Paolo |  |  |
| 186 | 70.2 | Improved Video Support for PSS and MBMS | 196d? | 2009-03-12 A | 2009-12-10 | 40% | 117.6d? | 2009-03-12 | 2009-12-10 | 196d? | 722d | finish no earlier than 2009-12-10 | S4 | 1568h | 627.2h | PMA-IVS | PCG-22 | Nokia | Rel-9 | SP-43 | Paolo |  |  |
| 187 | 71 | IMS based PSS and MBMS User Service extensions | 197d? | 2009-03-12 A | 2009-12-10 | 45% | 108.35d? | 2009-03-12 | 2009-12-10 | 197d? | 722d | finish no earlier than 2009-12-10 | S4 | 1576h | 709.2h | IMS_PSS_MBMS_US_EXT | PCG-22 | Ericsson | Rel-9 | SP-43 | Paolo |  |  |
| 188 | 72 | Syndicated Feed Reception within 3GPP environments | 136d? | 2009-06-04 A | 2009-12-10 | 50% | 68d? | 2009-06-04 | 2009-12-10 | 136d? | 722d | start no earlier than 2009-06-04 | S4 | 1088h | 544h | SFR | PCG-23 | Ericsson | Rel-9 | SP-44 | Paolo |  |  |
| 189 | 73 | Distortion Measurement Test Methods and Requirements | 56d? | 2009-09-24 | 2009-12-10 |  |  | 2009-09-24 | 2009-12-10 | 56d? | 722d | finish no earlier than 2009-12-10 | S4 | 448h |  | DTMR | PCG-23 | Motorola | Rel-9 | SP-45 | Paolo |  |  |
| 190 | 74 | **OAM&P 9** | 471d? | 2008-02-22 A | 2009-12-10 | 39% | 287.66d? | 2008-02-22 | 2009-12-10 | 471d? | 722d |  | S5 | 27200h | 11645.4h | OAM9 | PCG-22 |  | Rel-9 | SP-42 | Dionisio |  |  |
| 191 | 74.1 | **Network Infrastructure Management** | 262d? | 2008-12-11 A | 2009-12-10 | 42% | 153.17d? | 2008-12-11 | 2009-12-10 | 262d? | 722d |  | S5 | 7448h | 3093.87h | OAM9-NIM | PCG-22 |  | Rel-9 | SP-42 | Dionisio |  |  |
| 192 | 74.1.1 | Software Management for Network Elements | 261d? | 2008-12-11 A | 2009-12-10 | 70% | 78.3d? | 2008-12-11 | 2009-12-10 | 261d? | 722d | finish no earlier than 2009-12-10 | S5 | 2088h | 1461.6h | OAM9-NE_SWM | PCG-22 | Huawei, Nokia Siemens Networks | Rel-9 | SP-42 | Dionisio |  |  |
| 193 | 74.1.2 | Service Oriented Architecture (SOA) for IRP | 136d? | 2009-06-04 A | 2009-12-10 | 20% | 108.8d? | 2009-06-04 | 2009-12-10 | 136d? | 722d | finish no earlier than 2009-12-10 | S5 | 1088h | 217.6h | OAM9 | PCG-23 | Ericsson, Nokia Siemens Networks | Rel-9 | SP-44 | Dionisio |  |  |
| 194 | 74.1.3 | IRP SOAP Solution Sets continuation from Rel-8 | 136d? | 2009-06-04 A | 2009-12-10 | 20% | 108.8d? | 2009-06-04 | 2009-12-10 | 136d? | 722d | start no earlier than 2009-06-04 | S5 | 1088h | 217.6h | OAM9 | PCG-23 | Ericsson | Rel-9 | SP-44 | Dionisio |  |  |
| 195 | 74.1.4 | Automatic Radio Network Configuration Data Preparation | 136d? | 2009-06-04 A | 2009-12-10 | 30% | 95.2d? | 2009-06-04 | 2009-12-10 | 136d? | 722d | finish no earlier than 2009-12-10 | S5 | 1088h | 326.4h | OAM9 | PCG-23 | Nokia Siemens Networks | Rel-9 | SP-44 | Dionisio |  |  |

Notes:
- 171: SP#45 Stage 2 exception to 12/09. Continuation of Rel-8 UID_390044 SAE security architecture. Covers gaps in backhaul security in SAE (also applicable to UTRAN and GERAN backhaul) / Text5: Peter Howard
- 172: SP#45 Stage 2 exception to 12/09 [Identity Management and 3GPP Security Interworking (Interworking of GAA and OpenID)] / Text3: 33.102, 33.210, 33.310, 33.401, 33.402 / Text5: Peter Howard
- 173: - / Text3: 29.060, 29.274, 29.281 (Applicability of NDS/IP and NDS/AF to GTP, GTPv2-C and GTPv1-U) / Text5: Peter Howard
- 174: Allow 128 as an alternative to 64 bit keys (Stage 2/3 + Test spec) / Text5: Karl Norrman
- 175: SP#45 TS 55.226v100 for Information+Approval / Text3: 33.102,43.020, new 55.226 (A5/4 encryption algorithms for GSM and ECSD, and GEA4 encryption algorithm for GPRS) / Text5: Karl Norrman
- 176: CP#45 completed / Text3: 24.008,44.064 / Text5: Karl Norrman
- 177: - / Text3: 29.002,29.060 / Text5: Karl Norrman
- 178: GP#43 WID approved / Text3: 44.018,48.008,48.018,48.058 / Text5: Karl Norrman
- 179: GP#43 WID approved / Text3: 51.010 / Text5: Karl Norrman
- 180: SP#45 work stopped/abandoned / Text3: 23.060 / Text5: Karl Norrman
- 181: SP#45 Stage 2 exception to 12/09. WID approved (Stage 1,2,3) but needs updating for SP#46 / Text3: 33.106 (LI requirements), 33.107 (LI architecture and functions), 33.108 (Handover interface for LI) / Text5: Berthold Wilhelm, Ronald Ryan
- 182: Provide graphics in parallel to a video stream (without requiring an umbrella scene descriptor such as 3GPP DIMS in TS 26.142) / Text3: 26.xyz (Timed Graphics), 26.114, 26.140, 26.234, 26.244, 26.245, 26.346 / Text5: clinton.priddle@ericsson.com
- 183: Work to extend Rel-8 UID_34041 MTSI Video - Dynamic Rate Adaptation/Signalling of Image Size. Update speech/video adaptation algorithms used by network to control MTSI client terminal in congestion or poor transmission conditions. / Text3: 26.114 / Text5: kyunghun.jung@samsung.com
- 184: Umbrella WI: Evolved radio access technologies (HSPA, LTE) provide higher data rates allowing provision of services with higher quality. PSS and MBMS User Services are important for evolved mobile networks / Text5: Clinton.Priddle@ericsson.com, imed.bouazizi@nokia.com
- 185: SP#44 WID updated SP-090022=>SP-090262 (Feature=>BB). Work to extend Rel-8 UID_34043 PSS_MBMS_OMTV (Extending PSS and MBMS User Services for optimized Mobile TV) & ensure compatibility with UID_34046 (IMS_PSS_MBMS_US) / Text3: 26.234, 26.346 / Text5: Clinton.Priddle@ericsson.com
- 186: SP#44 WID updated SP-090023=>SP-090263 (Feature=>BB. Add support for more advanced H.264 profiles and levels to match PSS and MBMS capabilities and larger screen sizes (e.g. H.264 Scalable Baseline Profile) / Text3: 26.9xx (Study on improved video for PSS and MBMS), 26.234, 26.244, 26.346 / Text5: imed.bouazizi@nokia.com
- 187: Work to extend Rel-8 UID_34046 (IMS_PSS_MBMS_US), SA2 UID_410034 IMSSCC-SPI (IMS Service Continuity Enhancements: Service, Policy and Interactions) / Text3: 26.237 (IMS based PSS and MBMS User Service; Protocols) / Text5: Markus Kampmann
- 188: RSS optimized for mobile use. Reuse/reference OMA's enabler DCD client server transactions and metadata. Syndicated feeds, using Atom & Really Simple Syndication (RSS), are widely used on Internet for various scheduled pull applications such as podcasts. / Text3: TS 26.yyy (Syndicated Feed Reception within 3GPP environments; Protocols and codecs) / Text5: Thorsten.Lohmar@ericsson.com
- 189: - / Text3: 26.131, 26.132 / Text5: Stephen Kendall (wcsk01@motorola.com)
- 190: SP#42 umbrella Feature created to host OAM WIs
- 191: SP#42 umbrella BB created to host OAM WIs
- 192: - / Text3: 32.531, 32.532, 32.533, 32.537 / Text5: Bidipta Das (bidipta@huawei.com), Clemens Suerbaum (clemens.suerbaum@nsn.com)
- 193: Triggered by UID_400029 Study on Service Oriented Architecture (SOA) for IRP (TR 32.824) / Text3: 32.101, 32.102, 32.150 / Text5: Edwin Tse (Ericsson), Joerg Schmidt (NSN)
- 194: SP#45 for Information TS 32.127, 32.447. Continuation of Rel-8 UID_400030 IRP SOAP Solution Sets / Text3: 32.127, 32.327, 32.337, 32.357, 32.387, 32.397, 32.447, 32.121, 32.122, 32.123, 32.321, 32.322, 32.323, 32.325, 32.331, 32.332, 32.333, 32.335, 32.351, 32.352, 32.353, 32.381, 32.382, 32.383, 32.385, 32.391, 32.392, 32.393, 32.395, 32.441, 32.442, 32.443, / Text5: John Power
- 195: - / Text3: 32.501, 32.502, 32.503 / Text5: clemens.suerbaum@nsn.com

| ID | WBS | Task | Duration | Start | Finish | Complete | Remaining | Baseline start | Baseline finish | Baseline duration | Total slack | Constraint | Resources | Work | Actual work | Text1 | Text2 | Text6 | Text7 | Text8 | Text3 | Text4 |
| --- | --- | --- | --- | --- | --- | --- | --- | --- | --- | --- | --- | --- | --- | --- | --- | --- | --- | --- | --- | --- | --- | --- |
| 196 | 74.2 | **Performance Management** | 197d? | 2009-03-12 A | 2009-12-10 | 29% | 140.69d? | 2009-03-12 | 2009-12-10 | 197d? | 722d |  | S5 | 5800h | 1652.06h | OAM9-PM | PCG-22 | Rel-9 | SP-42 | Dionisio |  |  |
| 197 | 74.2.1 | Enhancement of E-UTRAN Performance Measurements | 196d? | 2009-03-12 A | 2009-12-09 | 30% | 137.2d? | 2009-03-12 | 2009-12-09 | 196d? | 723d | start no earlier than 2009-03-12 | S5 | 1568h | 470.4h | OAM9 | PCG-22 | Rel-9 | SP-43 | Dionisio | 32.425 | Motorola, Huawei |
| 198 | 74.2.2 | Enhancement of EPC Performance Measurements | 197d? | 2009-03-12 A | 2009-12-10 | 40% | 118.2d? | 2009-03-12 | 2009-12-10 | 197d? | 722d | start no earlier than 2009-03-12 | S5 | 1568h | 622.4h | OAM9 | PCG-22 | Rel-9 | SP-43 | Dionisio | 32.426 | China Mobile |
| 199 | 74.2.3 | Enhancement of UTRAN Performance Measurements | 136d? | 2009-06-04 A | 2009-12-10 | 10% | 122.4d? | 2009-06-04 | 2009-12-10 | 136d? | 722d | start no earlier than 2009-06-04 | S5 | 1088h | 108.8h | OAM9 | PCG-23 | Rel-9 | SP-44 | Dionisio | 32.405 | China Mobile |
| 200 | 74.3 | Trace | 196d? | 2009-03-13 | 2009-12-10 |  |  | 2009-03-13 | 2009-12-10 | 196d? | 722d | finish no earlier than 2009-12-10 | S5 | 1568h |  | OAM9-Trace | PCG-22 | Rel-9 | SP-42 | Dionisio |  |  |
| 201 | 74.4 | **Self-Organizing Networks (SON) - OAM aspects** | 471d? | 2008-02-22 A | 2009-12-10 | 70% | 141.3d? | 2008-02-22 | 2009-12-10 | 471d? | 722d |  | S5 | 7528h | 5269.6h | OAM9-SON | PCG-22 | Rel-9 | SP-43 | Dionisio |  |  |
| 202 | 74.4.1 | SON Self-Optimization & Self-Healing handling | 470d? | 2008-02-22 A | 2009-12-10 | 70% | 141d? | 2008-02-22 | 2009-12-10 | 470d? | 722d | finish no earlier than 2009-12-10 | S5 | 3760h | 2632h | LTE_SON-OAM | PCG-21 | Rel-9 | SP-39 | Dionisio | 32.521, 32.522, 32.523, 32.541, 32.542, 32.543 | Huawei, ZTE |
| 203 | 74.5 | Subscription Management (SuM) evolution | 136d? | 2009-06-04 A | 2009-12-10 | 15% | 115.6d? | 2009-06-04 | 2009-12-10 | 136d? | 722d | finish no earlier than 2009-12-10 | S5 | 1088h | 163.2h | OAM9-SuM | PCG-23 | Rel-9 | SP-44 | Dionisio | 32.140, 32.141, 32.152, 32.172, 32.175 | Ericsson |
| 204 | 75 | **Charging Management small Enhancements** | 136d? | 2009-06-04 A | 2009-12-10 | 5% | 129.2d? | 2009-06-04 | 2009-12-10 | 136d? | 722d |  | S5 | 2176h | 108.8h | CH9 | PCG-23 | Rel-9 | SP-44 | Dionisio |  |  |
| 205 | 75.1 | IWLAN mobility charging | 136d? | 2009-06-04 A | 2009-12-10 | 5% | 129.2d? | 2009-06-04 | 2009-12-10 | 136d? | 722d | finish no earlier than 2009-12-10 | S5 | 1088h | 54.4h | eIWLAN_Mob | PCG-23 | Rel-9 | SP-44 | Dionisio | 32.240, 32.252, 32.298, 32.299 | Orange |
| 206 | 76 | Definition of 3GPP UICC services over the new high-speed interface | 520d? | 2007-12-10 A | 2009-12-04 | 15% | 441.25d? | 2007-12-10 | 2009-12-04 | 520d? | 726d | finish no earlier than 2009-12-04 | C6 | 4160h | 630h | UICCHS | PCG-21 | Rel-9 | CP-38 | Xavier | 31.xyz | Gemalto |
| 207 | 77 | **Enhancements of IMS Customized Alerting Tone (CAT) Service** | 262d? | 2008-12-05 A | 2009-12-04 | 85% | 39.3d? | 2008-12-05 | 2009-12-04 | 262d? | 726d |  | C1 | 3766.4h | 1774.8h | eCAT | PCG-22 | Rel-9 | CP-42 | Frederic |  | China Mobile |
| 208 | 77.1 | Stage 3 Enhancements of IMS CAT Supplementary Service | 261d? | 2008-12-05 A | 2009-12-04 | 85% | 39.15d? | 2008-12-05 | 2009-12-04 | 261d? | 726d | finish no earlier than 2009-12-04 | C1 | 2088h | 1774.8h | eCAT-SS | PCG-22 | Rel-9 | CP-42 | Frederic | 24.182 | China Mobile |
| 209 | 78 | **CS-IBCF and CS-TrGW definition in 3GPP specifications** | 397d? | 2008-05-30 A | 2009-12-04 | 64% | 140.98d? | 2008-05-30 | 2009-12-04 | 397d? | 726d |  | C3,C4 | 9512h | 6131.38h | CS-IBCF | PCG-21 | Rel-9 | CP-40 | Gwiho |  | Telecom Italia |
| 210 | 78.1 | CT3 aspects of CS-IBCF | 397d? | 2008-05-30 A | 2009-12-04 | 69% | 123.2d? | 2008-05-30 | 2009-12-04 | 397d? | 726d | finish no earlier than 2009-12-04 | C3 | 3168h | 2182.4h | CS-IBCF | PCG-21 | Rel-9 | CP-40 | Gwiho | 29.235 | Telecom Italia |
| 211 | 78.2 | CT4 aspects of CS-IBCF | 396d? | 2008-05-30 A | 2009-12-04 | 60% | 158.4d? | 2008-05-30 | 2009-12-04 | 396d? | 726d | finish no earlier than 2009-12-04 | C4 | 3168h | 1900.8h | CS-IBCF | PCG-21 | Rel-9 | CP-40 | Kimmo | 29.238, 23.231, 29.232 | Telecom Italia |
| 212 | 79 | **IMS – Interconnection Border Control Function (IBCF) – Transition Gateway (TrGW); Ix Interface; Stage 3** | 322d? | 2008-09-12 A | 2009-12-04 | 70% | 97.92d? | 2008-09-12 | 2009-12-04 | 322d? | 726d |  | C4,C3 | 6858.4h | 3433.92h | IMS_IBCF | PCG-21 | Rel-9 | CP-41 | Kimmo |  | Alcatel-Lucent |
| 213 | 79.1 | CT4 part of IMS_IBCF | 321d? | 2008-09-12 A | 2009-12-04 | 60% | 128.4d? | 2008-09-12 | 2009-12-04 | 321d? | 726d | finish no earlier than 2009-12-04 | C4 | 2568h | 1540.8h | IMS_IBCF | PCG-21 | Rel-9 | CP-41 | Kimmo | 29.238 | Alcatel-Lucent |
| 214 | 79.2 | CT3 part of IMS_IBCF | 295.8d? | 2008-09-12 A | 2009-12-04 | 80% | 59.16d? | 2008-09-12 | 2009-12-04 | 295.8d? | 726d | finish no earlier than 2009-12-04 | C3 | 2366.4h | 1893.12h | IMS_IBCF | PCG-21 | Rel-9 | CP-41 | Gwiho | 29.162, 29.235 | Alcatel-Lucent |
| 215 | 80 | IMS Application Level Gateway Control Function (ALGCF) – IMS Access Media Gateway (IMA-MGW); Iq Interface; Stage 2 and Stage 3 | 321d? | 2008-09-12 A | 2009-12-04 | 65% | 112.35d? | 2008-09-12 | 2009-12-04 | 321d? | 726d | finish no earlier than 2009-12-04 | C4 | 2568h | 1669.2h | IMS_AGCF | PCG-21 | Rel-9 | CP-41 | Kimmo | 23.334, 29.334 | Alcatel-Lucent |
| 216 | 81 | **Completion of IMS Restoration Procedures** | 137d? | 2009-05-29 A | 2009-12-04 | 20% | 109.6d? | 2009-05-29 | 2009-12-04 | 137d? | 726d |  | C4,C1 | 3288h | 657.6h | eIMS_RP | PCG-23 | Rel-9 | CP-44 | Kimmo |  | Ericsson |
| 217 | 81.1 | CT4 aspects of eIMS_RP | 137d? | 2009-05-29 A | 2009-12-04 | 40% | 82.2d? | 2009-05-29 | 2009-12-04 | 137d? | 726d | finish no earlier than 2009-12-04 | C4 | 1096h | 438.4h | eIMS_RP | PCG-23 | Rel-9 | CP-44 | Kimmo | 23.380, 23.820 | Ericsson |
| 218 | 81.2 | CT1 aspects of eIMS_RP | 137d? | 2009-05-29 | 2009-12-04 |  |  | 2009-05-29 | 2009-12-04 | 137d? | 726d | finish no earlier than 2009-12-04 | C1 | 1096h |  | eIMS_RP | PCG-23 | Rel-9 | CP-44 | Kimmo | 24.229 | Ericsson |
| 219 | 82 | Operational description of the Inter-IMS Network to Network Interface (II-NNI) | 137d? | 2009-05-29 A | 2009-12-04 | 30% | 95.9d? | 2009-05-29 | 2009-12-04 | 137d? | 726d | finish no earlier than 2009-12-04 | C3 | 1096h | 328.8h | II-NNI | PCG-23 | Rel-9 | CP-44 | Gwiho | 29.165 | Orange |
| 220 | 83 | IMS Stage 3 - IETF Protocol Alignment | 137d? | 2009-05-29 A | 2009-12-04 | 30% | 95.9d? | 2009-05-29 | 2009-12-04 | 137d? | 726d | finish no earlier than 2009-12-04 | C1 | 1096h | 328.8h | IMSProtoc3 | PCG-23 | Rel-9 | CP-44 | Frederic | 23.218, 24.229, 24.940 | Alcatel-Lucent |
| 221 | 84 | Definition of Ml interface for Control Plane LCS (Stage 3) | 56d? | 2009-09-18 | 2009-12-04 |  |  | 2009-09-18 | 2009-12-04 | 56d? | 726d | start no earlier than 2009-09-18 | C1 | 448h |  | EMC2 | PCG-23 | Rel-9 | CP-45 | Frederic | 24.229 | Alcatel-Lucent |
| 222 | 85 | PCC enhancements | 56d? | 2009-09-18 A | 2009-12-04 | 30% | 39.2d? | 2009-09-18 | 2009-12-04 | 56d? | 726d | finish no earlier than 2009-12-04 | C3 | 448h | 134.4h | PCC-Enh | PCG-23 | Rel-9 | CP-45 | Gwiho | 29.212, 29.213, 29.215 | Huawei |

Notes:
- 196: SP#42 umbrella BB created to host OAM WIs
- 197: - / Text5: Yizhi Yao (yzyao@motorola.com),Lan Zou (zlan@huawei.com)
- 198: - / Text5: Li Jian (lijian@chinamobile.com), Liang Shuangchun (liangshuangchun@cmdi.chinamobile.com)
- 199: - / Text5: Liang Shuangchun, Li Jian, Bao Haitao
- 200: SP#42 umbrella BB created to host OAM WIs
- 201: SP#43 umbrella BB created to host OAM WIs
- 202: SP#45 for Information TS 32.541 / Text5: Yizhi Yao (yzyao@motorola.com),Lan Zou (zlan@huawei.com)
- 203: Expand the scope of SuM to better include the service layer / Text5: frode.nergard@ericsson.com
- 204: -
- 205: Radio Access Technology differentiation for charging. Completes Rel-8 Feature IWLAN_Mob UID_370049 Mobility between 3GPP-WLAN Interworking and 3GPP Systems / Text5: Jean-Luc Garcia
- 206: CP#42 moved to Rel-9 / Text5: jacques.seif@gemalto.com
- 207: CP#42 umbrella Feature created to host CT1 CAT WI (Stage 1 in 22.182) / Text5: Jiang Yi
- 208: Enhance IMS CAT Supplementary Service as defined in 22.182 and TR 23.872 / Text5: Jiang Yi
- 209: CP#43 moved to Rel-9. WID updated CP-080577=>CP-090073. Rel-8 UID_380061 (Ipinterc) covers Stage 1 in SA1 22.101, 22.228 / Text5: mauro.ficaccio@telecomitalia.it
- 210: CP#43 moved to Rel-9. WID updated CP-080577=>CP-090073 / Text5: mauro.ficaccio@telecomitalia.it
- 211: CP#43 moved to Rel-9. WID updated CP-080577=>CP-090073 / Text5: mauro.ficaccio@telecomitalia.it
- 212: CP#43 moved to Rel-9. WID updated CP-080746=>CP-090019 / Text5: Bruno.Landais@alcatel-lucent.fr
- 213: CP#43 moved to Rel-9. WID updated CP-080746=>CP-090019 / Text5: Bruno.Landais@alcatel-lucent.fr
- 214: CP#43 moved to Rel-9. WID updated CP-080746=>CP-090019 / Text5: Bruno.Landais@alcatel-lucent.fr
- 215: CP#43 moved to Rel-9. WID updated CP-080723=>CP-090020 / Text5: bruno.landais@alcatel-lucent.fr
- 216: Continuation (Stage 2/3) of Rel-8 Feature IMS Restoration Procedures UID_400012 / Text5: Emiliano Merino (emiliano.merino@ericsson.com)
- 217: - / Text5: Emiliano Merino (emiliano.merino@ericsson.com)
- 218: - / Text5: Emiliano Merino (emiliano.merino@ericsson.com)
- 219: - / Text5: sebastien.daudet@orange-ftgroup.com
- 220: - / Text5: Keith Drage (drage@alcatel-lucent.com)
- 221: Stage 3 for Rel-7 Emergency Calls (EMC1). Related to Rel-9 UID_400038 LCS Control Plane Solution for EPS (Supports stage 3 definition of SLs and SLg itf). Stage 2 in Rel-9 UID_400038 LCS CPS for EPS (23.271) , UID_410037 (IMS emergency sessions (23.167) / Text5: Keith Drage (drage@alcatel-lucent.com)
- 222: - / Text5: Wei Weihua (weiwh@huawei.com)

| ID | WBS | Task | Duration | Start | Finish | Complete | Remaining | Baseline start | Baseline finish | Baseline duration | Total slack | Constraint | Resources | Work | Actual work | Text1 | Text2 | Text6 | Text7 | Text8 | Text4 | Text5 | Text11 |
| --- | --- | --- | --- | --- | --- | --- | --- | --- | --- | --- | --- | --- | --- | --- | --- | --- | --- | --- | --- | --- | --- | --- | --- |
| 223 | 86 | **Rel-9 Improvements of the Radio Interface** | 597d? | 2007-11-30 A | 2010-03-12 | 61% | 234.55d? | 2007-11-30 | 2010-03-12 | 597d? | 656d |  | RP,GP | 21947.6h | 13189.7h | RInImp9 | PCG-21 | Rel-9 | RP-41 | Stefania |  |  |  |
| 224 | 86.1 | UMTS/LTE 3500 MHz | 515d? | 2007-11-30 A | 2009-12-04 | 45% | 283.25d? | 2007-11-30 | 2009-12-04 | 515d? | 726d |  | R4,R2,R3 | 4120h | 1854h | RInImp8-UMTSLTE3500 | PCG-21 | Rel Indep | RP-38 | Stefania | Ericsson | Jjohan.skold@ericsson.com | RP-090684 |
| 225 | 86.2 | LCR TDD UE OTA Performance Requirements | 186d? | 2008-09-12 A | 2009-05-29 A | 100% |  | 2008-09-12 | 2009-05-29 | 186d? |  | finish no earlier than 2009-05-29 | R4 | 1488h | 1488h | RInImp9-RFLCROTA | PCG-21 | Rel-9 | RP-41 | Stefania | RITT | Wu Xiang (wuxiang@chinattl.com) | RP-090389 |
| 226 | 86.3 | **RF requirements for Multicarrier and Multi-RAT BS** | 342d? | 2008-11-21 A | 2010-03-12 | 56% | 151.85d? | 2008-11-21 | 2010-03-12 | 342d? | 656d |  | R4,G1 | 7323.6h | 4071.82h | RInImp9-RFmulti | PCG-21 | Rel-9 | RP-41 | Stefania | Ericsson | Johan.skold@ericsson.com | RP-090685 |
| 227 | 86.3.1 | RAN4 part of RF requirements for Multicarrier and Multi RAT BS | 332d? | 2008-12-05 A | 2010-03-12 | 60% | 132.8d? | 2008-12-05 | 2010-03-12 | 332d? | 656d | finish no earlier than 2010-03-12 | R4 | 2656h | 1593.6h | RInImp9-RFmulti | PCG-22 | Rel-9 | RP-42 | Stefania | Ericsson | Johan.skold@ericsson.com | RP-090685 |
| 228 | 86.3.2 | GERAN part of RF requirements for Multicarrier and Multi RAT BS | 261d? | 2008-11-21 A | 2009-11-20 | 50% | 130.5d? | 2008-11-21 | 2009-11-20 | 261d? | 736d | finish no earlier than 2009-11-20 | G1 | 2088h | 1044h | RInImp9-RFmulti-GERAN | PCG-22 | Rel-9 | GP-40 | Paolo | Ericsson | mats.y.samuelsson@ericsson.com |  |
| 229 | 86.4 | Extended UMTS/LTE 800 MHz | 207d? | 2008-12-05 A | 2009-09-18 A | 100% |  | 2008-12-05 | 2009-09-18 | 207d? |  |  | R4,R2,R3 | 1648h | 1648h | RInImp9-UMTSLTE800 | PCG-22 | Rel Indep | RP-42 | Stefania | NTT DoCoMo | Shingo Suwa (suwas@nttdocomo.co.jp) | RP-090687 |
| 230 | 86.5 | UMTS/LTE 800 MHz for Europe | 197d? | 2009-03-06 A | 2009-12-04 | 40% | 118.2d? | 2009-03-06 | 2009-12-04 | 197d? | 726d |  | R4,R2,R3 | 1576h | 630.4h | RInImp9-UMTSLTE800EU | PCG-22 | Rel Indep | RP-43 | Stefania | Ericsson | olav.queseth@ericsson.com | RP-090688 |
| 231 | 86.6 | Performance requirement for LCR TDD with UE speeds up to 350 kph | 196d? | 2009-03-06 A | 2009-12-04 | 60% | 78.4d? | 2009-03-06 | 2009-12-04 | 196d? | 726d | finish no earlier than 2009-12-04 | R4 | 1568h | 940.8h | RInImp9-LCRTDD350 | PCG-22 | Rel-9 | RP-43 | Stefania | CATT | Yuexia Song (songyuexia@datangmobile.cn) | RP-090689 |
| 232 | 86.7 | Extended UMTS/LTE 1500 MHz | 136d? | 2009-05-30 A | 2009-12-04 | 60% | 54.4d? | 2009-05-30 | 2009-12-04 | 136d? | 726d |  | R4,R2,R3 | 1088h | 652.8h | UMTSLTE1500 | PCG-23 | Rel Indep | RP-44 | Stefania | NTT DoCoMo | Shingo Suwa (suwas@nttdocomo.co.jp) | RP-090690 |
| 233 | 87 | **Rel-9 Improvements of the Radio Interface - UE Conformance Testing** | 402d? | 2008-12-05 A | 2010-06-18 | 7% | 373.02d? | 2008-12-05 | 2010-06-18 | 402d? | 586d |  | R5 | 13024h | 938.77h | RInImp-UEConTest | PCG-23 | Rel-9 | RP-44 | Ingbert |  |  |  |
| 234 | 87.1 | Conformance Test Aspects – LTE 3500 | 402d? | 2008-12-05 A | 2010-06-18 | 1% | 399.39d? | 2008-12-05 | 2010-06-18 | 402d? | 586d | finish no earlier than 2010-06-18 | R5 | 3216h | 20.88h | LTE-UEConTest_LTE3500 | PCG-22 | Rel Indep | RP-42 | Ingbert | Ericsson | fredrik.sundstrom@ericsson.com | RP-090717 |
| 235 | 87.2 | Conformance Test Aspects – UMTS 3500 | 402d? | 2008-12-05 A | 2010-06-18 | 1% | 399.39d? | 2008-12-05 | 2010-06-18 | 402d? | 586d | finish no earlier than 2010-06-18 | R5 | 3216h | 20.88h | RInImp-UEConTest_UMTS3500 | PCG-22 | Rel Indep | RP-42 | Ingbert | Nokia | jukka.vikstedt@nokia.com | RP-090718 |
| 236 | 87.3 | Conformance Test Aspects – UMTS/LTE in 800 MHz for Europe | 215d? | 2009-05-19 A | 2010-03-12 | 1% | 212.85d? | 2009-05-19 | 2010-03-12 | 215d? | 656d | finish no earlier than 2010-03-12 | R5 | 1720h | 17.2h | UMTSLTE800EU_UEConTest | PCG-23 | Rel Indep | RP-44 | Ingbert | Ericsson | fredrik.sundstrom@ericsson.com | RP-090723 |
| 237 | 87.4 | Conformance Test Aspects – Extended UMTS/LTE 1500 MHz | 126d? | 2009-09-18 | 2010-03-12 |  |  | 2009-09-18 | 2010-03-12 | 126d? | 656d | finish no earlier than 2010-03-12 | R5 | 1008h |  | UMTSLTE1500_UEConTest | PCG-23 | Rel Indep | RP-45 | Ingbert | NTT DoCoMo | Nguyen Dung Dao (dao@nttdocomo.co.jp) |  |
| 238 | 87.5 | TDD UE Over The Air (Antenna) conformance testing methodology | 81d? | 2009-05-30 A | 2009-09-18 A | 100% |  | 2009-05-30 | 2009-09-18 | 81d? |  | finish no earlier than 2009-09-18 | R5 | 648h | 648h | UEAnt_TDDTest | PCG-23 | Rel-9 | RP-44 | Ingbert | CATR | Qu Yan (quyan@emcite.com) | RP-090727 |
| 239 | 88 | Conformance Test Aspects – SMS over IMS in E-UTRAN | 196d? | 2009-09-18 | 2010-06-18 |  |  | 2009-09-18 | 2010-06-18 | 196d? | 586d | finish no earlier than 2010-06-18 | R5 | 1568h |  | SMSoverIMS_UEConTest | PCG-23 | Rel-9 | RP-45 | Ingbert | Alcatel-Lucent | Nidal Khrais (khrais@alcatel-lucent.com) |  |
| 240 | 89 | **Rel-9 RAN improvements** | 197d? | 2009-03-06 A | 2009-12-04 | 66% | 66.68d? | 2009-03-06 | 2009-12-04 | 197d? | 726d |  | RP | 10512h | 6942.94h | RANimp | PCG-22 | Rel-9 | RP-43 | Stefania |  |  |  |
| 241 | 89.1 | Dual-Cell HSUPA | 197d? | 2009-03-06 A | 2009-12-04 | 70% | 59.1d? | 2009-03-06 | 2009-12-04 | 197d? | 726d |  | R1,R2,R3,R4 | 1568h | 1095.2h | RANimp-DC_HSUPA | PCG-22 | Rel-9 | RP-43 | Patrick | Nokia Siemens Networks | Karri Ranta-aho (karri.ranta-aho@nsn.com) | RP-090692 |
| 242 | 89.2 | Support for different bands for Dual-Cell HSDPA | 197d? | 2009-03-06 A | 2009-12-04 | 90% | 19.7d? | 2009-03-06 | 2009-12-04 | 197d? | 726d |  | R4,R2,R3 | 1568h | 1410.4h | RANimp-MultiBand_DC_HSDPA | PCG-22 | Rel-9 | RP-43 | Stefania | Nokia Siemens Networks | Tuomo Säynäjäkangas (tuomo.saynajakangas@nsn.com) | RP-090693 |
| 243 | 89.3 | Combination of DC-HSDPA with MIMO | 197d? | 2009-03-06 A | 2009-12-04 | 90% | 19.7d? | 2009-03-06 | 2009-12-04 | 197d? | 726d |  | R1,R2,R3,R4 | 1568h | 1410.4h | RANimp-DC_MIMO | PCG-22 | Rel-9 | RP-43 | Patrick | Ericsson | johan.bergman@ericsson.com | RP-090694 |
| 244 | 89.4 | UTRAN 2 ms TTI uplink range improvement | 197d? | 2009-03-06 A | 2009-12-04 | 10% | 177.3d? | 2009-03-06 | 2009-12-04 | 197d? | 726d | finish no earlier than 2009-12-04 | R1,R2,R3,R4 | 1576h | 157.6h | RANimp-2mTTI_ULimp | PCG-22 | Rel-9 | RP-43 |  | Nokia Siemens Networks | Karri Ranta-aho (karri.ranta-aho@nsn.com) | RP-090695 |
| 245 | 89.5 | TxAA extension for non-MIMO UEs | 197d? | 2009-03-06 A | 2009-12-04 | 75% | 49.25d? | 2009-03-06 | 2009-12-04 | 197d? | 726d |  | R1,R2,R3,R4 | 1568h | 1174h | RANimp-TxAA_nonMIMO | PCG-22 | Rel-9 | RP-43 | Patrick | Nokia | Arto Lehti (arto.lehti@nokia.com) | RP-090696 |
| 246 | 89.6 | Cell Portion for 1.28 Mcps TDD | 136d? | 2009-05-30 A | 2009-12-04 | 60% | 54.4d? | 2009-05-30 | 2009-12-04 | 136d? | 726d |  | R3,R1,R4 | 1088h | 652.8h | CP_LCRTDD | PCG-23 | Rel-9 | RP-44 | Juha | CATT | Ying Zhang (zhangying2@datangmobile.cn) | RP-090697 |

Notes:
- 223: RP#41 umbrella Feature created to host Rel-9 WIs
- 224: RP#44 completion target 05/09=>12/09. Testing in UID_420013 & UID_420014 / Text3: 25.101, 25.104, 25.113, 25.133, 25.141, 34.124, 36.101, 36.104, 36.141, 25.307, 25.331, 25.307, 36.331, 25.461, 25.463
- 225: RP#44 completed (Technical work completed, RAN4 internal TR abandoned. / Text3: Produced no TR 25.8xy (LCR TDD UE OTA performance requirements)
- 226: RF requirements specification applicable to Multi-Standard Radio (MSR) Base Station with multiple carriers and/or multiple 3GPP Radio Access Technologies (RAT)
- 227: RP#42 WID updated RP-080758=>RP-081098 / Text3: 25.104, 25.105, 36.104, 37.104, 37.141, 37.900
- 228: GP#40 WID approved / Text3: 45.005, 51.021
- 229: RP#45 completed. TR 36.800-200 for Approval / Text3: 36.800 (Extended UMTS/LTE 800 Work Item Technical Report), 25.101, 25.104, 25.113, 25.133, 34.124, 36.101, 36.104, 36.113, 36.124, 36.133, 36.141, 25.306, 25.307, 25.331, 36.331, 25.461, 25.466
- 230: - / Text3: 25.101, 25.104, 25.113, 25.133, 25.141, 34.124, 36.101, 36.104, 36.113, 36.124, 36.133, 36.141, new 36.810, 25.306, 25.307, 25.331, 36.331, 25.461, 25.466
- 231: - / Text3: 25.102, 25.105, 25.142
- 232: for potential deployment in Japan / Text3: 25.101, 25.104, 25.113, 25.133, 25.141, 34.124, 36.101, 36.104, 36.113, 36.124, 36.133, 36.141, new 36.821, 25.306, 25.307, 25.331, 36.331, 25.461, 25.466
- 233: -
- 234: RP#45 completion 12/09=>06/10 (RAN5 waiting for RAN4 to complete LTE3500 work item before RAN5 can get any progress). Testing for UID_380073 / Text3: 36.508, 36.521-1, 36.521-2, 36.521-3
- 235: RP#45 completion 12/09=>06/10. Testing for UID_380073 / Text3: 34.108, 34.121-1, 34.121-2
- 236: Testing for UID_430009 UMTS/LTE 800 MHz for Europe / Text3: 34.108, 34.121-1, 34.121-2, 34.123-1, 34.123-2, 34.123-3, 36.508, 36.521-1, 36.521-2, 36.521-3, 36.523-1, 36.523-2, 36.523-3
- 237: - / Text3: 34.108, 34.121-1, 34.121-2, 34.123-1, 34.123-2, 34.123-3, 36.508, 36.521-1, 36.521-2, 36.521-3, 36.523-1, 36.523-2, 36.523-3
- 238: RP#45 completed. Finalize TDD UE test methodology based on R4 TR 25.914 (UE and MS antenna performance evaluation method) and TS 25.144 Over the Air (Antenna) minimum performance requirements for the speech mode (terminal close to head) / Text3: 34.114
- 239: - / Text3: 34.229-1, 34.229-2, 34.229-3
- 240: -
- 241: RP#45 completed R1. / Text3: 25.101, 25.104, 25.133, 25.211, 25.212, 25.213, 25.214, 25.215, 25.319, 25.306, 25.321, 25.331, 25.423, 25.433
- 242: RP#45 updated WID RP-090015=>RP-090973 (added new R2 TS 25.317). RAN3 completed / Text3: 25.101, 25.104, 25.133, 25.306, 25.308, 25.331, new 25.317 (Requirements on Ues supporting a release-independent frequency band combination), 25.423, 25.433
- 243: RP#45 completed RAN1 / Text3: 25.101, 25.104, 25.133, 25.211, 25.212, 25.213, 25.214, 25.215, 25.308, 25.321, 25.331, 26.306, 25.423, 25.433
- 244: RP#45 completion 12/09=>03/10. Cell sets the TTI (Transmission Time Interval) to 2 ms / Text3: 25.133, 25.212, 25.214, 25.321, 25.331
- 245: Transmit Antenna Array (TxAA). RP#45 completed RAN1/2/3 / Text3: 25.101, 25.104, 25.211, 25.212, 25.213, 25.214, 25.215, 25.308, 25.306, 25.321, 25.331, 25.423, 25.433
- 246: - / Text3: 25.102, 25.105, 25.123, 25.225, 25.423, 25.433

| ID | WBS | Task | Duration | Start | Finish | Complete | Remaining | Baseline start | Baseline finish | Baseline duration | Total slack | Constraint | Resources | Work | Actual work | Text1 | Text2 | Text6 | Text7 | Text8 | Text4 | Text5 | Text11 | Text9 | Text12 |
| --- | --- | --- | --- | --- | --- | --- | --- | --- | --- | --- | --- | --- | --- | --- | --- | --- | --- | --- | --- | --- | --- | --- | --- | --- | --- |
| 247 | 90 | **LTE improvements** | 262d? | 2009-03-06 A | 2010-03-05 | 42% | 151.42d? | 2009-03-06 | 2010-03-05 | 262d? | 661d |  | RP | 5760h | 2431.02h | LTEimp | PCG-22 | Rel-9 | RP-42 | Stefania |  |  |  |  |  |
| 248 | 90.1 | LTE Pico NodeB RF Requirements | 261d? | 2009-03-06 A | 2010-03-05 | 25% | 195.75d? | 2009-03-06 | 2010-03-05 | 261d? | 661d | finish no earlier than 2010-03-05 | R4 | 2088h | 522h | LTEimp-Pico_eNB-RF | PCG-22 | Rel-9 | RP-43 | Stefania | Huawei | Liyan Yin (yinliyan@huawei.com) | RP-090702 |  |  |
| 249 | 90.2 | Enhanced Dual-Layer transmission for LTE | 197d? | 2009-03-06 A | 2009-12-04 | 65% | 68.95d? | 2009-03-06 | 2009-12-04 | 197d? | 726d |  | R1,R2,R4 | 1576h | 1024.4h | LTEimp-eDL | PCG-22 | Rel-9 | RP-43 | Patrick | China Mobile | Xu Xiaodong (xuxiaodong@chinamobile.com) | RP-090703 |  |  |
| 250 | 91 | **System aspects of vocoder rate adaptation for LTE** | 136d? | 2009-05-30 A | 2009-12-04 | 55% | 61.06d? | 2009-05-30 | 2009-12-04 | 136d? | 726d |  | S2,S4,R2 | 3440h | 1328h | LTEimp-Vocoder | PCG-23 | Rel-9 | SP-45 | Maurice | Qualcomm Europe | AC Mahendran (ac@qualcomm.com) |  |  |  |
| 251 | 91.1 | SA2 system aspects of vocoder rate adaptation for LTE | 81d? | 2009-06-04 A | 2009-09-24 A | 100% |  | 2009-06-04 | 2009-09-24 | 81d? |  | start no earlier than 2009-06-04 | S2 | 648h | 648h | LTEimp-Vocoder | PCG-23 | Rel-9 | SP-45 | Maurice | Qualcomm Europe | AC Mahendran (ac@qualcomm.com) |  |  |  |
| 252 | 91.2 | SA4 system aspects of vocoder rate adaptation for LTE | 132d? | 2009-06-04 | 2009-12-04 |  |  | 2009-06-04 | 2009-12-04 | 132d? | 726d | start no earlier than 2009-06-04 | S4 | 1056h |  | LTEimp-Vocoder | PCG-23 | Rel-9 | SP-45 | Paolo | Qualcomm Europe | Nikolai Leung |  |  |  |
| 253 | 91.3 | Vocoder rate adaptation for LTE | 81d? | 2009-05-30 A | 2009-09-18 A | 100% |  | 2009-05-30 | 2009-09-18 | 81d? |  | finish no earlier than 2009-09-18 | R2 | 648h | 648h | LTEimp-Vocoder | PCG-23 | Rel-9 | RP-44 | Joern | Alcatel-Lucent | Sudeep Palat (spalat@alcatel-lucent.com) | RP-090704 |  |  |
| 254 | 92 | Self-Organizing Networks (SON) | 197d? | 2009-03-06 A | 2009-12-04 | 60% | 78.8d? | 2009-03-06 | 2009-12-04 | 197d? | 726d | start no earlier than 2009-03-06 | R3,R2 | 1576h | 945.6h | SON | PCG-22 | Rel-9 | SP-42 | Juha | Nokia Siemens Networks | Krzysztof Kordybach | RP-090709 |  |  |
| 255 | 93 | **Voice services over Adaptive Multi-user channels on One Slot** | 262d? | 2008-11-21 A | 2009-11-20 | 57% | 113.42d? | 2008-11-21 | 2009-11-20 | 262d? | 736d |  | GP | 8360.68h | 4738.1h | VAMOS | PCG-22 | Rel-9 | SP-42 | Paolo | Nokia Siemens Networks, China Mobile | juergen.hofmann@nsn.com, liuxiaoyu@chinamobile.com |  |  |  |
| 256 | 93.1 | VAMOS Stage 2 | 262d? | 2008-11-21 A | 2009-11-20 | 90% | 26.2d? | 2008-11-21 | 2009-11-20 | 262d? | 736d | finish no earlier than 2009-11-20 | GP | 2088.68h | 1879.08h | VAMOS | PCG-22 | Rel-9 | GP-40 | Paolo | Nokia Siemens Networks, China Mobile | juergen.hofmann@nsn.com, liuxiaoyu@chinamobile.com |  |  |  |
| 257 | 93.2 | VAMOS Stage 3 | 261d? | 2008-11-21 A | 2009-11-20 | 50% | 130.5d? | 2008-11-21 | 2009-11-20 | 261d? | 736d | finish no earlier than 2009-11-20 | GP | 2088h | 1044h | VAMOS | PCG-22 | Rel-9 | GP-40 | Paolo | Nokia Siemens Networks, China Mobile | juergen.hofmann@nsn.com, liuxiaoyu@chinamobile.com |  |  |  |
| 258 | 93.3 | VAMOS Radio Performance Requirements | 261d? | 2008-11-24 A | 2009-11-20 | 30% | 182.7d? | 2008-11-24 | 2009-11-20 | 261d? | 736d | finish no earlier than 2009-11-20 | GP | 2088h | 626.4h | VAMOS | PCG-22 | Rel-9 | GP-40 | Paolo | Nokia Siemens Networks, China Mobile | juergen.hofmann@nsn.com, liuxiaoyu@chinamobile.com |  |  |  |
| 259 | 94 | **Local Call Local Switch** | 207d? | 2009-02-20 A | 2009-12-04 | 20% | 166.18d? | 2009-02-20 | 2009-12-04 | 207d? | 726d |  | GP,C4,C3,C1 | 7600h | 1392.42h | LCLS | PCG-22 | Rel-9 | GP-41 | Paolo | Huawei | Xing Zhu |  |  |  |
| 260 | 94.1 | Local Call Local Switch | 196d? | 2009-02-20 A | 2009-11-20 | 40% | 117.6d? | 2009-02-20 | 2009-11-20 | 196d? | 736d | finish no earlier than 2009-11-20 | GP | 1568h | 627.2h | LCLS | PCG-22 | Rel-9 | GP-41 | Paolo | Huawei | Xing Zhu |  |  |  |
| 261 | 94.2 | **CN aspects of Local Call Local Switch** | 137d? | 2009-05-29 A | 2009-12-04 | 10% | 123.27d? | 2009-05-29 | 2009-12-04 | 137d? | 726d |  | C4,C3,C1 | 4376h | 438.67h | LCLS-CN | PCG-23 | Rel-9 | CP-44 | Kimmo | Vodafone | David Hutton |  |  |  |
| 262 | 94.2.1 | CT4 aspects of LCLS | 137d? | 2009-05-29 A | 2009-12-04 | 30% | 95.9d? | 2009-05-29 | 2009-12-04 | 137d? | 726d | finish no earlier than 2009-12-04 | C4 | 1096h | 328.8h | LCLS-CN | PCG-23 | Rel-9 | CP-44 | Kimmo | Vodafone | David Hutton |  |  |  |
| 263 | 94.2.2 | CT3 aspects of LCLS | 136d? | 2009-05-29 | 2009-12-03 |  |  | 2009-05-29 | 2009-12-03 | 136d? | 727d | start no earlier than 2009-05-29 | C3 | 1088h |  | LCLS-CN | PCG-23 | Rel-9 | CP-44 | Gwiho | Vodafone | David Hutton |  |  |  |
| 264 | 94.2.3 | CT1 aspects of LCLS | 137d? | 2009-05-29 | 2009-12-04 |  |  | 2009-05-29 | 2009-12-04 | 137d? | 726d | finish no earlier than 2009-12-04 | C1 | 1096h |  | LCLS-CN | PCG-23 | Rel-9 | CP-44 | Frederic | Vodafone | David Hutton |  |  |  |
| 265 | 95 | **Cell Broadcast protocol Base Station Controller – Cell Broadcast Centre (BSC-CBC)** | 147d? | 2009-05-15 A | 2009-12-04 | 29% | 104.45d? | 2009-05-15 | 2009-12-04 | 147d? | 726d |  | GP,C1 | 3448h | 997.98h | CEBRO | PCG-23 | Rel-9 | GP-42 | Paolo | Ericsson | Claes-Göran Persson |  |  |  |
| 266 | 95.1 | Cell Broadcast protocol Base Station Controller – Cell Broadcast Centre (BSC-CBC) | 137d? | 2009-05-15 A | 2009-11-20 | 60% | 54.8d? | 2009-05-15 | 2009-11-20 | 137d? | 736d | finish no earlier than 2009-11-20 | GP | 1096h | 657.6h | CEBRO | PCG-23 | Rel-9 | GP-42 | Paolo | Ericsson | Claes-Göran Persson |  |  |  |
| 267 | 95.2 | Cell Broadcast protocol Base Station Controller – Cell Broadcast Centre (BSC-CBC) | 147d? | 2009-05-15 | 2009-12-04 |  |  | 2009-05-15 | 2009-12-04 | 147d? | 726d | finish no earlier than 2009-12-04 | C1 | 1176h |  | CEBRO | PCG-23 | Rel-9 | GP-42 | Frederic | Ericsson | Claes-Göran Persson |  |  |  |
| 268 | 96 | Hybrid Location | 136d? | 2009-05-18 | 2009-11-20 |  |  | 2009-05-18 | 2009-11-20 | 136d? | 736d | finish no earlier than 2009-11-20 | GP | 1088h |  | HILT | PCG-23 | Rel-9 | GP-42 | Paolo | TruePosition | Matt Ward (mward@trueposition.com) |  |  |  |
| 269 | 97 | (Small) Technical Enhancements and Improvements for Rel-9 | 391d? | 2008-09-15 | 2010-03-12 |  |  | 2008-09-15 | 2010-03-12 | 391d? | 656d | finish no earlier than 2010-03-12 | All | 3128h |  | TEI9 | PCG-22 | Rel-9 | SP-42 |  | ALL |  |  |  |  |
| 270 | 98 | **Deleted - SAES Enhancements (non RAN aspects)** | 381d? | 2007-06-25 A | 2008-12-08 A | 100% |  | 2007-06-25 | 2008-12-08 | 381d? |  |  | S2 | 11664h | 11664h | SAES_Ph2 | PCG-21 | Rel-9 | SP-39 | Maurice | Nokia Siemens Networks |  |  | PCG-21 | SP-39 |
| 271 | 98.1 | Deleted - Functions and procedures for SAE to support LTE MBMS | 381d? | 2007-06-25 A | 2008-12-08 A | 100% |  | 2007-06-25 | 2008-12-08 | 381d? |  | finish no earlier than 2008-12-08 | S2 | 3048h | 3048h | SAES_Ph2 |  | Rel-9 | SP-35 | Maurice |  |  |  | PCG-21 | SP-39 |
| 272 | 98.2 | Deleted - CS over EPS | 194d? | 2008-03-12 A | 2008-12-08 A | 100% |  | 2008-03-12 | 2008-12-08 | 194d? |  | finish no earlier than 2008-12-08 | S2 | 1552h | 1552h | SAES_Ph2 | PCG-21 | Rel-9 | SP-39 | Maurice |  |  |  | PCG-21 | SP-39 |

Notes:
- 247: -
- 248: - / Text3: 36.8xy (RF requirements for LTE Pico NodeB), 36.104, 36.141
- 249: RP#44 WID updated RP-090359=>RP-090648. Evolve Rel-8 single layer Dedicated Reference Symbols (DRS) based beamforming technology to multi-layer beamforming increasing cell throughput especially at cell edge in LCR TDD network / Text3: 36.101, 36.104, 36.106, 36.133, 36.211, 36.212, 36.213, 36.321, 36.331
- 250: Triggered by RAN2 UID_440013 Vocoder rate adaptation for LTE
- 251: SP#45 completed (CR adding support for Explicit Congestion Notification) / Text3: 23.401 CR#1103r3
- 252: - / Text3: 26.114 draft CR#0082r2 to specify the UE behaviour using ECN (Explicit Congestion Notification)
- 253: RP#45 completed (Stage 2 CR RP-090929) / Text3: 36.300 CR#0114
- 254: - / Text3: 36.300, 36.423, 36.902
- 255: GP#43 completion 09/09=>11/09 (was 05/09). GP#40 WID approved. Triggered by UID_50590 (MUROS) Study on Multi-User Reusing-One-Slot
- 256: GP#43 completion 09/09=>11/09 (was 05/09). GP#40 WID approved / Text3: 45.001 (Overview of VAMOS solution)
- 257: GP#43 completion 09/09=>11/09 (was 05/09). GP#40 WID approved / Text3: 24.008, 44.018, 45.002, 45.003, 45.004, 45.008, 48.008, 48.058
- 258: GP#40 WID approved / Text3: 45.005 (Test Scenarios for VAMOS Performance requirements)
- 259: CP#44 WID approved. GP#41 WID approved
- 260: GP#41 WID approved / Text3: 48.008 (MSC-BSS interface; Layer 3 specification)
- 261: CP#45 WID updated CP-090318=>CP-090519. Stage 2/3
- 262: CP#45 WID updated CP-090318=>CP-090519. Stage 2/3 / Text3: 23.205, 23.153, 23.231, 29.232, new 23.889
- 263: CP#45 WID updated CP-090318=>CP-090519. Stage 2/3 / Text3: 29.007
- 264: CP#45 WID updated CP-090318=>CP-090519. Stage 2/3 / Text3: 23.009
- 265: GP#42 WID approved
- 266: GP#42 WID approved / Text3: new 48.049
- 267: GP#42 WID approved / Text3: 23.041
- 268: GP#43 completion 09/09=>11/09. GP#42 WID approved (Hybrid Integrated Location Technology=HILT) / Text3: 43.059, 48.071
- 269: -
- 270: SP#39 created to host Rel-9 Wis. BUT no agreed WID
- 271: SP#39 SAE functionality moved to Rel-9. WID returned to SA2 for re-consideration & remove MBMS for EPS from Rel 8
- 272: SP#39 SAE functionality moved to Rel-9. BUT no agreed WID

| ID | WBS | Task | Type | Duration | Start | Finish | Predecessors | Complete | Remaining | Baseline start | Baseline finish | Baseline duration | Total slack | Constraint | Resources | Work | Actual work | Text1 | Text2 | Text6 | Text7 | Text8 | Text9 | Text12 | Text4 | Text5 | Text11 |
| --- | --- | --- | --- | --- | --- | --- | --- | --- | --- | --- | --- | --- | --- | --- | --- | --- | --- | --- | --- | --- | --- | --- | --- | --- | --- | --- | --- |
| 273 | 98.3 | **Deleted - SAE for generic support for non-3GPP accesses** |  | 251d? | 2007-06-25 A | 2008-06-09 A |  | 100% |  | 2007-06-25 | 2008-06-09 | 251d? |  |  | S2 | 4016h | 4016h | SAES_Ph2 | PCG-21 | Rel-9 | SP-39 | Maurice | PCG-21 | SP-39 |  |  |  |
| 274 | 98.3.1 | Deleted - Single Radio Aspects of SAE for Optimized Handover with WiMAX |  | 251d? | 2007-06-25 A | 2008-06-09 A |  | 100% |  | 2007-06-25 | 2008-06-09 | 251d? |  | finish no earlier than 2008-06-09 | S2 | 2008h | 2008h | SAES_Ph2 | PCG-21 | Rel-9 | SP-39 | Maurice | PCG-21 | SP-39 |  |  |  |
| 275 | 99 | Deleted - Harmonization of Gq'/Rx for Common IMS |  | 304d? | 2008-01-14 A | 2009-03-12 A |  | 100% |  | 2008-01-14 | 2009-03-12 | 304d? |  | finish no earlier than 2009-03-12 | S2 | 2432h | 2432h | IMS_Comm_GqRx_Harm | PCG-21 | Rel-9 | SP-38 | Maurice | PCG-22 | SP-43 | Alcatel-Lucent | geoffrey.cristallo@alcatel-lucent.be |  |
| 276 | 100 | Deleted - Support of WiMAX - LTE Mobility |  | 407d? | 2008-06-06 A | 2009-12-25 A |  | 100% |  | 2008-06-06 | 2009-12-25 | 407d? |  | start no earlier than 2008-06-06 | R2 | 3248h | 3248h | WiMAX_LTE_Mobility | PCG-21 | Rel-9 | RP-38 | Joern | PCG-21 | SP-39 | Samsung |  |  |
| 277 | 101 | Deleted - Support of WiMAX - UMTS Mobility |  | 407d? | 2008-06-06 A | 2009-12-25 A |  | 100% |  | 2008-06-06 | 2009-12-25 | 407d? |  | start no earlier than 2008-06-06 | R2 | 3248h | 3248h | WiMAX_UMTS_Mobility | PCG-21 | Rel-9 | RP-38 | Joern | PCG-21 | SP-39 | Intel |  |  |
| 278 | 102 | Release 9 Studies | milestone | 0d? | 2000-01-01 | 2000-01-01 |  |  |  | 2000-01-01 | 2000-01-01 | 0d? | 3318d |  | CP,GP,RP,SP |  |  |  |  | Rel-9 |  |  |  |  |  |  |  |
| 279 | 103 | **Study on enhanced voice service requirements for the EPS** |  | 595d? | 2007-09-03 A | 2009-12-10 |  | 68% | 190.43d? | 2007-09-03 | 2009-12-10 | 595d? | 722d |  | S1,S4 | 12184h | 8284.59h | FS_EV_EPS |  | Rel-9 | SP-37 | Alain |  |  | Orange | tim.haysom@orange-ftgroup.com |  |
| 280 | 103.1 | Use cases definition and service and system requirements |  | 334d? | 2007-09-03 A | 2008-12-11 A |  | 100% |  | 2007-09-03 | 2008-12-11 | 334d? |  | finish no earlier than 2008-12-11 | S1 | 2672h | 2672h | FS_EV_EPS-S1 |  | Rel-9 | SP-37 | Alain |  |  | Orange | tim.haysom@orange-ftgroup.com |  |
| 281 | 103.2 | Codec specific part of FS_EV_EPS |  | 594d? | 2007-09-03 A | 2009-12-10 |  | 50% | 297d? | 2007-09-03 | 2009-12-10 | 594d? | 722d | finish no earlier than 2009-12-10 | S4 | 4752h | 2376h | FS_EV_EPS-S4 |  | Rel-9 | SP-37 | Paolo |  |  | Orange | tim.haysom@orange-ftgroup.com |  |
| 282 | 104 | Study on Service Specific Access Control in EPS |  | 136d? | 2008-06-05 A | 2008-12-11 A |  | 100% |  | 2008-06-05 | 2008-12-11 | 136d? |  | start no earlier than 2008-06-05 | S1 | 1088h | 1088h | FS_SSAC | PCG-21 | Rel-9 | SP-40 | Alain |  |  | NTT DoCoMo | Frederic Thepot (thepot@docomolab-euro.com) |  |
| 283 | 105 | Study on CS Domain Services over EPS access |  | 492d? | 2007-04-25 A | 2009-03-12 A |  | 100% |  | 2007-04-25 | 2009-03-12 | 492d? |  | finish no earlier than 2009-03-12 | S2 | 3936h | 3936h | FS_CSoPS |  | Rel-9 | SP-35 | Maurice |  |  | T-Mobile | Karl-Heinz.Nenner@T-Mobile.net |  |
| 284 | 106 | Study on Extended Support of IMS Emergency Calls |  | 319d? | 2007-09-24 A | 2008-12-11 A |  | 100% |  | 2007-09-24 | 2008-12-11 | 319d? |  | finish no earlier than 2009-06-18 | S2 | 2552h | 2552h | FS_IMS-eCall |  | Rel-9 | SP-37 | Maurice |  |  | Qualcomm Europe | Stephen Edge |  |
| 285 | 107 | Study on Service Continuity for Emergency Voice Calls |  | 721d? | 2006-06-08 A | 2009-03-12 A |  | 100% |  | 2006-06-08 | 2009-03-12 | 721d? |  | finish no earlier than 2009-03-12 | S2 | 5768h | 5768h | FS_VCCEm |  | Rel-9 | SP-32 | Maurice |  |  | Nortel | Ricky Kaura (rkaura@nortel.com) |  |
| 286 | 108 | Study on Security Aspects of Remote Provisioning and Change of Subscription for M2M Equipment |  | 582d? | 2004-04-06 A | 2009-12-10 |  | 70% | 174.6d? | 2004-04-06 | 2009-12-10 | 582d? | 722d | finish no earlier than 2009-12-10 | S3,C6 | 4656h | 3259.2h | FS_UM2M |  | Rel-9 | SP-37 | Dionisio |  |  | Ericsson | vesa.lehtovirta@ericsson.com |  |
| 287 | 109 | Study on UTRAN key management enhancements |  | 517d? | 2007-12-20 A | 2009-12-10 |  | 30% | 361.9d? | 2007-12-20 | 2009-12-10 | 517d? | 722d | finish no earlier than 2009-12-10 | S3 | 4136h | 1240.8h | FS_UKM | PCG-21 | Rel-9 | SP-38 | Dionisio |  |  | Ericsson | Karl Norrman |  |
| 288 | 110 | Study on Surround Sound codec extension for PSS and MBMS |  | 196d? | 2009-03-12 A | 2009-12-10 |  | 40% | 117.6d? | 2009-03-12 | 2009-12-10 | 196d? | 722d | finish no earlier than 2009-12-10 | S4 | 1568h | 627.2h | FS_SS_PSS_MBMS | PCG-22 | Rel-9 | SP-43 | Paolo |  |  | Fraunhofer Gesellschaft | jan.plogsties@iis.franhofer.de |  |
| 289 | 111 | Study on System Maintenance over Itf-N |  | 602d? | 2007-06-07 A | 2009-09-24 A |  | 100% |  | 2007-06-07 | 2009-09-24 | 602d? |  | finish no earlier than 2009-09-24 | S5 | 4808h | 4808h | FS_OAM-Maint-Itf-N |  | Rel-9 | SP-36 | Dionisio |  |  | ZTE | HUANG, Shuqiang |  |
| 290 | 112 | Study on Self-Organizing Networks (SON) related OAM interfaces for Home NodeB |  | 522d? | 2007-06-07 A | 2009-06-04 A |  | 100% |  | 2007-06-07 | 2009-06-04 | 522d? |  | finish no earlier than 2009-12-10 | S5 | 4168h | 4168h | FS_OAM-SON-HNB |  | Rel-9 | SP-36 | Dionisio |  |  | Huawei | Zou Lan (zlan@huawei.com) |  |
| 291 | 113 | Study on Self-healing of Self-Organizing Networks (SON) |  | 416d? | 2008-02-22 A | 2009-09-24 A |  | 100% |  | 2008-02-22 | 2009-09-24 | 416d? |  | finish no earlier than 2009-09-24 | S5 | 3320.15h | 3320.15h | FS_OAM-SON-SH | PCG-21 | Rel-9 | SP-39 | Dionisio |  |  | ZTE | zhu.weihong@zte.com.cn |  |
| 292 | 114 | Study on Service Oriented Architecture (SOA) for IRP |  | 262d? | 2008-06-05 A | 2009-06-04 A |  | 100% |  | 2008-06-05 | 2009-06-04 | 262d? |  | finish no earlier than 2009-05-20 | S5 | 2088h | 2088h | FS_OAM_SOA_IRP | PCG-21 | Rel-9 | SP-40 | Dionisio |  |  | Ericsson | edwin.tse@ericsson.com |  |
| 293 | 115 | Study on Rc Reference Point Functionalities and Message Flows |  | 322d? | 2008-09-18 A | 2009-12-10 |  | 85% | 48.3d? | 2008-09-18 | 2009-12-10 | 322d? | 722d | finish no earlier than 2009-12-10 | S5 | 2568h | 2181.6h | FS_OAM_Rc | PCG-21 | Rel-9 | SP-41 | Dionisio |  |  | Huawei | shan.mingjun@huawei.com |  |
| 294 | 116 | Study on Telecommunication Management; Energy Savings Management (ESM) |  | 196d? | 2009-03-12 A | 2009-12-10 |  | 25% | 147d? | 2009-03-12 | 2009-12-10 | 196d? | 722d | finish no earlier than 2009-12-10 | S5 | 1568h | 392h | FS_OAM_ESM | PCG-22 | Rel-9 | SP-43 | Dionisio |  |  | Orange, Vodafone | Jean-Michel Cornilly (Orange) |  |
| 295 | 117 | Study on Integration of Device Management Information with Itf-N |  | 136d? | 2009-06-04 A | 2009-12-10 | 526 | 20% | 108.8d? | 2009-06-04 | 2009-12-10 | 136d? | 722d | finish no earlier than 2009-12-10 | S5 | 1088h | 217.6h | FS_IDMI_Itf-N | PCG-23 | Rel-9 | SP-44 | Dionisio |  |  | Motorola | Yizhi Yao (yzyao@motorola.com) |  |
| 296 | 118 | Study on EPC Charging enhancement |  | 136d? | 2009-06-04 A | 2009-12-10 |  | 5% | 129.2d? | 2009-06-04 | 2009-12-10 | 136d? | 722d | start no earlier than 2009-06-04 | S5 | 1088h | 54.4h | FS_EPCcharg | PCG-23 | Rel-9 | SP-44 | Dionisio |  |  | Nokia Siemens Networks | Gerald.Goermer@nsn.com |  |
| 297 | 119 | Study on Interworking Proxy between GTP based and PMIP based interfaces |  | 56d? | 2009-09-18 A | 2009-12-04 |  | 40% | 33.6d? | 2009-09-18 | 2009-12-04 | 56d? | 726d | finish no earlier than 2009-12-04 | C4 | 448h | 179.2h | FS_GTP-MIP-IW | PCG-23 | Rel-9 | CP-45 | Kimmo |  |  | NTT DoCoMo | takaaki.matsuura.sp@s1.nttdocomo.com |  |
| 298 | 120 | Study on Policy and Charging Rules Function (PCRF) failure and restoration |  | 126d? | 2009-08-18 A | 2010-03-12 |  | 5% | 119.7d? | 2009-08-18 | 2010-03-12 | 126d? | 656d | finish no earlier than 2010-03-12 | C3 | 1008h | 50.4h | FS_PCRF-FR | PCG-23 | Rel-9 | CP-45 | Gwiho |  |  | NEC | gottfried.punz@nw.neclab.eu |  |
| 299 | 121 | Study on Evaluation of the inclusion of Path Loss Based Technology in the UTRAN |  | 516d? | 2007-12-17 A | 2009-12-04 |  | 80% | 103.2d? | 2007-12-17 | 2009-12-04 | 516d? | 726d | finish no earlier than 2009-09-18 | R4 | 4120h | 3296h | FS_RAN-Pathloss | PCG-21 | Rel-9 | RP-38 | Stefania |  |  | Polaris Wireless | Norman Shaw (nshaw@polariswireless.com) | RP-090993 |
| 300 | 122 | Study on LTE-Advanced |  | 526d? | 2007-03-23 A | 2010-06-18 |  | 70% | 157.8d? | 2007-03-23 | 2010-06-18 | 526d? | 586d |  | R1,R2,R3,R4 | 4208h | 2945.6h | FS_RAN_LTEA | PCG-21 | Rel-9 | RP-39 | Patrick |  |  | NTT DoCoMo | Takehiro Nakamura (nakamurata@nttdocomo.co.jp) | RP-090729 |
| 301 | 123 | Study on 1.28 Mcps TDD Home NodeB |  | 387d? | 2008-02-20 A | 2009-12-04 |  | 80% | 77.4d? | 2008-02-20 | 2009-12-04 | 387d? | 726d | finish no earlier than 2009-12-04 | R4 | 3096h | 2476.8h | FS_RAN-HNBLCRTDD | PCG-21 | Rel-9 | RP-41 | Stefania |  |  | TD Tech | Li Rong (lirong@td-tech.com) | RP-090730 |
| 302 | 124 | Study on E-UTRAN Mobility Evaluation and Enhancement |  | 126d? | 2008-12-05 A | 2009-05-29 A |  | 100% |  | 2008-12-05 | 2009-05-29 | 126d? |  | finish no earlier than 2009-05-29 | R1 | 1008h | 1008h | FS_EUTRAN_mob | PCG-22 | Rel-9 | RP-42 | Patrick |  |  | Qualcomm Europe | Rajat Prakash (rprakash@qualcomm.com) | RP-090426 |
| 303 | 125 | Study on Measurement of Radiated Performance for MIMO and multi-antenna reception for HSPA and LTE terminals |  | 126.8d? | 2009-03-06 A | 2009-12-04 |  | 20% | 101.44d? | 2009-03-06 | 2009-12-04 | 126.8d? | 726d | start no earlier than 2009-03-06 | R4 | 1014.4h | 202.88h | FS_HSPA_LTE_measRP_MIMO_multi-antenna | PCG-22 | Rel-9 | RP-43 | Stefania |  |  | Vodafone | SoonLeh Ling (soonleh.ling@vodafone.com) | RP-090731 |
| 304 | 126 | Study on Minimization of drive-tests in Next Generation Networks |  | 196d? | 2009-03-06 A | 2009-12-04 |  | 60% | 78.4d? | 2009-03-06 | 2009-12-04 | 196d? | 726d | finish no earlier than 2009-12-04 | R2 | 1568h | 940.8h | FS_NGN_min_drive-tests | PCG-22 | Rel-9 | RP-43 | Joern |  |  | Qualcomm Europe | Masato Kitazoe (mkitazoe@qualcomm.com) | RP-090732 |
| 305 | 127 | Study on Enhanced Interference Management for HNBs |  | 61d? | 2009-03-06 A | 2009-05-29 A |  | 100% |  | 2009-03-06 | 2009-05-29 | 61d? |  | start no earlier than 2009-03-06 | R4 | 488h | 488h | FS_eInterfMgmt_HNB | PCG-22 | Rel-9 | RP-43 | Stefania |  |  | Qualcomm Europe | Farhad Meshkati (fmeshkat@qualcomm.com) | RP-090429 |
| 306 | 128 | Study on Enhanced Interference Management Mechanisms for HNBs |  | 81d? | 2009-05-30 A | 2009-09-18 A |  | 100% |  | 2009-05-30 | 2009-09-18 | 81d? |  | finish no earlier than 2009-09-18 | R3 | 648h | 648h | FS_eInterfMgmtMchsm_HNB | PCG-23 | Rel-9 | RP-44 | Juha |  |  | Qualcomm Europe | Farhad Meshkati (fmeshkat@qualcomm.com) | RP-090733 |
| 307 | 129 | Study on Extending 850 MHz |  | 136d? | 2009-05-30 A | 2009-12-04 |  | 5% | 129.2d? | 2009-05-30 | 2009-12-04 | 136d? | 726d | finish no earlier than 2009-12-04 | R4 | 1088h | 54.4h | FS_e850 | PCG-23 | Rel-9 | RP-44 | Stefania |  |  | Ericsson | Christian Bergljung (christian.bergljung@stericsson.com) | RP-090734 |
| 308 | 130 | Deleted - Study on Protection against SMS and MMS spam |  | 862d? | 2006-06-08 A | 2009-09-24 A |  | 100% |  | 2006-06-08 | 2009-09-24 | 862d? |  | finish no earlier than 2009-09-24 | S3 | 6896h | 6896h | FS_CPSMal |  | Rel-9 | SP-32 | Dionisio | PCG-23 | SP-45 | Orange | eric.gauthier@orange.ch |  |
| 309 | 131 | Release 8 Features | milestone | 0d? | 2000-01-03 | 2000-01-03 |  |  |  | 2000-01-03 | 2000-01-03 | 0d? | 3317d | start no earlier than 2000-01-03 | CP,GP,RP,SP |  |  |  |  | Rel-8 |  |  |  |  |  |  |  |

Notes:
- 273: SP#39 SAE functionality moved to Rel-9. BUT no agreed WID
- 274: SP#39 SAE functionality moved to Rel-9. BUT no agreed WID
- 275: SP#43 stopped. LS_out to TISPAN informs about stopping this activity / Text3: 23.822, 23.203
- 276: RP#39: No agreed WID / Text3: 36.306, 36.331, 36.413, 36.300, 36.214, 36.133, 36.304
- 277: RP#39: No agreed WID / Text3: 25.306, 25.331, 25.413
- 278: -
- 279: SP#42 SA1 part completed
- 280: SP#42 completed / Text3: 22.813
- 281: SP#45 target completion 09/09=>12/09.
- 282: SP#42 completed. Spin-off Feature UID_420020 (SSAC) / Text3: 22.986
- 283: SP#43 completed / Text3: 23.879
- 284: SP#42 completed / Text3: 23.868
- 285: SP#43 completed / Text3: 23.826
- 286: SP#45 completion 09/09=>12/09. SP#43 TR 33.812 for Information. Triggered by SA1 Study UID_7027 (FS_M2M) TR 22.868 / Text3: 33.812
- 287: SP#44 SID updated SP-070782=>SP-090283 (removed UTRAN/E-UTRAN IRAT signalling cases from Study scope (while IRAT handling is left as specified by 33.401). Study also focuses on support for a key hierarchy locally in UTRAN and intra-UTRAN mobility cases.) / Text3: 33.8xy
- 288: SP#45 target completion 09/09=>12/09. Work to extend Rel-8 UID_34043 PSS_MBMS_OMTV (Extending PSS and MBMS User Services for optimized Mobile TV) / Text3: 26.9xx (Study on Surround Sound for PSS and MBMS)
- 289: SP#45 completed / Text3: 32.822
- 290: SP#44 completed / Text3: 32.821
- 291: SP#45 completed / Text3: 32.823
- 292: SP#44 completed. Spin-off implementation WI UID_440064 Service Oriented Architecture (SOA) for IRP / Text3: 32.824
- 293: SP#44 for SA Information / Text3: 32.825
- 294: Study result might impact Feature UID_420011 Self Organising Networks (SON) / Text3: 32.826
- 295: Study the missing Itf-N part in the Framework. Study changes to Itf-N to utilize UE based measurements / Text3: 32.827
- 296: Study grouping the investigation of various minor EPC charging enhancements / Text3: It has to be decided whether it will be a new TR or Rel-9 CRs on TR 32.820
- 297: CT3 shall be involved if impacts to PCC are identified / Text3: 29.875
- 298: - / Text3: 29.816
- 299: RP#45 TR 25.907v100 for Information - Focus on RF Pattern Matching as the most promising near-term Path Loss technology for inclusion in UTRAN). See also RP-090762 RF Pattern Matching Discussion / Text3: 25.907
- 300: RP#45 updated WID RP-090665=>RP-090735. Completion 12/09=>06/10 (Added 2 new TRs). TR 36.912 for Approval / Text3: 36.913 , new 36.814, 36.912, R2 36.806 (Relay architectures for E-UTRA), R4 36.8xy (LTE-Advanced feasibility studies in RAN4)
- 301: RP#45 completion 05/09=>09/09=>12/09 / Text3: 25.866
- 302: RP#44 completed (RP-090452 R1 LS to RAN on Conclusions for LTE Mobility Study Item - no further Rel-9 action/TR needed
- 303: - / Text3: New TR (25/36) on Measurements of radiated performance for MIMO and multi-antenna reception for HSPA and LTE terminals
- 304: RP#44 TR 36.805-100 for Information. RP#45 completion 09/09=>12/09. R4 involvement is FFS / Text3: 36.805
- 305: RP#44 completed. Spin-off RAN3 UID_440015 Study on Enhanced Interference Management Mechanisms for HNBs / Text3: 25.967
- 306: Triggered by RAN4 UID_430027 Study on Enhanced Interference Management for HNBs. RP#45 completed / Text3: 25.967
- 307: - / Text3: TR xx.yyy (Extending 850 study Item Technical report)
- 308: SP#45 work stopped/abandoned / Text3: 33.9xx
- 309: -

| ID | WBS | Task | Duration | Start | Finish | Complete | Remaining | Baseline start | Baseline finish | Baseline duration | Total slack | Constraint | Resources | Work | Actual work | Text1 | Text4 | Text5 | Text6 | Text8 | Text7 | Text2 |
| --- | --- | --- | --- | --- | --- | --- | --- | --- | --- | --- | --- | --- | --- | --- | --- | --- | --- | --- | --- | --- | --- | --- |
| 310 | 132 | **3GPP System Architecture Evolution Specification - Evolved Packet System (non RAN aspects)** | 1024d? | 2006-04-12 A | 2010-03-12 | 99% | 1.27d? | 2006-04-12 | 2010-03-12 | 1024d? | 656d |  | SP,CP | 259980h | 253019h | SAES | T-Mobile | michael.kurz@t-mobile.at | Rel-8 | Alain |  |  |
| 311 | 132.1 | Requirements for evolution of the 3GPP system architecture | 395d? | 2006-06-08 A | 2007-12-12 A | 100% |  | 2006-06-08 | 2007-12-12 | 395d? |  | finish no earlier than 2007-11-30 | S1 | 3160h | 3160h | AIPN-SAE | T-Mobile | michael.kurz@t-mobile.at | Rel-8 | Alain |  |  |
| 312 | 132.2 | **High level and common (for all accesses) functions** | 629d? | 2007-01-02 A | 2009-05-29 A | 100% |  | 2007-01-02 | 2009-05-29 | 629d? |  |  | SP,CP | 42536h | 42536h | EPS-ComF | Nokia Siemens Networks | balazs.bertenyi@nsn.com | Rel-8 | Maurice | SP-37 |  |
| 313 | 132.2.1 | Stage 2 for High level functions | 370d? | 2007-01-02 A | 2008-06-02 A | 100% |  | 2007-01-02 | 2008-06-02 | 370d? |  | finish no earlier than 2008-06-02 | S2 | 2960h | 2960h | SAES-SA-HLF | Motorola | Irfan.Ali@motorola.com | Rel-8 | Maurice |  |  |
| 314 | 132.2.2 | Stage 2 Security Architecture | 197d? | 2008-03-12 A | 2008-12-11 A | 100% |  | 2008-03-12 | 2008-12-11 | 197d? |  | finish no earlier than 2008-12-11 | S3 | 1576h | 1576h | SAES | Nokia Siemens Networks | marc.blommaert.ext@nsn.com | Rel-8 | Dionisio | SP-39 | PCG-21 |
| 315 | 132.2.3 | Stage 3 (CT1) for SAE impact on services, network functions and capabilities | 545d? | 2007-02-05 A | 2009-03-06 A | 100% |  | 2007-02-05 | 2009-03-06 | 545d? |  | finish no earlier than 2009-03-06 | C1 | 4360h | 4360h | SAES | Nokia Siemens Networks | robert.zaus@nsn.com | Rel-8 | Frederic |  |  |
| 316 | 132.2.4 | Stage 3 SAE impact on existing capabilities | 480d? | 2007-02-05 A | 2008-12-05 A | 100% |  | 2007-02-05 | 2008-12-05 | 480d? |  | finish no earlier than 2008-12-12 | C3 | 3840h | 3840h | SAES | Huawei | Wei Weihua (weiwh@huawei.com) | Rel-8 | Gwiho |  |  |
| 317 | 132.2.5 | Stage 3 (CT4) of SAE impact on existing capabilities | 545d? | 2007-02-05 A | 2009-03-06 A | 100% |  | 2007-02-05 | 2009-03-06 | 545d? |  | finish no earlier than 2009-03-06 | C4 | 4360h | 4360h | SAES | Huawei | shahab.lavasani@huawei.com | Rel-8 | Kimmo |  |  |
| 318 | 132.2.6 | Stage 2/3 for Network selection procedures | 480d? | 2007-02-05 A | 2008-12-05 A | 100% |  | 2007-02-05 | 2008-12-05 | 480d? |  | finish no earlier than 2009-03-06 | C1 | 3840h | 3840h | SAES | Nokia Siemens Networks | robert.zaus@nsn.com | Rel-8 | Frederic |  |  |
| 319 | 132.2.7 | Stage 3 EPC interworking with external PDNs (SGi) | 605d? | 2007-02-05 A | 2009-05-29 A | 100% |  | 2007-02-05 | 2009-05-29 | 605d? |  | finish no earlier than 2009-05-29 | C3 | 4840h | 4840h | SAES-St3-intwk | Huawei | Wei Weihua (weiwh@huawei.com) | Rel-8 | Gwiho |  |  |
| 320 | 132.2.8 | Stage 3 PCC within SAE | 605d? | 2007-02-05 A | 2009-05-29 A | 100% |  | 2007-02-05 | 2009-05-29 | 605d? |  | finish no earlier than 2009-05-29 | C3 | 4840h | 4840h | SAES-St3-PCC | Ericsson | j.javier.pastor@ericsson.com | Rel-8 | Gwiho |  |  |
| 321 | 132.2.9 | Stage 3 for SAE / LTE identities | 545d? | 2007-02-05 A | 2009-03-06 A | 100% |  | 2007-02-05 | 2009-03-06 | 545d? |  | finish no earlier than 2009-03-06 | C4 | 4360h | 4360h | SAES | Huawei | shahab.lavasani@huawei.com | Rel-8 | Kimmo |  |  |
| 322 | 132.2.10 | Unified guidelines for Diameter usage within 3GPP | 316d? | 2007-09-21 A | 2008-12-05 A | 100% |  | 2007-09-21 | 2008-12-05 | 316d? |  | finish no earlier than 2008-12-05 | C3 | 2528h | 2528h | SAES-DIAM | Huawei | Javier Gonzalez Gallego | Rel-8 | Gwiho | CP-37 |  |
| 323 | 132.3 | **SAE for LTE access** | 569d? | 2007-01-02 A | 2009-03-06 A | 100% |  | 2007-01-02 | 2009-03-06 | 569d? |  |  | S2,C1,C3,C4 | 57824h | 57824h | SAES-LTE | Motorola | Irfan.Ali@motorola.com | Rel-8 | Maurice |  |  |
| 324 | 132.3.1 | CT4 Stage 3 for protocol between EPCs | 545d? | 2007-02-05 A | 2009-03-06 A | 100% |  | 2007-02-05 | 2009-03-06 | 545d? |  | finish no earlier than 2009-03-06 | C4 | 4360h | 4360h | SAES | Huawei | shahab.lavasani@huawei.com | Rel-8 | Kimmo |  |  |
| 325 | 7.2.2.1 | **SAES-SA-FP_LTE with GTP variant** | 569d? | 2007-01-02 A | 2009-03-06 A | 100% |  | 2007-01-02 | 2009-03-06 | 569d? |  |  | S2,C4 | 11896h | 11896h | SAES-SA-FP_LTE-GTP | Nokia Siemens Networks | balazs.bertenyi@nsn.com | Rel-8 | Maurice |  |  |
| 326 | 132.3.2.1 | Stage 2 for SAES-SA-FP_LTE with GTP variant | 373d? | 2007-01-02 A | 2008-06-05 A | 100% |  | 2007-01-02 | 2008-06-05 | 373d? |  | finish no earlier than 2008-06-02 | S2 | 2984h | 2984h | SAES-SA-FP_LTE-GTP-St2 | Nokia Siemens Networks | balazs.bertenyi@nsn.com | Rel-8 | Maurice |  |  |
| 327 | 132.3.2.2 | CT4 Stage 3 for GTP v2 protocol | 545d? | 2007-02-05 A | 2009-03-06 A | 100% |  | 2007-02-05 | 2009-03-06 | 545d? |  | finish no earlier than 2009-03-06 | C4 | 4360h | 4360h | SAES | Huawei | shahab.lavasani@huawei.com | Rel-8 | Kimmo |  |  |
| 328 | 7.2.2.2 | **SAES-SA-FP_LTE with PMIP variant** | 569d? | 2007-01-02 A | 2009-03-06 A | 100% |  | 2007-01-02 | 2009-03-06 | 569d? |  |  | S2,C4 | 15736h | 15736h | SAES-SA-FP_LTE-IETF | Nokia Siemens Networks | balazs.bertenyi@nsn.com | Rel-8 | Maurice |  |  |
| 329 | 132.3.3.1 | Stage 2 for SAES-SA-FP_LTE with PMIP variant | 373d? | 2007-01-02 A | 2008-06-05 A | 100% |  | 2007-01-02 | 2008-06-05 | 373d? |  | finish no earlier than 2008-06-02 | S2 | 2984h | 2984h | SAES-SA-FP_LTE-IETF-St2 | Nokia Siemens Networks | balazs.bertenyi@nsn.com | Rel-8 | Maurice |  |  |
| 330 | 132.3.3.2 | CT4 Stage 3 for PMIP protocol within EPC | 545d? | 2007-02-05 A | 2009-03-06 A | 100% |  | 2007-02-05 | 2009-03-06 | 545d? |  | finish no earlier than 2009-03-06 | C4 | 4360h | 4360h | SAES | Huawei | shahab.lavasani@huawei.com | Rel-8 | Kimmo | CP-37 |  |
| 331 | 132.3.3.3 | Mobile IPv4 (MIPv4) based Mobility protocols | 480d? | 2007-02-05 A | 2008-12-05 A | 100% |  | 2007-02-05 | 2008-12-05 | 480d? |  | finish no earlier than 2008-12-05 | C4 | 3840h | 3840h | SAES | Motorola | Lewis Milton | Rel-8 | Kimmo | CP-41 |  |
| 332 | 132.3.4 | Stage 3 for UE NAS mobility procedures in idle and active mode | 545d? | 2007-02-05 A | 2009-03-06 A | 100% |  | 2007-02-05 | 2009-03-06 | 545d? |  | finish no earlier than 2009-03-06 | C1 | 4360h | 4360h | SAES | Nokia Siemens Networks | robert.zaus@nsn.com | Rel-8 | Frederic |  |  |
| 333 | 132.3.5 | Stage 3 for Session management, bearer control and QoS aspects | 545d? | 2007-02-05 A | 2009-03-06 A | 100% |  | 2007-02-05 | 2009-03-06 | 545d? |  | finish no earlier than 2009-03-06 | C1 | 4360h | 4360h | SAES | Nokia Siemens Networks | robert.zaus@nsn.com | Rel-8 | Frederic |  |  |
| 334 | 132.3.6 | Stage 3 for security aspects of LTE Access | 545d? | 2007-02-05 A | 2009-03-06 A | 100% |  | 2007-02-05 | 2009-03-06 | 545d? |  | finish no earlier than 2009-03-06 | C1 | 4360h | 4360h | SAES | Nokia Siemens Networks | robert.zaus@nsn.com | Rel-8 | Frederic |  |  |
| 335 | 132.3.7 | Stage 3 for QoS mechanisms | 480d? | 2007-02-05 A | 2008-12-05 A | 100% |  | 2007-02-05 | 2008-12-05 | 480d? |  | finish no earlier than 2008-12-12 | C3 | 3840h | 3840h | SAES | Ericsson | j.javier.pastor@ericsson.com | Rel-8 | Gwiho |  |  |
| 336 | 132.3.8 | Stage 3 for EPC - HSS interface | 545d? | 2007-02-05 A | 2009-03-06 A | 100% |  | 2007-02-05 | 2009-03-06 | 545d? |  | finish no earlier than 2009-03-06 | C4 | 4360h | 4360h | SAES | Huawei | shahab.lavasani@huawei.com | Rel-8 | Kimmo |  |  |

Notes:
- 310: SP#39 WID updated SP-070933=>SP-080132
- 311: SP#38 completed / Text3: 22.278, 22.011, 22.246
- 312: SP#39 WID updated SP-070933=>SP-080132
- 313: SP#40 completed / Text3: 23.402
- 314: SP#42 completed. SP#39 WID updated SP-070933=>SP-080132 / Text3: 33.401, 33.210, 33.310
- 315: CP#43 completed / Text3: 24.229, 24.305, 27.007
- 316: CP#42 completed. WID updated CP-080056=>CP-080772 / Text3: 29.061
- 317: CP#43 completed. WID updated CP-080724=>CP-090247. Network sharing, etc, MBMS removed / Text3: 29.274, 29.275
- 318: CP#42 completed. CP#41 WID updated CP-080075=>CP-080493. / Text3: 23.122, 24.302
- 319: CP#44 completed / Text3: 29.061
- 320: CP#44 completed / Text3: 29.212, 29.213, 29.214, 29.215
- 321: CP#43 completed. WID updated CP-080724=>CP-090247 / Text3: 23.003
- 322: CP#42 completed / Text3: 29.909
- 323: CP#43 completed. SP#39 WID updated SP-070933=>SP-080132
- 324: CP#43 completed. WID updated CP-080724=>CP-090247. PMIP and GTP based S8 interface (EPC-EPC) / Text3: 29.274, 29.275
- 325: CP#43 completed. SP#39 WID updated SP-070933=>SP-080132
- 326: SP#40 completed / Text3: 23.401, 23.060, 23.002, 23.246, 23.203, 23.107, 23.234, 23.271
- 327: CP#43 completed. WID updated CP-080724=>CP-090247 / Text3: 29.274
- 328: CP#43 completed. SP#39 WID updated SP-070933=>SP-080132
- 329: SP#40 completed. Multiple PDN related alignments, 23.060-derived changes.
- 330: CP#43 completed. WID updated CP-080724=>CP-090247. PMIP based S5 interface / Text3: 29.275, 29.282
- 331: CP#42 completed. CP#43 WID updated CP-080724=>CP-090247 / Text3: 29.279
- 332: CP#43 completed / Text3: 24.007, 24.301
- 333: CP#43 completed / Text3: 24.007, 24.301
- 334: CP#43 completed / Text3: 24.008, 24.301
- 335: CP#42 completed. CP#41 updated WID CP-080057=>CP-080576. / Text3: 29.213
- 336: CP#43 completed. WID updated CP-080724=>CP-090247. S6a, S6d, S13, S13' interface / Text3: 29.272

| ID | WBS | Task | Type | Duration | Start | Finish | Complete | Baseline start | Baseline finish | Baseline duration | Constraint | Resources | Work | Actual work | Text1 | Text4 | Text5 | Text6 | Text8 | Text3 | Text7 | Text2 | Text12 |
| --- | --- | --- | --- | --- | --- | --- | --- | --- | --- | --- | --- | --- | --- | --- | --- | --- | --- | --- | --- | --- | --- | --- | --- |
| 337 | 132.4 | **SAE for Interoperation between LTE and legacy cellular PS accesses** |  | 545d? | 2007-02-05 A | 2009-03-06 A | 100% | 2007-02-05 | 2009-03-06 | 545d? |  | S2,C1,C4 | 40152h | 40152h | SAES-SA-FP_3GPP | Motorola | Irfan.Ali@motorola.com | Rel-8 | Maurice |  |  |  |  |
| 338 | 132.4.1 | Stage 2 for Interoperation between LTE and 2G/3G |  | 424d? | 2007-02-05 A | 2008-09-18 A | 100% | 2007-02-05 | 2008-09-18 | 424d? | finish no earlier than 2008-09-11 | S2 | 3392h | 3392h | EPSto2_3G | Motorola | Irfan.Ali@motorola.com | Rel-8 | Maurice | 23.401, 23.402 | SP-37 |  |  |
| 339 | 132.4.2 | Stage 3 for Inter-system mobility between E-UTRAN and 2G/3G |  | 545d? | 2007-02-05 A | 2009-03-06 A | 100% | 2007-02-05 | 2009-03-06 | 545d? | finish no earlier than 2009-03-06 | C1 | 4360h | 4360h | SAES | Nokia Siemens Networks | robert.zaus@nsn.com | Rel-8 | Frederic | 24.008, 24.301 | CP-38 | PCG-21 |  |
| 340 | 132.4.3 | Stage 2 GPRS enhancements for LTE access |  | 272d? | 2007-09-04 A | 2008-09-18 A | 100% | 2007-09-04 | 2008-09-18 | 272d? | start no earlier than 2007-09-04 | S2 | 2176h | 2176h | SAES-GPRS_LTE | Vodafone | chris.pudney@vodafone.com | Rel-8 | Maurice | 23.401 |  |  |  |
| 341 | 132.4.4 | Stage 2 GPRS for EPC (23.060, etc.) |  | 179d? | 2008-01-14 A | 2008-09-18 A | 100% | 2008-01-14 | 2008-09-18 | 179d? | finish no earlier than 2008-09-18 | S2 | 1432h | 1432h | SAES | Nokia Siemens Networks | balazs.bertenyi@nsn.com | Rel-8 | Maurice | 23.060 | SP-39 | PCG-21 |  |
| 342 | 132.4.5 | Stage 3 for EPC - GPRS |  | 545d? | 2007-02-05 A | 2009-03-06 A | 100% | 2007-02-05 | 2009-03-06 | 545d? | finish no earlier than 2009-03-06 | C4 | 4360h | 4360h | SAES | Huawei | shahab.lavasani@huawei.com | Rel-8 | Kimmo | 29.274, 29.275, 29.281 |  |  |  |
| 343 | 132.4.6 | Stage 3 for EPC to UTRAN |  | 545d? | 2007-02-05 A | 2009-03-06 A | 100% | 2007-02-05 | 2009-03-06 | 545d? | finish no earlier than 2009-03-06 | C4 | 4360h | 4360h | SAES | Huawei | shahab.lavasani@huawei.com | Rel-8 | Kimmo | 29.274, 29.275, 29.281 | CP-38 | PCG-21 |  |
| 344 | 132.4.7 | Stage 3 for EPC to 3GPP2 |  | 545d? | 2007-02-05 A | 2009-03-06 A | 100% | 2007-02-05 | 2009-03-06 | 545d? | finish no earlier than 2009-03-06 | C4 | 4360h | 4360h | SAES | Huawei | shahab.lavasani@huawei.com | Rel-8 | Kimmo | 29.277, 29.276 | CP-38 | PCG-21 |  |
| 345 | 132.4.8 | Stage 2 for Interoperation between LTE and CDMA2000 |  | 329d? | 2007-06-18 A | 2008-09-18 A | 100% | 2007-06-18 | 2008-09-18 | 329d? | finish no earlier than 2008-04-25 | S2 | 2632h | 2632h | EPStoC2k | Motorola, Vodafone | Irfan.Ali@motorola.com, chris.pudney@vodafone.com | Rel-8 | Maurice | 23.401, 23.402 | CP-37 |  |  |
| 346 | 132.4.9 | Stage 3 for Inter-system mobility between E-UTRAN and CDMA2000 |  | 545d? | 2007-02-05 A | 2009-03-06 A | 100% | 2007-02-05 | 2009-03-06 | 545d? | finish no earlier than 2009-03-06 | C1 | 4360h | 4360h | SAES | Nokia Siemens Networks | robert.zaus@nsn.com | Rel-8 | Frederic | 24.301, 24.302 |  |  |  |
| 347 | 132.4.10 | Stage 3 for MME - SGSN "signalling free" protocol |  | 545d? | 2007-02-05 A | 2009-03-06 A | 100% | 2007-02-05 | 2009-03-06 | 545d? | finish no earlier than 2009-03-06 | C4 | 4360h | 4360h | SAES | Huawei | shahab.lavasani@huawei.com | Rel-8 | Kimmo | 29.272, 29.274 |  |  |  |
| 348 | 132.5 | **SAE for support for non-3GPP accesses** |  | 569d? | 2007-01-02 A | 2009-03-06 A | 100% | 2007-01-02 | 2009-03-06 | 569d? |  | S2,S3,C1,C4 | 53872h | 53872h | SAES-SA-FP_n3GPP | Motorola | Irfan.Ali@motorola.com | Rel-8 | Maurice |  |  |  |  |
| 349 | 7.2.4.1 | Stage 2 for Host-based Mobility aspects |  | 373d? | 2007-01-02 A | 2008-06-05 A | 100% | 2007-01-02 | 2008-06-05 | 373d? | finish no earlier than 2008-04-11 | S2 | 2984h | 2984h | SAES-SA-FP_n3GPP-HBMob | Motorola | Irfan.Ali@motorola.com | Rel-8 | Maurice | 23.402 |  |  |  |
| 350 | 7.2.4.2 | Stage 2 for Network-based Mobility aspects |  | 448d? | 2007-01-02 A | 2008-09-18 A | 100% | 2007-01-02 | 2008-09-18 | 448d? | finish no earlier than 2008-09-18 | S2 | 3584h | 3584h | SAES-SA-FP_n3GPP-NBMob | Motorola | Irfan.Ali@motorola.com | Rel-8 | Maurice | 23.402 |  |  |  |
| 351 | 132.5.3 | Stage 3 for Mobility management based on DSMIP v6 |  | 480d? | 2007-02-05 A | 2008-12-05 A | 100% | 2007-02-05 | 2008-12-05 | 480d? | finish no earlier than 2008-12-05 | C1 | 3840h | 3840h | SAES | Nokia Siemens Networks | robert.zaus@nsn.com | Rel-8 | Frederic | 24.303 |  |  |  |
| 352 | 132.5.4 | Stage 3 for Mobility management based on MIP v4 |  | 480d? | 2007-02-05 A | 2008-12-05 A | 100% | 2007-02-05 | 2008-12-05 | 480d? | start no earlier than 2007-02-05 | C1 | 3840h | 3840h | SAES | Nokia Siemens Networks | robert.zaus@nsn.com | Rel-8 | Frederic | 24.304 | CP-39 | PCG-21 |  |
| 353 | 132.5.5 | Stage 3 for Inter-system mobility between E-UTRAN and non 3GPP accesses |  | 545d? | 2007-02-05 A | 2009-03-06 A | 100% | 2007-02-05 | 2009-03-06 | 545d? | finish no earlier than 2009-03-06 | C1 | 4360h | 4360h | SAES | Nokia Siemens Networks | robert.zaus@nsn.com | Rel-8 | Frederic | 24.008, 24.301 | CP-38 | PCG-21 |  |
| 354 | 132.5.6 | Stage 2 for Optimized Dual-Radio Handover with WiMAX |  | 249d? | 2007-06-25 A | 2008-06-05 A | 100% | 2007-06-25 | 2008-06-05 | 249d? | finish no earlier than 2008-06-09 | S2 | 1992h | 1992h | SAES-SA-FP_n3GPP-OptWIMAX | Motorola | Irfan.Ali@motorola.com | Rel-8 | Maurice | 23.402 |  |  |  |
| 355 | 132.5.7 | Stage 2 Security aspects for non-3GPP Access |  | 197d? | 2008-03-12 A | 2008-12-11 A | 100% | 2008-03-12 | 2008-12-11 | 197d? | finish no earlier than 2008-12-11 | S3 | 1576h | 1576h | SAES | Nokia Siemens Networks | marc.blommaert.ext@nsn.com | Rel-8 | Dionisio | 33.402, 33.210, 33.310 | SP-39 | PCG-21 |  |
| 356 | 132.5.8 | Stage 3 security aspects for DSMIP v6 Access |  | 480d? | 2007-02-05 A | 2008-12-05 A | 100% | 2007-02-05 | 2008-12-05 | 480d? | finish no earlier than 2008-12-05 | C1 | 3840h | 3840h | SAES | Nokia Siemens Networks | robert.zaus@nsn.com | Rel-8 | Frederic | 24.303 | CP-37 |  |  |
| 357 | 132.5.9 | Stage 3 security aspects for MIPv4 Access |  | 480d? | 2007-02-05 A | 2008-12-05 A | 100% | 2007-02-05 | 2008-12-05 | 480d? | finish no earlier than 2008-12-05 | C1 | 3840h | 3840h | SAES | Nokia Siemens Networks | robert.zaus@nsn.com | Rel-8 | Frederic | 24.304 | CP-39 | PCG-21 |  |
| 358 | 132.5.10 | Stage 3 for Access to the EPC via non-3GPP access networks |  | 545d? | 2007-02-05 A | 2009-03-06 A | 100% | 2007-02-05 | 2009-03-06 | 545d? | finish no earlier than 2009-03-06 | C1 | 4360h | 4360h | SAES | Nokia Siemens Networks | robert.zaus@nsn.com | Rel-8 | Frederic | 24.302, 24.312 |  |  |  |
| 359 | 132.5.11 | Stage 3 for interfaces within EPC |  | 383d? | 2007-09-19 A | 2009-03-06 A | 100% | 2007-09-19 | 2009-03-06 | 383d? | finish no earlier than 2009-03-06 | C4 | 3064h | 3064h | SAES | Huawei | shahab.lavasani@huawei.com | Rel-8 | Kimmo | 29.274, 29.281 | CP-37 |  |  |
| 360 | 132.5.12 | Stage 3 for Interfaces EPC - non-3GPP IP access |  | 545d? | 2007-02-05 A | 2009-03-06 A | 100% | 2007-02-05 | 2009-03-06 | 545d? | finish no earlier than 2009-03-06 | C4 | 4360h | 4360h | SAES | Huawei | shahab.lavasani@huawei.com | Rel-8 | Kimmo | 29.273, 29.275 |  |  |  |
| 361 | 132.5.13 | Stage 3 for AAA/HSS related |  | 480d? | 2007-02-05 A | 2008-12-05 A | 100% | 2007-02-05 | 2008-12-05 | 480d? | finish no earlier than 2008-12-05 | C4 | 3840h | 3840h | SAES | Huawei | shahab.lavasani@huawei.com | Rel-8 | Kimmo | 29.273 |  |  |  |
| 362 | 132.5.14 | Stage 3 for EPC - AAA interface |  | 480d? | 2007-02-05 A | 2008-12-05 A | 100% | 2007-02-05 | 2008-12-05 | 480d? | finish no earlier than 2008-12-05 | C4 | 3840h | 3840h | SAES | Huawei | shahab.lavasani@huawei.com | Rel-8 | Kimmo | 29.273 |  |  |  |
| 363 | 132.5.15 | Deleted (already covered) SAES-SA-FP_n3GPP Optimized Handover with CDMA | milestone | 0d? | 2007-06-25 A | 2007-06-25 A | 100% | 2007-06-25 | 2007-06-25 | 0d? | finish no earlier than 2007-06-25 | S2 |  |  | SAES-SA-FP_n3GPP-OptCDMA | Nokia Siemens Networks |  | Rel-8 | Maurice |  |  |  | SP-37 |

Notes:
- 337: CP#43 completed. SP#39 WID updated SP-070933=>SP-080132
- 338: SP#41 completed
- 339: CP#43 completed
- 340: SP#41 completed. 25/03/08 claimed as SP#34 stopped. Resurrected. WID updated SP-060926 => SP-080132
- 341: SP#41 completed
- 342: CP#43 completed. WID updated CP-080724=>CP-090247
- 343: CP#43 completed. WID updated CP-080724=>CP-090247
- 344: CP#43 completed. WID updated CP-080724=>CP-090247. S101, S103 Interface MME - HRPD access S102, Interface to CDMA2000 1x RTT
- 345: SP#41 completed (except: Handover of multiple PDNs=>Rel-9)
- 346: CP#43 completed
- 347: CP#43 completed. WID updated CP-080724=>CP-090247
- 348: CP#43 completed. SP#39 retained in Rel-8 (in addition to the essential functionality defined in SP-070699). Replaces UID_340037
- 349: SP#40 completed
- 350: SP#41 completed
- 351: CP#41 WID updated CP-080075=>CP-080493. CP#42 completed
- 352: CP#41 WID updated CP-080075=>CP-080493. CP#42 completed
- 353: CP#43 completed
- 354: SP#40 completed
- 355: SP#42 completed. SP#39 WID updated SP-070933=>SP-080132
- 356: CP#42 completed. post-CP#39: split into DSMIP v6 and MIPv4 Access. CP#41 WID updated CP-080075=>CP-080493
- 357: CP#42 completed. post-CP#39: split into DSMIP v6 and MIPv4 Access. UID_390072->390172. CP#41 WID updated CP-080075=>CP-080493
- 358: CP#43 completed
- 359: CP#43 completed. WID updated CP-080724=>CP-090247. S10, S11. GTP based S5 Interface
- 360: CP#43 completed. WID updated CP-080724=>CP-090247. S2a, S2b, SWa, STa, SWn (Untrusted IP access - ePDG) interface
- 361: CP#42 completd. CP#43 WID updated CP-080724=>CP-090247
- 362: CP#42 completd. CP#43 WID updated CP-080724=>CP-090247
- 363: SP#37 stopped

| ID | WBS | Task | Type | Duration | Start | Finish | Complete | Remaining | Baseline start | Baseline finish | Baseline duration | Total slack | Constraint | Resources | Work | Actual work | Text1 | Text4 | Text5 | Text6 | Text8 | Text2 | Text7 | Text9 | Text12 |
| --- | --- | --- | --- | --- | --- | --- | --- | --- | --- | --- | --- | --- | --- | --- | --- | --- | --- | --- | --- | --- | --- | --- | --- | --- | --- |
| 364 | 132.6 | **Single Radio Voice Call Continuity for 3GPP (SRVCC)** |  | 569d? | 2007-01-02 A | 2009-03-06 A | 100% |  | 2007-01-02 | 2009-03-06 | 569d? |  |  | S2,C1,C4 | 10752h | 10752h | SAES-SRVCC | Nokia Siemens Networks | curt.c.wong@nokia.com | Rel-8 | Maurice |  |  |  |  |
| 365 | 132.6.1 | Stage 2 for 2G/3G SRVCC |  | 448d? | 2007-01-02 A | 2008-09-18 A | 100% |  | 2007-01-02 | 2008-09-18 | 448d? |  | finish no earlier than 2008-09-15 | S2 | 3584h | 3584h | SAES-SRVCC | Nokia Siemens Networks | curt.c.wong@nokia.com | Rel-8 | Maurice |  |  |  |  |
| 366 | 132.6.2 | Stage 3 for SRVCC in EPS |  | 201d? | 2008-05-30 A | 2009-03-06 A | 100% |  | 2008-05-30 | 2009-03-06 | 201d? |  | finish no earlier than 2009-03-06 | C1 | 1608h | 1608h | SAES-SRVCC | Nokia Siemens Networks | robert.zaus@nsn.com | Rel-8 | Frederic | PCG-21 | CP-41 |  |  |
| 367 | 132.6.3 | MME to MSC interface for SRVCC |  | 126d? | 2008-09-12 A | 2009-03-06 A | 100% |  | 2008-09-12 | 2009-03-06 | 126d? |  | finish no earlier than 2009-03-06 | C4 | 1008h | 1008h | SAES-SRVCC | Nokia Siemens Networks | Giorgi Gulbani | Rel-8 | Kimmo | PCG-21 | CP-41 |  |  |
| 368 | 132.7 | Voice Call Continuity for CDMA2000 1X |  | 249d? | 2007-06-25 A | 2008-06-05 A | 100% |  | 2007-06-25 | 2008-06-05 | 249d? |  | finish no earlier than 2008-06-13 | S2 | 1992h | 1992h | SAES-VCC_1X | Nokia Siemens Networks | balazs.bertenyi@nsn.com | Rel-8 | Maurice |  |  |  |  |
| 369 | 132.8 | SAE impacts on IMS |  | 373d? | 2007-01-02 A | 2008-06-05 A | 100% |  | 2007-01-02 | 2008-06-05 | 373d? |  | finish no earlier than 2008-06-13 | S2 | 2984h | 2984h | SAES-SA_IMS | Nokia Siemens Networks | balazs.bertenyi@nsn.com | Rel-8 | Maurice |  |  |  |  |
| 370 | 132.9 | **CS Fallback in EPS** |  | 258d? | 2008-03-12 A | 2009-03-06 A | 100% |  | 2008-03-12 | 2009-03-06 | 258d? |  |  | S2,C1,C4 | 4800h | 4800h | SAES-CSFB | T-Mobile, Vodafone | sabine.demel@t-mobile.at, chris.pudney@vodafone.com | Rel-8 | Maurice | PCG-21 | SP-39 |  |  |
| 371 | 132.9.1 | Stage 2 for CS Fallback in EPS |  | 62d? | 2008-03-12 A | 2008-06-05 A | 100% |  | 2008-03-12 | 2008-06-05 | 62d? |  | finish no earlier than 2008-12-05 | S2 | 496h | 496h | SAES-CSFB | T-Mobile, Vodafone | sabine.demel@t-mobile.at, chris.pudney@vodafone.com | Rel-8 | Maurice | PCG-21 | SP-40 |  |  |
| 372 | 132.9.2 | Stage 3 for CS Fallback in EPS |  | 201d? | 2008-05-30 A | 2009-03-06 A | 100% |  | 2008-05-30 | 2009-03-06 | 201d? |  | finish no earlier than 2009-03-06 | C1 | 1608h | 1608h | SAES-CSFB | NEC | yannick.lair@nectech.fr | Rel-8 | Frederic | PCG-21 | CP-40 |  |  |
| 373 | 132.9.3 | Stage 3 for CS Fallback in EPS |  | 136d? | 2008-05-30 A | 2008-12-05 A | 100% |  | 2008-05-30 | 2008-12-05 | 136d? |  | finish no earlier than 2008-12-05 | C4 | 1088h | 1088h | SAES-CSFB | NEC | yannick.lair@nectech.fr | Rel-8 | Kimmo | PCG-21 | CP-40 |  |  |
| 374 | 132.10 | System enhancements for the use of IMS services in local breakout |  | 62d? | 2008-03-12 A | 2008-06-05 A | 100% |  | 2008-03-12 | 2008-06-05 | 62d? |  | finish no earlier than 2008-06-05 | S2 | 496h | 496h | SAES-IMS_LBO | Telecom Italia | mario.madella@telecomitalia.it | Rel-8 | Maurice | PCG-21 | SP-39 |  |  |
| 375 | 132.11 | **EPC Data Definitions** |  | 309d? | 2008-01-07 A | 2009-03-12 A | 100% |  | 2008-01-07 | 2009-03-12 | 309d? |  |  | S5 | 7144h | 7144h | EPC-OAM |  |  | Rel-8 | Dionisio | PCG-21 | SP-39 |  |  |
| 376 | 132.11.1 | EPC Network Resource Model (NRM) Integration Reference Point (IRP) |  | 309d? | 2008-01-07 A | 2009-03-12 A | 100% |  | 2008-01-07 | 2009-03-12 | 309d? |  | finish no earlier than 2009-03-12 | S5 | 2472h | 2472h | EPC-OAM | Huawei | WANG, Xuelong | Rel-8 | Dionisio | PCG-21 | SP-38 |  |  |
| 377 | 132.11.2 | Performance measurements for EPC |  | 275d? | 2008-02-22 A | 2009-03-12 A | 100% |  | 2008-02-22 | 2009-03-12 | 275d? |  | finish no earlier than 2009-03-12 | S5 | 2200h | 2200h | EPC-OAM | China Mobile | Li Jian, Liang Shuangchun | Rel-8 | Dionisio | PCG-21 | SP-39 |  |  |
| 378 | 132.12 | EPC Charging |  | 309d? | 2008-01-07 A | 2009-03-12 A | 100% |  | 2008-01-07 | 2009-03-12 | 309d? |  | finish no earlier than 2009-03-12 | S5 | 2472h | 2472h | EPC-CH | Nokia Siemens Networks | GÖRMER, Gerald | Rel-8 | Dionisio | PCG-21 | SP-38 |  |  |
| 379 | 132.13 | Issues for CT1 TR 24.801 |  | 420d? | 2007-01-04 A | 2008-12-05 A | 100% |  | 2007-01-04 | 2008-12-05 | 420d? |  | finish no earlier than 2008-12-05 | C1 | 3360h | 3360h | SAES | Nokia Siemens Networks | robert.zaus@nsn.com | Rel-8 | Frederic | PCG-21 | CP-39 |  |  |
| 380 | 132.14 | Issues for CT3 TR 29.804 |  | 420d? | 2007-02-05 A | 2008-09-12 A | 100% |  | 2007-02-05 | 2008-09-12 | 420d? |  | finish no earlier than 2008-12-12 | C3 | 3360h | 3360h | SAES | Ericsson | j.javier.pastor@ericsson.com | Rel-8 | Gwiho | PCG-21 | CP-39 |  |  |
| 381 | 132.15 | Deleted - Issues for CT4 TR 29.803 |  | 420d? | 2007-01-04 A | 2008-09-12 A | 100% |  | 2007-01-04 | 2008-09-12 | 420d? |  | finish no earlier than 2008-12-11 | C4 | 3360h | 3360h | SAES | Huawei |  | Rel-8 | Kimmo | PCG-21 | CP-39 | PCG-21 | CP-41 |
| 382 | 132.16 | Domain Name System Procedures for Evolved Packet System (DEPS) |  | 179.75d? | 2008-05-30 A | 2009-03-06 A | 100% |  | 2008-05-30 | 2009-03-06 | 179.75d? |  | finish no earlier than 2009-03-06 | C4 | 1438h | 1438h | SAES-DEPS | TeliaSonera | jouni.korhonen@teliasonera.com | Rel-8 | Kimmo | PCG-21 | CP-40 |  |  |
| 383 | 132.17 | InterWorking Function (IWF) between MAP based and Diameter based interfaces |  | 126d? | 2008-09-12 A | 2009-03-06 A | 100% |  | 2008-09-12 | 2009-03-06 | 126d? |  | finish no earlier than 2009-03-06 | C4 | 1008h | 1008h | SAES-MAP2Diam | Huawei | liming49985@huawei.com | Rel-8 | Kimmo | PCG-21 | CP-41 |  |  |
| 384 | 132.18 | **CT6 aspects of SAE** |  | 527d? | 2008-03-07 A | 2010-03-12 | 95% | 26.75d? | 2008-03-07 | 2010-03-12 | 527d? | 656d |  | C6 | 7872h | 6599.2h | SAES | Nokia | Rune Lindholm | Rel-8 | Xavier | PCG-21 | SP-39 |  |  |
| 385 | 132.18.1 | CT6 aspects of SAE |  | 321d? | 2008-03-07 A | 2009-05-29 A | 100% |  | 2008-03-07 | 2009-05-29 | 321d? |  | finish no earlier than 2009-05-29 | C6 | 2568h | 2568h | SAES | Nokia | Rune Lindholm | Rel-8 | Xavier | PCG-21 | CP-39 |  |  |
| 386 | 132.18.2 | Test interworking of LTE Terminals with the USIM |  | 331d? | 2008-12-05 A | 2010-03-12 | 90% | 33.1d? | 2008-12-05 | 2010-03-12 | 331d? | 656d | finish no earlier than 2010-03-12 | C6 | 2648h | 2383.2h | SAES-USIM_LTE-Test | Comprion | Udo Willenbrink | Rel-8 | Xavier | PCG-22 | CP-42 |  |  |
| 387 | 132.19 | Deleted (covered by 380068): Functions and procedures for SAE to support LCS | milestone | 0d? | 2008-03-03 A | 2008-03-03 A | 100% |  | 2008-03-03 | 2008-03-03 | 0d? |  | finish no earlier than 2008-03-03 | S2 |  |  | SAES-SA-FP_LCS | Nokia Siemens Networks |  | Rel-8 | Maurice |  |  |  | SP-37 |
| 388 | 132.20 | Deleted (covered by 380064): SAE aspects of Emergency Calls | milestone | 0d? | 2008-03-03 A | 2008-03-03 A | 100% |  | 2008-03-03 | 2008-03-03 | 0d? |  | start no earlier than 2008-03-03 | S2 |  |  | SAES-SA-EmCall | Nokia Siemens Networks |  | Rel-8 | Maurice |  |  |  | SP-37 |
| 389 | 132.21 | Deleted - CT1 aspects of SAES |  | 16.7d? | 2007-09-04 A | 2007-09-27 A | 100% |  | 2007-09-04 | 2007-09-27 | 16.7d? |  | start no earlier than 2007-09-04 | CP,C1 | 133.62h | 133.62h | SAES-St3 |  |  | Rel-8 | Frederic |  |  |  | SP-37 |
| 390 | 132.22 | Deleted - CT1 aspects of SAES | milestone | 0d? | 2007-09-04 A | 2007-09-04 A | 100% |  | 2007-09-04 | 2007-09-04 | 0d? |  | start no earlier than 2007-09-04 | C1 |  |  | SAES-St3 |  |  | Rel-8 | Frederic |  |  |  | SP-37 |
| 391 | 132.23 | Deleted - Interoperability | milestone | 0d? | 2008-03-14 A | 2008-03-14 A | 100% |  | 2008-03-14 | 2008-03-14 | 0d? |  | start no earlier than 2008-03-14 | C1 |  |  | SAES-St3-interop |  |  | Rel-8 | Frederic |  |  |  | SP-37 |
| 392 | 132.24 | Deleted - CT3 aspects of SAES | milestone | 0d? | 2007-09-04 A | 2007-09-04 A | 100% |  | 2007-09-04 | 2007-09-04 | 0d? |  | start no earlier than 2007-09-04 | C3 |  |  | SAES-St3 |  |  | Rel-8 | Gwiho |  |  |  | SP-37 |
| 393 | 132.25 | Deleted - CT4 aspects of SAES | milestone | 0d? | 2007-09-04 A | 2007-09-04 A | 100% |  | 2007-09-04 | 2007-09-04 | 0d? |  | start no earlier than 2007-09-04 | C4 |  |  | SAES-St3 |  |  | Rel-8 | Kimmo |  |  |  | SP-37 |
| 394 | 132.26 | Deleted - UE to EPC NAS signalling (incl. MBMS and QoS aspects) | milestone | 0d? | 2008-03-14 A | 2008-03-14 A | 100% |  | 2008-03-14 | 2008-03-14 | 0d? |  | start no earlier than 2008-03-14 | C1 |  |  | SAES-St3-sig |  |  | Rel-8 | Frederic |  |  |  | SP-37 |
| 395 | 132.27 | Deleted -User and Control plane protocols | milestone | 0d? | 2007-09-21 A | 2007-09-21 A | 100% |  | 2007-09-21 | 2007-09-21 | 0d? |  | start no earlier than 2007-09-21 | C4 |  |  | SAES-St3-prot |  |  | Rel-8 | Kimmo |  |  |  | SP-37 |
| 396 | 132.28 | Deleted - Architecture enhancements for non-3GPP accesses | milestone | 0d? | 2007-09-04 A | 2007-09-04 A | 100% |  | 2007-09-04 | 2007-09-04 | 0d? |  | start no earlier than 2007-09-04 | S2 |  |  | SAES-non_3GPP | Motorola | Irfan.Ali@motorola.com | Rel-8 | Maurice |  |  |  | SP-34 |
| 397 | 132.29 | Deleted: Stage 2 of architecture for the 3GPP System Architecture Evolution | milestone | 0d? | 2007-10-02 A | 2007-10-02 A | 100% |  | 2007-10-02 | 2007-10-02 | 0d? |  | start no earlier than 2007-10-02 | S2 |  |  | SAES-St2 | Vodafone | chris.pudney@vodafone.com | Rel-8 | Maurice |  |  |  | SP-34 |
| 398 | 132.30 | Deleted - SA aspects of System Architecture Evolution |  | 384d? | 2006-04-12 A | 2007-10-01 A | 100% |  | 2006-04-12 | 2007-10-01 | 384d? |  | finish no earlier than 2007-10-02 | S2 | 3072h | 3072h | SAES-SA |  |  | Rel-8 | Maurice |  |  |  | SP-34 |
| 399 | 133 | Conformance Test Aspects – Mobility management based on DSMIPv6 (Dual-Stack Mobile IPv6) |  | 196d? | 2009-09-18 | 2010-06-18 |  |  | 2009-09-18 | 2010-06-18 | 196d? | 586d | finish no earlier than 2010-06-18 | R5 | 1568h |  | DSMIPv6_UEConTest | Qualcomm Europe | Lena Chaponniere (lchaponn@qualcomm.com) | Rel-8 | Ingbert | PCG-23 | RP-45 |  |  |

Notes:
- 364: CP#43 completed. SP#41 Stage 2 completed. SP#38 WID approved (extract from SAE WID SP-070817).
- 365: SP#41 completed. SP#38 WID approved / Text3: 23.216
- 366: CP#43 completed / Text3: 23.009, 24.008, 24.301
- 367: CP#43 completed / Text3: 29.274, 29.277, 23.003, 23.008, 29.280
- 368: SP#40 completed
- 369: SP#40 completed
- 370: CP#43 completed. SP#40 Stage 2 completed.
- 371: SP#40 completed / Text3: 23.272, 23.401
- 372: CP#43 completed / Text3: 24.301, 24.801, 24.007, 24.008, 24.011, 29.018, 29.118 [Mobility Management Entity (MME) – Visitor Location Register (VLR) SGs interface specification]
- 373: CP#42 completed. WID updated CP-080321=>CP-080495=>CP-080791 / Text3: 23.007, 23.008, 29.274, 29.277
- 374: SP#40 completed / Text3: 23.228, 23.221, 23.203
- 375: SP#43 completed
- 376: SP#43 completed / Text3: 32.751, 32.752, 32.753, 32.755
- 377: SP#43 completed / Text3: 32.426
- 378: SP#43 completed / Text3: 32.240/296/251/252/298/299
- 379: CP#43 completed / Text3: 24.801
- 380: CP#41 completed / Text3: 29.804
- 381: CP#41 Work stopped and continued in Normative specifications / Text3: 29.803
- 382: CP#43 completed / Text3: 23.003, 29.303
- 383: CP#43 completed. Triggered by UID_380023 (FS_MAP2Diam) / Text3: 29.305
- 384: CP#44 completed core specification. Testing ongoing
- 385: CP#44 completed (Network Measurement Results collection via USAT are now specified) / Text3: 31.102, 31.111
- 386: CP#45 WID updated CP-080899=>CP-090711. Completion 09/09=>03/10. Testing for UID_390021 (BB: Rel-8 CT6 aspects of SAE) / Text3: 31.121, 31.124
- 387: SP#37 stopped
- 388: SP#37 stopped
- 389: SP#37 stopped
- 390: SP#37 stopped
- 391: SP#37 stopped
- 392: SP#37 stopped
- 393: SP#37 stopped / Text3: 29.803
- 394: SP#37 stopped
- 395: SP#37 stopped
- 396: SP#34 stopped. Replaced by UID_350027 and its children / Text3: 23.402
- 397: SP#34 stopped. Replaced by UIDs 340018 and 340037. (SP#34 report discussion of SP-060917.) / Text3: 23.002, 23.060, 23.107, 23.203, 23.228, 23.234, 23.246, 23.271, 23.279
- 398: SP#34 stopped
- 399: RP#45 testing for CT1's UID_360022 (24.303) under Rel-8 Feature SAES / Text3: 36.508, 36.523-1, 36.523-2, 36.523-3

| ID | WBS | Task | Duration | Start | Finish | Complete | Baseline start | Baseline finish | Baseline duration | Constraint | Resources | Work | Actual work | Text1 | Text4 | Text5 | Text6 | Text7 | Text8 | Text2 | Text9 | Text12 |
| --- | --- | --- | --- | --- | --- | --- | --- | --- | --- | --- | --- | --- | --- | --- | --- | --- | --- | --- | --- | --- | --- | --- |
| 400 | 134 | **IMS Centralized Service Control (ICSRA)** | 395d? | 2007-09-03 A | 2009-03-06 A | 100% | 2007-09-03 | 2009-03-06 | 395d? |  | S1,S2,C1,C3,C4 | 9072h | 9072h | ICSRA | AT&T | Randolph Wohlert (rwohlert@tri.sbc.com) | Rel-8 | SP-37 | Alain |  |  |  |
| 401 | 134.1 | Stage 1 for ICSRA | 138d? | 2007-09-03 A | 2008-03-12 A | 100% | 2007-09-03 | 2008-03-12 | 138d? | finish no earlier than 2007-12-14 | S1 | 1104h | 1104h | ICSRA | AT&T | Randolph Wohlert (rwohlert@tri.sbc.com) | Rel-8 | SP-38 | Alain | PCG-21 |  |  |
| 402 | 134.2 | Stage 2 for ICSRA | 125d? | 2007-12-14 A | 2008-06-05 A | 100% | 2007-12-14 | 2008-06-05 | 125d? | start no earlier than 2007-12-14 | S2 | 1000h | 1000h | ICSRA-St2 | Alcatel-Lucent |  | Rel-8 | SP-38 | Maurice | PCG-21 |  |  |
| 403 | 134.3 | Stage 3 for ICSRA – Protocol, Addressing, Subscriber Data | 201d? | 2008-05-30 A | 2009-03-06 A | 100% | 2008-05-30 | 2009-03-06 | 201d? | finish no earlier than 2009-03-06 | C1 | 1608h | 1608h | ICSRA | Ericsson | Sean Schneyer | Rel-8 | CP-40 | Frederic | PCG-21 |  |  |
| 404 | 134.4 | Deleted - Stage 3 for ICSRA – I1 interface | 76d? | 2008-05-30 A | 2008-09-12 A | 100% | 2008-05-30 | 2008-09-12 | 76d? | finish no earlier than 2008-09-12 | C1 | 608h | 608h | ICSRA | Huawei | xupeili@huawei.com | Rel-8 | CP-40 | Frederic | PCG-21 | PCG-21 | CP-41 |
| 405 | 134.5 | Stage 3 for ICSRA – Protocol, Addressing, Subscriber Data | 201d? | 2008-05-30 A | 2009-03-06 A | 100% | 2008-05-30 | 2009-03-06 | 201d? | finish no earlier than 2009-03-06 | C3 | 1608h | 1608h | ICSRA | Mavenir | Brett Wallis | Rel-8 | CP-40 | Gwiho | PCG-21 |  |  |
| 406 | 134.6 | Stage 3 for ICSRA – Protocol, Addressing, Subscriber Data | 136d? | 2008-05-30 A | 2008-12-05 A | 100% | 2008-05-30 | 2008-12-05 | 136d? | start no earlier than 2008-05-30 | C4 | 1088h | 1088h | ICSRA | Ericsson | Sean Schneyer | Rel-8 | CP-40 | Kimmo | PCG-21 |  |  |
| 407 | 135 | **IMS Multimedia Telephony and Supplementary Services** | 487d? | 2007-05-02 A | 2009-03-12 A | 100% | 2007-05-02 | 2009-03-12 | 487d? |  | S1,S5,C1,C3,C4 | 46006.4h | 46006.4h | IMSTSS |  |  | Rel-8 | SP-37 | Alain |  |  |  |
| 408 | 135.1 | **General aspects of IMS Sup Services** | 395d? | 2007-09-03 A | 2009-03-06 A | 100% | 2007-09-03 | 2009-03-06 | 395d? |  | S1,C1,C3,C4 | 9752h | 9752h | IMSSS-Gal | Ericsson | Susana Sabater | Rel-8 | SP-37 | Alain |  |  |  |
| 409 | 135.1.1 | Service and Capability for Core IMS - inclusion of TISPAN requirements | 75d? | 2007-09-03 A | 2007-12-14 A | 100% | 2007-09-03 | 2007-12-14 | 75d? | finish no earlier than 2007-12-14 | S1 | 600h | 600h | TISCAPR8 | Ericsson | Susana Sabater | Rel-8 | SP-37 | Alain |  |  |  |
| 410 | 135.1.2 | Documentation of TISPAN R1 and R2 in CT1 | 208d? | 2007-11-28 A | 2008-09-12 A | 100% | 2007-11-28 | 2008-09-12 | 208d? | finish no earlier than 2008-09-12 | C1 | 1664h | 1664h | REDOC_TIS-C1 | Nokia Siemens Networks | peter.leis@nsn.com | Rel-8 | CP-38 | Frederic | PCG-21 |  |  |
| 411 | 135.1.3 | Documentation of TISPAN R1 and R2 in CT3 | 333d? | 2007-11-28 A | 2009-03-06 A | 100% | 2007-11-28 | 2009-03-06 | 333d? | finish no earlier than 2009-03-06 | C3 | 2664h | 2664h | REDOC_TIS-C3 | Nokia Siemens Networks | peter.leis@nsn.com | Rel-8 | CP-38 | Gwiho | PCG-21 |  |  |
| 412 | 135.1.4 | Documentation of TISPAN R1 and R2 in CT4 | 208d? | 2007-11-28 A | 2008-09-12 A | 100% | 2007-11-28 | 2008-09-12 | 208d? | finish no earlier than 2008-09-12 | C4 | 1664h | 1664h | REDOC_TIS-C4 | Nokia Siemens Networks | peter.leis@nsn.com | Rel-8 | CP-38 | Kimmo | PCG-21 |  |  |
| 413 | 135.2 | **IMS Multimedia Telephony Service** | 394d? | 2007-09-10 A | 2009-03-12 A | 100% | 2007-09-10 | 2009-03-12 | 394d? |  | S1,S5 | 5096h | 5096h | IMS-MMTel |  |  | Rel-8 | SP-37 | Alain |  |  |  |
| 414 | 135.2.1 | Merging TISPAN MMTel [requirements] for Common IMS | 65d? | 2007-09-10 A | 2007-12-07 A | 100% | 2007-09-10 | 2007-12-07 | 65d? | finish no earlier than 2007-12-07 | S1 | 520h | 520h | TMMTEL | Nokia Siemens Networks |  | Rel-8 | SP-37 | Alain |  |  |  |
| 415 | 135.2.2 | Multimedia Telephony Service and Supplementary Services (MMTel) offline Charging | 309d? | 2008-01-07 A | 2009-03-12 A | 100% | 2008-01-07 | 2009-03-12 | 309d? | finish no earlier than 2009-03-12 | S5 | 2472h | 2472h | MMTel-CH | Alcatel-Lucent | GARDELLA, Maryse | Rel-8 | SP-38 | Dionisio | PCG-21 |  |  |
| 416 | 135.3 | **Call Completion on Busy Subscriber (CCBS)/Call Completion on Non-Reachable (CCNR) on IMS** | 483d? | 2007-05-02 A | 2009-03-06 A | 100% | 2007-05-02 | 2009-03-06 | 483d? |  | C1,C3 | 11072h | 11072h | CCBS_CCNR | Deutsche Telekom | martin.huelsemann@telekom.de | Rel-8 | SP-38 | Frederic | PCG-21 |  |  |
| 417 | 135.3.1 | Stage 3 CCBS_CCNR | 483d? | 2007-05-02 A | 2009-03-06 A | 100% | 2007-05-02 | 2009-03-06 | 483d? | finish no earlier than 2009-03-06 | C1 | 3864h | 3864h | CCBS_CCNR | Deutsche Telekom | martin.huelsemann@telekom.de | Rel-8 | CP-38 | Frederic | PCG-21 |  |  |
| 418 | 135.3.2 | Stage 3 CCBS_CCNR | 418d? | 2007-05-02 A | 2008-12-05 A | 100% | 2007-05-02 | 2008-12-05 | 418d? | finish no earlier than 2008-12-05 | C3 | 3344h | 3344h | CCBS_CCNR | Deutsche Telekom | martin.huelsemann@telekom.de | Rel-8 | CP-38 | Gwiho | PCG-21 |  |  |
| 419 | 135.4 | **Flexible Alerting** | 288d? | 2008-01-30 A | 2009-03-06 A | 100% | 2008-01-30 | 2009-03-06 | 288d? |  | S1,C1 | 5278.4h | 5278.4h | FA | Nortel | milanpa@nortel.com | Rel-8 | SP-39 | Alain | PCG-21 |  |  |
| 420 | 135.4.1 | Stage 1 FA | 92d? | 2008-01-30 A | 2008-06-05 A | 100% | 2008-01-30 | 2008-06-05 | 92d? |  | S1 | 670.4h | 670.4h | FA | Telecom Italia |  | Rel-8 | SP-39 | Alain | PCG-21 |  |  |
| 421 | 135.4.2 | Stage 3 FA | 288d? | 2008-01-30 A | 2009-03-06 A | 100% | 2008-01-30 | 2009-03-06 | 288d? | finish no earlier than 2009-03-06 | C1 | 2304h | 2304h | FA | Nortel | milanpa@nortel.com | Rel-8 | CP-39 | Frederic | PCG-21 |  |  |
| 422 | 135.5 | **Communication Wait on IMS** | 331d? | 2007-11-30 A | 2009-03-06 A | 100% | 2007-11-30 | 2009-03-06 | 331d? |  | C1,C3 | 7416h | 7416h | CW_IMS | Deutsche Telekom | martin.huelsemann@telekom.de | Rel-8 | SP-38 | Frederic | PCG-21 |  |  |
| 423 | 135.5.1 | Stage 3 CW-IMS | 331d? | 2007-11-30 A | 2009-03-06 A | 100% | 2007-11-30 | 2009-03-06 | 331d? | finish no earlier than 2009-03-06 | C1 | 2648h | 2648h | CW_IMS | Deutsche Telekom | martin.huelsemann@telekom.de | Rel-8 | CP-38 | Frederic | PCG-21 |  |  |
| 424 | 135.5.2 | Stage 3 CW-IMS | 265d? | 2007-11-30 A | 2008-12-04 A | 100% | 2007-11-30 | 2008-12-04 | 265d? | finish no earlier than 2008-12-05 | C3 | 2120h | 2120h | CW_IMS | Deutsche Telekom | martin.huelsemann@telekom.de | Rel-8 | CP-38 | Gwiho | PCG-21 |  |  |
| 425 | 135.6 | Advice of Charge (AoC) support in IMS Charging | 309d? | 2008-01-07 A | 2009-03-12 A | 100% | 2008-01-07 | 2009-03-12 | 309d? | finish no earlier than 2009-03-12 | S5 | 2472h | 2472h | IMSTSS | Nokia Siemens Networks | GÖRMER, Gerald | Rel-8 | SP-38 | Dionisio | PCG-21 |  |  |
| 426 | 135.7 | Add Interconnection Border Control Function (IBCF) to IMS Charging | 128d? | 2007-09-17 A | 2008-03-12 A | 100% | 2007-09-17 | 2008-03-12 | 128d? | finish no earlier than 2008-03-12 | S5 | 1024h | 1024h | IMSTSS | Alcatel-Lucent | GARDELLA, Maryse | Rel-8 | SP-37 | Dionisio |  |  |  |

Notes:
- 400: CP#43 completed. SP#40 SA1/2 completed. CP#40 WID approved.
- 401: SP#38 WID approved. SP#39 completed / Text3: 22.101
- 402: SP#38 WID approved. SP#40 completed / Text3: 23.292, 23.206
- 403: CP#43 completed / Text3: 24.292, 24.229
- 404: 23/07/08 Line created at CT1 Zagreb request. CP#41 WID updated CP-080319=>CP-080492. CP#41 work stopped / Text3: 24.293
- 405: CP#43 completed / Text3: 29.292
- 406: CP#42 completed. CP#41 WID updated CP-080319=>CP-080492. / Text3: 23.003, 29.232, 23.018, 29.002
- 407: SP#43 completed
- 408: CP#43 completed
- 409: SP#39 completed / Text3: 22.228, 22.115, 22.101
- 410: CP#41 completed / Text3: 24.141, 24.147, 24.173, 24.229, 24.247, 24.341, 24.604, 24.605, 24.606, 24.607, 24.608, 24.610, 24.611, 24.616, 24.623, 24.628, 24.629, 24.647, 24.654
- 411: CP#43 completed / Text3: 29.162, 29.163, 29.658
- 412: CP#41 completed / Text3: 29.228, 29.229
- 413: SP#43 completed
- 414: SP#38 completed / Text3: 22.173
- 415: CP#43 completed / Text3: 32.275, 32.298/299
- 416: CP#43 completed
- 417: CP#43 completed / Text3: 24.642, 24.229, 24.173
- 418: CP#42 completed / Text3: 29.163
- 419: CP#43 completed
- 420: SP#40 completed / Text3: 22.173
- 421: CP#43 completed / Text3: 24.239, 24.173
- 422: CP#43 completed
- 423: CP#43 completed / Text3: 24.615, 24.229, 24.173
- 424: CP#42 completed / Text3: 29.163
- 425: SP#43 completed / Text3: 32.280, 32.240/260/296/298/299
- 426: SP#39 completed / Text3: 32.260, 32.298

| ID | WBS | Task | Duration | Start | Finish | Complete | Remaining | Baseline start | Baseline finish | Baseline duration | Total slack | Constraint | Resources | Work | Actual work | Text1 | Text2 | Text4 | Text5 | Text6 | Text7 | Text8 |
| --- | --- | --- | --- | --- | --- | --- | --- | --- | --- | --- | --- | --- | --- | --- | --- | --- | --- | --- | --- | --- | --- | --- |
| 427 | 136 | **3GPP2 Input to Common IMS** | 200d? | 2008-03-07 A | 2008-12-11 A | 100% |  | 2008-03-07 | 2008-12-11 | 200d? |  |  | S1,S2,S3,C1,C3,C4 | 8653.2h | 8653.2h | CIMS_3GPP2 | PCG-21 | Nortel | Amar Deol (deola@nortelnetworks.com) | Rel-8 | SP-39 | Alain |
| 428 | 136.1 | Stage 1 CIMS_3GPP2 (SA1) | 30.65d? | 2008-03-12 A | 2008-06-05 A | 100% |  | 2008-03-12 | 2008-06-05 | 30.65d? |  | finish no earlier than 2008-06-12 | S1 | 245.2h | 245.2h | CIMS_3GPP2 | PCG-21 | Nortel | Amar Deol (deola@nortelnetworks.com) | Rel-8 | SP-39 | Alain |
| 429 | 136.2 | Stage 2 CIMS_3GPP2 (SA2) | 62d? | 2008-03-12 A | 2008-06-05 A | 100% |  | 2008-03-12 | 2008-06-05 | 62d? |  | finish no earlier than 2008-09-11 | S2 | 496h | 496h | IMS_Common | PCG-21 | Nortel | Amar Deol (deola@nortelnetworks.com) | Rel-8 | SP-39 | Maurice |
| 430 | 136.3 | Security CIMS_3GPP2 (SA3) | 197d? | 2008-03-12 A | 2008-12-11 A | 100% |  | 2008-03-12 | 2008-12-11 | 197d? |  | finish no earlier than 2008-12-11 | S3 | 1576h | 1576h | IMS_Common | PCG-21 | Nortel | Amar Deol (deola@nortelnetworks.com) | Rel-8 | SP-39 | Dionisio |
| 431 | 136.4 | Stage 3 CIMS_3GPP2 (CT1) | 196d? | 2008-03-07 A | 2008-12-05 A | 100% |  | 2008-03-07 | 2008-12-05 | 196d? |  | finish no earlier than 2008-12-11 | C1 | 1568h | 1568h | REDOC_3GPP2 | PCG-21 | Alcatel-Lucent | orsic@alcatel-lucent.com | Rel-8 | CP-39 | Frederic |
| 432 | 136.5 | Stage 3 CIMS_3GPP2 (CT3) | 196d? | 2008-03-07 A | 2008-12-05 A | 100% |  | 2008-03-07 | 2008-12-05 | 196d? |  | finish no earlier than 2008-12-05 | C3 | 1568h | 1568h | REDOC_3GPP2 | PCG-21 | Alcatel-Lucent | orsic@alcatel-lucent.com | Rel-8 | CP-39 | Gwiho |
| 433 | 136.6 | Stage 3 CIMS_3GPP2 (CT4) | 200d? | 2008-03-07 A | 2008-12-11 A | 100% |  | 2008-03-07 | 2008-12-11 | 200d? |  | finish no earlier than 2008-12-11 | C4 | 1600h | 1600h | REDOC_3GPP2 | PCG-21 | Alcatel-Lucent | orsic@alcatel-lucent.com | Rel-8 | CP-39 | Kimmo |
| 434 | 137 | **IMS Enhancements for support of Packet Cable access** | 388d? | 2006-12-06 A | 2008-05-30 A | 100% |  | 2006-12-06 | 2008-05-30 | 388d? |  |  | S2,S3,C1,C3,C4 | 27448h | 27448h | PktCbl |  | Cablelabs | Bernie McKibben | Rel-8 |  | Maurice |
| 435 | 137.1 | **IMS Enhancements for Cable Client Types and Deployment Models** | 345d? | 2007-02-05 A | 2008-05-30 A | 100% |  | 2007-02-05 | 2008-05-30 | 345d? |  |  | S2,C1 | 6992h | 6992h | PktCbl-Deploy |  | Cablelabs | Bernie McKibben | Rel-8 |  | Maurice |
| 436 | 137.1.1 | Architecture aspects of PktCbl-Deploy | 219d? | 2007-02-05 A | 2007-12-06 A | 100% |  | 2007-02-05 | 2007-12-06 | 219d? |  | finish no earlier than 2007-12-03 | S2 | 1752h | 1752h | PktCbl-Deploy |  | Cablelabs | Bernie McKibben | Rel-8 |  | Maurice |
| 437 | 137.1.2 | CT1 aspects of PktCbl-Deploy | 310d? | 2007-03-26 A | 2008-05-30 A | 100% |  | 2007-03-26 | 2008-05-30 | 310d? |  | finish no earlier than 2008-06-15 | C1 | 2480h | 2480h | PktCbl-Deploy |  | Cablelabs | D.Hancock@ CableLabs.com | Rel-8 |  | Frederic |
| 438 | 137.2 | **IMS Inter-working aspects in Support of Cable Regulatory requirements** | 290d? | 2007-02-05 A | 2008-03-14 A | 100% |  | 2007-02-05 | 2008-03-14 | 290d? |  |  | S2,C1,C3 | 5640h | 5640h | PktCbl-Intw |  | Cablelabs | B.McKibben@CableLabs.com | Rel-8 |  | Maurice |
| 439 | 137.2.1 | Architecture PktCbl-Interwork | 160d? | 2007-02-05 A | 2007-09-14 A | 100% |  | 2007-02-05 | 2007-09-14 | 160d? |  | start no earlier than 2007-02-05 | S2 | 1280h | 1280h | PktCbl-Intw |  | Cablelabs | B.McKibben@CableLabs.com | Rel-8 |  | Maurice |
| 440 | 137.2.2 | CT1,CT3 PktCbl-Interwork | 255d? | 2007-03-26 A | 2008-03-14 A | 100% |  | 2007-03-26 | 2008-03-14 | 255d? |  | finish no earlier than 2008-03-15 | C1,C3 | 2040h | 2040h | PktCbl-Intw |  | Cablelabs | D.Hancock@ CableLabs.com | Rel-8 |  | Frederic |
| 441 | 137.3 | **IMS Enhancements for Security Requirements in Support of Cable Deployments** | 388d? | 2006-12-06 A | 2008-05-30 A | 100% |  | 2006-12-06 | 2008-05-30 | 388d? |  |  | S3,C1,C3,C4 | 11712h | 11712h | PktCbl-Sec |  | Cablelabs | s.dotson@cablelabs.com | Rel-8 |  | Dionisio |
| 442 | 137.3.1 | SA3 Aspects of PktCbl-Sec | 331d? | 2006-12-06 A | 2008-03-12 A | 100% |  | 2006-12-06 | 2008-03-12 | 331d? |  | finish no earlier than 2007-12-20 | S3 | 2648h | 2648h | PktCbl-Sec |  | Cablelabs | s.dotson@cablelabs.com | Rel-8 |  | Dionisio |
| 443 | 137.3.2 | CT1 Aspects of PktCbl-Sec | 310d? | 2007-03-26 A | 2008-05-30 A | 100% |  | 2007-03-26 | 2008-05-30 | 310d? |  | finish no earlier than 2008-06-06 | C1 | 2480h | 2480h | PktCbl-Sec |  | Cablelabs | D.Hancock@ CableLabs.com | Rel-8 |  | Frederic |
| 444 | 137.3.3 | CT3 Aspects of PktCbl-Sec | 180d? | 2007-03-26 A | 2007-11-30 A | 100% |  | 2007-03-26 | 2007-11-30 | 180d? |  | finish no earlier than 2008-03-15 | C3 | 1440h | 1440h | PktCbl-Intw | PCG-21 | Cablelabs | D.Hancock@ CableLabs.com | Rel-8 | CP-38 | Gwiho |
| 445 | 137.3.4 | CT4 Aspects of PktCbl-Sec | 255d? | 2007-03-26 A | 2008-03-14 A | 100% |  | 2007-03-26 | 2008-03-14 | 255d? |  | finish no earlier than 2008-03-14 | C4 | 2040h | 2040h | PktCbl-Sec |  | Cablelabs | D.Hancock@ CableLabs.com | Rel-8 |  | Kimmo |
| 446 | 138 | **IMS System enhancements for corporate network access** | 642d? | 2007-06-22 A | 2009-12-04 | 99% | 5.86d? | 2007-06-22 | 2009-12-04 | 642d? | 726d |  | S2,S1,C1,C4 | 13138.6h | 13018.8h | IMS_Corp |  | Orange | Delphin Barankanira | Rel-8 |  | Maurice |
| 447 | 138.1 | SA1 aspects of IMS_Corp | 23.6d? | 2008-03-12 A | 2008-06-05 A | 100% |  | 2008-03-12 | 2008-06-05 | 23.6d? |  | finish no earlier than 2008-06-05 | S1 | 188.8h | 188.8h | IMS_Corp | PCG-21 | Telecom Italia |  | Rel-8 | SP-39 | Alain |
| 448 | 138.2 | SA2 aspects of IMS_Corp | 325d? | 2007-06-22 A | 2008-09-18 A | 100% |  | 2007-06-22 | 2008-09-18 | 325d? |  | finish no earlier than 2008-12-25 | S2 | 2600h | 2600h | IMS_Corp |  | Orange | Delphin Barankanira | Rel-8 |  | Maurice |
| 449 | 138.3 | CT1 aspects of IMS_Corp | 457d? | 2008-03-07 A | 2009-12-04 | 98% | 9.14d? | 2008-03-07 | 2009-12-04 | 457d? | 726d | finish no earlier than 2009-12-04 | C1 | 3645.77h | 3572.86h | IMS_Corp | PCG-21 | Alcatel-Lucent | Keith Drage (drage@alcatel-lucent.com) | Rel-8 | CP-39 | Frederic |
| 450 | 138.4 | CT4 aspects of IMS_Corp | 196d? | 2008-02-26 A | 2008-12-05 A | 100% |  | 2008-02-26 | 2008-12-05 | 196d? |  | finish no earlier than 2008-12-11 | C4 | 1568h | 1568h | IMS_Corp | PCG-21 | Alcatel-Lucent | Keith Drage (drage@alcatel-lucent.com) | Rel-8 | CP-39 | Kimmo |

Notes:
- 427: TSG#42 completed
- 428: SP#40 completed / Text3: 22.228, 22.173, 22.101, 22.153
- 429: SP#40 completed / Text3: 23.002, 23.141, 23.203, 23.167, 23.228
- 430: SP#42 completed [issues addressed under UID_370078 (IMS-Sec)] / Text3: 33.141, 33.203, 33.210
- 431: CP#42 completed. WID updated CP-080218=>CP-080494=>CP-080795 / Text3: 23.218, 24.141, 24.147, 24.173, 24.229, 24.238, 24.247, 24.604, 24.605, 24.606, 24.607, 24.608, 24.610, 24.611, 24.629, 24.930
- 432: CP#42 completed. WID updated CP-080218=>CP-080494=>CP-080795 / Text3: 29.163, 29.212, 29.213, 29.214
- 433: CP#42 completed. WID updated CP-080218=>CP-080494=>CP-080795 / Text3: 29.228, 29.229, 29.328, 29.329
- 434: CP#40 completed
- 435: CP#40 completed
- 436: SP#38 completed / Text3: 23.228
- 437: CP#40 completed
- 438: CP#39 completed
- 439: SP#37 completed / Text3: 23.228
- 440: CP#39 completed / Text3: 24.229
- 441: CP#40 completed
- 442: SP#39 completed / Text3: 33.203, 33.210, 33.220
- 443: CP#40 completed / Text3: 24.229
- 444: CP#38 completed / Text3: 29.163
- 445: CP#39 completed / Text3: 29.228, 29.229, 23.008
- 446: CP#45 still some unresolved issue. SP#41 no Stage 2 impacts identified by Joint Workshop
- 447: SP#40 completed
- 448: SP#41 completed / Text3: 23.228
- 449: CP#45 still some unresolved issue / Text3: 24.229, 24.503
- 450: CP#42 completed / Text3: 29.228, 29.229, 23.003, 23.008, 29.433

| ID | WBS | Task | Duration | Start | Finish | Complete | Baseline start | Baseline finish | Baseline duration | Constraint | Resources | Work | Actual work | Text1 | Text2 | Text7 | Text8 | Text4 | Text5 | Text6 |
| --- | --- | --- | --- | --- | --- | --- | --- | --- | --- | --- | --- | --- | --- | --- | --- | --- | --- | --- | --- | --- |
| 451 | 139 | **Maintenance of TISPAN documentation** | 244d? | 2007-07-02 A | 2008-06-05 A | 100% | 2007-07-02 | 2008-06-05 | 244d? |  | S2,C1,C3,C4 | 5984h | 5984h | MAINTISP | PCG-21 | SP-38 | Maurice |  |  |  |
| 452 | 139.1 | Maintenance of TISPAN R1 | 86d? | 2007-11-09 A | 2008-03-07 A | 100% | 2007-11-09 | 2008-03-07 | 86d? | start no earlier than 2007-11-09 | C1,C3,C4 | 688h | 688h | MAINT_R1 | PCG-21 | CP-38 | Frederic | Alcatel-Lucent | Keith Drage (drage@alcatel-lucent.com) | Rel-7 |
| 453 | 139.2 | Maintenance of TISPAN R2 | 86d? | 2007-11-09 A | 2008-03-07 A | 100% | 2007-11-09 | 2008-03-07 | 86d? | start no earlier than 2007-11-09 | C1,C3,C4 | 688h | 688h | MAINT_R2 | PCG-21 | CP-38 | Frederic | Alcatel-Lucent | Keith Drage (drage@alcatel-lucent.com) | Rel-8 |
| 454 | 139.3 | Documentation of TISPAN NGN R1 and R2 in 3GPP SA2 | 104d? | 2008-01-14 A | 2008-06-05 A | 100% | 2008-01-14 | 2008-06-05 | 104d? | finish no earlier than 2008-06-20 | S2 | 832h | 832h | IMS_Comm_Doc | PCG-21 | SP-38 | Maurice | Nokia Siemens Networks | jozsef.varga@nsn.com | Rel-8 |
| 455 | 139.4 | Maintenance of TISPAN release 1 common IMS | 114d? | 2007-07-02 A | 2007-12-06 A | 100% | 2007-07-02 | 2007-12-06 | 114d? | finish no earlier than 2007-12-06 | S2,S1 | 912h | 912h | IMS_Comm_Mtce7 | PCG-21 | SP-38 | Maurice | BT, Ericsson | Dick Knight, Raymond Forbes | Rel-7 |
| 456 | 139.5 | Maintenance of TISPAN release 2 common IMS | 114d? | 2007-07-02 A | 2007-12-06 A | 100% | 2007-07-02 | 2007-12-06 | 114d? | finish no earlier than 2007-12-06 | S2 | 912h | 912h | IMS_Comm_Mtce8 | PCG-21 | SP-38 | Maurice | Telecom Italia | antonio.ascolese@telecomitalia.it | Rel-8 |
| 457 | 140 | **IMS Service Continuity** | 318d? | 2008-03-12 A | 2009-05-29 A | 100% | 2008-03-12 | 2009-05-29 | 318d? |  | S2,S1,C1 | 5624h | 5624h | IMS-Cont | PCG-21 | SP-39 | Maurice | LG Electronics | JaeSeung SONG (anthonys@lge.com) | Rel-8 |
| 458 | 140.1 | Stage 1 IMS Service Continuity | 62d? | 2008-03-12 A | 2008-06-05 A | 100% | 2008-03-12 | 2008-06-05 | 62d? | start no earlier than 2008-03-12 | S1 | 496h | 496h | IMS-Cont | PCG-21 | SP-39 | Alain | LG Electronics | JaeSeung SONG (anthonys@lge.com) | Rel-8 |
| 459 | 140.2 | Stage 2 IMS Service Continuity | 62d? | 2008-03-12 A | 2008-06-05 A | 100% | 2008-03-12 | 2008-06-05 | 62d? | finish no earlier than 2008-06-05 | S2 | 496h | 496h | IMS-Cont | PCG-21 | SP-39 | Maurice | LG Electronics | JaeSeung SONG (anthonys@lge.com) | Rel-8 |
| 460 | 140.3 | Stage 3 IMS Service Continuity | 261d? | 2008-05-30 A | 2009-05-29 A | 100% | 2008-05-30 | 2009-05-29 | 261d? | finish no earlier than 2009-05-29 | C1 | 2088h | 2088h | IMS-Cont | PCG-21 | CP-40 | Frederic | Huawei | Lili Yang (kadyyang@huawei.com) | Rel-8 |
| 461 | 141 | **Security Enhancements for IMS** | 643.3d? | 2006-09-19 A | 2009-03-06 A | 100% | 2006-09-19 | 2009-03-06 | 643.3d? |  | S3,C1,C4 | 18624h | 18624h | IMS-Sec |  | SP-37 | Dionisio | Ericsson | Bengt.Sahlin@ericsson.com | Rel-8 |
| 462 | 141.1 | Stage 2 for IMS-Sec | 466d? | 2007-03-01 A | 2008-12-11 A | 100% | 2007-03-01 | 2008-12-11 | 466d? | finish no earlier than 2008-12-11 | S3 | 3728h | 3728h | IMS-Sec |  |  | Dionisio | Ericsson | Bengt.Sahlin@ericsson.com | Rel-8 |
| 463 | 141.2 | CT1 part of Stage 3 for IMS-Sec | 392d? | 2006-09-19 A | 2008-12-05 A | 100% | 2006-09-19 | 2008-12-05 | 392d? | finish no earlier than 2008-12-05 | C1 | 3136h | 3136h | IMS-Sec | PCG-21 | CP-39 | Frederic | Ericsson |  | Rel-8 |
| 464 | 141.3 | CT4 part of Stage 3 for IMS-Sec | 457d? | 2007-06-07 A | 2009-03-06 A | 100% | 2007-06-07 | 2009-03-06 | 457d? | finish no earlier than 2009-03-06 | C4 | 3656h | 3656h | IMS-Sec | PCG-21 | CP-39 | Kimmo | Ericsson |  | Rel-8 |
| 465 | 141.4 | CT1 part of NASS Bundled Authentication | 343d? | 2007-11-14 A | 2009-03-06 A | 100% | 2007-11-14 | 2009-03-06 | 343d? | finish no earlier than 2009-03-06 | C1 | 2744h | 2744h | NBA | PCG-21 | CP-39 | Frederic | Alcatel-Lucent | Keith Drage (drage@alcatel-lucent.com) | Rel-8 |
| 466 | 141.5 | CT4 part of NASS Bundled Authentication | 143d? | 2007-11-14 A | 2008-05-30 A | 100% | 2007-11-14 | 2008-05-30 | 143d? | start no earlier than 2007-11-14 | C4 | 1144h | 1144h | NBA-CT4 | PCG-21 | CP-39 | Kimmo | Alcatel-Lucent |  | Rel-8 |
| 467 | 142 | IMS initiated and controlled PSS and MBMS User Service | 262d? | 2008-03-12 A | 2009-03-12 A | 100% | 2008-03-12 | 2009-03-12 | 262d? | finish no earlier than 2009-03-12 | S4,S3 | 1003.2h | 1003.2h | IMS_PSS_MBMS_US |  |  | Paolo | FT, Ericsson | olle.franceschi@ericsson.com | Rel-8 |
| 468 | 143 | **Multimedia interworking between IMS and CS networks** | 836d? | 2005-09-23 A | 2008-12-05 A | 100% | 2005-09-23 | 2008-12-05 | 836d? |  | C3,C4 | 16112h | 16112h | MIW-IMS |  |  | Gwiho | Vodafone | nico.gabriele@vodafone.com | Rel-8 |
| 469 | 143.1 | Note: Stages 1 and 2 defined in earlier Release | 49d? | 2005-09-23 A | 2005-11-30 A | 100% | 2005-09-23 | 2005-11-30 | 49d? | start no earlier than 2005-09-23 | S2 | 392h | 392h | MIW-IMS |  |  | Maurice | Vodafone | nico.gabriele@vodafone.com | Rel-8 |
| 470 | 143.2 | Stage 3 of MW-IMS | 571d? | 2005-09-23 A | 2007-11-30 A | 100% | 2005-09-23 | 2007-11-30 | 571d? | finish no earlier than 2007-09-14 | C3 | 4568h | 4568h | MIW-IMS-St3 |  |  | Gwiho | Vodafone | nico.gabriele@vodafone.com | Rel-8 |
| 471 | 143.3 | Stage 3 for MW-IMS, MONA extension | 285d? | 2007-11-05 A | 2008-12-05 A | 100% | 2007-11-05 | 2008-12-05 | 285d? | finish no earlier than 2008-12-05 | C3 | 2280h | 2280h | MIW-IMS | PCG-21 | CP-38 | Gwiho | Vodafone | Christer.Holmberg@ericsson.com | Rel-8 |
| 472 | 143.4 | Mn interface (MGCF – IM MGW) | 273d? | 2007-11-21 A | 2008-12-05 A | 100% | 2007-11-21 | 2008-12-05 | 273d? | finish no earlier than 2008-12-19 | C4 | 2184h | 2184h | MIW-IMS | PCG-21 | CP-38 | Kimmo | Vodafone | Christer.Holmberg@ericsson.com | Rel-8 |
| 473 | 144 | IMS Stage 3 IETF Protocol Alignment | 446d? | 2007-06-22 A | 2009-03-06 A | 100% | 2007-06-22 | 2009-03-06 | 446d? | finish no earlier than 2009-03-06 | C1 | 3568h | 3568h | IMSProtoc2 |  |  | Frederic | Alcatel-Lucent | Keith Drage (drage@alcatel-lucent.com) | Rel-8 |
| 474 | 145 | **Interworking between User-to-User Signalling (UUS) and SIP** | 335d? | 2007-11-30 A | 2009-03-12 A | 100% | 2007-11-30 | 2009-03-12 | 335d? |  | C1,C3 | 7488h | 7488h | UUSIW | PCG-21 | CP-38 | Kimmo | Huawei | Lili Yang (kadyyang@huawei.com) | Rel-8 |
| 475 | 145.1 | Stage 3 MGCF UUSIW | 266d? | 2007-11-30 A | 2008-12-05 A | 100% | 2007-11-30 | 2008-12-05 | 266d? | finish no earlier than 2008-12-05 | C1 | 2128h | 2128h | UUSIW | PCG-21 | CP-38 | Frederic | Huawei | Lili Yang (kadyyang@huawei.com) | Rel-8 |
| 476 | 145.2 | Stage 3 MGCF UUSIW | 335d? | 2007-11-30 A | 2009-03-12 A | 100% | 2007-11-30 | 2009-03-12 | 335d? | finish no earlier than 2009-03-12 | C3 | 2680h | 2680h | UUSIW | PCG-21 | CP-38 | Gwiho | Huawei | Lili Yang (kadyyang@huawei.com) | Rel-8 |

Notes:
- 451: SP#40 completed
- 452: CP#39 completed / Text3: 24.404, 24.405, 24.406, 24.407, 24.408, 24.410, 24.411, 24.416, 29.421, 24.423, 24.428, 24.429, 29.433, 24.441, 24.403, 29.427, 24.430, 29.412
- 453: CP#39 completed / Text3: 24.406, 24.407, 24.410, 24.411, 24.423, 24.430, 24.447, 24.451, 24.454, 24.503, 24.505, 24.508, 24.516, 24.528, 24.529, 29.412, 29.421, 29.433, 29.458, 29.527
- 454: WID approved SP#38. per OPs & ETSI GA 39. This is a joint effort of SA WG2 and TISPAN WG2. SP#40 completed / Text3: 23.228, 23.204, 23.167
- 455: SP#38 WID and TSs approved. SP#40 WID updated SP-070915=>SP-080315. SP#41 WID updated SP-080315=>SP-080501 / Text3: 22.273, 22.401, 23.406, 23.417, 23.508, 23.509, 23.511, 22.401, 22.173
- 456: SP#38 approved WID and TSs / Text3: 23.506, 23.507,23.517, 23.521
- 457: CP#44 completed. SP#40 Stage 1/2 completed
- 458: SP#40 completed
- 459: SP#40 completed / Text3: 23.237, 23.292
- 460: CP#44 completed / Text3: 24.237, 24.229, 24.216
- 461: CP#43 completed. SP#36 WID approved
- 462: SP#42 completed. SP#39 SA3 to remove Stage 3 from 33.178-100 for CTx work. SP#40 withdrawn 33.178-100. / Text3: 33.203, 33.141, 33.978, 33.803
- 463: CP#42 completed. SP#39 SA3 to remove Stage 3 from 33.178-100 for CT1 work
- 464: CP#43 completed
- 465: CP#43 completed / Text3: 24.229
- 466: CP#40 completed / Text3: 29.229, 29.228, 23.008
- 467: SP#43 completed. SP#39 WID approved / Text3: 26.237, 26.234, 26.346, 33.246
- 468: CP#42 completed
- 469: SP#31 Moved from FS section Feb 2006
- 470: Moved from R7 WP because it is part of Feature UID_713024. This feature was extended to R8 by the inclusion (at Nov 2007 CT3 meeting) of Stage 3 exception covering MONA (WI 380021) / Text3: 29.863, 29.163
- 471: CP#42 completed / Text3: 29.863, 29.163
- 472: CP#42 completed / Text3: 29.332
- 473: CP#43 completed / Text3: 23.218, 24.229, 24.930
- 474: CP#43 completed
- 475: CP#42 completed / Text3: 24.279, 24.229
- 476: Depending on IETF draft. CP#43 completed / Text3: 29.163

| ID | WBS | Task | Type | Duration | Start | Finish | Complete | Baseline start | Baseline finish | Baseline duration | Constraint | Resources | Work | Actual work | Text1 | Text2 | Text4 | Text5 | Text6 | Text7 | Text8 | Text3 |
| --- | --- | --- | --- | --- | --- | --- | --- | --- | --- | --- | --- | --- | --- | --- | --- | --- | --- | --- | --- | --- | --- | --- |
| 477 | 146 | **Support of Overlap signalling** |  | 331d? | 2007-11-30 A | 2009-03-06 A | 100% | 2007-11-30 | 2009-03-06 | 331d? |  | C3,C1,C4 | 10008.2h | 10008.2h | Overlap | PCG-21 | Deutsche Telekom | r.jesske@telekom.de | Rel-8 | CP-38 | Gwiho |  |
| 478 | 146.1 | Stage 3 Overlap (CT1) |  | 331d? | 2007-11-30 A | 2009-03-06 A | 100% | 2007-11-30 | 2009-03-06 | 331d? | finish no earlier than 2009-03-06 | C1 | 2648h | 2648h | Overlap | PCG-21 | Deutsche Telekom | r.jesske@telekom.de | Rel-8 | CP-38 | Frederic | 24.229 |
| 479 | 146.2 | Stage 3 Overlap (CT3) |  | 331d? | 2007-11-30 A | 2009-03-06 A | 100% | 2007-11-30 | 2009-03-06 | 331d? | finish no earlier than 2009-03-06 | C3 | 2648h | 2648h | Overlap | PCG-21 | Deutsche Telekom | r.jesske@telekom.de | Rel-8 | CP-38 | Gwiho | 29.163 |
| 480 | 146.3 | Stage 3 Overlap (CT4) |  | 258.02d? | 2007-11-30 A | 2008-12-05 A | 100% | 2007-11-30 | 2008-12-05 | 258.02d? | start no earlier than 2007-11-30 | C4 | 2064.16h | 2064.16h | Overlap | PCG-21 | Deutsche Telekom | r.jesske@telekom.de | Rel-8 | CP-38 | Kimmo | 29.228, 29.229 |
| 481 | 147 | AS/MRFC Stage 2 and 3 |  | 278d? | 2007-11-14 A | 2008-12-05 A | 100% | 2007-11-14 | 2008-12-05 | 278d? | finish no earlier than 2008-12-05 | C1 | 2224h | 2224h | MRFC_TS | PCG-21 | HP | mark.syrett@hp.com | Rel-8 | CP-38 | Frederic | 23.218, 24.229, 24.147, 24.247 |
| 482 | 148 | **IMS Restoration Procedures** |  | 201d? | 2008-05-30 A | 2009-03-06 A | 100% | 2008-05-30 | 2009-03-06 | 201d? |  | C4,C1 | 4824h | 4824h | IMS_RP | PCG-21 | Ericsson | german.blanco@ericsson.com | Rel-8 | SP-40 | Kimmo |  |
| 483 | 148.1 | IMS Restoration Procedures |  | 201d? | 2008-05-30 A | 2009-03-06 A | 100% | 2008-05-30 | 2009-03-06 | 201d? | finish no earlier than 2009-03-06 | C4 | 1608h | 1608h | IMS_RP | PCG-21 | Ericsson | german.blanco@ericsson.com | Rel-8 | SP-40 | Kimmo | 23.380, 29.228, 29.229, 29.230, 23.008 |
| 484 | 148.2 | IMS Restoration Procedures |  | 201d? | 2008-05-30 A | 2009-03-06 A | 100% | 2008-05-30 | 2009-03-06 | 201d? | finish no earlier than 2009-03-06 | C1 | 1608h | 1608h | IMS_RP | PCG-21 | Ericsson | german.blanco@ericsson.com | Rel-8 | SP-40 | Frederic | 24.229 |
| 485 | 149 | IMS Application Server Service Data Descriptions for AS interoperability |  | 125d? | 2008-09-12 A | 2009-03-06 A | 100% | 2008-09-12 | 2009-03-06 | 125d? | finish no earlier than 2009-03-06 | C4 | 1000h | 1000h | IMS_ASIO | PCG-21 | Alcatel-Lucent | nhberry@alcatel-lucent.com | Rel-8 | CP-41 | Kimmo | 29.328, 29.329, 29.364 |
| 486 | 150 | **I-WLAN Network Selection Principle (NSP)** |  | 451d? | 2007-06-14 A | 2009-03-06 A | 100% | 2007-06-14 | 2009-03-06 | 451d? |  | S1,C1,C6 | 6643.2h | 6643.2h | IWLANNSP |  | Telefonica O2 | chris.friel@o2.com | Rel-8 |  | Alain |  |
| 487 | 150.1 | Stage 1 for I-WLAN NSP | milestone | 0d? | 2007-06-14 A | 2007-06-14 A | 100% | 2007-06-14 | 2007-06-14 | 0d? |  | S1 |  |  | IWLANNSP | PCG-21 | Telefonica O2 | chris.friel@o2.com | Rel-8 | SP-39 | Alain | 22.234 |
| 488 | 150.2 | Stage 3 for I-WLAN NSP |  | 261d? | 2008-03-07 A | 2009-03-06 A | 100% | 2008-03-07 | 2009-03-06 | 261d? | finish no earlier than 2008-12-05 | C1 | 2088h | 2088h | IWLANNSP | PCG-21 | RIM | Adrian Buckley (abuckley@rim.com) | Rel-8 | CP-39 | Frederic | 24.234 |
| 489 | 150.3 | Stage 3 for I-WLAN NSP |  | 118.4d? | 2008-03-07 A | 2008-12-11 A | 100% | 2008-03-07 | 2008-12-11 | 118.4d? | finish no earlier than 2008-12-11 | C6 | 947.2h | 947.2h | IWLANNSP | PCG-21 | RIM | Adrian Buckley (abuckley@rim.com) | Rel-8 | CP-39 | Xavier | 31.102, 31.111 |
| 490 | 151 | **Mobility between 3GPP-WLAN Interworking and 3GPP Systems** |  | 386d? | 2007-09-14 A | 2009-03-06 A | 100% | 2007-09-14 | 2009-03-06 | 386d? |  | S2,C1 | 6216h | 6216h | IWLAN_Mob |  | Orange | xiaobao.chen@orange-ftgroup.com | Rel-8 | SP-37 | Maurice |  |
| 491 | 151.1 | Stage 2: I-WLAN Mobility |  | 190d? | 2007-09-14 A | 2008-06-05 A | 100% | 2007-09-14 | 2008-06-05 | 190d? | finish no earlier than 2008-09-08 | S2 | 1520h | 1520h | IWLAN_Mob | PCG-21 | Orange | xiaobao.chen@orange-ftgroup.com | Rel-8 | SP-38 | Maurice | 23.327 |
| 492 | 151.2 | CT1 aspects of I-WLAN Mobility |  | 201d? | 2008-05-30 A | 2009-03-06 A | 100% | 2008-05-30 | 2009-03-06 | 201d? | finish no earlier than 2009-03-06 | C1 | 1608h | 1608h | IWLAN_Mob | PCG-21 | Orange | reina.nader@orange-ftgroup.com | Rel-8 | CP-40 | Frederic | 24.327, 24.303 |
| 493 | 152 | **Enhancements for VGCS Applications (EVA)** |  | 919d? | 2006-03-15 A | 2009-09-18 A | 100% | 2006-03-15 | 2009-09-18 | 919d? |  | S1,C1,C4,G2 | 23503.5h | 23503.5h | EVA |  | Nortel | Amar Deol (deola@nortelnetworks.com) | Rel-8 |  | Alain |  |
| 494 | 152.1 | SA1 aspects of EVA |  | 191d? | 2006-03-15 A | 2006-12-06 A | 100% | 2006-03-15 | 2006-12-06 | 191d? | finish no earlier than 2006-12-06 | S1 | 1528h | 1528h | EVA-s1 |  | Nortel | Amar Deol (deola@nortelnetworks.com) | Rel-8 |  | Alain | 42.068 |
| 495 | 152.2 | VGCS/VBS and GPRS Interactions |  | 145d? | 2007-09-03 A | 2008-03-21 A | 100% | 2007-09-03 | 2008-03-21 | 145d? | finish no earlier than 2008-03-21 | S1 | 1160h | 1160h | EVA |  | Huawei | Ling Liu | Rel-8 | SP-37 | Alain | 42.068, 42.069 |
| 496 | 152.3 | CT1 aspects of EVA |  | 862d? | 2006-06-02 A | 2009-09-18 A | 100% | 2006-06-02 | 2009-09-18 | 862d? | finish no earlier than 2009-12-04 | C1 | 6887.53h | 6887.53h | EVA |  | Nortel | milanpa@nortel.com | Rel-8 |  | Frederic | 43.068, 44.068 |
| 497 | 152.4 | CT4 aspects of EVA |  | 391d? | 2006-06-02 A | 2007-11-30 A | 100% | 2006-06-02 | 2007-11-30 | 391d? | finish no earlier than 2007-06-01 | C4 | 3128h | 3128h | EVA |  | Nortel |  | Rel-8 |  | Kimmo | 29.002 |
| 498 | 152.5 | GERAN2 aspects of EVA |  | 431d? | 2006-06-30 A | 2008-02-22 A | 100% | 2006-06-30 | 2008-02-22 | 431d? | finish no earlier than 2008-02-22 | G2 | 3448h | 3448h | EVA-EVGCSA |  | Nortel | frank.billenkamp@nortel.com | Rel-8 |  | Gert | 44.018, 48.008 |
| 499 | 153 | **Personal Network Management** |  | 955d? | 2005-07-11 A | 2009-03-06 A | 100% | 2005-07-11 | 2009-03-06 | 955d? |  | S1,C1,S3 | 27008h | 27008h | PNM |  | Vodafone | armin.toepfer@vodafone.com | Rel-8 |  | Alain |  |
| 500 | 153.1 | Stage 1 for PNM |  | 276d? | 2005-07-11 A | 2006-07-31 A | 100% | 2005-07-11 | 2006-07-31 | 276d? | start no earlier than 2005-07-11 | S1 | 2208h | 2208h | PNM |  | Vodafone | armin.toepfer@vodafone.com | Rel-8 |  | Alain | 22.259 |
| 501 | 153.2 | Stage 2 for PNM |  | 445d? | 2007-03-26 A | 2008-12-05 A | 100% | 2007-03-26 | 2008-12-05 | 445d? | finish no earlier than 2008-12-05 | C1 | 3560h | 3560h | PNM |  | Vodafone | yang.lu@vodafone.com | Rel-8 |  | Frederic | 23.259 |

Notes:
- 477: CP#43 completed
- 478: CP#43 completed
- 479: CP#43 completed
- 480: CP#42 completed
- 481: CP#42 completed. Triggered by Study UID_7048 (MRFC)
- 482: CP#43 completed. CP#41 WID updated CP-080281=>CP-080447. Triggered by Study TR 23.820 (FS_IMS_RP) UID_350018
- 483: CP#43 completed
- 484: CP#43 completed
- 485: CP#43 completed. Triggered by UID_360030 (FS_IMS_ASIO)
- 486: CP#43 completed. SP#36 Stage 1 completed
- 487: SP#36 completed
- 488: CP#43 completed
- 489: CP#42 completed
- 490: CP#43 completed. SP#40 Stage 2 completed
- 491: SP#40 completed
- 492: CP#43 completed
- 493: CP#45 completed (Voice Group Call Service)
- 494: SP#38 completed
- 495: SP#39 completed
- 496: CP#45 completed. CT1 will not do more but SA1 may remove the requirement not solved by CT1 (planned for completion by SP#46)
- 497: CP#38 completed
- 498: GP#37 completed
- 499: CP#43 completed. Feb 06 moved FS=>Feature. SP#31 Stage 1 completed. SP#40 WID updated with reduced scope SP-060574=>SP-080327
- 500: SP#31 completed. SP#40 WID updated SP-060574=>SP-080327
- 501: CP#42 completed

| ID | WBS | Task | Type | Duration | Start | Finish | Complete | Remaining | Baseline start | Baseline finish | Baseline duration | Total slack | Constraint | Resources | Work | Actual work | Text1 | Text4 | Text5 | Text6 | Text8 | Text3 | Text12 | Text7 | Text2 |
| --- | --- | --- | --- | --- | --- | --- | --- | --- | --- | --- | --- | --- | --- | --- | --- | --- | --- | --- | --- | --- | --- | --- | --- | --- | --- |
| 502 | 153.3 | **Stage 3 for PNM** |  | 510d? | 2007-03-26 A | 2009-03-06 A | 100% |  | 2007-03-26 | 2009-03-06 | 510d? |  |  | C1,C4 | 11720h | 11720h | PNM | Vodafone | yang.lu@vodafone.com | Rel-8 | Frederic |  |  |  |  |
| 503 | 153.3.1 | CT1 aspects of Stage 3 PNM |  | 510d? | 2007-03-26 A | 2009-03-06 A | 100% |  | 2007-03-26 | 2009-03-06 | 510d? |  | finish no earlier than 2008-12-05 | C1 | 4080h | 4080h | PNM | Vodafone | yang.lu@vodafone.com | Rel-8 | Frederic | 24.259, 24.229 |  |  |  |
| 504 | 153.3.2 | CT4 aspects of Stage 3 PNM |  | 445d? | 2007-03-26 A | 2008-12-05 A | 100% |  | 2007-03-26 | 2008-12-05 | 445d? |  | finish no earlier than 2008-12-11 | C4 | 3560h | 3560h | PNM | Vodafone | yang.lu@vodafone.com | Rel-8 | Kimmo |  |  |  |  |
| 505 | 153.4 | Key establishment between a UICC hosting device and a remote device |  | 235d? | 2006-12-06 A | 2007-10-30 A | 100% |  | 2006-12-06 | 2007-10-30 | 235d? |  | finish no earlier than 2007-10-30 | S3 | 1880h | 1880h | PNM | Ericsson | Vesa.Lehtovirta@ericsson.com | Rel-8 | Dionisio | 33.259 |  |  |  |
| 506 | 153.5 | Deleted - Actual Requirements of PNM | milestone | 0d? | 2007-03-26 A | 2007-03-26 A | 100% |  | 2007-03-26 | 2007-03-26 | 0d? |  | finish no earlier than 2007-03-26 | C1 |  |  | PNM | Ericsson |  | Rel-8 | Frederic |  | SP-37 |  |  |
| 507 | 154 | **eCall Data Transfer** |  | 637d? | 2006-09-28 A | 2009-03-06 A | 100% |  | 2006-09-28 | 2009-03-06 | 637d? |  |  | S1,C1 | 9744h | 9744h | EData | Airbiquity | rrobinson@airbiquity.com | Rel-8 | Alain |  |  |  |  |
| 508 | 154.1 | eData Requirements |  | 380d? | 2006-09-28 A | 2008-03-12 A | 100% |  | 2006-09-28 | 2008-03-12 | 380d? |  | finish no earlier than 2006-12-07 | S1 | 3040h | 3040h | EData | Airbiquity | rrobinson@airbiquity.com | Rel-8 | Alain | 22.101, 22.105 |  | SP-37 |  |
| 509 | 154.2 | Transfer of data during an emergency call |  | 201d? | 2008-05-30 A | 2009-03-06 A | 100% |  | 2008-05-30 | 2009-03-06 | 201d? |  | finish no earlier than 2009-03-06 | C1 | 1608h | 1608h | EData | T-Mobile | Dieter Jacobsohn | Rel-8 | Frederic | 24.008 |  | SP-40 | PCG-21 |
| 510 | 155 | eCall data transfer Phase 2: Comparison of alternative in-band modem solutions and standardization of one in-band modem solution |  | 472d? | 2007-12-06 A | 2009-09-24 A | 100% |  | 2007-12-06 | 2009-09-24 | 472d? |  | finish no earlier than 2009-09-24 | S4 | 3768.09h | 3768.09h | eCall_Phase2 | Airbiquity | lhong@airbiquity.com & rrobinson@airbiquity.com | Rel-8 | Paolo | 26.267, 26.268, 26.269, 26.967, 26.969 |  |  |  |
| 511 | 156 | eCall Conformance Testing |  | 181d? | 2009-09-04 A | 2010-05-14 | 10% | 162.9d? | 2009-09-04 | 2010-05-14 | 181d? | 611d | finish no earlier than 2010-05-14 | G3new | 1448h | 144.8h | eCall_MSTest | Ericsson, Qualcomm Europe | Vikrant Jain (vikrantj@qualcomm.com) | Rel-8 | Ingbert | 51.010-1, 51.010-2 |  | GP-45 | PCG-23 |
| 512 | 157 | Conformance Test Aspects - non-modem procedures of eCall sessions in UTRA |  | 126d? | 2009-09-18 | 2010-03-12 |  |  | 2009-09-18 | 2010-03-12 | 126d? | 656d | finish no earlier than 2010-03-12 | R5 | 1008h |  | UMTS_eCall_UEConTest | Ericsson, Qualcomm Europe | Shubhang Vora (svora@qualcomm.com) | Rel-8 | Ingbert | 34.108, 34.123-1, 34.123-2, 34.123-3 |  | RP-45 | PCG-23 |
| 513 | 158 | **IP Interconnection of Services** |  | 668d? | 2006-08-16 A | 2009-03-06 A | 100% |  | 2006-08-16 | 2009-03-06 | 668d? |  |  | S1,S2,S5,C3 | 17520h | 17520h | IPinterc | Telefonica O2 | chris.friel@O2.com | Rel-8 | Alain |  |  | SP-38 | PCG-21 |
| 514 | 158.1 | Stage 1 for IPinterc |  | 70d? | 2007-12-06 A | 2008-03-12 A | 100% |  | 2007-12-06 | 2008-03-12 | 70d? |  | start no earlier than 2007-12-06 | S1 | 560h | 560h | IPinterc | Telefonica O2 | chris.friel@O2.com | Rel-8 | Alain | 22.101, 22.228 |  | SP-38 | PCG-21 |
| 515 | 158.2 | **System enhancements for interconnection interfaces between two IMSs** |  | 668d? | 2006-08-16 A | 2009-03-06 A | 100% |  | 2006-08-16 | 2009-03-06 | 668d? |  |  | S2,S5,C3 | 11616h | 11616h | IMS_NNI | Telecom Italia | Mario Madella (mario.madella@telecomitalia.it) | Rel-8 | Maurice |  |  |  |  |
| 516 | 158.2.1 | Stage 2 for IMS_NNI |  | 120d? | 2007-06-22 A | 2007-12-06 A | 100% |  | 2007-06-22 | 2007-12-06 | 120d? |  | finish no earlier than 2007-12-21 | S2 | 960h | 960h | IMS_NNI | Telecom Italia | Mario Madella (mario.madella@telecomitalia.it) | Rel-8 | Maurice | 23.002, 23.228 |  |  |  |
| 517 | 158.2.2 | IMS inter-operator service interconnection interface |  | 461d? | 2007-06-01 A | 2009-03-06 A | 100% |  | 2007-06-01 | 2009-03-06 | 461d? |  | finish no earlier than 2009-03-06 | C3 | 3688h | 3688h | FBI2-IOPSI | Telecom Italia | antonio.ascolese@telecomitalia.it | Rel-8 | Gwiho | 29.865, 29.165 |  |  |  |
| 518 | 158.2.3 | Charging harmonization for NGN between 3GPP and ATIS-TMOC |  | 51d? | 2006-09-28 A | 2006-12-07 A | 100% |  | 2006-09-28 | 2006-12-07 | 51d? |  | finish no earlier than 2006-12-07 | S5 | 408h | 408h | FBI2-TISP2-CH | Amdocs | Brown, Yishai | Rel-8 | Dionisio | 32.297 |  |  |  |
| 519 | 158.2.4 | Deleted - Protocol impact of FBI for TISPAN R2 |  | 152d? | 2006-08-16 A | 2007-03-15 A | 100% |  | 2006-08-16 | 2007-03-15 | 152d? |  | finish no earlier than 2007-03-15 | C1 | 1216h | 1216h | FBI2-TISP2-c1 | Ericsson |  | Rel-8 | Frederic |  | SP-38 |  |  |
| 520 | 158.2.5 | Deleted (never approved) - Stage 2 of FBI for TISPAN R2 - Rel 8 | milestone | 0d? | 2007-11-30 A | 2007-11-30 A | 100% |  | 2007-11-30 | 2007-11-30 | 0d? |  | finish no earlier than 2007-11-30 | S2 |  |  | FBI2-TISP2-s2 | Nokia Siemens Networks |  | Rel-8 | Maurice |  | SP-36 |  |  |
| 521 | 159 | **Support of (G)MSC-S – (G)MSC-S Nc Interface based on the SIP-I protocol** |  | 386d? | 2007-09-14 A | 2009-03-06 A | 100% |  | 2007-09-14 | 2009-03-06 | 386d? |  |  | C4,C3 | 11872h | 11872h | SIP_Nc | Vodafone | David.Hutton@vodafone.com | Rel-8 | Kimmo |  |  |  |  |
| 522 | 159.1 | Stage 1 for SIP_Nc (covered by Feature IPinterc) |  | 70d? | 2007-12-06 A | 2008-03-12 A | 100% |  | 2007-12-06 | 2008-03-12 | 70d? |  | start no earlier than 2007-12-06 | S1 | 560h | 560h | IPinterc | Telefonica O2 | chris.friel@O2.com | Rel-8 | Alain | 22.101, 22.228 |  | CP-41 | PCG-21 |
| 523 | 159.2 | SIP-I based circuit-switched core network; Stage 2 |  | 321d? | 2007-09-14 A | 2008-12-05 A | 100% |  | 2007-09-14 | 2008-12-05 | 321d? |  | finish no earlier than 2008-12-11 | C4 | 2568h | 2568h | SIP_Nc-St2 | Vodafone | David.Hutton@vodafone.com | Rel-8 | Kimmo | 23.231, 23.153, 23.205 |  |  |  |
| 524 | 159.3 | Application of SIP-I Protocols to Circuit Switched (CS) core network architecture; Stage 3 |  | 321d? | 2007-09-14 A | 2008-12-05 A | 100% |  | 2007-09-14 | 2008-12-05 | 321d? |  | finish no earlier than 2008-12-11 | C4 | 2568h | 2568h | SIP_Nc-St3 | Vodafone | David.Hutton@vodafone.com | Rel-8 | Kimmo | 29.231, 29.232, 29.332 |  |  |  |
| 525 | 159.4 | Interworking between the 3GPP CS domain with SIP-I as signalling protocol and other networks |  | 386d? | 2007-09-14 A | 2009-03-06 A | 100% |  | 2007-09-14 | 2009-03-06 | 386d? |  | finish no earlier than 2009-03-06 | C3 | 3088h | 3088h | SIP_Nc | Nokia Siemens Networks | Thomas.Belling@nsn.com | Rel-8 | Gwiho | 29.235, 23.172, 23.202, 29.007, 29.163, 29.414 |  |  |  |

Notes:
- 502: CP#43 completed. Moved from FS section Feb 06: SP-33: Create new section to capture the PNM stage 2 aspects and identify any impacts to existing stage 2 specifications.
- 503: CP#43 completed
- 504: CP#42 No impact to CT4 specifications
- 505: 07/08: Moved from Rel-7 to Rel-8 WP; Feature=>BB as per SA3/SA WID in SP-060839, keeping the same UID
- 506: SP#37 stopped
- 507: SP#39 completed. Linked to SA4 Feature UID_34042 (eCall_Phase2). CP#40 approved Stage 3 WID.
- 508: SA4 to select a suitable in-band modem. SP#39 completed
- 509: CP#43 completed
- 510: SP#45 completed. TR 26.969 for Approval. Triggered by Study UID_360015 (eCALLIBMS). Linked to SA1 Feature UID_330005 (EData)
- 511: GP#43 testing for Rel-8 eCall_Phase2 (UID_34042) and EData (UID_330005)
- 512: RP#45 testing for Rel-8 eCall_Phase2 (UID_34042) and Edata (UID_330005)
- 513: SP#43 completed. CP#42 Rel-8 exception to 03/09. Covers Stage 1 for IMS_NNI (UID_360024),SIP_Nc (UID_360026),CS-IBCF (UID_400008). SP#41 WID updated SP-070871=>SP-080565 [Moved under it as BBs 2 existing Features: CS-IBCF, IMS_NNI]
- 514: SP#39 completed.
- 515: CP#43 completed. CP#42 Rel-8 exception to 03/09. SP#36 Name changed from "System enhancements for TISPAN Rel2". Stage 1 in Feature UID_380060 (IPinterc). CP#41 updated WID CP-080054=>CP-080578 (Feature IMS_NNI=>BB under Ipinterc)
- 516: SP#38 completed. SP#41 WID updated SP-070490=>SP-080554
- 517: CP#43 completed
- 518: SP#34 completed
- 519: SP#38 stopped
- 520: SP#36 stopped
- 521: CP#43 completed. Stage 1 in Feature UID_380060 (IPinterc). CP#40 updated WID CP-070517=>CP-080282
- 522: 22/07/08 Created. Stage 1 for SIP_Nc (covered by SA1 Feature UID_380060 Ipinterc)
- 523: CP#42 completed
- 524: CP#42 completed
- 525: CP#43 completed. CP#42 target 12/08=>03/09

| ID | WBS | Task | Type | Duration | Start | Finish | Complete | Remaining | Baseline start | Baseline finish | Baseline duration | Total slack | Constraint | Resources | Work | Actual work | Text1 | Text4 | Text5 | Text6 | Text7 | Text8 | Text3 | Text2 | Text11 | Text9 | Text12 |
| --- | --- | --- | --- | --- | --- | --- | --- | --- | --- | --- | --- | --- | --- | --- | --- | --- | --- | --- | --- | --- | --- | --- | --- | --- | --- | --- | --- |
| 526 | 160 | **Earthquake and Tsunami Warning System** |  | 440d? | 2007-09-10 A | 2009-05-15 A | 100% |  | 2007-09-10 | 2009-05-15 | 440d? |  |  | S1,S2,CP,G2 | 6136h | 6136h | ETWS | NTT DoCoMo | kitaharar@nttdocomo.co.jp | Rel-8 | SP-37 | Alain |  |  |  |  |  |
| 527 | 160.1 | Stage 1 for ETWS |  | 133d? | 2007-09-10 A | 2008-03-12 A | 100% |  | 2007-09-10 | 2008-03-12 | 133d? |  | finish no earlier than 2008-03-12 | S1 | 1064h | 1064h | ETWS | NTT DoCoMo | kitaharar@nttdocomo.co.jp | Rel-8 | SP-37 | Alain | 22.168 |  |  |  |  |
| 528 | 160.2 | SA2 aspects of ETWS |  | 179d? | 2008-01-14 A | 2008-09-18 A | 100% |  | 2008-01-14 | 2008-09-18 | 179d? |  | finish no earlier than 2008-09-08 | S2 | 1432h | 1432h | ETWS | NTT DoCoMo | tanakai@nttdocomo.co.jp | Rel-8 | SP-38 | Maurice | 23.828, 23.401 | PCG-21 |  |  |  |
| 529 | 160.3 | CT1 aspects of ETWS |  | 50.5d? | 2008-05-30 A | 2008-12-05 A | 100% |  | 2008-05-30 | 2008-12-05 | 50.5d? |  | finish no earlier than 2008-12-05 | C1 | 404h | 404h | ETWS | NTT DoCoMo | yamashitahi@s1.nttdocomo.co.jp | Rel-8 | CP-40 | Frederic | 23.041 | PCG-21 |  |  |  |
| 530 | 160.4 | CT4 aspects of ETWS |  | 50.5d? | 2008-09-26 A | 2008-12-05 A | 100% |  | 2008-09-26 | 2008-12-05 | 50.5d? |  | finish no earlier than 2008-12-05 | C4 | 404h | 404h | ETWS | NTT DoCoMo | yamashitahi@s1.nttdocomo.co.jp | Rel-8 | CP-40 | Kimmo | 29.168 | PCG-21 |  |  |  |
| 531 | 160.5 | ETWS primary notification message definition in GERAN |  | 47d? | 2009-03-12 A | 2009-05-15 A | 100% |  | 2009-03-12 | 2009-05-15 | 47d? |  | finish no earlier than 2009-05-15 | G2 | 376h | 376h | ETWS | Ericsson | claes-goran.persson@ericsson.com | Rel-8 | SP-43 | Gert | 44.018, 44.060 | PCG-22 |  |  |  |
| 532 | 161 | Conformance Test Aspects – UMTS Earthquake and Tsunami Warning System (ETWS) FDD |  | 207d? | 2009-05-29 A | 2010-03-12 | 5% | 196.65d? | 2009-05-29 | 2010-03-12 | 207d? | 656d | finish no earlier than 2010-03-12 | R5 | 1656h | 82.8h | ETWS_UMTS_UEConTestFDD | NTT DoCoMo | Makoto Ito (itohm@nttdocomo.co.jp) | Rel-8 | RP-44 | Ingo | 34.108, 34.123-1, 34.123-2, 34.123-3 | PCG-23 | RP-090724 |  |  |
| 533 | 162 | **In Case of Emergency numbers storage and easy access on UICC** |  | 519d? | 2007-03-13 A | 2009-03-06 A | 100% |  | 2007-03-13 | 2009-03-06 | 519d? |  |  | S1,C6 | 8864h | 8864h | ICE | Vodafone | armin.toepfer@vodafone.com | Rel-8 | SP-38 | Alain |  | PCG-21 |  |  |  |
| 534 | 162.1 | Stage 1 for ICE |  | 262d? | 2007-03-13 A | 2008-03-12 A | 100% |  | 2007-03-13 | 2008-03-12 | 262d? |  | finish no earlier than 2008-03-12 | S1 | 2096h | 2096h | ICE | Vodafone | armin.toepfer@vodafone.com | Rel-8 | SP-38 | Alain | 22.030, 22.101 | PCG-21 |  |  |  |
| 535 | 162.2 | CT6 aspects of ICE |  | 519d? | 2007-03-13 A | 2009-03-06 A | 100% |  | 2007-03-13 | 2009-03-06 | 519d? |  | finish no earlier than 2009-03-06 | C6 | 4152h | 4152h | ICE | Vodafone | armin.toepfer@vodafone.com | Rel-8 | SP-38 | Xavier | 31.102 | PCG-21 |  |  |  |
| 536 | 163 | Local Charging Zone Requirements |  | 380d? | 2006-09-28 A | 2008-03-12 A | 100% |  | 2006-09-28 | 2008-03-12 | 380d? |  | finish no earlier than 2006-12-07 | S1 | 3040h | 3040h | LCZR | China Mobile | liuhongyfw@chinamobile.com | Rel-8 |  | Alain | 22.115 |  |  |  |  |
| 537 | 164 | **Customized Alerting Tone (CAT) Service** |  | 729d? | 2006-12-06 A | 2009-09-18 A | 100% |  | 2006-12-06 | 2009-09-18 | 729d? |  |  | S1,C1,C3,C4 | 12302h | 12302h | CAT | China Mobile | fenglingjuan@chinamobile.com | Rel-8 |  | Alain |  |  |  |  |  |
| 538 | 164.1 | Stage 1 for CAT |  | 207d? | 2006-12-06 A | 2007-09-20 A | 100% |  | 2006-12-06 | 2007-09-20 | 207d? |  | start no earlier than 2006-12-06 | S1 | 1656h | 1656h | CAT | China Mobile | fenglingjuan@chinamobile.com | Rel-8 | SP-37 | Alain | 22.182 |  |  |  |  |
| 539 | 164.2 | TISPAN requirements for customized multimedia information services |  | 71d? | 2007-09-03 A | 2007-12-10 A | 100% |  | 2007-09-03 | 2007-12-10 | 71d? |  | finish no earlier than 2007-12-10 | S1 | 568h | 568h | TISCMI | China Mobile | fenglingjuan@chinamobile.com | Rel-8 | SP-37 | Alain | 22.182 |  |  |  |  |
| 540 | 164.3 | IMS CAT Supplementary Service |  | 164d? | 2008-04-21 A | 2008-12-04 A | 100% |  | 2008-04-21 | 2008-12-04 | 164d? |  | finish no earlier than 2008-12-05 | C1 | 1312h | 1312h | CAT-SS | Nortel | milanpa@nortel.com | Rel-8 | CP-39 | Frederic | 24.182 | PCG-21 |  |  |  |
| 541 | 164.4 | CAT solution for voice and video call in CS domain |  | 389.8d? | 2008-03-12 A | 2009-09-18 A | 100% |  | 2008-03-12 | 2009-09-18 | 389.8d? |  | finish no earlier than 2009-09-11 | C3 | 3118.4h | 3118.4h | CAT-SS | Nortel | milanpa@nortel.com | Rel-8 | CP-39 | Gwiho | 29.163 | PCG-21 |  |  |  |
| 542 | 164.5 | CAT Service in 3GPP CS domain |  | 126d? | 2008-09-12 A | 2009-03-06 A | 100% |  | 2008-09-12 | 2009-03-06 | 126d? |  | finish no earlier than 2009-03-06 | C4 | 1008h | 1008h | CAT-3G_CS | China Mobile | zhaoyuyi@chinamobile.com | Rel-8 | CP-41 | Kimmo | 23.205, 23.231, 29.002 | PCG-21 |  |  |  |
| 543 | 164.6 | CAT Service in 3GPP CS domain |  | 57.95d? | 2008-09-12 A | 2008-12-05 A | 100% |  | 2008-09-12 | 2008-12-05 | 57.95d? |  | start no earlier than 2008-09-12 | C1 | 463.6h | 463.6h | CAT-3G_CS | China Mobile | zhaoyuyi@chinamobile.com | Rel-8 | CP-41 | Frederic | 24.008, 23.014 | PCG-21 |  |  |  |
| 544 | 165 | **Service-Level Interworking for Messaging Services** |  | 509d? | 2007-03-26 A | 2009-03-06 A | 100% |  | 2007-03-26 | 2009-03-06 | 509d? |  |  | S1,S2,C3,C1 | 8584h | 8584h | MESSIW | Huawei | ling.liu@huawei.com; duanxiaoqin@huawei.com | Rel-8 |  | Alain |  |  |  |  |  |
| 545 | 165.1 | Stage 1 for MESSIW | milestone | 0d? | 2007-03-26 A | 2007-03-26 A | 100% |  | 2007-03-26 | 2007-03-26 | 0d? |  | finish no earlier than 2007-12-01 | S1 |  |  | MESSIW | Huawei | ling.liu@huawei.com | Rel-8 |  | Alain | 22.105, 22.340 |  |  |  |  |
| 546 | 165.2 | Stage 2 for MESSIW |  | 227d? | 2007-04-26 A | 2008-03-07 A | 100% |  | 2007-04-26 | 2008-03-07 | 227d? |  | finish no earlier than 2008-03-07 | S2 | 1816h | 1816h | MESSIW | Huawei | patrice.hede@huawei.com | Rel-8 |  | Maurice | 23.811, 23.204 |  |  |  |  |
| 547 | 165.3 | Stage 3 for MESSIW |  | 201d? | 2008-05-30 A | 2009-03-06 A | 100% |  | 2008-05-30 | 2009-03-06 | 201d? |  | finish no earlier than 2008-12-05 | C3 | 1608h | 1608h | MESSIW | Huawei | xupeili@huawei.com | Rel-8 | CP-40 | Gwiho | 29.311 | PCG-21 |  |  |  |
| 548 | 165.4 | Stage 3 for MESSIW |  | 136d? | 2008-05-30 A | 2008-12-05 A | 100% |  | 2008-05-30 | 2008-12-05 | 136d? |  | finish no earlier than 2008-12-12 | C1 | 1088h | 1088h | MESSIW | Huawei | xupeili@huawei.com | Rel-8 | CP-40 | Frederic | 24.229 | PCG-21 |  |  |  |
| 549 | 166 | **Multimedia Priority Service** |  | 858d? | 2006-06-08 A | 2009-09-18 A | 100% |  | 2006-06-08 | 2009-09-18 | 858d? |  |  | S1,C1,C3,C4 | 22424h | 22424h | PRIOR | Telcordia | jgarraha@telcordia.com | Rel-8 | SP-34 | Alain |  |  |  |  |  |
| 550 | 166.1 | Service Requirements for PRIOR |  | 391d? | 2006-06-08 A | 2007-12-06 A | 100% |  | 2006-06-08 | 2007-12-06 | 391d? |  | finish no earlier than 2007-11-30 | S1 | 3128h | 3128h | PRIOR-EMR | Telcordia | jgarraha@telcordia.com | Rel-8 | SP-32 | Alain | 22.153 |  |  |  |  |
| 551 | 166.2 | Stage 3 for PRIOR |  | 732d? | 2006-12-01 A | 2009-09-18 A | 100% |  | 2006-12-01 | 2009-09-18 | 732d? |  | finish no earlier than 2009-09-18 | C1 | 5856h | 5856h | PRIOR | Alcatel-Lucent | Keith Drage (drage@alcatel-lucent.com) | Rel-8 | CP-34 | Frederic | 24.229 |  |  |  |  |
| 552 | 166.3 | Deleted - Stage 3 for PRIOR |  | 441d? | 2007-09-21 A | 2009-05-29 A | 100% |  | 2007-09-21 | 2009-05-29 | 441d? |  | finish no earlier than 2009-05-29 | C3 | 3528h | 3528h | PRIOR | Alcatel-Lucent | Keith Drage (drage@alcatel-lucent.com) | Rel-8 | CP-37 | Gwiho | 29.212, 29.213, 29.214, 29.163 |  |  | PCG-23 | CP-44 |
| 553 | 166.4 | Stage 3 for PRIOR |  | 381d? | 2007-09-21 A | 2009-03-06 A | 100% |  | 2007-09-21 | 2009-03-06 | 381d? |  | finish no earlier than 2009-03-06 | C4 | 3048h | 3048h | PRIOR | Alcatel-Lucent | Keith Drage (drage@alcatel-lucent.com) | Rel-8 | CP-37 | Kimmo | 23.008, 29.228, 29.229 |  |  |  |  |

Notes:
- 526: SP#43 GERAN task included. Larger scope Feature UID_380057 (PWS) moved to Rel-9
- 527: SP#39 completed
- 528: SP#41 completed . SP#40 exception to Sep 2008 on impacts of adding the CBC to MME interface.
- 529: CP#42 completed. WID updated CP-080318=>CP-080659=>CP-080951
- 530: CP#42 completed. WID updated CP-080318=>CP-080659=>CP-080951
- 531: SP#44 completed with CT1 help (GERAN2 LS_in SP-090154)
- 532: Testing for Rel-8 ETWS UID_370051
- 533: CP#43 completed (ICE Graphics not included in Rel-8)
- 534: SP#39 Stage 1 completed
- 535: CP#43 completed (ICE Graphics not in Rel-8 / not explicitly in SA1 WID either)
- 536: SP#39 Stage 1 completed
- 537: CP#45 completed
- 538: -
- 539: SP#38 completed
- 540: CP#42 completed. CP#41 WID updated CP-080074=>CP-080496.
- 541: CP#45 completed. CP#44 sent LS to ITU-T (CP-090501) request to specify explicit parameter for CAT signalling and APM container for 3GPP to define the contents. Triggered by Study UID_360031 (FS_CAT_VVC_CS) TR 29.882
- 542: CP#43 completed. Triggered by Study UID_360031 (FS_CAT_VVC_CS) TR 29.882.
- 543: Triggered by Study UID_360031 (FS_CAT_VVC_CS) TR 29.882. CP#42 completed
- 544: CP#43 completed. SP#39 Stage 2 completed
- 545: SP#35 completed
- 546: SP#39 completed
- 547: CP#43 completed
- 548: CP#42 completed. WID updated CP-080391=>CP-080575=>CP-080773
- 549: CP#45 completed. SP#38 Stage 1 completed. No Stage 2 identified
- 550: SP#38 completed
- 551: CP#45 completed
- 552: CP#44 closed (Reason: No Rel-8 solution expected (LS sent to SA2, but not prioritized in SA2)
- 553: CP#43 completed

| ID | WBS | Task | Duration | Start | Finish | Complete | Baseline start | Baseline finish | Baseline duration | Constraint | Resources | Work | Actual work | Text1 | Text4 | Text5 | Text6 | Text8 | Text3 | Text7 | Text2 | Text9 | Text12 |
| --- | --- | --- | --- | --- | --- | --- | --- | --- | --- | --- | --- | --- | --- | --- | --- | --- | --- | --- | --- | --- | --- | --- | --- |
| 554 | 167 | **OSA Rel-8** | 202d? | 2007-08-23 A | 2008-05-30 A | 100% | 2007-08-23 | 2008-05-30 | 202d? |  | S1,C5 | 23552h | 23552h | OSA8 | Orange | Song Dong | Rel-8 | Alain |  |  |  |  |  |
| 555 | 167.1 | OSA Stage 1 - Service Requirements | 145d? | 2007-08-23 A | 2008-03-12 A | 100% | 2007-08-23 | 2008-03-12 | 145d? | finish no earlier than 2007-12-04 | S1 | 1160h | 1160h | OSA8 | Orange, AePONA | Song Dong | Rel-8 | Alain | 22.127 |  |  |  |  |
| 556 | 167.2 | OSA Stage 1 - NGN Service Requirement | 140d? | 2007-09-03 A | 2008-03-14 A | 100% | 2007-09-03 | 2008-03-14 | 140d? | finish no earlier than 2008-03-14 | S1 | 1120h | 1120h | OSA8-IMS | Orange | Song Dong | Rel-8 | Alain | 22.127 | SP-37 |  |  |  |
| 557 | 167.3 | **OSA Stage 2/3 enhancements** | 157d? | 2007-10-25 A | 2008-05-30 A | 100% | 2007-10-25 | 2008-05-30 | 157d? |  | C5 | 20016h | 20016h | OSA8 | Alcatel-Lucent | unmehopa@alcatel-lucent.com | Rel-8 | Kimmo | 23.198, 29.198, 29.199 |  |  |  |  |
| 558 | 167.3.1 | Delete - Ensure Parlay-X composable with identity management frameworks, in particular Liberty Alliance | 157d? | 2007-10-25 A | 2008-05-30 A | 100% | 2007-10-25 | 2008-05-30 | 157d? | finish no earlier than 2008-12-25 | C5 | 1256h | 1256h | OSA8 | Ericsson, FT/Orange, Sprint, Telecom Italia | catherine.mulligan@ericsson.com | Rel-8 | Kimmo | existing 29.199-xy | CP-37 | PCG-21 | PCG-21 | CP-40 |
| 559 | 167.3.2 | Parlay-X Content Management web service (store/manage meta-data) | 157d? | 2007-10-25 A | 2008-05-30 A | 100% | 2007-10-25 | 2008-05-30 | 157d? | finish no earlier than 2008-12-04 | C5 | 1256h | 1256h | OSA8 | Alcatel-Lucent | unmehopa@alcatel-lucent.com | Rel-8 | Kimmo | 29.199-21 | CP-37 |  |  |  |
| 560 | 167.3.3 | Parlay-X Policy web service | 157d? | 2007-10-25 A | 2008-05-30 A | 100% | 2007-10-25 | 2008-05-30 | 157d? | finish no earlier than 2008-12-04 | C5 | 1256h | 1256h | OSA8 | Alcatel-Lucent | unmehopa@alcatel-lucent.com | Rel-8 | Kimmo | 29.199-22 | CP-37 |  |  |  |
| 561 | 167.3.4 | Parlay-X Terminal status web service | 157d? | 2007-10-25 A | 2008-05-30 A | 100% | 2007-10-25 | 2008-05-30 | 157d? | finish no earlier than 2008-05-30 | C5 | 1256h | 1256h | OSA8 | Alcatel-Lucent | unmehopa@alcatel-lucent.com | Rel-8 | Kimmo | 29.199-08 | CP-37 |  |  |  |
| 562 | 167.3.5 | Delete - Identify communication format used by a particular application | 157d? | 2007-10-25 A | 2008-05-30 A | 100% | 2007-10-25 | 2008-05-30 | 157d? | finish no earlier than 2008-05-30 | C5 | 1256h | 1256h | OSA8 | Ericsson | catherine.mulligan@ericsson.com | Rel-8 | Kimmo | existing 29.199-xy | CP-37 | PCG-21 | PCG-21 | CP-40 |
| 563 | 167.3.6 | Delete - Security on User Profile Management - reuse GUP API (22.127 CR 0084 S1-071794) | 128d? | 2007-12-05 A | 2008-05-30 A | 100% | 2007-12-05 | 2008-05-30 | 128d? | finish no earlier than 2008-12-25 | C5 | 1024h | 1024h | OSA8 | Telecom Italia | vincenzo.amorino@telecomitalia.it | Rel-8 | Kimmo | PXWS Framework | CP-38 | PCG-21 | PCG-21 | CP-40 |
| 564 | 167.3.7 | Delete - Privacy on Subscriber Identity (Liberty Alliance, OASIS) (22.127 CR 0085 S1-071835) | 128d? | 2007-12-05 A | 2008-05-30 A | 100% | 2007-12-05 | 2008-05-30 | 128d? | finish no earlier than 2008-12-25 | C5 | 1024h | 1024h | OSA8 | Telecom Italia | vincenzo.amorino@telecomitalia.it | Rel-8 | Kimmo | PXWS Framework | CP-38 | PCG-21 | PCG-21 | CP-40 |
| 565 | 167.3.8 | Delete - Topology Hiding (22.127 CR 0086 S1-071838) | 128d? | 2007-12-05 A | 2008-05-30 A | 100% | 2007-12-05 | 2008-05-30 | 128d? | finish no earlier than 2008-12-25 | C5 | 1024h | 1024h | OSA8 | Telecom Italia | vincenzo.amorino@telecomitalia.it | Rel-8 | Kimmo | PXWS Framework | CP-38 | PCG-21 | PCG-21 | CP-40 |
| 566 | 167.3.9 | Delete - Subscriber event notification (22.127 CR 0087 S1-071836) | 128d? | 2007-12-05 A | 2008-05-30 A | 100% | 2007-12-05 | 2008-05-30 | 128d? | finish no earlier than 2008-12-25 | C5 | 1024h | 1024h | OSA8 | Telecom Italia | vincenzo.amorino@telecomitalia.it | Rel-8 | Kimmo | PXWS Framework | CP-38 | PCG-21 | PCG-21 | CP-40 |
| 567 | 167.3.10 | Delete - Event notification (22.127 CR 0088 S1-071762) | 128d? | 2007-12-05 A | 2008-05-30 A | 100% | 2007-12-05 | 2008-05-30 | 128d? | finish no earlier than 2008-12-25 | C5 | 1024h | 1024h | OSA8 | Telecom Italia | vincenzo.amorino@telecomitalia.it | Rel-8 | Kimmo | PXWS Framework | CP-38 | PCG-21 | PCG-21 | CP-40 |
| 568 | 167.3.11 | Delete - Access policy (22.127 CR 0089 S1-071763) | 128d? | 2007-12-05 A | 2008-05-30 A | 100% | 2007-12-05 | 2008-05-30 | 128d? | finish no earlier than 2008-12-25 | C5 | 1024h | 1024h | OSA8 | Telecom Italia | vincenzo.amorino@telecomitalia.it | Rel-8 | Kimmo | PXWS Framework | CP-38 | PCG-21 | PCG-21 | CP-40 |
| 569 | 167.3.12 | Delete - API usage accounting (22.127 CR 0090 S1-071792) | 128d? | 2007-12-05 A | 2008-05-30 A | 100% | 2007-12-05 | 2008-05-30 | 128d? | finish no earlier than 2008-12-25 | C5 | 1024h | 1024h | OSA8 | Telecom Italia | vincenzo.amorino@telecomitalia.it | Rel-8 | Kimmo | PXWS Framework | CP-38 | PCG-21 | PCG-21 | CP-40 |
| 570 | 167.3.13 | Presence alignment with OMA and IETF (22.127 CR 0092 S1-071764) | 128d? | 2007-12-05 A | 2008-05-30 A | 100% | 2007-12-05 | 2008-05-30 | 128d? | finish no earlier than 2008-05-30 | C5 | 1024h | 1024h | OSA8 | Alcatel-Lucent | unmehopa@alcatel-lucent.com | Rel-8 | Kimmo | 29.199-14/13 | CP-38 | PCG-21 |  |  |
| 571 | 167.3.14 | Delete - Service identification (22.127 CR 0095 S1-071837) | 128d? | 2007-12-05 A | 2008-05-30 A | 100% | 2007-12-05 | 2008-05-30 | 128d? | finish no earlier than 2008-05-30 | C5 | 1024h | 1024h | OSA8 | Ericsson | catherine.mulligan@ericsson.com | Rel-8 | Kimmo | existing 29.199-xy | CP-38 | PCG-21 | PCG-21 | CP-40 |
| 572 | 167.3.15 | Framework Enterprise Operator (Service Subscription function) | 102d? | 2008-01-10 A | 2008-05-30 A | 100% | 2008-01-10 | 2008-05-30 | 102d? | finish no earlier than 2008-05-30 | C5 | 816h | 816h | OSA8 | Alcatel-Lucent | unmehopa@alcatel-lucent.com | Rel-8 | Kimmo | 29.198-03 | CP-39 | PCG-21 |  |  |
| 573 | 167.3.16 | Mobility Emergency Location | 102d? | 2008-01-10 A | 2008-05-30 A | 100% | 2008-01-10 | 2008-05-30 | 102d? | finish no earlier than 2008-05-30 | C5 | 816h | 816h | OSA8 | Alcatel-Lucent | unmehopa@alcatel-lucent.com | Rel-8 | Kimmo | 29.198-06 | CP-39 | PCG-21 |  |  |
| 574 | 167.3.17 | Connectivity Manager SCF | 102d? | 2008-01-10 A | 2008-05-30 A | 100% | 2008-01-10 | 2008-05-30 | 102d? |  | C5 | 816h | 816h | OSA8 | Alcatel-Lucent | unmehopa@alcatel-lucent.com | Rel-8 | Kimmo | 29.198-10 | CP-39 | PCG-21 |  |  |
| 575 | 167.3.18 | PAM Presence Agent | 102d? | 2008-01-10 A | 2008-05-30 A | 100% | 2008-01-10 | 2008-05-30 | 102d? | finish no earlier than 2008-05-30 | C5 | 816h | 816h | OSA8 | Alcatel-Lucent | unmehopa@alcatel-lucent.com | Rel-8 | Kimmo | 29.198-14 | CP-39 | PCG-21 |  |  |
| 576 | 168 | **Paging Permission with Access Control (PPACR)** | 389d? | 2007-06-12 A | 2008-12-05 A | 100% | 2007-06-12 | 2008-12-05 | 389d? |  | S1,C1 | 5888h | 5888h | PPACR | NTT DoCoMo | Morita Takashi | Rel-8 | Alain |  |  |  |  |  |
| 577 | 168.1 | Stage 1 for PPACR | 69d? | 2007-06-12 A | 2007-09-14 A | 100% | 2007-06-12 | 2007-09-14 | 69d? | finish no earlier than 2007-09-14 | S1 | 552h | 552h | PPACR-S1 | NTT DoCoMo | Morita Takashi | Rel-8 | Alain | 22.011 | SP-37 |  |  |  |
| 578 | 168.2 | Stage 3 for PPACR (CT1) | 278d? | 2007-11-14 A | 2008-12-05 A | 100% | 2007-11-14 | 2008-12-05 | 278d? | finish no earlier than 2008-12-05 | C1 | 2224h | 2224h | PPACR-CT1 | NTT DoCoMo |  | Rel-8 | Frederic | 24.008, 23.122, 24.301 | CP-38 | PCG-21 |  |  |

Notes:
- 554: TSG#40 completed. New OSA work in OMA. SA1 need to remove unfulfilled Requirements to align with CT5 Stage 2/3 reality.
- 555: TSG#40 New OSA work in OMA. SA1 to remove non-fulfilled Requirements.
- 556: TSG#40 New OSA work in OMA. SA1 to remove non-fulfilled Requirements.
- 557: CP#40 WID updated CP-070349=>CP-080252. Started work completed. Unfulfilled Rel-8 Stage 1 and New OSA work to be done in OMA. SA1 needs to remove non-fulfilled requirements in 22.127
- 558: CP#40: Work moved to OMA
- 559: CP#40 completed
- 560: CP#40 completed
- 561: CP#40 completed
- 562: CP#40: Work moved to OMA
- 563: SP#38 SP-070853 R8 CRs 22.127 OSA Stage 1. CP#40: Work moved to OMA
- 564: SP#38 SP-070853 R8 CRs 22.127 OSA Stage 1. CP#40: Work moved to OMA
- 565: SP#38 SP-070853 R8 CRs 22.127 OSA Stage 1. CP#40: Work moved to OMA
- 566: SP#38 SP-070853 R8 CRs 22.127 OSA Stage 1. CP#40: Work moved to OMA
- 567: SP#38 SP-070853 R8 CRs 22.127 OSA Stage 1. CP#40: Work moved to OMA
- 568: SP#38 SP-070853 R8 CRs 22.127 OSA Stage 1. CP#40: Work moved to OMA
- 569: SP#38 SP-070853 R8 CRs 22.127 OSA Stage 1. CP#40: Work moved to OMA
- 570: CP#40 completed
- 571: SP#38 SP-070853 R8 CRs 22.127 OSA Stage 1. CP#40: Work moved to OMA
- 572: CP#40 completed
- 573: CP#40 completed
- 574: CP#40 completed
- 575: CP#40 completed
- 576: CP#42 completed. Triggered by Study UID_330016 (PPAC).
- 577: SP#37 completed
- 578: CP#42 completed

| ID | WBS | Task | Duration | Start | Finish | Complete | Remaining | Baseline start | Baseline finish | Baseline duration | Total slack | Constraint | Resources | Work | Actual work | Text1 | Text2 | Text4 | Text6 | Text7 | Text8 | Text11 |
| --- | --- | --- | --- | --- | --- | --- | --- | --- | --- | --- | --- | --- | --- | --- | --- | --- | --- | --- | --- | --- | --- | --- |
| 579 | 169 | **Charging for multi-phases services** | 70d? | 2007-12-06 A | 2008-03-12 A | 100% |  | 2007-12-06 | 2008-03-12 | 70d? |  |  | S1 | 560h | 560h | CHRGMPH | PCG-21 | Telecom Italia | Rel-8 | SP-38 | Alain |  |
| 580 | 169.1 | Stage 1 for CHRGMPH | 70d? | 2007-12-06 A | 2008-03-12 A | 100% |  | 2007-12-06 | 2008-03-12 | 70d? |  | start no earlier than 2007-12-06 | S1 | 560h | 560h | CHRGMPH-s1 | PCG-21 | Telecom Italia | Rel-8 | SP-38 | Alain |  |
| 581 | 170 | **Home NodeB / eNodeB** | 327d? | 2007-12-06 A | 2009-03-06 A | 100% |  | 2007-12-06 | 2009-03-06 | 327d? |  |  | S1,C1,C4 | 5720h | 5720h | HomeNB | PCG-21 | Vodafone | Rel-8 | SP-38 | Alain |  |
| 582 | 170.1 | Stage 1 for HNB_eHNB | 70d? | 2007-12-06 A | 2008-03-12 A | 100% |  | 2007-12-06 | 2008-03-12 | 70d? |  | start no earlier than 2007-12-06 | S1 | 560h | 560h | HomeNB-S1 | PCG-21 | Vodafone | Rel-8 | SP-38 | Alain |  |
| 583 | 170.2 | CSG and Idle Mode Mobility for LTE Home eNodeB | 126d? | 2008-09-12 A | 2009-03-06 A | 100% |  | 2008-09-12 | 2009-03-06 | 126d? |  | finish no earlier than 2009-03-06 | C1 | 1008h | 1008h | HomeNB-LTE | PCG-21 | Huawei | Rel-8 | CP-41 | Frederic |  |
| 584 | 170.3 | CSG and Idle Mode Mobility for 3G Home NodeB | 126d? | 2008-09-12 A | 2009-03-06 A | 100% |  | 2008-09-12 | 2009-03-06 | 126d? |  | finish no earlier than 2009-03-06 | C1 | 1008h | 1008h | HomeNB-3G | PCG-21 | Qualcomm Europe | Rel-8 | CP-41 | Frederic |  |
| 585 | 170.4 | Support of Closed Subscriber Group (CSG) | 66d? | 2008-12-05 A | 2009-03-06 A | 100% |  | 2008-12-05 | 2009-03-06 | 66d? |  | finish no earlier than 2009-03-06 | C4 | 528h | 528h | HomeNB | PCG-22 | CT#42 | Rel-8 | CP-42 | Kimmo | CT#42 report |
| 586 | 171 | **UTRA HNB** | 326d? | 2008-03-07 A | 2009-06-04 A | 100% |  | 2008-03-07 | 2009-06-04 | 326d? |  |  | RP,S5 | 6832h | 6832h | HNB | PCG-21 |  | Rel-8 | SP-39 | Stefania |  |
| 587 | 171.1 | Support of UTRA HNB | 201d? | 2008-05-30 A | 2009-03-06 A | 100% |  | 2008-05-30 | 2009-03-06 | 201d? |  | finish no earlier than 2009-03-06 | R2 | 1608h | 1608h | HNB-supp | PCG-21 | Huawei | Rel-8 | SP-40 | Joern | RP-090040 |
| 588 | 171.2 | FDD Home NodeB RF requirements | 261d? | 2008-03-07 A | 2009-03-06 A | 100% |  | 2008-03-07 | 2009-03-06 | 261d? |  | finish no earlier than 2009-03-06 | R4 | 2088h | 2088h | HNB-RF | PCG-21 | Motorola | Rel-8 | SP-39 | Stefania | RP-090041 |
| 589 | 171.3 | UTRAN Architecture for 3G HNB | 136d? | 2008-05-30 A | 2008-12-05 A | 100% |  | 2008-05-30 | 2008-12-05 | 136d? |  | finish no earlier than 2008-12-05 | R3 | 1088h | 1088h | HNB-arch | PCG-21 | Alcatel-Lucent | Rel-8 | SP-40 | Juha | RP-090042 |
| 590 | 171.4 | 3G Home NodeB OAM&P Type 1 Management Interface | 127d? | 2008-12-11 A | 2009-06-04 A | 100% |  | 2008-12-11 | 2009-06-04 | 127d? |  | finish no earlier than 2009-06-04 | S5 | 1008h | 1008h | HNB-3G_OAM | PCG-22 | Huawei | Rel-8 | SP-42 | Dionisio |  |
| 591 | 172 | **UTRA HNB – UE Conformance Testing** | 197d? | 2009-03-06 A | 2009-12-04 | 30% | 137.9d? | 2009-03-06 | 2009-12-04 | 197d? | 726d |  | R5 | 3144h | 943.2h | HNB-UEConTest | PCG-22 |  | Rel-8 | RP-43 | Ingbert |  |
| 592 | 172.1 | Conformance Test Aspects – UTRA HNB (FDD) | 196d? | 2009-03-06 A | 2009-12-04 | 30% | 137.2d? | 2009-03-06 | 2009-12-04 | 196d? | 726d | finish no earlier than 2009-12-04 | R5 | 1568h | 470.4h | HNB-UEConTestFDD | PCG-22 | Huawei | Rel-8 | RP-43 | Ingbert | RP-090719 |
| 593 | 173 | Lawful Interception in the 3GPP Rel-8 | 524d? | 2007-03-12 A | 2009-03-12 A | 100% |  | 2007-03-12 | 2009-03-12 | 524d? |  | finish no earlier than 2009-03-12 | S3 | 4192h | 4192h | LI8 |  | BMWI, Verizon | Rel-8 |  | Dionisio |  |
| 594 | 174 | **Generic Bootstrapping Architecture Push Function** | 258d? | 2008-03-12 A | 2009-03-06 A | 100% |  | 2008-03-12 | 2009-03-06 | 258d? |  |  | S3,C1,C4 | 6468.8h | 6468.8h | GBAPush | PCG-21 | Ericsson | Rel-8 | SP-39 | Dionisio |  |
| 595 | 174.1 | SA3 part of GBAPush (33.223) | 193d? | 2008-03-12 A | 2008-12-05 A | 100% |  | 2008-03-12 | 2008-12-05 | 193d? |  | finish no earlier than 2008-12-05 | S3 | 1544h | 1544h | GBAPush | PCG-21 | Ericsson | Rel-8 | SP-39 | Dionisio |  |
| 596 | 174.2 | CT1 part of GBAPush | 178.8d? | 2008-03-12 A | 2009-03-06 A | 100% |  | 2008-03-12 | 2009-03-06 | 178.8d? |  | finish no earlier than 2009-03-06 | C1 | 1430.4h | 1430.4h | GBAPush | PCG-21 | Ericsson | Rel-8 | SP-39 | Frederic |  |
| 597 | 174.3 | CT4 part of GBAPush | 178.8d? | 2008-03-12 A | 2009-03-06 A | 100% |  | 2008-03-12 | 2009-03-06 | 178.8d? |  | finish no earlier than 2009-03-06 | C4 | 1430.4h | 1430.4h | GBAPush | PCG-21 | Ericsson | Rel-8 | SP-39 | Kimmo |  |
| 598 | 175 | Requirements and Test methods for Wideband Terminals | 197d? | 2008-03-12 A | 2008-12-11 A | 100% |  | 2008-03-12 | 2008-12-11 | 197d? |  | start no earlier than 2008-03-12 | S4 | 1576h | 1576h | RETEM_WB_T |  | FT, Ericsson | Rel-8 |  | Paolo |  |
| 599 | 176 | Extending PSS and MBMS User Services for optimized Mobile TV | 266d? | 2007-12-06 A | 2008-12-11 A | 100% |  | 2007-12-06 | 2008-12-11 | 266d? |  | finish no earlier than 2008-12-11 | S4 | 2128h | 2128h | PSS_MBMS_OMTV |  | Ericsson | Rel-8 |  | Paolo |  |
| 600 | 177 | **Encoding formats, transport formats and media description signalling for interworking, QoE, and other enhancements to MTSI-MHI** | 331d? | 2007-12-06 A | 2009-03-12 A | 100% |  | 2007-12-06 | 2009-03-12 | 331d? |  |  | S4,C3,C1,C4 | 9640h | 9640h | MTSI_eMHI | PCG-21 | Ericsson, Qualcomm Europe | Rel-8 | SP-40 | Paolo |  |
| 601 | 177.1 | MTSI Video - Dynamic Rate Adaptation/Signalling of Image Size | 331d? | 2007-12-06 A | 2009-03-12 A | 100% |  | 2007-12-06 | 2009-03-12 | 331d? |  | finish no earlier than 2009-03-12 | S4 | 2648h | 2648h | MTSI_eMHI-DRASIS |  | Qualcomm Europe, Samsung | Rel-8 |  | Paolo |  |
| 602 | 177.2 | CT3 part of Enhancement of interworking between MTSI and CS networks | 201d? | 2008-05-30 A | 2009-03-06 A | 100% |  | 2008-05-30 | 2009-03-06 | 201d? |  | finish no earlier than 2009-03-06 | C3 | 1608h | 1608h | MTSI_eMHI | PCG-21 | Huawei | Rel-8 | CP-40 | Gwiho |  |
| 603 | 177.3 | CT1 part of Enhancement of interworking between MTSI and CS networks | 141d? | 2008-05-30 A | 2008-12-12 A | 100% |  | 2008-05-30 | 2008-12-12 | 141d? |  | start no earlier than 2008-05-30 | C1 | 1128h | 1128h | MTSI_eMHI | PCG-21 | Huawei | Rel-8 | CP-40 | Frederic |  |
| 604 | 177.4 | CT4 part of Enhancement of interworking between MTSI and CS networks | 201d? | 2008-05-30 A | 2009-03-06 A | 100% |  | 2008-05-30 | 2009-03-06 | 201d? |  | finish no earlier than 2009-03-06 | C4 | 1608h | 1608h | MTSI_eMHI | PCG-21 | Huawei | Rel-8 | CP-40 | Kimmo |  |

Notes:
- 579: SP#39 Stage 1 completed / Text3: 22.115 / Text5: Marco.DeLuca1@telecomitalia.it
- 580: SP#39 completed / Text3: 22.115 / Text5: Marco.DeLuca1@telecomitalia.it
- 581: CP#43 completed. SP#39 Stage 1 completed / Text5: John Watson
- 582: SP#39 completed / Text3: 22.011, 22.115 / Text5: John Watson
- 583: CP#43 completed / Text3: 23.122, 24.301, 24.801, 24.285 / Text5: zhang.peng@huawei.com
- 584: CP#43 completed / Text3: 23.122, 24.008, 24.285 / Text5: Osok Song
- 585: CP#43 completed. SP#42 SP-080874 22.011CR0141 confirmed Requirement to support roaming subscribers with CSG home network subscription but did NOT confirmed requirement for home network independent support of roamers in CSG / Text3: 29.002, 29.272, 23.008, 23.003 / Text5: Hannu Hietalahti
- 586: RP#43 completed. SP#44 completed
- 587: RP#43 completed. RP#41 WID updated RP-080483=>RP-080752. / Text3: 25.304, 25.306, 25.331, 25.367 / Text5: Yang Xudong (yangxudong@huawei.com)
- 588: RP#43 completed / Text3: 25.104, 25.141, 25.967 / Text5: Ying Cai (yingcai@motorola.com)
- 589: RP#42 completed / Text3: 25.401, 25.410, 25.412, 25.413, 25.414, 25.415, 25.467, 25.468, 25.469 / Text5: Martin Warner (mw15@alcatel-lucent.com)
- 590: SP#44 completed. Complements work in BroadBand Forum / Text3: 32.581, 32.582, 32.583, 32.584 / Text5: Zou Lan (zlan@huawei.com)
- 591: Testing for Feature UID_390033 UTRA HNB
- 592: Testing for Feature UID_390033 UTRA HNB / Text3: 34.108, 34.123-1, 34.123-2, 34.123-3 / Text5: Trica Li (trica_li@huawei.com)
- 593: SP#43 completed / Text3: 33.106, 33.107, 33.108 / Text5: berthold.wilhelm@bnetza.de, ron_ryan@verizon.net
- 594: CP#43 completed / Text5: Rolf Blom
- 595: SP#42 completed 33.223 as Rel-8. TS 33.224 moved to Rel-9 under new UID_420039 / Text3: 33.223 / Text5: Rolf Blom
- 596: CP#43 completed / Text3: 24.109 / Text5: Rolf Blom
- 597: CP#43 completed / Text3: 29.109 / Text5: Rolf Blom
- 598: SP#42 completed. SP#39 WID approved. / Text3: 26.131, 26.132 / Text5: stephane.ragot@orange-ftgroup.com, wanqing.shi@sonyericsson.com
- 599: SP#42 completed. SP#38 WID approved. / Text3: 26.234, 26.346, 26.946 / Text5: thorsten.lohmar@ericsson.com
- 600: TSG#43 completed / Text5: olle.franceschi@ericsson.com, nleung@qualcomm.com
- 601: SP#43 completed. SP#40 WID updated SP-070755=>SP-080246. [Feature=>BB under new Feature UID_400028 (MTSI)] / Text3: 26.114 / Text5: nleung@qualcomm.com & kyunghun.jung@samsung.com
- 602: CP#43 completed / Text3: 29.163 / Text5: Tingfang Tang (tagna_online@huawei.com)
- 603: CP#42 completed (No CT1-impact). WID updated CP-080422=>CP-080774 / Text5: Tingfang Tang (tagna_online@huawei.com)
- 604: CP#43 completed / Text3: 29.332 / Text5: Tingfang Tang (tagna_online@huawei.com)

| ID | WBS | Task | Duration | Start | Finish | Complete | Remaining | Baseline start | Baseline finish | Baseline duration | Total slack | Constraint | Resources | Work | Actual work | Text1 | Text6 | Text8 | Text4 | Text5 | Text2 | Text7 | Text9 | Text12 |
| --- | --- | --- | --- | --- | --- | --- | --- | --- | --- | --- | --- | --- | --- | --- | --- | --- | --- | --- | --- | --- | --- | --- | --- | --- |
| 605 | 178 | **OAM&P 8** | 723d? | 2007-06-07 A | 2010-03-12 | 97% | 24.17d? | 2007-06-07 | 2010-03-12 | 723d? | 656d |  | S5,C1 | 44907.2h | 39736.3h | OAM8 | Rel-8 | Dionisio |  |  |  |  |  |  |
| 606 | 178.1 | **Network Infrastructure Management** | 723d? | 2007-06-07 A | 2010-03-12 | 93% | 47.68d? | 2007-06-07 | 2010-03-12 | 723d? | 656d |  | S5 | 20584h | 17509.9h | OAM8-NIM | Rel-8 | Dionisio |  |  |  |  |  |  |
| 607 | 178.1.1 | Telecom Management Methodology | 461d? | 2007-06-07 A | 2009-03-12 A | 100% |  | 2007-06-07 | 2009-03-12 | 461d? |  | finish no earlier than 2009-03-12 | S5 | 3688h | 3688h | OAM8 | Rel-8 | Dionisio | Ericsson | thomas.tovinger@ericsson.com |  |  |  |  |
| 608 | 178.1.2 | Advanced Alarming on Itf-N | 266d? | 2007-06-07 A | 2008-06-12 A | 100% |  | 2007-06-07 | 2008-06-12 | 266d? |  | finish no earlier than 2008-12-11 | S5 | 2128h | 2128h | OAM8 | Rel-8 | Dionisio | Nokia Siemens Networks | SUERBAUM, Clemens |  |  |  |  |
| 609 | 178.1.3 | CN CS Bearer Transport Network (BTN) relative NRM | 266d? | 2007-06-07 A | 2008-06-12 A | 100% |  | 2007-06-07 | 2008-06-12 | 266d? |  | finish no earlier than 2008-12-11 | S5 | 2128h | 2128h | OAM8 | Rel-8 | Dionisio | China Mobile | LI, Jian |  |  |  |  |
| 610 | 178.1.4 | Alignment with eTOM and M.3060 architectural concepts | 210d? | 2008-02-22 A | 2008-12-11 A | 100% |  | 2008-02-22 | 2008-12-11 | 210d? |  | start no earlier than 2008-02-22 | S5 | 1680h | 1680h | OAM8 | Rel-8 | Dionisio | TeliaSonera | Berggren, Tommy | PCG-21 | SP-39 |  |  |
| 611 | 178.1.5 | IRP SOAP Solution Sets | 201d? | 2008-06-05 A | 2009-03-12 A | 100% |  | 2008-06-05 | 2009-03-12 | 201d? |  | finish no earlier than 2009-03-12 | S5 | 1608h | 1608h | OAM8 | Rel-8 | Dionisio | Ericsson | edwin.tse@ericsson.com | PCG-21 | SP-40 |  |  |
| 612 | 178.1.6 | Create missing specifications for IRP XML definitions | 122d? | 2009-09-24 | 2010-03-12 |  |  | 2009-09-24 | 2010-03-12 | 122d? | 656d | finish no earlier than 2010-03-12 | S5 | 976h |  | OAM8 | Rel-8 | Dionisio | ZTE | Shuqiang Huang (huangsq@zte.com.cn) | PCG-23 | SP-45 |  |  |
| 613 | 178.1.7 | Deleted - End point modelling for reference point | 324d? | 2007-09-17 A | 2008-12-11 A | 100% |  | 2007-09-17 | 2008-12-11 | 324d? |  | finish no earlier than 2008-12-11 | S5 | 2592h | 2592h | OAM8 | Rel-8 | Dionisio | Motorola | YAO, Yizhi |  | SP-37 | PCG-21 | SP-41 |
| 614 | 178.2 | **Performance Management** | 461d? | 2007-06-07 A | 2009-03-12 A | 100% |  | 2007-06-07 | 2009-03-12 | 461d? |  |  | S5 | 13712h | 13712h | OAM8-PM | Rel-8 | Dionisio |  |  |  |  |  |  |
| 615 | 178.2.1 | IP bearer network Performance measurement definitions | 396d? | 2007-06-07 A | 2008-12-11 A | 100% |  | 2007-06-07 | 2008-12-11 | 396d? |  | finish no earlier than 2008-12-11 | S5 | 3168h | 3168h | OAM8 | Rel-8 | Dionisio | China Mobile | lilianyuan@chinamobile.com |  |  |  |  |
| 616 | 178.2.2 | HSUPA performance measurements | 396d? | 2007-06-07 A | 2008-12-11 A | 100% |  | 2007-06-07 | 2008-12-11 | 396d? |  | finish no earlier than 2008-12-11 | S5 | 3168h | 3168h | OAM8 | Rel-8 | Dionisio | China Mobile | LI, Jian |  |  |  |  |
| 617 | 178.2.3 | Key Performance Indicators (KPIs) for UMTS and GSM | 461d? | 2007-06-07 A | 2009-03-12 A | 100% |  | 2007-06-07 | 2009-03-12 | 461d? |  | finish no earlier than 2009-03-12 | S5 | 3688h | 3688h | OAM8 | Rel-8 | Dionisio | China Mobile | Liang Shuangchun |  |  |  |  |
| 618 | 178.3 | **Trace Management** | 196d? | 2008-03-07 A | 2008-12-05 A | 100% |  | 2008-03-07 | 2008-12-05 | 196d? |  |  | S5,C1,C3,C4 | 5777.6h | 5777.6h | OAM8-Trace | Rel-8 | Dionisio |  |  |  |  |  |  |
| 619 | 178.3.1 | Service Level Tracing in IMS | 196d? | 2008-03-07 A | 2008-12-05 A | 100% |  | 2008-03-07 | 2008-12-05 | 196d? |  | finish no earlier than 2008-12-05 | C1 | 1568h | 1568h | OAM8-Trace | Rel-8 | Frederic | Vodafone | peter.dawes@vodafone.com |  |  |  |  |
| 620 | 178.3.2 | Service Level Tracing in IMS | 175.4d? | 2008-03-07 A | 2008-12-05 A | 100% |  | 2008-03-07 | 2008-12-05 | 175.4d? |  | finish no earlier than 2008-12-05 | C3 | 1403.2h | 1403.2h | OAM8-Trace | Rel-8 | Gwiho | Vodafone | peter.dawes@vodafone.com | PCG-21 | CP-40 |  |  |
| 621 | 178.3.3 | Service Level Tracing in IMS | 175.4d? | 2008-03-07 A | 2008-12-05 A | 100% |  | 2008-03-07 | 2008-12-05 | 175.4d? |  | finish no earlier than 2008-12-05 | C4 | 1403.2h | 1403.2h | OAM8-Trace | Rel-8 | Frederic | Vodafone | peter.dawes@vodafone.com | PCG-21 | CP-40 |  |  |
| 622 | 179 | **Charging Management small Enhancements** | 716d? | 2006-03-16 A | 2008-12-11 A | 100% |  | 2006-03-16 | 2008-12-11 | 716d? |  |  | S5 | 12544h | 12544h | CH8 | Rel-8 | Dionisio |  |  |  |  |  |  |
| 623 | 179.1 | Online charging correlation | 457d? | 2006-03-16 A | 2007-12-14 A | 100% |  | 2006-03-16 | 2007-12-14 | 457d? |  | start no earlier than 2006-03-16 | S5 | 3656h | 3656h | CH8 | Rel-8 | Dionisio | Orange | Chahine, Rony |  |  |  |  |
| 624 | 179.2 | SMS online charging | 137d? | 2007-06-07 A | 2007-12-14 A | 100% |  | 2007-06-07 | 2007-12-14 | 137d? |  | finish no earlier than 2007-12-14 | S5 | 1096h | 1096h | CH8 | Rel-8 | Dionisio | Vodafone | WONG, Gavin |  |  |  |  |
| 625 | 179.3 | Introduce Online Charging from SMS-SC into the SMS Charging Specifications | 61d? | 2008-09-18 A | 2008-12-11 A | 100% |  | 2008-09-18 | 2008-12-11 | 61d? |  | finish no earlier than 2008-12-11 | S5 | 488h | 488h | CH8 | Rel-8 | Dionisio | Acision | Gebler, Erik - Acision [erik.gebler (at) acision.com] | PCG-21 | SP-41 |  |  |
| 626 | 179.4 | Deleted - WLAN Offline Charging | 244d? | 2008-01-07 A | 2008-12-11 A | 100% |  | 2008-01-07 | 2008-12-11 | 244d? |  | finish no earlier than 2008-12-11 | S5 | 1952h | 1952h | CH8 | Rel-8 | Dionisio | Alcatel-Lucent | GARDELLA, Maryse | PCG-21 | SP-38 | PCG-22 | SP-42 |
| 627 | 180 | **Conferencing enhancements for Mp interface** | 266d? | 2007-11-30 A | 2008-12-05 A | 100% |  | 2007-11-30 | 2008-12-05 | 266d? |  |  | C4 | 6384h | 6384h | eMp | Rel-8 | Kimmo | Huawei | Chencheng@huawei.com | PCG-21 |  |  |  |
| 628 | 180.1 | Stage 2 for eMp | 266d? | 2007-11-30 A | 2008-12-05 A | 100% |  | 2007-11-30 | 2008-12-05 | 266d? |  | finish no earlier than 2008-12-11 | C4 | 2128h | 2128h | eMp | Rel-8 | Kimmo | Huawei | Chencheng@huawei.com | PCG-21 | CP-38 |  |  |
| 629 | 180.2 | Stage 3 for eMp | 266d? | 2007-11-30 A | 2008-12-05 A | 100% |  | 2007-11-30 | 2008-12-05 | 266d? |  | finish no earlier than 2008-12-05 | C4 | 2128h | 2128h | eMp | Rel-8 | Kimmo | Huawei | Chencheng@huawei.com | PCG-21 | CP-38 |  |  |

Notes:
- 605: -
- 606: -
- 607: SP#43 completed / Text3: 32.155, 32.153
- 608: SP#40 completed / Text3: 32.121, 32.122, 32.123
- 609: SP#40 completed / Text3: 32.632/3/5
- 610: SP#42 completed / Text3: 32.101/2, 32-series
- 611: SP#43 completed. WID updated SP-080276=>SP-090148 (removed the planned but not delivered new TSs 32.127, 32.327, 32.337, 32.357, 32.387, 32.397, 32.447) / Text3: 32.111-7, 32.617, 32.417, 32.367, 32.347, 32.111-1, 32.111-2, 32.111-3, 32.111-5, 32.307, 32.317, 32.341, 32.342, 32.343, 32.345, 32.361, 32.362, 32.363, 32.365, 32.411, 32.412, 32.413, 32.415, 32.611, 32.612, 32.613, 32.615, 32.625
- 612: Create missing XML definitions specifications for IRPs (Advanced Alarm Management, Communication Surveillance, Self-Configuration of Network Elements, Software Management) needed for implementation of a Rel-8 Notification Log IRP (TS 32.33x) / Text3: New TS (32.125, 32.355, 32.505, 32.535), 32.150, 32.153, 32.335
- 613: SP#41 Work stopped. Contributions related to E-UTRAN/EPC to be submitted to UID_380036 E-UTRAN NRM IRP/ UID_380037 EPC NRM IRP / Text3: 32.152, 32.62/3/4x, 32.73x
- 614: -
- 615: SP#42 completed. SP#36 WID updated SP-050319=>SP-070301 / Text3: 32.321/2/3/5
- 616: SP#42 completed / Text3: 32.405
- 617: SP#43 completed / Text3: 32.410
- 618: -
- 619: CP#42 completed. CP#40 WID updated CP-060521=>CP-080315. / Text3: 24.323, 24.229
- 620: CP#42 completed (No CT3-impact). CP#40 WID updated CP-060521=>CP-080315
- 621: CP#42 completed. CP#40 WID updated CP-060521=>CP-080315. / Text3: 29.228, 29.229
- 622: SP#42 completed.
- 623: SP#38 completed / Text3: 32.296
- 624: SP#38 completed / Text3: 32.274, 32.240/299
- 625: SP#42 completed. Linked to SA2 UID 32081 (Support of SMS over IP networks) and CT4 UID 340016 (Routeing of MT-SMS via the HPLMN). / Text3: 32.274, 32.299
- 626: SP#42 stopped / Text3: 32.252, 32.298, 32.299
- 627: CP#42 completed. WID updated CP-070868=>CP-080725
- 628: CP#42 completed. WID updated CP-070868=>CP-080725 / Text3: 23.333
- 629: CP#42 completed. WID updated CP-070868=>CP-080725 / Text3: 29.333

| ID | WBS | Task | Type | Duration | Start | Finish | Complete | Remaining | Baseline start | Baseline finish | Baseline duration | Total slack | Constraint | Resources | Work | Actual work | Text1 | Text4 | Text5 | Text6 | Text8 | Text7 | Text12 | Text2 | Text11 |
| --- | --- | --- | --- | --- | --- | --- | --- | --- | --- | --- | --- | --- | --- | --- | --- | --- | --- | --- | --- | --- | --- | --- | --- | --- | --- |
| 630 | 181 | **Contact Manager for 3GPP UICC applications** |  | 642d? | 2006-06-22 A | 2008-12-05 A | 100% |  | 2006-06-22 | 2008-12-05 | 642d? |  |  | C6 | 13352h | 13352h | eUPHBOOK | Gemalto | Jacques.seif@gemalto.com | Rel-8 | Xavier |  |  |  |  |
| 631 | 181.1 | Requirements for Contact Manager |  | 392d? | 2006-06-22 A | 2007-12-21 A | 100% |  | 2006-06-22 | 2007-12-21 | 392d? |  | finish no earlier than 2007-12-21 | C6 | 3136h | 3136h | eUPHBOOK-St1 | Gemalto | Jacques.seif@gemalto.com | Rel-8 | Xavier |  |  |  |  |
| 632 | 181.2 | External interface for eUPHBOOK |  | 220d? | 2007-05-07 A | 2008-03-07 A | 100% |  | 2007-05-07 | 2008-03-07 | 220d? |  | finish no earlier than 2008-03-07 | C6 | 1760h | 1760h | eUPHBOOK-Ext_Spec | Gemalto | Jacques.seif@gemalto.com | Rel-8 | Xavier |  |  |  |  |
| 633 | 181.3 | Internal interface for eUPHBOOK |  | 415d? | 2007-05-07 A | 2008-12-05 A | 100% |  | 2007-05-07 | 2008-12-05 | 415d? |  | finish no earlier than 2008-12-05 | C6 | 3320h | 3320h | eUPHBOOK-Int_Spec | Gemalto | Jacques.seif@gemalto.com | Rel-8 | Xavier | CP-37 |  |  |  |
| 634 | 181.4 | Deleted - Implementation of eUPHBOOK | milestone | 0d? | 2007-06-21 A | 2007-06-21 A | 100% |  | 2007-06-21 | 2007-06-21 | 0d? |  | start no earlier than 2007-06-21 | C6 |  |  | eUPHBOOK-St23 | Giesecke & Devrient | Claus Dietze | Rel-8 | Xavier |  | SP-33 |  |  |
| 635 | 182 | **Contact Manager Conformance Test specifications** |  | 396d? | 2008-06-02 | 2009-12-04 |  |  | 2008-06-02 | 2009-12-04 | 396d? | 726d |  | C6 | 9504h |  | eUPHBOOK-Test | Comprion, Gemalto | Udo Willenbrink, Jacques Seif | Rel-8 | Xavier | CP-40 |  | PCG-21 |  |
| 636 | 182.1 | Contact Manager for 3GPP UICC applications test specifications |  | 396d? | 2008-06-02 | 2009-12-04 |  |  | 2008-06-02 | 2009-12-04 | 396d? | 726d | finish no earlier than 2009-12-04 | C6 | 3168h |  | eUPHBOOK-Test | Comprion | Udo Willenbrink | Rel-8 | Xavier | CP-40 |  |  |  |
| 637 | 182.2 | Contact Manager API for Java™ Card test specification |  | 396d? | 2008-06-02 | 2009-12-04 |  |  | 2008-06-02 | 2009-12-04 | 396d? | 726d | finish no earlier than 2009-12-04 | C6 | 3168h |  | eUPHBOOK-Test | Gemalto | jacques.seif@gemalto.com | Rel-8 | Xavier | CP-40 |  |  |  |
| 638 | 183 | **Rel-8 LTE – 3G Long Term Evolution - Evolved Packet System RAN part** |  | 644d? | 2006-09-25 A | 2009-03-12 A | 100% |  | 2006-09-25 | 2009-03-12 | 644d? |  |  | RP,S5 | 44896h | 44896h | LTE | NTT DoCoMo | Takehiro Nakamura (nakamurata@nttdocomo.co.jp) | Rel-8 | Stefania |  |  |  | RP-080741 |
| 639 | 183.1 | LTE – Physical Layer |  | 380d? | 2006-09-25 A | 2008-03-07 A | 100% |  | 2006-09-25 | 2008-03-07 | 380d? |  | finish no earlier than 2007-09-14 | R1 | 3040h | 3040h | LTE-Phys | NTT DoCoMo | Sadayuki Abeta | Rel-8 | Patrick |  |  |  | RP-080741 |
| 640 | 183.2 | LTE – Radio Interface Layer 2 and 3 Protocol Aspect |  | 575d? | 2006-09-25 A | 2008-12-05 A | 100% |  | 2006-09-25 | 2008-12-05 | 575d? |  | finish no earlier than 2008-12-11 | R2 | 4600h | 4600h | LTE-L23 | Nokia Siemens Networks | benoist.sebire@nokia.com | Rel-8 | Joern |  |  |  | RP-080741 |
| 641 | 183.3 | LTE – eUTRAN Interfaces |  | 575d? | 2006-09-25 A | 2008-12-05 A | 100% |  | 2006-09-25 | 2008-12-05 | 575d? |  | finish no earlier than 2008-12-11 | R3 | 4600h | 4600h | LTE-interfaces | Ericsson | Martin Israelsson | Rel-8 | Juha |  |  |  | RP-080741 |
| 642 | 183.4 | LTE – Evolved UTRA and UTRAN RF Radio Transmission/Reception, System Performance Requirements and Conformance Testing |  | 575d? | 2006-09-25 A | 2008-12-05 A | 100% |  | 2006-09-25 | 2008-12-05 | 575d? |  | finish no earlier than 2008-12-11 | R4 | 4600h | 4600h | LTE-RF | Nokia Siemens Networks | Tuomo Saynajakangas | Rel-8 | Stefania |  |  |  | RP-080741 |
| 643 | 183.5 | LTE – FDD repeaters |  | 386d? | 2007-09-14 A | 2009-03-06 A | 100% |  | 2007-09-14 | 2009-03-06 | 386d? |  | finish no earlier than 2009-03-06 | R4 | 3088h | 3088h | LTE-Repeaters | Powerwave Technologies, Andrew Wireless | ralf.michanikl@andrew.com, Alf.Ahlstrom@pwav.com | Rel-8 | Stefania | RP-37 |  |  | RP-090037 |
| 644 | 183.6 | **E-UTRAN Data Definitions** |  | 389d? | 2007-09-17 A | 2009-03-12 A | 100% |  | 2007-09-17 | 2009-03-12 | 389d? |  |  | S5 | 13096h | 13096h | E-UTRAN-OAM |  |  | Rel-8 | Dionisio | SP-39 |  | PCG-21 |  |
| 645 | 183.6.1 | Subscriber and Equipment Trace for E-UTRAN and EPC |  | 389d? | 2007-09-17 A | 2009-03-12 A | 100% |  | 2007-09-17 | 2009-03-12 | 389d? |  | finish no earlier than 2009-03-12 | S5 | 3112h | 3112h | E-UTRAN-OAM | Ericsson | PETERSEN, Robert | Rel-8 | Dionisio | SP-37 |  |  |  |
| 646 | 183.6.2 | E-UTRAN Network Resource Model (NRM) Integration Reference Point (IRP) |  | 309d? | 2008-01-07 A | 2009-03-12 A | 100% |  | 2008-01-07 | 2009-03-12 | 309d? |  | finish no earlier than 2009-03-12 | S5 | 2472h | 2472h | E-UTRAN-OAM | Ericsson | ELMDAHL, Per | Rel-8 | Dionisio | SP-38 |  | PCG-21 |  |
| 647 | 183.6.3 | Performance measurements for E-UTRAN |  | 275d? | 2008-02-22 A | 2009-03-12 A | 100% |  | 2008-02-22 | 2009-03-12 | 275d? |  | finish no earlier than 2009-03-12 | S5 | 2200h | 2200h | E-UTRAN-OAM | Motorola, Huawei | YAO, Yizhi | Rel-8 | Dionisio | SP-39 |  | PCG-21 |  |
| 648 | 183.6.4 | Key Performance Indicators (KPIs) for E-UTRAN |  | 275d? | 2008-02-22 A | 2009-03-12 A | 100% |  | 2008-02-22 | 2009-03-12 | 275d? |  | finish no earlier than 2009-03-12 | S5 | 2200h | 2200h | E-UTRAN-OAM | Ericsson | HÜBINETTE, Ulf | Rel-8 | Dionisio | SP-39 |  | PCG-21 |  |
| 649 | 183.7 | **Self-Organizing Networks (SON)** |  | 210d? | 2008-02-22 A | 2008-12-11 A | 100% |  | 2008-02-22 | 2008-12-11 | 210d? |  |  | S5 | 6720h | 6720h | LTE_SON-OAM | Vodafone | GOMPAKIS, Panagiotis | Rel-8 | Dionisio | SP-39 |  | PCG-21 |  |
| 650 | 183.7.1 | SON Concepts and requirements |  | 210d? | 2008-02-22 A | 2008-12-11 A | 100% |  | 2008-02-22 | 2008-12-11 | 210d? |  |  | S5 | 1680h | 1680h | LTE_SON-OAM | Vodafone | GOMPAKIS, Panagiotis | Rel-8 | Dionisio | SP-39 |  | PCG-21 |  |
| 651 | 183.7.2 | Self-Establishment of eNBs, including automated Software Management |  | 210d? | 2008-02-22 A | 2008-12-11 A | 100% |  | 2008-02-22 | 2008-12-11 | 210d? |  | start no earlier than 2008-02-22 | S5 | 1680h | 1680h | LTE_SON-OAM | Nokia Siemens Networks | SUERBAUM, Clemens | Rel-8 | Dionisio | SP-39 |  | PCG-21 |  |
| 652 | 183.7.3 | SON Automatic Neighbour Relations (ANR) List Management |  | 210d? | 2008-02-22 A | 2008-12-11 A | 100% |  | 2008-02-22 | 2008-12-11 | 210d? |  | finish no earlier than 2008-12-11 | S5 | 1680h | 1680h | LTE_SON-OAM | Ericsson | edwin.tse@ericsson.com | Rel-8 | Dionisio | SP-39 |  | PCG-21 |  |
| 653 | 184 | **Rel-8 LTE – Terminal Conformance Test Specification** |  | 657d? | 2007-06-01 A | 2009-12-04 | 88% | 78.84d? | 2007-06-01 | 2009-12-04 | 657d? | 726d |  | R5 | 14336h | 11866.6h | LTE-UEConTest |  |  | Rel-8 | Ingbert |  |  |  |  |
| 654 | 184.1 | 3G LTE – Terminal Protocol Conformance Test Specifications |  | 657d? | 2007-06-01 A | 2009-12-04 | 90% | 65.7d? | 2007-06-01 | 2009-12-04 | 657d? | 726d | finish no earlier than 2009-12-04 | R5 | 5256h | 4730.4h | LTE-UEConTest_SIG | NEC, Motorola | david.lecompte@nectech.fr, Jacob.John@motorola.com | Rel-8 | Ingbert |  |  |  | RP-090682 |
| 655 | 184.2 | LTE – Terminal Radio Transmission and Reception Conformance Test Specifications |  | 657d? | 2007-06-01 A | 2009-12-04 | 86% | 91.98d? | 2007-06-01 | 2009-12-04 | 657d? | 726d |  | R5 | 5256h | 4520.16h | LTE-UEConTest_RF | Agilent | andrea_leonardi@agilent.com | Rel-8 | Ingbert |  |  |  | RP-090683 |

Notes:
- 630: CP#42 completed. CP#40: WID updated CP-070622=>CP-080382. aka Enhanced USIM phonebook
- 631: CP#38 completed / Text3: 21.111
- 632: CP#39 completed / Text3: 31.220
- 633: CP#42 completed / Text3: 31.221
- 634: SP#33 stopped / Text3: 31.102
- 635: CP#45 work not started
- 636: CP#45 work not started / Text3: 31.320 (external interface for communication with the ME)
- 637: CP#45 work not started / Text3: 31.321 (internal interface (API))
- 638: RP#43 completed. RP#42 Rel-8 exception for UID_370046 (LTE FDD repeaters) to 03/09. / Text3: 36.300, 36.938
- 639: RP#39 completed. / Text3: 36.201, 36.211, 36.212, 36.213, 36.214, 25.215, 25.225
- 640: RP#42 completed. ASN.1 freezing target 03/09 / Text3: 36.302, 36.304, 36.306, 36.314, 36.321, 36.322, 36.323, 36.331, 25.302, 25.304, 25.331
- 641: RP#42 completed / Text3: 36.401, 36.410, 36.411, 36.412, 36.413, 36.414, 36.420, 36.421, 36.422, 36.423, 36.424, 25.413
- 642: RP#42 completed (closed at 95%) / Text3: 36.101, 36.104, 36.113, 36.124, 36.133, 36.141, 36.942, 25.123, 25.133
- 643: RP#43 completed / Text3: 36.106, 36.143, 25.113
- 644: SP#43 completed
- 645: SP#43 completed / Text3: 32.42x, 32.44x
- 646: SP#43 completed / Text3: 32.761, 32.762, 32.763, 32.765
- 647: SP#43 completed / Text3: 32.425
- 648: SP#43 completed / Text3: 32.450, 32.451
- 649: SP#42 completed (WT UID_390007 moved to Rel-9). SP#40 updated WID SP-080064=>SP-080275.
- 650: SP#42 completed. SP#40 updated WID SP-080064=>SP-080275. SP#41 UID_390004 split to monitor 32.500 progress. / Text3: 32.500
- 651: SP#42 completed. WID updated SP-080065=>SP-080849 / Text3: 32.501, 32.502, 32.531, 32.532, 32.533
- 652: SP#42 completed / Text3: 32.511, 32.761, 32.762, 32.763, 32.765
- 653: Testing for Feature UID_20068 (LTE)
- 654: RP#45 completion 09/09=>12/09 / Text3: 36.521-1, 36.521-2, 36.508, 36.509, 36.523-1, 36.523-2, 36.523-3
- 655: RP#45 completion 09/09=>12/09 / Text3: 36.521-1, 36.521-2, 36.521-3, 36.508, 36.509, 36.903

| ID | WBS | Task | Duration | Start | Finish | Complete | Baseline start | Baseline finish | Baseline duration | Constraint | Resources | Work | Actual work | Text1 | Text6 | Text8 | Text4 | Text5 | Text11 | Text2 | Text7 | Text9 | Text12 |
| --- | --- | --- | --- | --- | --- | --- | --- | --- | --- | --- | --- | --- | --- | --- | --- | --- | --- | --- | --- | --- | --- | --- | --- |
| 656 | 185 | **Rel-8 Improvements of the Radio Interface** | 525d? | 2007-03-05 A | 2009-03-06 A | 100% | 2007-03-05 | 2009-03-06 | 525d? |  | RP | 18152h | 18152h | RInImp8 | Rel-8 | Stefania |  |  |  |  |  |  |  |
| 657 | 185.1 | UMTS 1500 MHz | 140d? | 2007-03-05 A | 2007-09-14 A | 100% | 2007-03-05 | 2007-09-14 | 140d? | finish no earlier than 2007-09-14 | R4 | 1120h | 1120h | RInImp8-UMTS1500 | Rel-8 | Stefania | NTT DoCoMo | Takehiro Nakamura (nakamurata@nttdocomo.co.jp) | RP-070526 |  |  |  |  |
| 658 | 185.2 | UMTS 700 MHz FDD | 325d? | 2007-03-05 A | 2008-05-30 A | 100% | 2007-03-05 | 2008-05-30 | 325d? | finish no earlier than 2008-06-12 | R4 | 2600h | 2600h | RInImp8-UMTS700 | Rel-8 | Stefania | Nokia | Tuomo Saynajakangas | RP-080260 |  |  |  |  |
| 659 | 185.3 | UMTS 2300 MHz TDD LCR | 195d? | 2007-12-17 A | 2008-09-12 A | 100% | 2007-12-17 | 2008-09-12 | 195d? | finish no earlier than 2008-09-12 | R4 | 1560h | 1560h | RInImp8-UMTS2300TDD | Rel-8 | Stefania | CATT | songyuexia@datangmobile.cn | RP-080517 | PCG-21 | RP-38 |  |  |
| 660 | 185.4 | Further Improved Minimum Performance Requirements for HSDPA UE (FDD) - Two-Branch Interference Cancellation | 265d? | 2007-03-05 A | 2008-03-07 A | 100% | 2007-03-05 | 2008-03-07 | 265d? | finish no earlier than 2008-03-12 | R4 | 2120h | 2120h | RInImp8-2BIC | Rel-8 | Stefania | AT&T | Marc Grant | RP-080041 |  |  |  |  |
| 661 | 185.5 | CS Voice Service over HSPA | 167d? | 2007-07-19 A | 2008-03-07 A | 100% | 2007-07-19 | 2008-03-07 | 167d? |  | R2 | 1336h | 1336h | RInImp8-CsHspa | Rel-8 | Joern | Nokia Siemens Networks | woonhee.hwang@nsn.com | RP-080042 |  | RP-37 |  |  |
| 662 | 185.6 | Performance requirements for 15 code reception with 16QAM/QPSK (FDD) | 126d? | 2007-06-11 A | 2008-03-07 A | 100% | 2007-06-11 | 2008-03-07 | 126d? | finish no earlier than 2008-06-12 | R4 | 1008h | 1008h | RInImp8-Hsdpa15codes | Rel-8 | Stefania | Vodafone | tim.frost@vodafone.com | RP-080043 |  | RP-37 |  |  |
| 663 | 185.7 | UMTS 1880 MHz TDD | 126d? | 2008-09-12 A | 2009-03-06 A | 100% | 2008-09-12 | 2009-03-06 | 126d? | finish no earlier than 2009-03-09 | R4 | 1008h | 1008h | RInImp9-UMTS1880TDD | Rel-8 | Stefania | CATT | Yuexia Song (songyuexia@datangmobile.cn) | RP-090044 | PCG-21 | RP-41 |  |  |
| 664 | 185.8 | Deleted - UMTS 2300 MHz FDD/TDD | 400d? | 2007-03-05 A | 2008-09-12 A | 100% | 2007-03-05 | 2008-09-12 | 400d? | finish no earlier than 2008-12-11 | R4 | 3200h | 3200h | RInImp8-UMTS2300 | Rel-8 | Stefania | AT&T | Marc Grant | RP-080515 |  |  | PCG-21 | RP-41 |
| 665 | 186 | **Rel-8 Improvements of the Radio Interface - UE Conformance Testing** | 396d? | 2007-06-01 A | 2008-12-05 A | 100% | 2007-06-01 | 2008-12-05 | 396d? |  | R5 | 6256h | 6256h | RInImp-UEConTest | Rel-8 | Ingbert |  |  |  |  |  |  |  |
| 666 | 186.1 | Conformance Test Aspects – CS Voice Service over HSPA | 336d? | 2007-06-01 A | 2008-09-12 A | 100% | 2007-06-01 | 2008-09-12 | 336d? | finish no earlier than 2008-09-12 | R5 | 2688h | 2688h | RInImp8-CsHspa_UEConTest | Rel-8 | Ingbert | Huawei | baoyi@huawei.com | RP-080542 |  |  |  |  |
| 667 | 186.2 | Conformance Test Aspects – Performance requirements for 15 code reception with 16QAM/QPSK (FDD) | 195d? | 2008-03-07 A | 2008-12-05 A | 100% | 2008-03-07 | 2008-12-05 | 195d? | finish no earlier than 2008-12-05 | R5 | 1560h | 1560h | RInImp8-UEConTest_ Hsdpa15codes | Rel-8 | Ingbert | Ericsson | Mikael.Ziren@Ericsson.com | RP-080818 | PCG-21 | RP-40 |  |  |
| 668 | 187 | **Rel-8 RAN improvements** | 520d? | 2007-06-04 A | 2009-05-29 A | 100% | 2007-06-04 | 2009-05-29 | 520d? |  | RP | 29776h | 29776h | RANimp | Rel-8 | Stefania |  |  |  |  |  |  |  |
| 669 | 187.1 | Combination of 64QAM and MIMO for HSDPA (FDD) | 205d? | 2007-06-04 A | 2008-09-12 A | 100% | 2007-06-04 | 2008-09-12 | 205d? | finish no earlier than 2008-09-12 | R1 | 1640h | 1640h | RANimp-64QamMimoHsdpa | Rel-8 | Patrick | Ericsson | Johan.Bergman@ericsson.com | RP-080518 |  |  |  |  |
| 670 | 187.2 | Improved L2 for uplink | 186d? | 2007-09-14 A | 2008-05-30 A | 100% | 2007-09-14 | 2008-05-30 | 186d? | finish no earlier than 2008-05-30 | R2 | 1488h | 1488h | RANimp-UplinkL2dataRates | Rel-8 | Joern | Ericsson | Janne.Peisa@ericsson.com | RP-080265 |  | RP-37 |  |  |
| 671 | 187.3 | Enhanced Uplink for CELL_FACH State in FDD | 321d? | 2007-09-14 A | 2008-12-05 A | 100% | 2007-09-14 | 2008-12-05 | 321d? | finish no earlier than 2008-12-12 | R2 | 2568h | 2568h | RANimp-UplinkEnhState | Rel-8 | Joern | Nokia Siemens Networks | markus.wimmer@nsn.com | RP-080804 |  | RP-37 |  |  |
| 672 | 187.4 | Enhanced UE DRX for FDD | 261d? | 2007-09-14 A | 2008-09-12 A | 100% | 2007-09-14 | 2008-09-12 | 261d? | finish no earlier than 2008-09-12 | R2 | 2088h | 2088h | RANimp-DRX | Rel-8 | Joern | Nokia | luis.barreto@nokia.com | RP-080520 |  | RP-37 |  |  |
| 673 | 187.5 | Enhancements for SRNS Relocation Procedure | 261d? | 2007-09-14 A | 2008-09-12 A | 100% | 2007-09-14 | 2008-09-12 | 261d? | finish no earlier than 2008-09-12 | R3 | 2088h | 2088h | RANimp-SrnsReloc | Rel-8 | Juha | Nokia Siemens Networks | masatoshi.nakamata@nsn.com | RP-080521 |  | RP-37 |  |  |
| 674 | 187.6 | Enhancements for FDD HSPA Evolution | 321d? | 2007-09-14 A | 2008-12-05 A | 100% | 2007-09-14 | 2008-12-05 | 321d? | finish no earlier than 2008-12-05 | R3,R2 | 2568h | 2568h | RANimp-HSPAEvo | Rel-8 | Juha | Nokia Siemens Networks | masatoshi.nakamata@nsn.com | RP-080805 |  | RP-37 |  |  |
| 675 | 187.7 | 64QAM for 1.28 Mcps TDD HSDPA | 264d? | 2007-12-04 A | 2008-12-05 A | 100% | 2007-12-04 | 2008-12-05 | 264d? | finish no earlier than 2008-12-05 | R1 | 2112h | 2112h | RANimp-64Qam1.28TDD | Rel-8 | Patrick | ZTE | zfmail@zte.com.cn | RP-080806 | PCG-21 | RP-38 |  |  |
| 676 | 187.8 | Enhanced CELL_FACH state in 1.28 Mcps TDD | 264d? | 2007-12-04 A | 2008-12-05 A | 100% | 2007-12-04 | 2008-12-05 | 264d? | finish no earlier than 2008-12-12 | R2 | 2112h | 2112h | RANimp-EnhState1.28TDD | Rel-8 | Joern | ZTE | zhang.yincheng@zte.com.cn | RP-080807 | PCG-21 | RP-38 |  |  |
| 677 | 187.9 | Continuous Connectivity for packet data users for 1.28 Mcps TDD | 321d? | 2008-03-07 A | 2009-05-29 A | 100% | 2008-03-07 | 2009-05-29 | 321d? | finish no earlier than 2009-05-29 | R1 | 2568h | 2568h | RANimp-LCRCPC | Rel-8 | Patrick | TD Tech | chenying@td-tech.com | RP-090394 | PCG-21 | RP-39 |  |  |
| 678 | 187.10 | HSPA VoIP to WCDMA/GSM CS continuity | 261d? | 2008-03-07 A | 2009-03-06 A | 100% | 2008-03-07 | 2009-03-06 | 261d? | finish no earlier than 2009-03-06 | R2 | 2088h | 2088h | RANimp-HSPAVoIP | Rel-8 | Joern | Nokia | Simone.Provvedi@nokia.com | RP-090050 | PCG-21 | RP-39 |  |  |
| 679 | 187.11 | HS-DSCH Serving Cell Change Enhancements | 196d? | 2008-03-07 A | 2008-12-05 A | 100% | 2008-03-07 | 2008-12-05 | 196d? | finish no earlier than 2008-12-12 | R2 | 1568h | 1568h | RANimp-HSDSCH | Rel-8 | Joern | Ericsson | henrik.enbuske@ericsson.com | RP-080811 | PCG-21 | RP-39 |  |  |
| 680 | 187.12 | MIMO for 1.28 Mcps TDD | 201d? | 2007-11-01 A | 2009-03-06 A | 100% | 2007-11-01 | 2009-03-06 | 201d? | finish no earlier than 2009-05-29 | R1,R4 | 1608h | 1608h | RANimp-MIMOLCR | Rel-8 | Patrick | CATT | wangke@datangmobile.cn | RP-090313 | PCG-21 | RP-40 |  |  |
| 681 | 187.13 | Dual-Cell HSDPA operation on adjacent carriers | 140d? | 2008-05-30 A | 2008-12-11 A | 100% | 2008-05-30 | 2008-12-11 | 140d? | finish no earlier than 2009-05-29 | R1,R4 | 1120h | 1120h | RANimp-DCHSDPA | Rel-8 | Patrick | Ericsson | johan.bergman@ericsson.com | RP-080814 | PCG-21 | RP-40 |  |  |

Notes:
- 656: -
- 657: SR in RP-070526. Introduction of Band XI / Text3: 25.101, 25.104, 25.133, 25.141, 25.331, 25.942, 25.306, 25.307, 34.121
- 658: SR in RP-080260. Introduction of UMTS 700 MHz (Bands XII XIV) in 25.307 / Text3: 25.101, 25.104, 25.133, 25.141, 25.331, 25.942, 25.306, 25.307, 34.121
- 659: SR in RP-080517. RP#41 completed / Text3: 25.102, 25.105, 25.113, 25.123, 25.142, 34.124, 25.306, 25.331, 34.122
- 660: SR in RP-080041.
- 661: SR in RP-080042. / Text3: 25.323, 25.331, 25.322
- 662: SR in RP-080043. / Text3: 25.101
- 663: RP#43 completed as Rel-8 / Text3: 25.102, 25.105, 25.113, 25.123, 25.142, 34.124, 25.307
- 664: SR in RP-080515. RP#41 stopped / Text3: 25.101, 25.104, 25.133, 25.141, 25.331, 25.942, 25.306, 25.307, 34.121
- 665: 05/08: Linked to Feature UID_20028 (RInImp)
- 666: SR in RP-080542. RP#41 completed. / Text3: 34.108, 34.123-1, 34.123-2, 34.123-3
- 667: RP#42 completed. SR in RP-080818. Linked to UID_370033. / Text3: 34.121-1, 34.121-2
- 668: -
- 669: SR in RP-080518. RP#41 completed / Text3: 25.308, 25.211, 25.212, 25.213, 25.306, 25.331, 25.433, 25.435, 25.423, 25.425, 25.101, 25.104, 25.141
- 670: SR in RP-080265. RP#40 completed / Text3: 25.319, 25.301, 25.306, 25.321, 25.331, 25.433, 25.435, 25.423, 25.425, 25.427
- 671: SR in RP-080804. RP#42 completed / Text3: 25.309, 25.211, 25.214, 25.321, 25.331, 25.423, 25.433
- 672: SR in RP-080520. RP#41 completed / Text3: 25.306, 25.308, 25.321, 25.331, 25.423
- 673: SR in RP-080521. RP#41 completed / Text3: 25.306, 25.308, 25.321, 25.331, 25.423, 25.433, 25.214, 25.133
- 674: SR in RP-080805. RP#42 completed. WID updated RP-070760=>RP-080830 / Text3: 25.401, 25.413, 25.420, 25.423, 25.427, 25.433, 25.446, 25.301, 25.346
- 675: SR in RP-080806. RP#42 completed / Text3: 25.102, 25.105, 25.123, 25.142, 25.201, 25.221, 25.222, 25.223, 25.224, 25.306, 25.308, 25.321, 25.331, 25.423, 25.433
- 676: SR in RP-080807. RP#42 completed / Text3: 25.123, 25.221, 25.222, 25.224, 25.301, 25.302, 25.304, 25.306, 25.308, 25.319, 25.321, 25.331, 25.401, 25.423, 25.425, 25.433, 25.435
- 677: RP#44 completed / Text3: 25.929, 25.308, 25.319
- 678: RP#43 completed / Text3: 25.331, 25.413
- 679: SR in RP-080811. RP#42 completed / Text3: 25.101, 25.104, 25.133, 25.212, 25.214, 25.308, 25.321, 25.331, 25.423, 25.433
- 680: RP#43 completed (part missing R4 performance part) / Text3: 25.201, 25.221, 25.222, 25.223, 25.224, 25.306, 25.308, 25.321, 25.331, 25.423, 25.433, 25.102, 25.105, 25.142
- 681: RP#42 completed except R4 performance part 05/09. Triggered by FS_RAN-DCHS UID_390032 / Text3: 25.101, 25.104, 25.133, 25.141, 25.211, 25.212, 25.213, 25.214, 25.215, 25.306, 25.308, 25.321, 25.331, 25.423, 25.433

| ID | WBS | Task | Duration | Start | Finish | Complete | Remaining | Baseline start | Baseline finish | Baseline duration | Total slack | Constraint | Resources | Work | Actual work | Text1 | Text6 | Text8 | Text2 | Text4 | Text7 | Text11 |
| --- | --- | --- | --- | --- | --- | --- | --- | --- | --- | --- | --- | --- | --- | --- | --- | --- | --- | --- | --- | --- | --- | --- |
| 682 | 188 | **Rel-8 RAN improvements - UE Conformance Testing** | 602d? | 2008-05-30 A | 2010-09-17 | 43% | 341.4d? | 2008-05-30 | 2010-09-17 | 602d? | 521d |  | R5 | 27831.2h | 10053.6h | RANimp-UEConTest | Rel-8 | Ingbert |  |  |  |  |
| 683 | 188.1 | Conformance Test Aspects – Combination of 64QAM and MIMO for HSDPA (FDD) | 322d? | 2008-09-12 A | 2009-12-04 | 90% | 32.2d? | 2008-09-12 | 2009-12-04 | 322d? | 726d | finish no earlier than 2009-12-04 | R5 | 2576h | 2318.4h | RANimp-UEConTest_64QamMimoHsdpa | Rel-8 | Ingbert | PCG-21 | Ericsson | RP-41 | RP-090714 |
| 684 | 188.2 | Conformance Test Aspects – Improved L2 for uplink | 341d? | 2008-05-30 A | 2009-09-18 A | 100% |  | 2008-05-30 | 2009-09-18 | 341d? |  | finish no earlier than 2009-09-18 | R5 | 2728h | 2728h | RANimp-UEConTest_UplinkL2dataRates | Rel-8 | Ingbert | PCG-21 | Ericsson | RP-40 | RP-090712 |
| 685 | 188.3 | Conformance Test Aspects – 64QAM for 1.28 Mcps TDD HSDPA | 261d? | 2008-05-30 A | 2009-05-29 A | 100% |  | 2008-05-30 | 2009-05-29 | 261d? |  | finish no earlier than 2009-05-29 | R5 | 2088h | 2088h | RANimp-UEConTest_64Qam1.28TDD | Rel-8 | Ingbert | PCG-21 | ZTE | RP-40 | RP-090415 |
| 686 | 188.4 | Conformance Test Aspects – Dual-Cell HSDPA operation on adjacent carriers | 261d? | 2008-12-05 A | 2009-12-04 | 40% | 156.6d? | 2008-12-05 | 2009-12-04 | 261d? | 726d | finish no earlier than 2009-12-04 | R5 | 2088h | 835.2h | RANimp-UEConTest_DCHSDPA | Rel-8 | Ingbert | PCG-22 | Qualcomm Europe | RP-42 | RP-090716 |
| 687 | 188.5 | Conformance Test Aspects – Enhanced Uplink for CELL_FACH State in FDD | 266d? | 2009-03-06 A | 2010-03-12 | 20% | 212.8d? | 2009-03-06 | 2010-03-12 | 266d? | 656d | finish no earlier than 2010-03-12 | R5 | 2128h | 425.6h | RANimp-UEConTest_EnhancedRACHCellFACHState | Rel-8 | Ingbert | PCG-22 | Nokia | RP-43 | RP-090721 |
| 688 | 188.6 | Conformance Test Aspects – Receiver Type 3i | 196d? | 2009-03-06 A | 2009-12-04 | 80% | 39.2d? | 2009-03-06 | 2009-12-04 | 196d? | 726d | finish no earlier than 2009-12-04 | R5 | 1568h | 1254.4h | RANimp_UEConTest_ReceiverType3i | Rel-8 | Ingbert | PCG-22 | Qualcomm Europe | RP-43 | RP-090720 |
| 689 | 188.7 | Conformance Test Aspects – Enhanced CELL_FACH State in LCR TDD | 336d? | 2009-05-30 A | 2010-09-10 | 5% | 319.2d? | 2009-05-30 | 2010-09-10 | 336d? | 526d | finish no earlier than 2010-09-10 | R5 | 2688h | 134.4h | EnhancedCellFACHStateLCRTDD_UEConTest | Rel-8 | Ingbert | PCG-23 | CATT | RP-44 | RP-090722 |
| 690 | 188.8 | Conformance Test Aspects – 1.28 Mcps TDD Improved L2 support for high data rates | 337d? | 2009-05-29 A | 2010-09-10 | 10% | 303.3d? | 2009-05-29 | 2010-09-10 | 337d? | 526d | finish no earlier than 2010-09-10 | R5 | 2696h | 269.6h | ImprovedL2LCRTDD_UEConTest | Rel-8 | Ingbert | PCG-23 | CATT | RP-44 | RP-090725 |
| 691 | 188.9 | Conformance Test Aspects – Continuous Connectivity for packet data users for 1.28 Mcps TDD | 261d? | 2009-09-18 | 2010-09-17 |  |  | 2009-09-18 | 2010-09-17 | 261d? | 521d | finish no earlier than 2010-09-17 | R5 | 2088h |  | LCRCPC_UEConTest | Rel-8 | Ingbert | PCG-23 | ZTE | RP-45 |  |
| 692 | 188.10 | Conformance Test Aspects – MIMO for 1.28 Mcps TDD | 196d? | 2009-09-18 | 2010-06-18 |  |  | 2009-09-18 | 2010-06-18 | 196d? | 586d | finish no earlier than 2010-06-18 | R5 | 1568h |  | MIMOLCR_UEConTest | Rel-8 | Ingbert | PCG-23 | ZTE | RP-45 |  |
| 693 | 188.11 | Conformance Test Aspects – HS-DSCH Serving Cell Change Enhancements | 126d? | 2009-09-18 | 2010-03-12 |  |  | 2009-09-18 | 2010-03-12 | 126d? | 656d | finish no earlier than 2010-03-12 | R5 | 1008h |  | HSDSCH_UEConTest | Rel-8 | Ingbert | PCG-23 | Qualcomm Europe | RP-45 |  |
| 694 | 189 | 3.84 Mcps TDD MBSFN Integrated Mobile Broadcast | 395d? | 2007-06-04 A | 2008-12-05 A | 100% |  | 2007-06-04 | 2008-12-05 | 395d? |  |  | R1 | 3160h | 3160h | MBSFN-DOB | Rel-8 | Patrick |  | Ericsson |  | RP-080218 |
| 695 | 190 | Conformance Test Aspects – 3.84 Mcps TDD MBSFN Integrated Mobile Broadcast | 136d? | 2009-05-30 A | 2009-12-04 | 40% | 81.6d? | 2009-05-30 | 2009-12-04 | 136d? | 726d | finish no earlier than 2009-12-04 | R5 | 1088h | 435.2h | MBSFN_IMB_UEConTest | Rel-8 | Ingbert | PCG-23 | IPwireless | RP-44 | RP-090726 |
| 696 | 191 | GERAN support for GERAN - 3G Long Term Evolution interworking | 641d? | 2006-09-08 A | 2009-02-20 A | 100% |  | 2006-09-08 | 2009-02-20 | 641d? |  | finish no earlier than 2009-02-20 | GP | 5128h | 5128h | GELTE | Rel-8 | Paolo |  | Nokia, Nokia Siemens Networks |  |  |
| 697 | 192 | U-TDOA Enhancement | 131d? | 2007-05-18 A | 2007-11-16 A | 100% |  | 2007-05-18 | 2007-11-16 | 131d? |  | finish no earlier than 2007-05-18 | GP | 1048h | 1048h | GUTEN | Rel-8 | Paolo |  | TruePosition |  |  |
| 698 | 193 | **GAN Enhancements** | 604.2d? | 2007-05-15 A | 2009-09-04 A | 100% |  | 2007-05-15 | 2009-09-04 | 604.2d? |  |  | GP | 9432h | 9432h | GANENH | Rel-8 | Paolo |  | T-Mobile |  |  |
| 699 | 193.1 | Update to GAN specifications | 126d? | 2007-08-31 A | 2008-02-22 A | 100% |  | 2007-08-31 | 2008-02-22 | 126d? |  | finish no earlier than 2008-02-22 | GP | 1008h | 1008h | GANENH-SPEC | Rel-8 | Paolo |  | T-Mobile |  |  |
| 700 | 193.2 | Update TS 51.010 Mobile Station (MS) Conformance Specification for GAN Enhancements | 526d? | 2007-05-15 A | 2009-09-04 A | 100% |  | 2007-05-15 | 2009-09-04 | 526d? |  | finish no earlier than 2009-09-04 | G3new | 4208h | 4208h | GANENH-MStest | Rel-8 | Ingbert |  | T-Mobile |  |  |
| 701 | 194 | **AoIP (A-interface over IP)** | 2335d? | 2000-01-03 A | 2008-12-11 A | 100% |  | 2000-01-03 | 2008-12-11 | 2335d? |  |  | GP,S4,C4,C1,C3 | 41412.1h | 41412.1h | AoIP | Rel-8 | Paolo | PCG-21 | China Mobile, Ericsson |  |  |
| 702 | 194.1 | GERAN aspects of AoIP | 2321d? | 2000-01-03 A | 2008-11-21 A | 100% |  | 2000-01-03 | 2008-11-21 | 2321d? |  | finish no earlier than 2008-11-21 | GP | 18560h | 18560h | AoIP | Rel-8 | Paolo | PCG-21 | China Mobile, Ericsson | SP-40 |  |
| 703 | 194.2 | Media Requirements for CS over IP based User Plane | 267d? | 2007-12-05 A | 2008-12-11 A | 100% |  | 2007-12-05 | 2008-12-11 | 267d? |  | finish no earlier than 2008-12-11 | S4 | 1996.09h | 1996.09h | AoIP-CSoIP | Rel-8 | Paolo | PCG-21 | China Mobile, Ericsson | SP-40 |  |
| 704 | 194.3 | Core Network Impacts for A-Interface User Plane over IP | 136d? | 2008-05-30 A | 2008-12-05 A | 100% |  | 2008-05-30 | 2008-12-05 | 136d? |  | start no earlier than 2008-05-30 | C4 | 1088h | 1088h | AoIP-CN | Rel-8 | Kimmo | PCG-21 | Ericsson | CP-40 |  |
| 705 | 194.4 | Core Network Impacts for A-Interface User Plane over IP | 68d? | 2008-05-30 A | 2008-12-05 A | 100% |  | 2008-05-30 | 2008-12-05 | 68d? |  | finish no earlier than 2008-12-05 | C1 | 544h | 544h | AoIP-CN | Rel-8 | Frederic | PCG-21 | Ericsson | CP-40 |  |
| 706 | 194.5 | Core Network Impacts for A-Interface User Plane over IP | 68d? | 2008-05-30 A | 2008-12-05 A | 100% |  | 2008-05-30 | 2008-12-05 | 68d? |  | finish no earlier than 2008-12-05 | C3 | 544h | 544h | AoIP-CN | Rel-8 | Gwiho | PCG-21 | Ericsson | CP-40 |  |
| 707 | 195 | New multicarrier BTS class | 261d? | 2007-08-31 A | 2008-08-29 A | 100% |  | 2007-08-31 | 2008-08-29 | 261d? |  | finish no earlier than 2008-08-29 | G1 | 2088h | 2088h | MCBTS | Rel-8 | Paolo |  | Alcatel-Lucent |  |  |

Notes:
- 682: 05/08: Linked to Feature UID_20029 (RANimp)
- 683: RP#45 completion 09/09=>12/09 / Text3: 34.108, 34.121-1, 34.121-2, 34.123-1, 34.123-2, 34.123-3 / Text5: leif.mattisson@ericsson.com
- 684: RP#45 completed. Linked to UID_370036 / Text3: 34.108, 34.123-1, 34.123-2, 34.123-3 / Text5: leif.mattisson@ericsson.com
- 685: RP#44 completed. Linked UID_380075 RANimp-64Qam1.28TDD / Text3: 34.108, 34.122, 34.123-1, 34.123-2, 34.123-3 / Text5: ma.zijiang@zte.com.cn
- 686: RP#44 completion target 09/09=>12/09. Testing for UID_400052 / Text3: 34.108, 34.121-1, 34.121-2, 34.123-1, 34.123-2, 34.123-3 / Text5: Shubhang Vora (svora@qualcomm.com)
- 687: Testing for UID_370037 / Text3: 34.108, 34.121-1, 34.121-2, 34.123-1, 34.123-2, 34.123-3 / Text5: jarkko.hellsten@nokia.com
- 688: Testing for Receiver Type3i in RAN4 TS 25.101 UE radio Tx and Rx (FDD) / Text3: 34.108, 34.121-1, 34.121-2 / Text5: Ashok Kumar Narayanaswamy (anarayan@qualcomm.com)
- 689: Linked to UID_380076 Enhanced CELL_FACH state in 1.28 Mcps TDD / Text3: 34.108, 34.123-1, 34.123-2, 34.123-3 / Text5: Xiaozhong Chen (chenxiaozhong@datangmobile.cn)
- 690: Linked to Rel-7 UID_340039 Improved L2 support for high data rates and Rel-8 UID_370036 Improved L2 for uplink / Text3: 34.108, 34.123-1, 34.123-2, 34.123-3 / Text5: Xiaozhong Chen (chenxiaozhong@datangmobile.cn)
- 691: RP#45 testing for UID_390028 / Text3: 34.108, 34.123-1, 34.123-2, 34.123-3 / Text5: He Huang (huang.he4@zte.com.cn)
- 692: RP#45 testing for UID_400050 / Text3: 34.108, 34.123-1, 34.123-2, 34.123-3 / Text5: He Huang (huang.he4@zte.com.cn)
- 693: RP#45 testing for UID_390030 / Text3: 34.108, 34.121-1, 34.121-2, 34.123-1, 34.123-2, 34.123-3 / Text5: Shubhang Vora (svora@qualcomm.com)
- 694: RP#42 completed. WID updated RP-070493=>RP-081124 (changed WI title "MBSFN Downlink Optimized Broadcast (DOB) 3.84 Mcps TDD" => "3.84Mcps TDD MBSFN Integrated Mobile Broadcast"). RP#39 SR in RP-080218. / Text3: 25.102, 25.105, 25.123, 25.201, 25.221, 25.222, 25.223, 25.224, 25.304, 25.306, 25.331, 25.346, 25.402, 25.433 / Text5: Lars.Lindbom@ericsson.com
- 695: Testing for Rel-8 MBSFN-DOB UID_360008 / Text3: 34.108, 34.122, 34.123-1, 34.123-2, 34.123-3 / Text5: Phil Young (pyoung@ipwireless.com)
- 696: GP#41 completed (MS conformance testing open) / Text3: 24.008, 43.055, 43.129, 43.246, 44.018, 44.060, 45.002, 45.008, 45.010, 48.008, 48.018, 51.010 / Text5: sergio.parolari@nsn.com, vlora.rexhepi@nokia.com
- 697: GP#36 completed U-TDOA (Uplink Time Difference of Arrival) / Text3: 43.059, 45.008, 48.071 / Text5: Terry Brooks (terri.brooks@trueposition.com)
- 698: GP#37 completed. GP#43 completed Testing / Text5: mohammed.versi@t-mobile.com
- 699: GP#37 completed / Text3: 43.318, 44.318 / Text5: mohammed.versi@t-mobile.com
- 700: GP#43 completed / Text3: 51.010 / Text5: mohammed.versi@t-mobile.com
- 701: GP#40/TSG#42 completed . Triggered by TR 43.903 Study on A-interface over IP (AINTIP) UID_50589. / Text5: wangshuaiyu@chinamobile.com, paul.schliwa-bertling@ericsson.com
- 702: GP#40 completed. GP#39 updated WID GP-080901=>GP-081362. / Text3: 48.001, 48.002, 48.008, 48.020, 49.008, 48.103 / Text5: wangshuaiyu@chinamobile.com, paul.schliwa-bertling@ericsson.com
- 703: SP#42 completed / Text3: 26.102, 26.103, 26.202 / Text5: Karl.Hellwig@Ericsson.com
- 704: CP#42 completed. Updated WID CP-080278=>CP-080722 / Text3: 23.205, 23.153, 23.231, 29.232 / Text5: philip.hodges@ericsson.com
- 705: CP#42 completed. Updated WID CP-080278=>CP-080722 / Text3: 23.009 / Text5: philip.hodges@ericsson.com
- 706: CP#42 completed. Updated WID CP-080278=>CP-080722 / Text3: 29.007 / Text5: philip.hodges@ericsson.com
- 707: GP#39 completed / Text3: 45.005, 45.050, 51.021 / Text5: thomas.bitzer@alcatel-lucent.de

| ID | WBS | Task | Type | Duration | Start | Finish | Complete | Remaining | Baseline start | Baseline finish | Baseline duration | Total slack | Constraint | Resources | Work | Actual work | Text1 | Text4 | Text6 | Text8 | Text11 | Text2 | Text3 | Text7 | Text12 | Text9 |
| --- | --- | --- | --- | --- | --- | --- | --- | --- | --- | --- | --- | --- | --- | --- | --- | --- | --- | --- | --- | --- | --- | --- | --- | --- | --- | --- |
| 708 | 196 | **Support for Additional Navigation Satellite Systems (ANSS) for LCS** |  | 150d? | 2008-05-16 A | 2008-12-11 A | 100% |  | 2008-05-16 | 2008-12-11 | 150d? |  |  | S1,G2 | 3384h | 3384h | ANSS | Qualcomm Europe | Rel-8 | Paolo | RP-080813 |  |  |  |  |  |
| 709 | 196.1 | Stage 1 for ANSS for LCS |  | 1d? | 2008-12-11 A | 2008-12-11 A | 100% |  | 2008-12-11 | 2008-12-11 | 1d? |  | start no earlier than 2008-12-11 | S1 | 8h | 8h | ANSS |  | Rel-8 | Alain |  | PCG-22 | 22.071 | SP-42 |  |  |
| 710 | 196.2 | Support for Additional Navigation Satellite Systems (ANSS) for LCS |  | 136d? | 2008-05-16 A | 2008-11-21 A | 100% |  | 2008-05-16 | 2008-11-21 | 136d? |  | start no earlier than 2008-05-16 | G2 | 1088h | 1088h | ANSS | Qualcomm Europe | Rel-8 | Paolo |  |  | 43.059, 44.031, 49.031, 44.071, 48.031, 51.010 |  |  |  |
| 711 | 196.3 | Support for Additional Navigation Satellite Systems (ANSS) for LCS |  | 136d? | 2008-05-30 A | 2008-12-05 A | 100% |  | 2008-05-30 | 2008-12-05 | 136d? |  | finish no earlier than 2008-12-08 | R2 | 1088h | 1088h | RANimp-ANSS | Qualcomm Europe | Rel-8 | Joern | RP-080813 | PCG-21 | 25.305, 25.306, 25.331, 25.413, 25.423, 25.433, 25.453 | RP-40 |  |  |
| 712 | 197 | **A-GNSS Performances and Testing Procedures** |  | 397d? | 2008-05-16 A | 2009-11-20 | 45% | 218.35d? | 2008-05-16 | 2009-11-20 | 397d? | 736d |  | GP | 9528h | 3176h | AGNSSPTP | Thales | Rel-8 | Paolo |  |  |  |  |  |  |
| 713 | 197.1 | A-GNSS Minimum Performances |  | 397d? | 2008-05-16 A | 2009-11-20 | 80% | 79.4d? | 2008-05-16 | 2009-11-20 | 397d? | 736d | finish no earlier than 2009-11-20 | G1 | 3176h | 2540.8h | AGNSSPTP- Perfreq | Thales | Rel-8 | Paolo |  |  | 45.005 |  |  |  |
| 714 | 197.2 | A-GNSS Testing Procedures |  | 397d? | 2008-05-16 A | 2009-11-20 | 10% | 357.3d? | 2008-05-16 | 2009-11-20 | 397d? | 736d | finish no earlier than 2009-11-20 | G3new | 3176h | 317.6h | AGNSSPTP-MStest | Thales | Rel-8 | Ingbert |  |  | 51.010-1 |  |  |  |
| 715 | 198 | **Conformance testing for the Latency Reductions feature** |  | 457d? | 2008-02-22 A | 2009-11-20 | 97% | 14.54d? | 2008-02-22 | 2009-11-20 | 457d? | 736d |  | G1, G3new | 9392h | 9092.85h | CTLATRED | Ericsson | Rel-8 | Paolo |  | PCG-21 |  |  |  |  |
| 716 | 198.1 | MS conformance testing for the Latency Reductions feature |  | 457d? | 2008-02-22 A | 2009-11-20 | 95% | 22.85d? | 2008-02-22 | 2009-11-20 | 457d? | 736d | finish no earlier than 2009-11-20 | G3new | 3648h | 3465.2h | CTLATRED-MStest | Ericsson | Rel-8 | Ingbert |  | PCG-21 | 51.010 |  |  |  |
| 717 | 198.2 | BTS conformance testing for the Latency Reductions feature |  | 261d? | 2008-02-22 A | 2009-02-20 A | 100% |  | 2008-02-22 | 2009-02-20 | 261d? |  | finish no earlier than 2009-02-20 | G1 | 2088h | 2088h | CTLATRED-BTStest | Ericsson | Rel-8 | Paolo |  | PCG-21 | 51.021 |  |  |  |
| 718 | 199 | MS conformance testing of changes introduced by WI “Support of Packet-switched Handover for GERAN A/Gb mode” |  | 196d? | 2008-02-22 A | 2008-11-21 A | 100% |  | 2008-02-22 | 2008-11-21 | 196d? |  | finish no earlier than 2008-11-21 | G3new | 1568h | 1568h | PSHCT-MStest | Rohde & Schwarz | Rel-8 | Ingbert |  | PCG-21 | 51.010 |  |  |  |
| 719 | 200 | (Small) Technical Enhancements and Improvements for Rel-8 |  | 509d? | 2007-01-01 A | 2008-12-11 A | 100% |  | 2007-01-01 | 2008-12-11 | 509d? |  | finish no earlier than 2008-12-11 | All | 4072h | 4072h | TEI8 | ALL | Rel-8 |  |  |  |  |  |  |  |
| 720 | 201 | Test - (Small) Technical Enhancements and Improvements for Rel-8 |  | 402d? | 2008-05-30 A | 2009-12-11 | 80% | 80.4d? | 2008-05-30 | 2009-12-11 | 402d? | 721d | finish no earlier than 2009-12-11 | R5 | 3216h | 2572.8h | TEI8_Test | ALL | Rel-8 | Ingbert |  | PCG-21 |  | RP-40 |  |  |
| 721 | 202 | **Deleted - All-IP Network** |  | 448d? | 2004-06-28 A | 2006-03-15 A | 100% |  | 2004-06-28 | 2006-03-15 | 448d? |  |  | S1 | 7168h | 7168h | AIPN | NTT DoCoMo | Rel-8 | Alain |  |  |  |  | SP-38 |  |
| 722 | 202.1 | Deleted - Stage 1 |  | 448d? | 2004-06-28 A | 2006-03-15 A | 100% |  | 2004-06-28 | 2006-03-15 | 448d? |  | finish no earlier than 2006-03-15 | S1 | 3584h | 3584h | AIPN | NTT DoCoMo | Rel-8 | Alain |  |  | 22.258 |  | SP-38 |  |
| 723 | 203 | Deleted - was Rel7 - LCS for 3GPP Interworking WLAN | milestone | 0d? | 2007-09-28 A | 2007-09-28 A | 100% |  | 2007-09-28 | 2007-09-28 | 0d? |  | start no earlier than 2007-09-28 | S2 |  |  | LCS4_IWLAN | LG Electronics | Rel-8 | Maurice |  |  | 23.234, 23.271, 23.167 |  | SP-35 |  |
| 724 | 204 | Deleted - never approved- FBI Phase 2 | milestone | 0d | 2007-09-28 A | 2007-09-28 A | 100% |  | 2007-09-28 | 2007-09-28 | 0d |  | start no earlier than 2007-09-28 | S2 |  |  | FBI2 | Nokia Siemens Networks | Rel-8 | Maurice |  |  |  |  | SP-38 |  |
| 725 | 205 | Deleted -Enhancements to BS30 Bearer service for Videotelephony | milestone | 0d? | 2007-03-15 A | 2007-03-15 A | 100% |  | 2007-03-15 | 2007-03-15 | 0d? |  | finish no earlier than 2007-03-15 | S1 |  |  | BS30 |  | Rel-8 | Alain |  |  | 22.002, 22.004, 22.101, 22.105, 24.008 |  | SP-38 |  |
| 726 | 206 | Deleted - IMS Enhancements Rel-8 |  | 75d? | 2007-09-03 A | 2007-12-14 A | 100% |  | 2007-09-03 | 2007-12-14 | 75d? |  |  | S1 | 600h | 600h | IMS8 | Telecom Italia | Rel-8 | Alain |  |  |  | SP-37 | SP-38 |  |
| 727 | 207 | Deleted - MS conformance testing of Support of Conversational Services in A/Gb mode via the PS domain |  | 401d? | 2008-02-25 A | 2009-09-04 A | 100% |  | 2008-02-25 | 2009-09-04 | 401d? |  | finish no earlier than 2009-09-04 | G3new | 3208h | 3208h | SCSAGBCT-MStest | Nokia | Rel-8 | Ingbert |  | PCG-21 | 51.010 |  | GP-43 | PCG-23 |
| 728 | 208 | Release 8 Studies | milestone | 0d? | 2008-03-20 | 2008-03-20 |  |  | 2008-03-20 | 2008-03-20 | 0d? | 1173d | finish no earlier than 2008-03-20 | CP,GP,RP,SP |  |  |  |  | Rel-8 |  |  |  |  |  |  |  |
| 729 | 209 | Study on Customised Alerting Tone (CAT) Requirements |  | 245d? | 2005-10-07 A | 2006-09-14 A | 100% |  | 2005-10-07 | 2006-09-14 | 245d? |  | start no earlier than 2005-10-07 | S1 | 1960h | 1960h | FS_CAT | China Mobile | Rel-8 | Alain |  |  | 22.982 |  |  |  |
| 730 | 210 | Study on Facilitating Machine to Machine Communication in GSM and UMTS (M2M) |  | 350d? | 2005-11-04 A | 2007-03-08 A | 100% |  | 2005-11-04 | 2007-03-08 | 350d? |  | finish no earlier than 2006-06-16 | S1 | 2800h | 2800h | FS_M2M | Siemens | Rel-8 | Alain |  |  | 22.868 |  |  |  |
| 731 | 211 | Study on Network Composition |  | 526d? | 2005-12-07 A | 2007-12-12 A | 100% |  | 2005-12-07 | 2007-12-12 | 526d? |  | finish no earlier than 2006-09-27 | S1 | 4208h | 4208h | FS_NetComp | Nokia Siemens Networks | Rel-8 | Alain |  |  | 22.980 |  |  |  |
| 732 | 212 | Study on Requirements of IMS Multimedia Conferencing |  | 330d? | 2006-06-08 A | 2007-09-12 A | 100% |  | 2006-06-08 | 2007-09-12 | 330d? |  | finish no earlier than 2007-03-21 | S1 | 2640h | 2640h | FS_IMSconf | China Mobile | Rel-8 | Alain |  |  | 22.948 |  |  |  |
| 733 | 213 | Study on support of a Public Warning System |  | 140d? | 2007-09-03 A | 2008-03-14 A | 100% |  | 2007-09-03 | 2008-03-14 | 140d? |  |  | S1 | 1120h | 1120h | FS_PWS | T-Mobile | Rel-8 | Alain |  |  | 22.968 |  |  |  |
| 734 | 214 | Study on Paging Permission with Access Control |  | 256d? | 2006-09-28 A | 2007-09-20 A | 100% |  | 2006-09-28 | 2007-09-20 | 256d? |  | finish no earlier than 2007-09-20 | S1 | 2048h | 2048h | FS_PPAC | NTT DoCoMo | Rel-8 | Alain |  |  | 22.908 |  |  |  |
| 735 | 215 | Study on Non 3GPP access NSP |  | 392d? | 2006-12-06 A | 2008-06-05 A | 100% |  | 2006-12-06 | 2008-06-05 | 392d? |  | finish no earlier than 2007-11-19 | S1 | 3136h | 3136h | FS_N3GtoNSP | Telefonica O2 | Rel-8 | Alain |  |  | 22.912 |  |  |  |
| 736 | 216 | Study on Value Added Services for Short Message Service |  | 263d? | 2006-12-06 A | 2007-12-07 A | 100% |  | 2006-12-06 | 2007-12-07 | 263d? |  | finish no earlier than 2007-12-07 | S1 | 2104h | 2104h | FS_VAS4SMS | China Mobile | Rel-8 | Alain |  |  | 22.942 |  |  |  |
| 737 | 217 | Study on Service continuity between mobile and WLAN networks |  | 262d? | 2006-12-06 A | 2007-12-06 A | 100% |  | 2006-12-06 | 2007-12-06 | 262d? |  | finish no earlier than 2008-12-25 | S1 | 2096h | 2096h | FS_SMLSWLAN | BT | Rel-8 | Alain |  |  | 22.937 |  |  |  |
| 738 | 218 | Study on Services Alignment and Migration |  | 331d? | 2006-12-06 A | 2008-03-12 A | 100% |  | 2006-12-06 | 2008-03-12 | 331d? |  | finish no earlier than 2007-09-20 | S1 | 2648h | 2648h | FS_ServAl | China Mobile | Rel-8 | Alain |  |  | 22.983 | SP-37 |  |  |

Notes:
- 708: GP#40 completed. Align with RANimp-ANSS ongoing work item. GP#40 WID updated GP-080776=>GP-081784 (Conformance testing moved to A-GNSS WID) / Text5: Mungal Dhanda
- 709: SP#42 completed by 22.071 CR0077
- 710: GP#40 completed. Align with RANimp-ANSS ongoing work item. GP#40 WID updated GP-080776=>GP-081784 (Conformance testing moved to A-GNSS WID) / Text5: Mungal Dhanda
- 711: SR in RP-080813. RP#42 WI closed at 95%. GERAN leading the work / considers performance requirements for Rel-9 / Text5: Etienne Chaponniere (echaponn@qualcomm.com)
- 712: GP#43 completion 09/09=>11/09 (was 05/09). Linked to Rel-10 RAN4 UID_450027 (A-GNSS Minimum Performance for UTRAN) / Text5: Michel.monnerat@thalesaleniaspace.com
- 713: GP#43 completion 09/09=>11/09 (was 05/09) / Text5: Michel.monnerat@thalesaleniaspace.com
- 714: GP#43 completion 09/09=>11/09 (was 05/09) / Text5: Michel.monnerat@thalesaleniaspace.com
- 715: GP#41 completion 09/09=>11/09 / Text5: mats.y.samuelsson@ericsson.com, hakan.e.grunditz@ericsson.com
- 716: GP#41 completion 09/09=>11/09 / Text5: hakan.e.grunditz@ericsson.com
- 717: GP#41 completed / Text5: mats.y.samuelsson@ericsson.com
- 718: GP#40 completed / Text5: Franz.Segerer@ROHDE-SCHWARZ.COM
- 719: -
- 720: -
- 721: SP#38 stopped. 25/07/08 Moved UID_31059 Study on All-IP Network (FS_AIPN/was AIPFS ) to Rel-7 out of the stopped Rel-8 Feature UID_31067 Deleted - All-IP Network (AIPN) / Text5: c.masyu@nttdocomo.co.jp
- 722: 22.258 withdrawn, superseded by 22.278 (UID 320022). SP#38 stopped / Text5: c.masyu@nttdocomo.co.jp
- 723: SP-35 stopped / Text5: dhshim@lge.com
- 724: SP#38 stopped
- 725: SP#38 stopped (no support) / Text5: andre.jarvis@three.co.uk
- 726: SP#38 stopped
- 727: GP#43 work stopped/abandoned (completion 0%) / Text5: arsi.heino@nokia.com
- 728: -
- 729: Spin-off WID UID_370028 under Feature CAT UID_340029 / Text5: fenglingjuan@chinamobile.com
- 730: SP#35 completed. Spin-off SA3 SID UID_370053. SP#40 Spin-off new Feature UID_410030 (NIMTC) / Text5: Juergen Merkel
- 731: SP#38 completed / Text5: Joerg Swetina (joerg.swetina@nw.neclab.eu)
- 732: SP#37 completed. Spin-off New Feature UID_370026 (VAS4SM) / Text5: zhengjianping@chinamobile.com
- 733: SP#39 completed. Spin-off Rel-9 Feature UID_380057 (PWS) / Text5: mark.younge@t-mobile.com
- 734: SP#37 completed. Spin-off new Feature UID_370084 (PPACR) / Text5: noguchi@nttdocomo.co.jp
- 735: SP#38 completed. Spin-off New Feature UID_380062 (N3GTONSP). SP#40 WID updated SP-060930=>SP-080318. TR re-approved with new # 22.812=>22.912 / Text5: chris.friel@o2.com
- 736: SP#38 completed. Spin-off New Feature UID_370026 (VAS4SM) / Text5: wubin@chinamobile.com
- 737: SP#38 completed / Text5: mike.meyerstein@bt.com
- 738: SP#39 completed. Spin-off Feature UID_330017 (ServAl) / Text5: fenglingjuan@chinamobile.com

| ID | WBS | Task | Duration | Start | Finish | Complete | Remaining | Baseline start | Baseline finish | Baseline duration | Total slack | Constraint | Resources | Work | Actual work | Text1 | Text4 | Text5 | Text6 | Text8 | Text3 | Text2 | Text7 | Text11 | Text9 | Text12 |
| --- | --- | --- | --- | --- | --- | --- | --- | --- | --- | --- | --- | --- | --- | --- | --- | --- | --- | --- | --- | --- | --- | --- | --- | --- | --- | --- |
| 739 | 219 | **Study on 3GPP System Architecture Evolution** | 1115d? | 2004-12-03 A | 2009-03-12 A | 100% |  | 2004-12-03 | 2009-03-12 | 1115d? |  |  | S2,S3 | 23456h | 23456h | FS_SAE | Vodafone | Chris Pudney | Rel-8 | Maurice |  |  |  |  |  |  |
| 740 | 219.1 | Stage 2 Interim conclusion for RAN Work to start | 990d? | 2004-12-03 A | 2008-09-18 A | 100% |  | 2004-12-03 | 2008-09-18 | 990d? |  | finish no earlier than 2005-09-23 | S2 | 7920h | 7920h | FS_SAE | Vodafone | Chris Pudney | Rel-8 | Maurice | 23.882 |  |  |  |  |  |
| 741 | 219.2 | Stage 2 study on 3GPP architectural development | 704d? | 2006-01-09 A | 2008-09-18 A | 100% |  | 2006-01-09 | 2008-09-18 | 704d? |  | finish no earlier than 2007-09-28 | S2 | 5632h | 5632h | FS_SAE | Vodafone | Chris Pudney | Rel-8 | Maurice | 23.882 |  |  |  |  |  |
| 742 | 219.3 | Security study for Inter-access mobility between non-3GPP and 3GPP system | 334d? | 2007-09-03 A | 2009-03-12 A | 100% |  | 2007-09-03 | 2009-03-12 | 334d? |  | finish no earlier than 2009-03-12 | S3 | 2672h | 2672h | FS_SAE | Nokia | dajiang.zhang@nokia.com | Rel-8 | Dionisio | 33.821, 33.822 |  |  |  |  |  |
| 743 | 220 | Study on Stage 2 aspects of IMS Service Brokering | 589d? | 2006-06-19 A | 2008-09-18 A | 100% |  | 2006-06-19 | 2008-09-18 | 589d? |  | finish no earlier than 2008-09-18 | S2 | 4712h | 4712h | FS_ISB_ST2 | Telcordia | raquel@research.telcordia.com | Rel-8 | Maurice | 23.810 |  |  |  |  |  |
| 744 | 221 | Study on IMS utilizing multicast bearer services | 447d? | 2006-03-22 A | 2007-12-06 A | 100% |  | 2006-03-22 | 2007-12-06 | 447d? |  | finish no earlier than 2007-12-03 | S2 | 3576h | 3576h | FS_MLTICAST-IMS | Nokia Siemens Networks |  | Rel-8 | Maurice | 23.847 |  |  |  |  |  |
| 745 | 222 | Study on Mobility between 3GPP-WLAN Interworking and 3GPP Systems | 393d? | 2007-03-20 A | 2008-09-18 A | 100% |  | 2007-03-20 | 2008-09-18 | 393d? |  | finish no earlier than 2008-09-18 | S2 | 3144h | 3144h | FS_SM3GWLAN | Orange |  | Rel-8 | Maurice | 23.827 withdrawn |  |  |  |  |  |
| 746 | 223 | Study on Multimedia Session Continuity | 291d? | 2007-04-26 A | 2008-06-05 A | 100% |  | 2007-04-26 | 2008-06-05 | 291d? |  | finish no earlier than 2008-06-05 | S2 | 2328h | 2328h | FS_MMSC | LG Electronics |  | Rel-8 | Maurice | 23.893 |  |  |  |  |  |
| 747 | 224 | **Study on centralized IMS service control** | 363d? | 2006-10-23 A | 2008-03-12 A | 100% |  | 2006-10-23 | 2008-03-12 | 363d? |  |  | S2,S1 | 7952h | 7952h | FS_ICS | Ericsson | peter.bleckert@ericsson.com | Rel-8 | Alain |  | PCG-21 | SP-38 |  |  |  |
| 748 | 224.1 | Study on centralized IMS services requirements | 268d? | 2007-03-05 A | 2008-03-12 A | 100% |  | 2007-03-05 | 2008-03-12 | 268d? |  | start no earlier than 2007-03-05 | S1 | 2144h | 2144h | FS_ICS-S1 | Ericsson | peter.bleckert@ericsson.com | Rel-8 | Alain | 22.892 |  | SP-37 |  |  |  |
| 749 | 224.2 | Study on centralized IMS services control | 363d? | 2006-10-23 A | 2008-03-12 A | 100% |  | 2006-10-23 | 2008-03-12 | 363d? |  | finish no earlier than 2008-02-21 | S2 | 2904h | 2904h | FS_IMS_CSC | Alcatel-Lucent | Andy Bennett (andybennett@alcatel-lucent.com) | Rel-8 | Maurice | 23.892 |  |  |  |  |  |
| 750 | 225 | Study on Architecture of IMS based Customized Alerting Tone (CAT) | 208d? | 2007-12-04 A | 2008-09-18 A | 100% |  | 2007-12-04 | 2008-09-18 | 208d? |  | finish no earlier than 2008-09-08 | S2 | 1664h | 1664h | FS_CAT-St2 | China Mobile | WANG, Jing (wangjing@chinamobilecom) | Rel-8 | Maurice | 23.872 | PCG-21 | SP-38 |  |  |  |
| 751 | 226 | Study on Home (e)NodeB Security | 321d? | 2007-12-20 A | 2009-03-12 A | 100% |  | 2007-12-20 | 2009-03-12 | 321d? |  | finish no earlier than 2009-03-10 | S3 | 2568h | 2568h | FS_HNB_Sec | Huawei | yangyanmei@huawei.com | Rel-8 | Dionisio | 33.820 | PCG-21 | SP-38 |  |  |  |
| 752 | 227 | Study on Transferring of emergency call data – in-band modem solution | 265d? | 2006-12-07 A | 2007-12-12 A | 100% |  | 2006-12-07 | 2007-12-12 | 265d? |  | finish no earlier than 2008-09-18 | S4 | 2120h | 2120h | eCALLIBMS | Airbiquity | lhong@airbiquity.com | Rel-8 | Paolo | 26.967 |  |  |  |  |  |
| 753 | 228 | Study on Element Operations Systems Function (EOSF) definition | 266d? | 2007-06-07 A | 2008-06-12 A | 100% |  | 2007-06-07 | 2008-06-12 | 266d? |  | finish no earlier than 2008-12-11 | S5 | 2128h | 2128h | OAM7-NIM- EOSF | China Mobile | LI, Jian | Rel-8 | Dionisio | 32.819 |  |  |  |  |  |
| 754 | 229 | Study on SA5 MTOSI XML Harmonization | 351d? | 2006-05-10 A | 2007-09-12 A | 100% |  | 2006-05-10 | 2007-09-12 | 351d? |  | finish no earlier than 2007-12-14 | S5 | 2808h | 2808h | OAM7-NIM-XML | Nortel | jduguay@nortel.com | Rel-8 | Dionisio | 32.818 |  |  |  |  |  |
| 755 | 230 | Study on Common Profile Storage (CPS) Framework of User Data for network services and management | 244d? | 2006-07-03 A | 2007-06-07 A | 100% |  | 2006-07-03 | 2007-06-07 | 244d? |  | finish no earlier than 2007-06-07 | S5 | 1952h | 1952h | OAM7-CPS | T-Mobile | istvan.aba@t-mobile.at | Rel-8 | Dionisio | 32.808 |  |  |  |  |  |
| 756 | 231 | Study on Management for LTE and SAE | 526d? | 2006-12-07 A | 2008-12-11 A | 100% |  | 2006-12-07 | 2008-12-11 | 526d? |  | finish no earlier than 2008-12-11 | S5 | 4208h | 4208h | FS_OAM_LTE_SAE | Ericsson | PETERSEN, Robert | Rel-8 | Dionisio | 32.816 |  |  |  |  |  |
| 757 | 232 | Study on Charging Aspects of 3GPP System Evolution | 179d? | 2007-04-02 A | 2007-12-06 A | 100% |  | 2007-04-02 | 2007-12-06 | 179d? |  | finish no earlier than 2007-12-06 | S5 | 1432h | 1432h | FS_SAEcharg | Nokia Siemens Networks | GÖRMER, Gerald | Rel-8 | Dionisio | 32.820 |  |  |  |  |  |
| 758 | 233 | Study on AS-MRFC media server control protocol | 583d? | 2006-03-22 A | 2008-06-13 A | 100% |  | 2006-03-22 | 2008-06-13 | 583d? |  | finish no earlier than 2008-06-13 | C1 | 4664h | 4664h | MRFC | HP | mark.syrett@hp.com | Rel-8 | Frederic | 24.880 |  |  |  |  |  |
| 759 | 234 | Study on IMS Restoration Procedures | 310d? | 2007-03-26 A | 2008-05-30 A | 100% |  | 2007-03-26 | 2008-05-30 | 310d? |  | finish no earlier than 2008-05-30 | C4 | 2480h | 2480h | FS_IMS_RP | Ericsson | german.blanco@ericsson.com | Rel-8 | Kimmo | 23.820 |  |  |  |  |  |
| 760 | 235 | Study on IMS Application Server Service Data Descriptions for AS interoperability | 261d? | 2007-09-14 A | 2008-09-12 A | 100% |  | 2007-09-14 | 2008-09-12 | 261d? |  | finish no earlier than 2008-09-12 | C4 | 2088h | 2088h | FS_IMS_ASIO | Alcatel-Lucent | Jean-Jacques Trottin | Rel-8 | Kimmo | 29.864 |  |  |  |  |  |
| 761 | 236 | Study on Customized Alerting Tone (CAT) solution for voice and video call in CS domain | 261d? | 2007-09-14 A | 2008-09-12 A | 100% |  | 2007-09-14 | 2008-09-12 | 261d? |  |  | C4 | 626.4h | 626.4h | FS_CAT_VVC_CS | China Mobile | zhanghao@chinamobile.com | Rel-8 | Kimmo | 29.882 |  |  |  |  |  |
| 762 | 237 | Study on InterWorking Function between MAP based and Diameter based interfaces | 266d? | 2007-11-30 A | 2008-12-05 A | 100% |  | 2007-11-30 | 2008-12-05 | 266d? |  | finish no earlier than 2008-12-05 | C4 | 2128h | 2128h | FS_MAP2Diam | Huawei | liming49985@huawei.com | Rel-8 | Kimmo | 29.805 | PCG-21 | CP-38 |  |  |  |
| 763 | 238 | Study on Scope of future HSPA Evolution for 1.28 Mcps TDD | 186d? | 2007-09-14 A | 2008-05-30 A | 100% |  | 2007-09-14 | 2008-05-30 | 186d? |  | finish no earlier than 2008-05-30 | R1 | 1488h | 1488h | FS_RAN-LCRTDDHSPAEvo | RITT | Xu Fei | Rel-8 | Patrick | 25.824 |  | RP-37 | RP-080290 |  |  |
| 764 | 239 | Study on Synchronized E-DCH for UTRA FDD | 126d? | 2007-09-14 A | 2008-03-07 A | 100% |  | 2007-09-14 | 2008-03-07 | 126d? |  | finish no earlier than 2008-03-14 | R1 | 1008h | 1008h | FS_RAN-UplinkSync | Nokia Siemens Networks | Karri.Ranta-aho@nsn.com | Rel-8 | Patrick | 25.823 |  | RP-37 | RP-080068 |  |  |
| 765 | 240 | Study on Improved network controlled mobility between LTE and 3GPP2/mobile WiMAX radio technologies | 131d? | 2007-06-04 A | 2007-12-03 A | 100% |  | 2007-06-04 | 2007-12-03 | 131d? |  | finish no earlier than 2007-12-03 | R4 | 1048h | 1048h | FS_RAN-LTEmob | Motorola | hao.bi@Motorola.com | Rel-8 | Stefania | 36.938 |  |  | RP-070827 |  |  |
| 766 | 241 | Study on 3G Home NodeB/eNodeB | 325d? | 2007-03-05 A | 2008-05-30 A | 100% |  | 2007-03-05 | 2008-05-30 | 325d? |  | finish no earlier than 2008-05-30 | R4 | 2600h | 2600h | FS_RAN-HNBeNB | Motorola | howard.thomas@motorola.com | Rel-8 | Stefania | 25.820 |  |  | RP-080289 |  |  |
| 767 | 242 | Study on HS-PDSCH serving cell change enhancements | 60d? | 2007-12-17 A | 2008-03-07 A | 100% |  | 2007-12-17 | 2008-03-07 | 60d? |  | finish no earlier than 2008-06-12 | R4 | 480h | 480h | FS_RAN-HSPDSCH | Qualcomm Europe |  | Rel-8 | Stefania | none | PCG-21 | RP-38 | RP-080070 |  |  |
| 768 | 243 | Study on Dual-Cell HSDPA operation | 261d? | 2007-08-15 A | 2009-03-06 A | 100% |  | 2007-08-15 | 2009-03-06 | 261d? |  | finish no earlier than 2009-03-06 | R1 | 2088h | 2088h | FS_RAN-DCHS | Qualcomm Europe | Josef Blanz | Rel-8 | Patrick | withdrawn 25.825 v100 | PCG-21 | RP-39 | RP-090066 |  |  |
| 769 | 244 | Study on A-interface over IP | 126d? | 2007-08-31 A | 2008-02-22 A | 100% |  | 2007-08-31 | 2008-02-22 | 126d? |  | finish no earlier than 2008-02-22 | GP | 1008h | 1008h | AINTIP | China Mobile, Ericsson | paul.schliwa-bertling@ericsson.com | Rel-8 | Paolo | 43.903 |  |  |  |  |  |
| 770 | 245 | Study on Multi-User Reusing-One-Slot | 527d? | 2007-11-16 A | 2009-11-20 | 98% | 10.54d? | 2007-11-16 | 2009-11-20 | 527d? | 736d | finish no earlier than 2009-11-20 | GP | 4208h | 4123.68h | MUROS | Nokia Siemens Networks | juergen.hofmann@nsn.com | Rel-8 | Paolo | 45.914 |  |  |  |  |  |
| 771 | 246 | Study on Optimized Transmit Pulse Shape for Downlink EGPRS2-B | 527d? | 2007-11-16 A | 2009-11-20 | 95% | 26.35d? | 2007-11-16 | 2009-11-20 | 527d? | 736d | finish no earlier than 2009-11-20 | G1 | 4208h | 3997.2h | WIDER | RIM, Nokia Siemens Networks | jdwyer@RIM.COM and eddie.riddington@nsn.com | Rel-8 | Paolo | 45.913 |  |  |  |  |  |
| 772 | 247 | Deleted - equals 340035 -FS on Service continuity between mobile and WLAN networks | 75d? | 2007-09-03 A | 2007-12-14 A | 100% |  | 2007-09-03 | 2007-12-14 | 75d? |  | finish no earlier than 2007-12-14 | S1 | 600h | 600h | FSSCMobToW | BT | mike.meyerstein@bt.com | Rel-8 | Alain | 22.937 |  | SP-37 |  | PCG-21 | SP-39 |
| 773 | 248 | Deleted - Study on Evaluation of LCS Control Plane Solution for EPS | 100d? | 2008-01-14 A | 2008-05-30 A | 100% |  | 2008-01-14 | 2008-05-30 | 100d? |  | finish no earlier than 2009-03-20 | S2 | 800h | 800h | FS_LCS_EPS | SiRF |  | Rel-8 | Maurice | 23.891 |  | SP-38 |  | PCG-21 | SP-40 |
| 774 | 249 | Release 7 Features | 1d? | 2000-01-03 | 2000-01-03 |  |  | 2000-01-03 | 2000-01-03 | 1d? | 3317d | start no earlier than 2000-01-01 | CP,GP,RP,SP | 8h |  |  |  |  | Rel-7 |  |  |  |  |  |  |  |

Notes:
- 739: SP#43 completed
- 740: SP#41 completed
- 741: SP#41 completed
- 742: SP#43 completed
- 743: SP#41 completed. No spin-off activity proposed. [Note: IMS Service Brokering enhancements UID_31088 moved back from R8 to R7 to give a home to 22228CR0036_(Rel-7)_S1-051232. Hence, Rel-7 ISB has Stage 1 only (and is misaligned with Rel-7 Stages 2/3.]
- 744: SP#38 completed
- 745: 08/08/08 TR 23.827 v 0.4.0 no progress for 1 year. MCC recommended FS be completed and 23.827 brought under CR. SP#41 completed (draft TR 23.827 not SA approved/published; TR content implemented in TSs)
- 746: SP#40 completed
- 747: SP#39 completed
- 748: SP#39 completed
- 749: SP#39 completed
- 750: SP#41 completed as Rel-8
- 751: SP#43 completed as Rel-8
- 752: SP#38 completed. Spin-off WID UID_34042 (eCall_Phase2)
- 753: SP#40 completed. SID updated SP-050608=>SP-070307
- 754: SP#37 completed. SID updated SP-050295=>SP-070305
- 755: SP#36 completed. Spin-off New Feature UID_400034 (UDC)
- 756: SP#42 completed
- 757: SP#38 completed
- 758: CP#40 completed. Spin-off New Feature UID_380035 (MRFC_TS)
- 759: CP#40 completed. Spin-off WID UID_400012 (IMS_RP)
- 760: CP#41 completed. Linked to SA5 Study on Common Profile Storage framework UID_320006. Spin-off WID UID_410003 (IMS_ASIO)
- 761: CP#41 completed. Spin-off WID under Feature CAT UID_340029
- 762: CP#41 Spin-off WID UID_410007 (MAP2Diam). CP#42 completed
- 763: RP#40 completed. SR in RP-080290
- 764: SID in RP-070678. RP#39 completed. SR in RP-080068
- 765: RP#38 completed. SR in RP-070827
- 766: RP#40 completed. SR in RP-080289
- 767: SID in RP-071044. SR in RP-080070. The study produced no TR. RP#39 completed. Spin-off New implementation WID in RP-080227
- 768: RP#43 closed. TR 25.825 v100 withdrawn. Conclusions in RP-090318 RAN1 findings of the UTRA Multi-Carrier Evolution study). RP#42 New WID RP-080490 (RANimp-DCHSDPA) UID_400052 approved
- 769: GP#37 completed. Spin-off implementation Feature AoIP (A-interface over IP) UID_50591
- 770: GP#43 completion 09/09=>11/09 (was 11/08=>02/09=>05/09). Spin-off implementation WI UID_420002 VAMOS (Voice services over Adaptive Multi-user channels on One Slot)
- 771: GP#43 completion 09/09=>11/09 (was 11/08=>02/09=>05/09). Needs some more work to define possible Rel-9 or Rel-10 implementation work
- 772: SP#39 stopped
- 773: SP#40 spin-off Feature UID_400038 (LCS_CPS_EPS). SP#40 FS stopped
- 774: -

| ID | WBS | Task | Type | Duration | Start | Finish | Complete | Baseline start | Baseline finish | Baseline duration | Constraint | Resources | Work | Actual work | Text1 | Text4 | Text5 | Text6 | Text8 | Text12 | Text11 | Text7 | Text2 |
| --- | --- | --- | --- | --- | --- | --- | --- | --- | --- | --- | --- | --- | --- | --- | --- | --- | --- | --- | --- | --- | --- | --- | --- |
| 775 | 250 | **Identification of Communication Services in IMS** |  | 620d? | 2005-05-02 A | 2007-09-14 A | 100% | 2005-05-02 | 2007-09-14 | 620d? |  | S2,S1,C1,S5 | 13016h | 13016h | ServID | Ericsson | stephen.terrill@ericsson.com | Rel-7 | Maurice |  |  |  |  |
| 776 | 250.1 | TR on ServID |  | 232d? | 2005-05-02 A | 2006-03-21 A | 100% | 2005-05-02 | 2006-03-21 | 232d? | finish no earlier than 2006-03-20 | S2 | 1856h | 1856h | ServID | Ericsson | stephen.terrill@ericsson.com | Rel-7 | Maurice |  |  |  |  |
| 777 | 250.2 | Stage 1,2 of ServID |  | 144d? | 2005-11-11 A | 2006-05-31 A | 100% | 2005-11-11 | 2006-05-31 | 144d? | start no earlier than 2005-11-11 | S1,S2 | 1152h | 1152h | ServID | Ericsson | stephen.terrill@ericsson.com | Rel-7 | Maurice |  |  |  |  |
| 778 | 250.3 | Stage 3 of ServID |  | 250d? | 2006-03-31 A | 2007-03-15 A | 100% | 2006-03-31 | 2007-03-15 | 250d? | finish no earlier than 2007-03-15 | C1 | 2000h | 2000h | ServID | Ericsson | christer.holmberg@ericsson.com | Rel-7 | Frederic |  |  |  |  |
| 779 | 250.4 | Charging of ServID |  | 381d? | 2006-03-31 A | 2007-09-14 A | 100% | 2006-03-31 | 2007-09-14 | 381d? | finish no earlier than 2007-09-14 | S5 | 3048h | 3048h | ServID | Orange | alain.bibas@orange-ft.com | Rel-7 | Dionisio |  |  |  |  |
| 780 | 251 | **Supporting Globally Routable User Agent URIs in IMS** |  | 415d? | 2005-11-14 A | 2007-06-15 A | 100% | 2005-11-14 | 2007-06-15 | 415d? |  | S2,S1,C1 | 7760h | 7760h | GRUU | RIM | Adrian Buckley (abuckley@rim.com) | Rel-7 | Maurice |  |  |  |  |
| 781 | 251.1 | Deleted - TR on GRUU |  | 219d? | 2005-11-14 A | 2006-09-14 A | 100% | 2005-11-14 | 2006-09-14 | 219d? | finish no earlier than 2006-09-14 | S2 | 1752h | 1752h | GRUU | RIM | Adrian Buckley (abuckley@rim.com) | Rel-7 | Maurice | SP-32 |  |  |  |
| 782 | 251.2 | Stage 1,2 of GRUU |  | 65d? | 2006-07-03 A | 2006-09-29 A | 100% | 2006-07-03 | 2006-09-29 | 65d? | start no earlier than 2006-07-03 | S1,S2 | 520h | 520h | GRUU | RIM | Adrian Buckley (abuckley@rim.com) | Rel-7 | Maurice |  |  |  |  |
| 783 | 251.3 | Stage 3 of GRUU |  | 271d? | 2006-06-02 A | 2007-06-15 A | 100% | 2006-06-02 | 2007-06-15 | 271d? | finish no earlier than 2007-06-15 | C1 | 2168h | 2168h | GRUU | CableLabs | Bernie McKibben | Rel-7 | Frederic |  |  |  |  |
| 784 | 252 | **Multimedia Telephony Service for IMS** |  | 357d? | 2006-02-01 A | 2007-06-15 A | 100% | 2006-02-01 | 2007-06-15 | 357d? |  | S1,C1,S4 | 8976h | 8976h | MTSI | Ericsson | peter.bleckert@ericsson.com | Rel-7 | Alain |  |  |  |  |
| 785 | 252.1 | Stage 1 of MTSI |  | 173d? | 2006-02-01 A | 2006-09-29 A | 100% | 2006-02-01 | 2006-09-29 | 173d? | start no earlier than 2006-02-01 | S1 | 1384h | 1384h | MTSI-REQ | Ericsson | peter.bleckert@ericsson.com | Rel-7 | Alain |  |  |  |  |
| 786 | 252.2 | Stage 3 of MTSI |  | 330d? | 2006-03-10 A | 2007-06-14 A | 100% | 2006-03-10 | 2007-06-14 | 330d? | finish no earlier than 2007-06-15 | C1 | 2640h | 2640h | MTSI | Ericsson | christer.holmberg@ericsson.com | Rel-7 | Frederic |  |  |  |  |
| 787 | 252.3 | Media handling and interaction in MTSI |  | 262d? | 2006-03-15 A | 2007-03-15 A | 100% | 2006-03-15 | 2007-03-15 | 262d? | finish no earlier than 2007-03-15 | S4 | 2096h | 2096h | MTSI-MHI | Ericsson | olle.franceschi@ericsson.com | Rel-7 | Paolo |  |  |  |  |
| 788 | 252.4 | Deleted - duplicates UID7039 - IMS Multimedia Telephony Service | milestone | 0d? | 2007-06-15 A | 2007-06-15 A | 100% | 2007-06-15 | 2007-06-15 | 0d? | start no earlier than 2007-06-15 | S1 |  |  | MMTEL | Ericsson | peter.bleckert@ericsson.com | Rel-7 | Alain | SP-32 |  |  |  |
| 789 | 253 | Multimedia Telephony Service for IMS (MTSI) - UE Conformance Testing |  | 387d | 2007-09-19 A | 2009-03-12 A | 100% | 2007-09-19 | 2009-03-12 | 387d | finish no earlier than 2009-03-13 | R5 | 1664h | 1664h | MTSI-UEConfTest | Ericsson, Motorola | Leif.Mattisson@ericsson.com, Jacob.John@motorola.com | Rel-7 | Ingbert |  | RP-090056 |  |  |
| 790 | 254 | TISPAN requirements for Multimedia Telephony with PSTN/ISDN simulation services |  | 58d? | 2007-09-18 A | 2007-12-06 A | 100% | 2007-09-18 | 2007-12-06 | 58d? | start no earlier than 2007-09-18 | S1 | 464h | 464h | TMMTEL7 |  |  | Rel-7 | Alain |  |  | SP-37 |  |
| 791 | 255 | **Maintenance of TISPAN release 1 common IMS** |  | 58d? | 2007-09-18 A | 2007-12-06 A | 100% | 2007-09-18 | 2007-12-06 | 58d? |  | S2 | 1392h | 1392h | MCIMSTR1 | Ericsson | Raymond Forbes | Rel-7 | Maurice |  |  | SP-38 | PCG-21 |
| 792 | 255.1 | SA1 aspects of MCIMSTR1 |  | 58d? | 2007-09-18 A | 2007-12-06 A | 100% | 2007-09-18 | 2007-12-06 | 58d? | finish no earlier than 2007-12-06 | S1 | 464h | 464h | MCIMSTR1-S1 | Telecom Italia | Marco.DeLuca1@telecomitalia.it | Rel-7 | Alain |  |  | SP-38 | PCG-21 |
| 793 | 255.2 | SA2 aspects of MCIMSTR1 |  | 58d? | 2007-09-18 A | 2007-12-06 A | 100% | 2007-09-18 | 2007-12-06 | 58d? | finish no earlier than 2007-12-06 | S2 | 464h | 464h | MCIMSTR1-S2 | Ericsson | Raymond Forbes | Rel-7 | Maurice |  |  | SP-38 | PCG-21 |
| 794 | 256 | **PS domain and IMS impacts for supporting IMS Emergency calls** |  | 1760d? | 2000-09-18 A | 2007-06-15 A | 100% | 2000-09-18 | 2007-06-15 | 1760d? |  | S2,S1 | 44157h | 44157h | EMC1 | Siemens | Rainer Liebhart | Rel-7 | Maurice |  |  |  |  |
| 795 | 10.1.1 | Service Requirements for IP-based emergency calls |  | 985d | 2000-09-18 A | 2004-06-25 A | 100% | 2000-09-18 | 2004-06-25 | 985d | finish no earlier than 2004-06-25 | S1 | 7880h | 7880h | EMC1 | Siemens | Rainer Liebhart | Rel-7 | Alain |  |  |  |  |
| 796 | 256.2 | Study on Stage 2 for IMS-level solution |  | 668d? | 2003-02-26 A | 2005-09-16 A | 100% | 2003-02-26 | 2005-09-16 | 668d? | finish no earlier than 2005-09-16 | S2 | 5344h | 5344h | EMC1 | Siemens | Rainer Liebhart | Rel-7 | Maurice |  |  |  |  |
| 797 | 256.3 | Study on Stage 2 for GPRS-level solution |  | 301d? | 2004-10-14 A | 2005-12-08 A | 100% | 2004-10-14 | 2005-12-08 | 301d? | finish no earlier than 2005-12-08 | S2 | 2408h | 2408h | EMC1 | Siemens | Rainer Liebhart | Rel-7 | Maurice |  |  |  |  |
| 798 | 256.4 | Stage 2 Specification Phase - IMS-level |  | 200d? | 2005-09-05 A | 2006-06-09 A | 100% | 2005-09-05 | 2006-06-09 | 200d? | finish no earlier than 2006-06-09 | S2 | 1600h | 1600h | EMC1 | Siemens | Rainer Liebhart | Rel-7 | Maurice |  |  |  |  |
| 799 | 256.5 | Deleted - Stage 2 Specification Phase - GPRS-level | milestone | 0d? | 2007-03-02 A | 2007-03-02 A | 100% | 2007-03-02 | 2007-03-02 | 0d? | start no earlier than 2007-03-02 | S2 |  |  | EMC1 | Siemens | Rainer Liebhart | Rel-7 | Maurice | SP-32 |  |  |  |

Notes:
- 775: WID approved SP#28. WID updated SP#32
- 776: - / Text3: 23.816
- 777: - / Text3: 22.228, 23.228, 23.203
- 778: CP#32 approved WID / Text3: 23.218, 24.229
- 779: - / Text3: 32.260, 32.298, 32.299
- 780: SP#29 approved WID
- 781: Abandoned
- 782: SP#29 approved WID / Text3: 22.228, 23.228, 23.218, 24.229
- 783: CP#32 approved WID / Text3: 24.229
- 784: -
- 785: - / Text3: 22.173
- 786: - / Text3: 24.173
- 787: - / Text3: 26.114
- 788: - / Text3: 22.173
- 789: RP#43 completed. Linked UID_7038 (MTSI) / Text3: 34.123-1, 34.123-2, 34.123-3, 34.229-1, 34.229-2
- 790: - / Text3: 22.273 (EI 181 002 maintenance)
- 791: - / Text3: http://www.3gpp.org/specs/TISPAN-IMS-ansfer.htm
- 792: - / Text3: 22.173, 22.273
- 793: - / Text3: 23.406, 23.417, 23.508,23.509, 23.511
- 794: -
- 795: - / Text3: 22.976 (DB shows 04/2003 withdrawn Study on PS domain services and capabilities (az: belongs this really here ?!)
- 796: - / Text3: 23.867
- 797: - / Text3: 23.867
- 798: - / Text3: 23.167, 23.228, 23.060, 23.002, 23.271
- 799: -

| ID | WBS | Task | Type | Duration | Start | Finish | Complete | Baseline start | Baseline finish | Baseline duration | Constraint | Resources | Work | Actual work | Text1 | Text4 | Text5 | Text6 | Text8 | Text3 | Text12 | Text10 | Text11 |
| --- | --- | --- | --- | --- | --- | --- | --- | --- | --- | --- | --- | --- | --- | --- | --- | --- | --- | --- | --- | --- | --- | --- | --- |
| 800 | 10.1 | **Emergency Call Enhancements for IP& PS Based Calls – stage 3** |  | 375d | 2006-01-09 A | 2007-06-15 A | 100% | 2006-01-09 | 2007-06-15 | 375d |  | C1 | 12845h | 12845h | EMC1 | Ericsson | alf.heidermark@ericsson.com | Rel-7 | Frederic |  |  |  |  |
| 801 | 10.1.2 | CT1 IMS aspects to support IMS Emergency sessions |  | 350.82d | 2006-01-09 A | 2007-06-15 A | 100% | 2006-01-09 | 2007-06-15 | 350.82d | finish no earlier than 2007-06-15 | C1 | 2806.57h | 2806.57h | EMC1 | Ericsson | alf.heidermark@ericsson.com | Rel-7 | Frederic | 24.229 |  |  |  |
| 802 | 10.1.2 | Deleted - CT3 IMS aspects to support IMS Emergency sessions |  | 95d | 2006-05-08 A | 2006-09-15 A | 100% | 2006-05-08 | 2006-09-15 | 95d | finish no earlier than 2006-09-15 | C3 | 760h | 760h | EMC1 | Ericsson | alf.heidermark@ericsson.com | Rel-7 | Gwiho | 29.163 | CP-33 |  |  |
| 803 | 10.1.5 | Deleted - CT3 PS domain aspects to support IMS Emergency sessions |  | 95d | 2006-05-08 A | 2006-09-15 A | 100% | 2006-05-08 | 2006-09-15 | 95d | start no earlier than 2006-05-08 | C3 | 760h | 760h | EMC1 | Ericsson | alf.heidermark@ericsson.com | Rel-7 | Gwiho | 29.061 | CP-33 |  |  |
| 804 | 10.1.5 | CT1 PS domain aspects to support IMS Emergency sessions |  | 349.9d | 2006-01-09 A | 2007-06-15 A | 100% | 2006-01-09 | 2007-06-15 | 349.9d | finish no earlier than 2007-06-15 | C1 | 2799.2h | 2799.2h | EMC1 | Ericsson | alf.heidermark@ericsson.com | Rel-7 | Frederic | 24.008, 24.234 |  |  |  |
| 805 | 10.1.5 | CT4 PS domain aspects to support IMS Emergency sessions |  | 365d | 2006-01-09 A | 2007-06-01 A | 100% | 2006-01-09 | 2007-06-01 | 365d | finish no earlier than 2007-06-01 | C4 | 2920h | 2920h | EMC1-GPRSc4 | Ericsson | alf.heidermark@ericsson.com | Rel-7 | Kimmo | 29.060 |  |  |  |
| 806 | 257 | IMS Support of Conferencing |  | 355d? | 2005-11-04 A | 2007-03-15 A | 100% | 2005-11-04 | 2007-03-15 | 355d? | finish no earlier than 2007-03-15 | C1 | 2840h | 2840h | IMSconf | Alcatel-Lucent | Keith Drage (drage@alcatel-lucent.com) | Rel-7 | Frederic | 24.147, 24.229 |  |  |  |
| 807 | 258 | Performance Characterization of VoIMS over HSDPA\EUL channels |  | 713d? | 2005-03-15 A | 2007-12-06 A | 100% | 2005-03-15 | 2007-12-06 | 713d? | finish no earlier than 2007-12-06 | S4 | 5704h | 5704h | VoIMS-PCVoIMS | Alcatel-Lucent | mcgowan@alcatel-lucent.com | Rel-7 | Paolo | 26.935 |  |  |  |
| 808 | 259 | **WLAN-UMTS Interworking Phase 2** |  | 371d? | 2004-01-05 A | 2005-06-07 A | 100% | 2004-01-05 | 2005-06-07 | 371d? |  | S1 | 3888h | 3888h | WLAN2 | Telenor | frederic.paint@telenor.com | Rel-7 | Alain | 33.234 (SP-36 SA3 CRs approved) |  |  |  |
| 809 | 259.1 | Stage 1 on Session Continuity |  | 115d? | 2004-01-05 A | 2004-06-11 A | 100% | 2004-01-05 | 2004-06-11 | 115d? | start no earlier than 2004-01-05 | S1 | 920h | 920h | WLAN-SC |  |  | Rel-7 | Alain | 22.234 |  | SP-24 |  |
| 810 | 259.2 | Stage 2 on Session Continuity: covered by SAE | milestone | 0d? | 2005-06-07 A | 2005-06-07 A | 100% | 2005-06-07 | 2005-06-07 | 0d? | finish no earlier than 2005-06-07 | S2 |  |  | WLAN-SC |  |  | Rel-7 | Maurice |  |  |  |  |
| 811 | 260 | **WLAN Interworking – Private Network access from WLAN 3GPP IP Access** |  | 252d? | 2005-10-10 A | 2006-09-26 A | 100% | 2005-10-10 | 2006-09-26 | 252d? |  | S2,C1,C3,C4 | 8936h | 8936h | WLANPNA | NEC | Toshiyuki Tamura (tamurato@aj.jp.nec.com) | Rel-7 | Maurice |  |  |  |  |
| 812 | 260.1 | WLAN-PNA - Stage 2 |  | 185d? | 2005-10-10 A | 2006-06-23 A | 100% | 2005-10-10 | 2006-06-23 | 185d? | start no earlier than 2005-10-10 | S2 | 1480h | 1480h | WLANPNA-st2 | NEC | Toshiyuki Tamura (tamurato@aj.jp.nec.com) | Rel-7 | Maurice | 23.234, 33.234 |  |  |  |
| 813 | 260.2 | **WLAN-PNA - Stage 3** |  | 170d? | 2006-02-01 A | 2006-09-26 A | 100% | 2006-02-01 | 2006-09-26 | 170d? |  | C1,C3,C4 | 5440h | 5440h | WLANPNA-st3 | NEC |  | Rel-7 | Frederic |  |  |  |  |
| 814 | 260.2.1 | CT1 aspets for WLAN-PNA |  | 170d? | 2006-02-01 A | 2006-09-26 A | 100% | 2006-02-01 | 2006-09-26 | 170d? | start no earlier than 2006-02-01 | C1 | 1360h | 1360h | WLANPNA-st3 | NEC |  | Rel-7 | Frederic | 24.234 |  |  |  |
| 815 | 260.2.2 | CT3 aspets for WLAN-PNA |  | 170d? | 2006-02-01 A | 2006-09-26 A | 100% | 2006-02-01 | 2006-09-26 | 170d? | start no earlier than 2006-02-01 | C3 | 1360h | 1360h | WLANPNA-st3 | NEC |  | Rel-7 | Gwiho | 29.161 |  |  |  |
| 816 | 260.2.3 | Deleted - CT4 aspets for WLAN-PNA |  | 170d? | 2006-02-01 A | 2006-09-26 A | 100% | 2006-02-01 | 2006-09-26 | 170d? | start no earlier than 2006-02-01 | C4 | 1360h | 1360h | WLANPNA-st3 | NEC |  | Rel-7 | Kimmo | 29.234 | CP-32 |  |  |
| 817 | 261 | **Enhancements to support QoS provisioning over 3GPP/WLAN Interworking** |  | 520d? | 2005-03-14 A | 2007-03-09 A | 100% | 2005-03-14 | 2007-03-09 | 520d? |  | S2,C4,C1 | 8360h | 8360h | WLANQOS | Samsung |  | Rel-7 | Maurice |  |  |  |  |
| 818 | 261.1 | Deleted - TR on support of QoS on WLAN |  | 232d? | 2005-03-14 A | 2006-01-31 A | 100% | 2005-03-14 | 2006-01-31 | 232d? | start no earlier than 2005-03-14 | S2 | 1856h | 1856h | WLANQOS | Samsung |  | Rel-7 | Maurice | 23.836 | SP-32 |  |  |
| 819 | 261.2 | Stage 2 on support of QoS over 3GPP/WLAN interworking |  | 108d? | 2006-02-01 A | 2006-06-30 A | 100% | 2006-02-01 | 2006-06-30 | 108d? | start no earlier than 2006-02-01 | S2 | 864h | 864h | WLANQOS | Samsung |  | Rel-7 | Maurice | 23.234 |  |  |  |
| 820 | 261.3 | Stage 3 CT4 on support of QoS over 3GPP/WLAN Interworking |  | 121d? | 2006-09-22 A | 2007-03-09 A | 100% | 2006-09-22 | 2007-03-09 | 121d? | finish no earlier than 2007-03-09 | C4 | 968h | 968h | WLANQOS | Huawei | zhang.peng@huawei.com | Rel-7 | Kimmo | 29.234, 23.008 |  |  |  |
| 821 | 261.4 | Stage 3 CT1 on support of QoS over 3GPP/WLAN Interworking |  | 64d? | 2006-09-04 A | 2006-11-30 A | 100% | 2006-09-04 | 2006-11-30 | 64d? | finish no earlier than 2006-11-30 | C1 | 512h | 512h | WLANQOS | Huawei | zhang.peng@huawei.com | Rel-7 | Frederic | 24.234 |  |  |  |
| 822 | 262 | **Location Services enhancements** |  | 906d? | 2004-06-28 A | 2007-12-17 A | 100% | 2004-06-28 | 2007-12-17 | 906d? |  | S1,S2,GP,C4,R2 | 46933.6h | 46933.6h | LCS3 |  |  | Rel-7 | Alain |  |  |  |  |
| 823 | 262.1 | Stage 2 for LCS3 (including IMS emergency location aspects) |  | 446d? | 2004-12-31 A | 2006-09-15 A | 100% | 2004-12-31 | 2006-09-15 | 446d? | finish no earlier than 2006-09-15 | S2 | 3568h | 3568h | LCS3 | SiRF | brodilitz@sirf.com | Rel-7 | Maurice | 23.271 |  |  |  |
| 824 | 262.2 | LCS Enhancements related to Location-Based Services |  | 695d? | 2005-01-03 A | 2007-08-31 A | 100% | 2005-01-03 | 2007-08-31 | 695d? | finish no earlier than 2007-08-31 | GP | 5560h | 5560h | LCS3-LBS | SiRF | kjudge@sirf.com | Rel-7 | Paolo | 43.059, 44.031, 48.008, 49.031 |  |  |  |
| 825 | 262.3 | CT4 aspects for LCS UEPos-LBS |  | 240d? | 2006-01-02 A | 2006-12-01 A | 100% | 2006-01-02 | 2006-12-01 | 240d? | finish no earlier than 2006-12-01 | C4 | 1920h | 1920h | LCS3-UEPos-LBS | SiRF | brodilitz@sirf.com | Rel-7 | Kimmo | 24.030, 24.080, 29.002 |  |  |  |
| 826 | 262.4 | UE positioning - Velocity |  | 394d? | 2005-03-15 A | 2006-09-15 A | 100% | 2005-03-15 | 2006-09-15 | 394d? | finish no earlier than 2006-09-15 | R2 | 3152h | 3152h | LCS3-UEPos-Velocity | SiRF | BRodilitz@SiRF.com | Rel-7 | Joern | 25.305, 25.331, 25.410, 25.413, 25.453 |  |  | RP-060459 |
| 827 | 262.5 | Inclusion of Uplink TDOA UE positioning method in the UTRAN specifications |  | 849d? | 2004-09-15 A | 2007-12-17 A | 100% | 2004-09-15 | 2007-12-17 | 849d? | finish no earlier than 2007-12-17 | R2 | 6792h | 6792h | LCS3-UEPos-UTDOA | TruePosition | Robert Gross | Rel-7 | Joern | 25.305, 25.453 |  |  | RP-070797 |

Notes:
- 800: -
- 801: -
- 802: Cancelled for Rel-7 and there is now corresponding Rel-8 WI
- 803: Cancelled for Rel-7 and there is now corresponding Rel-8 WI
- 804: -
- 805: -
- 806: CP#35 revised WID
- 807: -
- 808: Created at TSG#27 by A. Sultan because of WLAN items belonging to Rel-7. az: This WI is an exception of the WLAN-UMTS Interworking Rel-6 (No new WID)
- 809: -
- 810: -
- 811: -
- 812: Approved at SP#29
- 813: Approved at CP#29
- 814: Approved at CP#29
- 815: Approved at CP#29
- 816: CT4#31; no impacts identified, therefore completed. CP-32 stopped
- 817: Moved from FS section Feb 06. SP-30 updated WID
- 818: SP-32 stopped
- 819: SP-30 updated WID
- 820: CP-32 approved WID
- 821: CP-32 approved WID
- 822: -
- 823: SP#27 approved WID.
- 824: -
- 825: -
- 826: Completed Sept 2006; SR in RP-060459
- 827: Completed Nov 2007; SR in RP-070797

| ID | WBS | Task | Type | Duration | Start | Finish | Complete | Remaining | Baseline start | Baseline finish | Baseline duration | Total slack | Constraint | Resources | Work | Actual work | Text1 | Text4 | Text5 | Text6 | Text8 | Text12 | Text11 | Text2 | Text7 |
| --- | --- | --- | --- | --- | --- | --- | --- | --- | --- | --- | --- | --- | --- | --- | --- | --- | --- | --- | --- | --- | --- | --- | --- | --- | --- |
| 828 | 262.6 | **LCS for 3GPP Interworking WLAN** |  | 700d? | 2004-06-28 A | 2007-03-02 A | 100% |  | 2004-06-28 | 2007-03-02 | 700d? |  |  | S1 | 11901.6h | 11901.6h | LCS3-IWLAN | Telcordia | Mike Loushine | Rel-7 | Alain |  |  |  |  |
| 829 | 262.6.1 | FS on 3GPP system to WLAN Interworking with LCS |  | 512.7d? | 2004-06-28 A | 2006-06-30 A | 100% |  | 2004-06-28 | 2006-06-30 | 512.7d? |  | finish no earlier than 2005-09-29 | S1 | 4101.6h | 4101.6h | LCS3-IWLAN-FSs1 | Telcordia | Mike Loushine, Vijay Varma | Rel-7 | Alain |  |  |  |  |
| 830 | 262.6.2 | Delete - Study of work on an LCS architecture for I-WLAN. |  | 180d? | 2006-06-26 A | 2007-03-02 A | 100% |  | 2006-06-26 | 2007-03-02 | 180d? |  | finish no earlier than 2007-03-02 | S2 | 1440h | 1440h | LCS3-IWLAN-FSs2 | LG Electronics | dhshim@lge.com ; phede@lge.com | Rel-7 | Maurice | SP-35 |  |  |  |
| 831 | 262.6.3 | Stage 2 for LCS architecture for I-WLAN |  | 95d? | 2006-10-23 A | 2007-03-02 A | 100% |  | 2006-10-23 | 2007-03-02 | 95d? |  | finish no earlier than 2007-03-02 | S2 | 760h | 760h | LCS3-IWLAN | LG Electronics | dhshim@lge.com ; phede@lge.com | Rel-7 | Maurice |  |  |  |  |
| 832 | 262.7 | Deleted - UE positioning Rel-7 |  | 849d? | 2004-09-15 A | 2007-12-17 A | 100% |  | 2004-09-15 | 2007-12-17 | 849d? |  |  | RP | 6792h | 6792h | LCS3-UEpos |  |  | Rel-7 |  | RP-38 |  |  |  |
| 833 | 262.8 | Deleted - RAN2 aspects for LBS | milestone | 0d? | 2005-06-15 A | 2005-06-15 A | 100% |  | 2005-06-15 | 2005-06-15 | 0d? |  | start no earlier than 2005-06-15 | R2 |  |  | LCS3-UEPos-LBS | SiRF | BRodilitz@SiRF.com | Rel-7 | Joern | RP-31 |  |  |  |
| 834 | 263 | **MBMS Enhancements** |  | 625d? | 2005-07-11 A | 2007-11-30 A | 100% |  | 2005-07-11 | 2007-11-30 | 625d? |  |  | S1 | 10844.6h | 10844.6h | MBMSE | China Mobile | liuhongyfw@chinamobile.com | Rel-7 | Alain |  |  |  |  |
| 835 | 263.1 | Stage 1 of MBMSE |  | 109d? | 2005-07-11 A | 2005-12-08 A | 100% |  | 2005-07-11 | 2005-12-08 | 109d? |  | finish no earlier than 2005-12-08 | S1,R1,C3 | 872h | 872h | MBMSE | China Mobile | liuhongyfw@chinamobile.com | Rel-7 | Alain |  |  |  |  |
| 836 | 263.2 | MBMS FDD Physical layer Enhancements |  | 117.29d? | 2006-12-15 A | 2007-06-04 A | 100% |  | 2006-12-15 | 2007-06-04 | 117.29d? |  | finish no earlier than 2007-06-04 | R1 | 938.32h | 938.32h | MBMSE-RANPhysFDD | Ericsson | Lars.Lindbom@ericsson.com | Rel-7 | Patrick |  | RP-070290 |  |  |
| 837 | 263.3 | MBMS TDD Physical layer Enhancements |  | 117.29d? | 2006-12-15 A | 2007-06-04 A | 100% |  | 2006-12-15 | 2007-06-04 | 117.29d? |  | finish no earlier than 2007-06-04 | R1 | 938.32h | 938.32h | MBMSE-RANPhysTDD | IPWireless | Nicholas Anderson | Rel-7 | Patrick |  | RP-070291 |  |  |
| 838 | 263.4 | MBMS Low Chip Rate TDD Physical Layer Enhancement |  | 127d? | 2007-03-16 A | 2007-09-10 A | 100% |  | 2007-03-16 | 2007-09-10 | 127d? |  | finish no earlier than 2007-09-10 | R1 | 1016h | 1016h | MBMSE-RANPhysLCRTDD | RITT | Lin Hui | Rel-7 | Patrick |  | RP-070292 |  |  |
| 839 | 263.5 | MBMS Mz interface |  | 260d? | 2006-12-04 A | 2007-11-30 A | 100% |  | 2006-12-04 | 2007-11-30 | 260d? |  | finish no earlier than 2007-05-11 | C3 | 2080h | 2080h | MBMSMz | Huawei | Deng Tingting (ttdeng@huawei.com) | Rel-7 | Gwiho |  |  |  |  |
| 840 | 264 | **MBMS - UE Conformance Testing** |  | 727d? | 2007-06-01 A | 2010-03-12 | 80% | 148.26d? | 2007-06-01 | 2010-03-12 | 727d? | 656d |  | R5 | 14968h | 11913.9h | MBMSE_UEConTest |  |  | Rel-7 | Ingbert |  |  | PCG-21 | SP-40 |
| 841 | 264.1 | Conformance Test Aspects – MBMS TDD Physical layer Enhancements – MBSFN for HCR and VHCR TDD |  | 336d? | 2007-06-01 A | 2008-09-12 A | 100% |  | 2007-06-01 | 2008-09-12 | 336d? |  | start no earlier than 2007-06-01 | R5 | 2688h | 2688h | MBMSE-RANPhysTDD_UEConTest | IPWireless | tspeight@ipwireless.com | Rel-7 | Ingbert |  | RP-080541 |  |  |
| 842 | 264.2 | Conformance Test Aspects – MBMS LCR TDD Physical Layer Enhancement |  | 342d? | 2008-05-30 A | 2009-09-18 A | 100% |  | 2008-05-30 | 2009-09-18 | 342d? |  | finish no earlier than 2009-09-18 | R5 | 2728h | 2728h | MBMSE-RANPhysLCRTDD_UEConTest | CATT | chenxiaozhong@datangmobile.cn | Rel-7 | Ingbert |  | RP-090715 | PCG-21 | RP-40 |
| 843 | 264.3 | Conformance Test Aspects – MBSFN for FDD |  | 467d? | 2008-05-30 A | 2010-03-12 | 50% | 233.5d? | 2008-05-30 | 2010-03-12 | 467d? | 656d | finish no earlier than 2010-03-12 | R5 | 3736h | 1868h | MBMSE-UEConTest_RANPhysFDD | Huawei | Xiang Li (trica_li@huawei.com) | Rel-7 | Ingbert |  | RP-090713 | PCG-21 | RP-40 |
| 844 | 265 | MBMS User Service Extensions |  | 392d? | 2005-12-07 A | 2007-06-07 A | 100% |  | 2005-12-07 | 2007-06-07 | 392d? |  | finish no earlier than 2007-06-07 | S4 | 3136h | 3136h | MBMSUSE | Ericsson | Thorsten.Lohmar@ericsson.com | Rel-7 | Paolo |  |  |  |  |
| 845 | 266 | **Advanced Global Navigation Satellite System (A-GNSS) concept** |  | 830d? | 2004-06-28 A | 2007-08-31 A | 100% |  | 2004-06-28 | 2007-08-31 | 830d? |  |  | S1,GP,R2 | 9553.6h | 9553.6h | LCS3-AGNSS | Alcatel | Michel.monnerat@thalesaleniaspace.com | Rel-7 | Alain |  |  |  |  |
| 846 | 266.1 | Towards A-GNSS Concept |  | 811.2d? | 2004-06-28 A | 2007-08-31 A | 100% |  | 2004-06-28 | 2007-08-31 | 811.2d? |  | finish no earlier than 2007-08-31 | GP | 6489.6h | 6489.6h | AGNSS-GP | Alcatel | richard.couty@space.alcatel.fr | Rel-7 | Paolo |  |  |  |  |
| 847 | 266.2 | Global Navigation Satellite System (GNSS) in UTRAN |  | 383d? | 2005-12-15 A | 2007-06-04 A | 100% |  | 2005-12-15 | 2007-06-04 | 383d? |  | finish no earlier than 2007-06-04 | R2 | 3064h | 3064h | LCS3-GNSS-UTRAN | France Telecom | alain.abinakhoul@francetelecom.com | Rel-7 | Joern |  | RP-070482 |  |  |
| 848 | 266.3 | Deleted - Towards A-GNSS Concept | milestone | 0d? | 2007-02-16 A | 2007-02-16 A | 100% |  | 2007-02-16 | 2007-02-16 | 0d? |  | start no earlier than 2007-02-16 | S1 |  |  | GNSS | Alcatel | richard.couty@space.alcatel.fr | Rel-7 | Alain | SP-34 |  |  |  |
| 849 | 267 | A-GPS Minimum Performance |  | 351d? | 2006-04-28 A | 2007-08-31 A | 100% |  | 2006-04-28 | 2007-08-31 | 351d? |  | finish no earlier than 2007-08-31 | GP | 2808h | 2808h | GAGR | Spirent | richard.catmur@spirentcom.com | Rel-7 | Paolo |  |  |  |  |
| 850 | 268 | **USSD message delivery and transfer to USIM** |  | 376d? | 2004-03-05 A | 2005-08-12 A | 100% |  | 2004-03-05 | 2005-08-12 | 376d? |  |  | S1,C6 | 2762.4h | 2762.4h | USSD-USIM | Axalto | Christophe Dubois (cdubois@axalto.com) | Rel-7 | Alain |  |  |  |  |
| 851 | 268.1 | Stage 1 |  | 152d? | 2004-03-18 A | 2004-10-15 A | 100% |  | 2004-03-18 | 2004-10-15 | 152d? |  | start no earlier than 2004-03-18 | S1 | 1216h | 1216h | USSD-USIM | Axalto | Christophe Dubois (cdubois@axalto.com) | Rel-7 | Alain |  |  |  |  |
| 852 | 268.2 | Alignment with requirements regarding USSD usage |  | 193.3d? | 2004-03-05 A | 2005-08-12 A | 100% |  | 2004-03-05 | 2005-08-12 | 193.3d? |  | finish no earlier than 2005-08-12 | C6 | 1546.4h | 1546.4h | USSD-USIM | Axalto | Christophe Dubois (cdubois@axalto.com) | Rel-7 | Xavier |  |  |  |  |

Notes:
- 828: - / Text3: 22.935
- 829: - / Text3: 22.935
- 830: Updated WID at SP#32 to change "stage 2" to "study" , duplicated UID 320017 deleted. SP#33 TR for Information. Last mention SP-35 Mar 2007 (abandoned ?) / Text3: 23.837
- 831: WID at SP#55 / Text3: 23.234, 23.271, 23.167
- 832: -
- 833: - / Text3: 25.305, 25.331, 25.410, 25.413, 25.453
- 834: -
- 835: Structure created by MCC to include RAN aspects under SA1 Feature / Text3: 22.146, 22.246, 22.228
- 836: Completed May 2007; SR in RP-070290 / Text3: 25.211, 25.212, 25.213, 25.101, 25.104, 25.331, 25.433, 25.346, 25.306
- 837: Completed May 2007; SR in RP-070291 / Text3: 25.346, 25.221, 25.222, 25.223, 25.224, 25.306, 25.331, 25.402, 25.433, 25.102, 25.105, 25.123
- 838: Completed May 2007; SR in RP-070292 / Text3: 25.346, 25.221, 25.222, 25.223, 25.224, 25.306, 25.331, 25.402, 25.433, 25.102, 25.105, 25.123
- 839: - / Text3: 29.061
- 840: Linked to Feature UID_31084 (MBMSE). 1 Apr 2009 Flagged as Rel-7 i/o Rel-8 to match the Core specs release
- 841: SR in RP-080541. RP#41 completed / Text3: 34.108, 34.122, 34.123-1/2/3
- 842: RP#45 completed / Text3: 34.108, 34.123-1
- 843: RP#45 completion 09/09=>03/10 / Text3: 34.108, 34.109, 34.121-1, 34.121-2, 34.123-1, 34.123-2, 34.123-3
- 844: - / Text3: 26.346, 26.946
- 845: -
- 846: GP#36 completed
- 847: Completed Sept 2006; SR in RP-070482 / Text3: 25.305, 25.331, 25.306, 25.413, 25.423, 25.433, 25.453, 25.302, 25.215, 25.401, 25.402, 25.450, 25.452
- 848: -
- 849: - / Text3: 45.005, 51.010
- 850: -
- 851: - / Text3: 22.090
- 852: -

| ID | WBS | Task | Type | Duration | Start | Finish | Complete | Baseline start | Baseline finish | Baseline duration | Constraint | Resources | Work | Actual work | Text1 | Text4 | Text5 | Text6 | Text8 | Text3 | Text12 |
| --- | --- | --- | --- | --- | --- | --- | --- | --- | --- | --- | --- | --- | --- | --- | --- | --- | --- | --- | --- | --- | --- |
| 853 | 269 | **Combinational Services** |  | 296d? | 2005-01-17 A | 2006-03-06 A | 100% | 2005-01-17 | 2006-03-06 | 296d? |  | S1,S2,C1,S4 | 5176h | 5176h | CSICS | TeliaSonera | Robert.Frank@teliasonera.com | Rel-7 | Alain |  |  |
| 854 | 269.1 | Stage 1 for CSICS |  | 104d? | 2005-01-17 A | 2005-06-09 A | 100% | 2005-01-17 | 2005-06-09 | 104d? | start no earlier than 2005-01-17 | S1 | 832h | 832h | CSICS | TeliaSonera | Robert.Frank@teliasonera.com | Rel-7 | Alain | 22.279 |  |
| 855 | 269.2 | Stage 2 for CSICS |  | 130d? | 2005-01-17 A | 2005-07-15 A | 100% | 2005-01-17 | 2005-07-15 | 130d? | start no earlier than 2005-01-17 | S2 | 1040h | 1040h | CSICS | TeliaSonera | Robert.Frank@teliasonera.com | Rel-7 | Maurice | 23.279 |  |
| 856 | 269.3 | Stage 3 for CSICS CN aspects |  | 221d? | 2005-05-02 A | 2006-03-06 A | 100% | 2005-05-02 | 2006-03-06 | 221d? | finish no earlier than 2006-03-06 | C1 | 1768h | 1768h | CSICS | Vodafone | Peter Dawes | Rel-7 | Frederic | 24.879, 24.279, 24.229, 24.008 |  |
| 857 | 269.4 | Stage 3 for codec aspects |  | 192d? | 2005-03-15 A | 2005-12-07 A | 100% | 2005-03-15 | 2005-12-07 | 192d? | finish no earlier than 2005-12-07 | S4 | 1536h | 1536h | CSICS-Codec | Ericsson | Per.Frojdh@ericsson.com | Rel-7 | Paolo | 26.141, 26.235 |  |
| 858 | 270 | **CAMEL Trunk Triggers** |  | 251d? | 2004-12-17 A | 2005-12-05 A | 100% | 2004-12-17 | 2005-12-05 | 251d? |  | S1,C4 | 6024h | 6024h | TTCAMEL | Nortel | Amar Deol (deola@nortelnetworks.com) | Rel-7 | Alain |  |  |
| 859 | 270.1 | Stage 1 for CAMEL Trunk Triggers |  | 251d? | 2004-12-17 A | 2005-12-05 A | 100% | 2004-12-17 | 2005-12-05 | 251d? |  | S1 | 2008h | 2008h | TTCAMEL | Nortel | Amar Deol (deola@nortelnetworks.com) | Rel-7 | Alain | 22.078 |  |
| 860 | 270.2 | CAMEL Trunk Originated Trigger Detection Points |  | 251d? | 2004-12-17 A | 2005-12-05 A | 100% | 2004-12-17 | 2005-12-05 | 251d? | start no earlier than 2004-12-17 | C4 | 2008h | 2008h | CamelR7 | Nortel | David Hutton (dhutton@nortel.com) | Rel-7 | Kimmo |  |  |
| 861 | 271 | **IMS Service Brokering enhancements** |  | 69d? | 2005-12-07 A | 2006-03-13 A | 100% | 2005-12-07 | 2006-03-13 | 69d? |  | S1 | 1104h | 1104h | ISB | Telcordia | jbakker@telcordia.com | Rel-7 | Alain | 22.228 |  |
| 862 | 271.1 | Stage 1 for ISB |  | 69d? | 2005-12-07 A | 2006-03-13 A | 100% | 2005-12-07 | 2006-03-13 | 69d? | finish no earlier than 2006-03-13 | S1 | 552h | 552h | ISB-s1 | Telcordia | jbakker@telcordia.com | Rel-7 | Alain | 22.228 |  |
| 863 | 272 | **Enhancements of VGCS for public authority officials** |  | 731d? | 2004-08-27 A | 2007-06-15 A | 100% | 2004-08-27 | 2007-06-15 | 731d? |  | S1 | 25920h | 25920h | EVGCS |  |  | Rel-7 | Alain | 43.068, 44.068, 24.008, 29.002 |  |
| 864 | 272.1 | Stage 1 | milestone | 0d? | 2004-08-27 A | 2004-08-27 A | 100% | 2004-08-27 | 2004-08-27 | 0d? | finish no earlier than 2004-08-27 | S1 |  |  | EVGCS | Siemens | Joerg Swetina (joerg.swetina@nw.neclab.eu) | Rel-7 | Alain | 42.068, 43.068 |  |
| 865 | 272.2 | **Architecture and protocol aspects** |  | 731d? | 2004-08-27 A | 2007-06-15 A | 100% | 2004-08-27 | 2007-06-15 | 731d? |  | C1 | 14904h | 14904h | EVGCS | Siemens | robert.zaus@nsn.com | Rel-7 | Frederic | 43.068, 44.068 |  |
| 866 | 272.2.1 | CT1 aspects of EVGCS |  | 731d? | 2004-08-27 A | 2007-06-15 A | 100% | 2004-08-27 | 2007-06-15 | 731d? | finish no earlier than 2006-09-15 | C1 | 5848h | 5848h | EVGCS | Siemens |  | Rel-7 | Frederic | 43.068, 44.068, 24.008 |  |
| 867 | 272.2.2 | CT4 aspects of EVGCS |  | 401d? | 2004-08-27 A | 2006-03-10 A | 100% | 2004-08-27 | 2006-03-10 | 401d? | finish no earlier than 2006-03-10 | C4 | 3208h | 3208h | EVGCS-St23-c4 | Siemens |  | Rel-7 | Kimmo | 29.002 |  |
| 868 | 272.3 | GERAN2 aspects |  | 646d? | 2004-08-27 A | 2007-02-16 A | 100% | 2004-08-27 | 2007-02-16 | 646d? | finish no earlier than 2007-02-16 | G2 | 5168h | 5168h | EVGCS | Siemens | kenneth.isaacs@roke.co.uk | Rel-7 | Gert |  |  |
| 869 | 273 | **Improvements of VGCS for parallel use of services** |  | 523d? | 2005-03-15 A | 2007-03-15 A | 100% | 2005-03-15 | 2007-03-15 | 523d? |  | S1 | 12230.2h | 12230.2h | IVGCS |  |  | Rel-7 | Alain |  |  |
| 870 | 273.1 | Service Requirements for VGCS improvements |  | 62d? | 2005-03-15 A | 2005-06-08 A | 100% | 2005-03-15 | 2005-06-08 | 62d? | finish no earlier than 2005-06-08 | S1 | 496h | 496h | IVGCS | T-Mobile | kurt.bischinger@t-mobile.at | Rel-7 | Alain | 42.068 |  |
| 871 | 273.2 | Stage 2 modifications for VGCS improvements |  | 335d? | 2005-12-01 A | 2007-03-14 A | 100% | 2005-12-01 | 2007-03-14 | 335d? | start no earlier than 2005-12-01 | C1 | 2680h | 2680h | IVGCS | T-Mobile | kurt.bischinger@t-mobile.at | Rel-7 | Frederic | 43.068 |  |
| 872 | 273.3 | **Protocol aspects** |  | 336d? | 2005-12-01 A | 2007-03-15 A | 100% | 2005-12-01 | 2007-03-15 | 336d? |  | C1 | 5376h | 5376h | IVGCS | T-Mobile | Dieter Jacobsohn | Rel-7 | Frederic | 44.068 |  |
| 873 | 273.3.1 | CT1 aspects of IVGCS |  | 336d? | 2005-12-01 A | 2007-03-15 A | 100% | 2005-12-01 | 2007-03-15 | 336d? | finish no earlier than 2007-03-15 | C1 | 2688h | 2688h | IVGCS | T-Mobile |  | Rel-7 | Frederic | 43.068, 44.068 |  |
| 874 | 273.3.2 | Deleted - CT4 aspects of IVGCS | milestone | 0d? | 2007-03-09 A | 2007-03-09 A | 100% | 2007-03-09 | 2007-03-09 | 0d? | finish no earlier than 2007-03-09 | C4 |  |  | IVGCS-St3-c4 | T-mobile |  | Rel-7 | Kimmo | 29.002 | CP-35 |
| 875 | 274 | **OSA Rel-7** |  | 584d? | 2005-03-15 A | 2007-06-08 A | 100% | 2005-03-15 | 2007-06-08 | 584d? |  | S1,C5 | 17920h | 17920h | OSA7 | AePONA | eamonn.murray@aepona.com | Rel-7 | Alain |  |  |
| 876 | 274.1 | Service Requirements for OSA Service Broker |  | 62d? | 2005-03-15 A | 2005-06-08 A | 100% | 2005-03-15 | 2005-06-08 | 62d? | finish no earlier than 2005-06-08 | S1 | 496h | 496h | OSA7-SB | AePONA | eamonn.murray@aepona.com | Rel-7 | Alain | 22.127 |  |
| 877 | 274.2 | Stage 2 OSA API Service Brokering |  | 156d? | 2006-04-28 A | 2006-12-01 A | 100% | 2006-04-28 | 2006-12-01 | 156d? |  | C5 | 1248h | 1248h | OSA7-SB | AePONA | damian.oneill@aepona.com | Rel-7 | Kimmo | 23.198 |  |
| 878 | 274.3 | Stage 3 OSA API Service Brokering |  | 156d? | 2006-04-28 A | 2006-12-01 A | 100% | 2006-04-28 | 2006-12-01 | 156d? | finish no earlier than 2006-12-01 | C5 | 1248h | 1248h | OSA7-SB | AePONA | damian.oneill@aepona.com | Rel-7 | Kimmo | 29.198-16 |  |

Notes:
- 853: -
- 854: -
- 855: -
- 856: -
- 857: -
- 858: -
- 859: -
- 860: -
- 861: No CR submitted in rel-8 (according to CR database).
- 862: No Rel-8 changes
- 863: Voice Group Call Service
- 864: -
- 865: -
- 866: -
- 867: -
- 868: -
- 869: Voice Group Call Service
- 870: -
- 871: -
- 872: Previous name (before CT32) was Architecture and protocol aspects
- 873: -
- 874: CT4#33 stage 2 solution is still open. ...
- 875: -
- 876: az: WID URL corrected
- 877: -
- 878: -

| ID | WBS | Task | Type | Duration | Start | Finish | Complete | Baseline start | Baseline finish | Baseline duration | Constraint | Resources | Work | Actual work | Text1 | Text3 | Text4 | Text5 | Text6 | Text8 | Text12 | Text11 |
| --- | --- | --- | --- | --- | --- | --- | --- | --- | --- | --- | --- | --- | --- | --- | --- | --- | --- | --- | --- | --- | --- | --- |
| 879 | 274.4 | **OSA Stage 2/3 enhancements** |  | 291d? | 2006-04-28 A | 2007-06-08 A | 100% | 2006-04-28 | 2007-06-08 | 291d? |  | C5 | 10256h | 10256h | OSA7 | 29.198/9, 23.198 | AePONA | damian.oneill@aepona.com | Rel-7 | Kimmo |  |  |
| 880 | 274.4.1 | Parlay X Message Broadcast Web Service |  | 156d? | 2006-04-28 A | 2006-12-01 A | 100% | 2006-04-28 | 2006-12-01 | 156d? | finish no earlier than 2006-12-01 | C5 | 1248h | 1248h | OSA7 | 29.199-15, 23.198 | ETRI |  | Rel-7 | Kimmo |  |  |
| 881 | 274.4.2 | Parlay X Geocoding Web Service |  | 156d? | 2006-04-28 A | 2006-12-01 A | 100% | 2006-04-28 | 2006-12-01 | 156d? | finish no earlier than 2006-12-01 | C5 | 1248h | 1248h | OSA7 | 29.199-16, 23.198 | ETRI |  | Rel-7 | Kimmo |  |  |
| 882 | 274.4.3 | Parlay X Application driven QoS Web Service |  | 226d? | 2006-04-28 A | 2007-03-09 A | 100% | 2006-04-28 | 2007-03-09 | 226d? | finish no earlier than 2007-03-09 | C5 | 1808h | 1808h | OSA7 | 29.199-17, 23.198 | BT |  | Rel-7 | Kimmo |  |  |
| 883 | 274.4.4 | Parlay-X Device Capabilities and Configuration |  | 162d? | 2006-10-26 A | 2007-06-08 A | 100% | 2006-10-26 | 2007-06-08 | 162d? | finish no earlier than 2007-06-09 | C5 | 1296h | 1296h | OSA7 | 29.199-18, 23.198 | Telenor |  | Rel-7 | Kimmo |  |  |
| 884 | 274.4.5 | Parlay-X Multimedia Streaming Session Management Web Service |  | 97d? | 2006-10-26 A | 2007-03-09 A | 100% | 2006-10-26 | 2007-03-09 | 97d? | start no earlier than 2006-10-26 | C5 | 776h | 776h | OSA7 | 29.199-19, 23.198 | Telenor |  | Rel-7 | Kimmo |  |  |
| 885 | 274.4.6 | Parlay-X Multimedia Multicast Control Web Service |  | 97d? | 2006-10-26 A | 2007-03-09 A | 100% | 2006-10-26 | 2007-03-09 | 97d? | start no earlier than 2006-10-26 | C5 | 776h | 776h | OSA7 | 29.199-20, 23.198 | ETRI |  | Rel-7 | Kimmo |  |  |
| 886 | 274.4.7 | OSA API Conference Call Control SCF |  | 97d? | 2006-10-26 A | 2007-03-09 A | 100% | 2006-10-26 | 2007-03-09 | 97d? | start no earlier than 2006-10-26 | C5 | 776h | 776h | OSA7 | 29.198-04-5, 23.198 | Ericsson |  | Rel-7 | Kimmo |  |  |
| 887 | 275 | **Selective Disabling of UE Capabilities** |  | 624.36d? | 2005-01-24 A | 2007-06-15 A | 100% | 2005-01-24 | 2007-06-15 | 624.36d? |  | S1,S2,C1 | 12351.7h | 12351.7h | SDoUE |  | Motorola |  | Rel-7 | Alain |  |  |
| 888 | 275.1 | Stage 1 of SDoUE |  | 393.6d? | 2005-01-24 A | 2006-12-08 A | 100% | 2005-01-24 | 2006-12-08 | 393.6d? | finish no earlier than 2006-12-08 | S1 | 3148.8h | 3148.8h | SDoUE-CR | 22.011 | Motorola |  | Rel-7 | Alain |  |  |
| 889 | 275.2 | Deleted - TR on different possible architectures |  | 195d? | 2005-03-21 A | 2005-12-16 A | 100% | 2005-03-21 | 2005-12-16 | 195d? | finish no earlier than 2005-12-16 | S2 | 1560h | 1560h | SDoUE-FS | 23.805 abandonned at SP-30; descendant C1 24.305 | Vodafone | Gavin.Wong@vodafone.com | Rel-7 | Maurice | SP-30 |  |
| 890 | 275.3 | Stage 3 of SDoUE |  | 331d? | 2006-03-10 A | 2007-06-15 A | 100% | 2006-03-10 | 2007-06-15 | 331d? | finish no earlier than 2007-06-15 | C1 | 2648h | 2648h | SDoUE | 24.305 | Ericsson | christian.herrero@ericsson.com | Rel-7 | Frederic |  |  |
| 891 | 276 | **Network selection enhancements (NSP)** |  | 328d? | 2006-03-15 A | 2007-06-15 A | 100% | 2006-03-15 | 2007-06-15 | 328d? |  | S1 | 6320h | 6320h | NSP-CR | 22.101, 22.011, 23.122, 24.008, 25.304, 31.102, 45.008 | O2 | chris.friel@o2.com | Rel-7 | Alain |  |  |
| 892 | 276.1 | Stage 1 of NSP |  | 191d? | 2006-03-15 A | 2006-12-06 A | 100% | 2006-03-15 | 2006-12-06 | 191d? | start no earlier than 2006-03-15 | S1 | 1528h | 1528h | NSP-TS | 22.101, 22.011, 23.122, 24.008, 25.304, 31.102, 45.008 | O2 | chris.friel@o2.com | Rel-7 | Alain |  |  |
| 893 | 276.2 | Procedural aspects of NSP |  | 271d? | 2006-06-02 A | 2007-06-15 A | 100% | 2006-06-02 | 2007-06-15 | 271d? | finish no earlier than 2007-06-15 | C1 | 2168h | 2168h | NSP-CR | 23.122, 24.008, 31.102 | Motorola | Andrew Howell | Rel-7 | Frederic |  |  |
| 894 | 277 | Network Selection enhancements (NSP) - UE Conformance Testing |  | 396d? | 2007-06-01 A | 2008-12-05 A | 100% | 2007-06-01 | 2008-12-05 | 396d? | finish no earlier than 2008-12-05 | R5 | 3168h | 3168h | NSP-CR_UEConTest | 34.108, 34.123-1, 34.123-2, 34.123-3 | Nokia | jarkko.hellsten@nokia.com | Rel-7 | Ingbert |  | RP-080819 |
| 895 | 278 | **Access Class Barring and Overload Protection** |  | 650d? | 2004-03-15 A | 2006-09-08 A | 100% | 2004-03-15 | 2006-09-08 | 650d? |  | S2,C1 | 3568h | 3568h | ACBOP | 23.898 | Vodafone | Chris Pudney | Rel-7 | Maurice |  |  |
| 896 | 278.1 | TR on Stage 2 |  | 274d? | 2004-03-15 A | 2005-03-31 A | 100% | 2004-03-15 | 2005-03-31 | 274d? | finish no earlier than 2005-03-31 | S2 | 2192h | 2192h | ACBOP | 23.898 | NTT DoCoMo | Jean-Jacques Davidian (davidian@docomo.fr) | Rel-7 | Maurice |  |  |
| 897 | 278.2 | Stage 3 CN aspects of ACBOP |  | 172d? | 2005-06-06 A | 2006-01-31 A | 100% | 2005-06-06 | 2006-01-31 | 172d? | start no earlier than 2005-06-06 | C1 | 1376h | 1376h | ACBOP | 24.008 |  |  | Rel-7 | Frederic |  |  |
| 898 | 278.3 | Deleted - Potential impact on Iu interface Overload functionality | milestone | 0d? | 2004-03-15 A | 2004-03-15 A | 100% | 2004-03-15 | 2004-03-15 | 0d? | finish no earlier than 2004-03-15 | RP |  |  | ACBOP | 25.413 |  |  | Rel-7 | Stefania | RP-25 |  |
| 899 | 278.4 | Deleted - Extra ACBOP information in RAN | milestone | 0d? | 2004-03-15 A | 2004-03-15 A | 100% | 2004-03-15 | 2004-03-15 | 0d? | finish no earlier than 2004-03-15 | RP |  |  | ACBOP | 25.331 |  |  | Rel-7 | Stefania | RP-25 |  |
| 900 | 278.5 | Deleted - Extra ACBOP information in GERAN | milestone | 0d? | 2006-09-08 A | 2006-09-08 A | 100% | 2006-09-08 | 2006-09-08 | 0d? | start no earlier than 2006-09-08 | GP |  |  | ACBOP | 44.018 |  |  | Rel-7 | Paolo | RP-33 |  |
| 901 | 279 | **System enhancements for fixed broadband access to IMS** |  | 876d? | 2003-11-05 A | 2007-03-14 A | 100% | 2003-11-05 | 2007-03-14 | 876d? |  | S2,S3,S5,C1,C3,C4 | 36656h | 36656h | FBI |  |  |  | Rel-7 | Maurice |  |  |
| 902 | 279.1 | **TISPAN Rel 1 related aspects** |  | 873d? | 2003-11-05 A | 2007-03-09 A | 100% | 2003-11-05 | 2007-03-09 | 873d? |  | S2 | 31568h | 31568h | FBI-TIS1 |  |  |  | Rel-7 | Maurice |  |  |
| 903 | 279.1.1 | Stage 2 of FBI for TISPAN R1 |  | 365d? | 2004-10-14 A | 2006-03-08 A | 100% | 2004-10-14 | 2006-03-08 | 365d? | start no earlier than 2004-10-14 | S2 | 2920h | 2920h | FBI-TIS1 |  |  |  | Rel-7 | Maurice |  |  |

Notes:
- 879: CP#34: WID updated. Completion 12/06 =>03/07
- 880: -
- 881: -
- 882: -
- 883: -
- 884: -
- 885: -
- 886: -
- 887: Moved from FS section Feb 06
- 888: Moved from FS section Feb 06
- 889: Moved from FS section Feb 06. Abandoned at SP-30
- 890: -
- 891: -
- 892: -
- 893: -
- 894: RP#42 completed. SR in RP-080819. Linked to UID_7041 (NSP-CR).
- 895: -
- 896: -
- 897: NEW - inserted on 2/9/2004
- 898: -
- 899: -
- 900: -
- 901: -
- 902: -
- 903: -

| ID | WBS | Task | Duration | Start | Finish | Complete | Baseline start | Baseline finish | Baseline duration | Constraint | Resources | Work | Actual work | Text1 | Text4 | Text5 | Text6 | Text8 | Text3 | Text12 |
| --- | --- | --- | --- | --- | --- | --- | --- | --- | --- | --- | --- | --- | --- | --- | --- | --- | --- | --- | --- | --- |
| 904 | 279.1.2 | **Protocol impact of FBI for TISPAN R1** | 873d? | 2003-11-05 A | 2007-03-09 A | 100% | 2003-11-05 | 2007-03-09 | 873d? |  | C1 | 20720h | 20720h | FBI-TIS1 | Siemens | peter.leis@nsn.com | Rel-7 | Frederic |  |  |
| 905 | 279.1.2.1 | CT1 aspects of FBI for TISPAN R1 | 802d? | 2003-11-05 A | 2006-11-30 A | 100% | 2003-11-05 | 2006-11-30 | 802d? | finish no earlier than 2006-11-30 | C1 | 6416h | 6416h | FBI-TIS1 | Siemens | peter.leis@nsn.com | Rel-7 | Frederic | 24.819, 24.229 |  |
| 906 | 279.1.2.2 | CT3 aspects of FBI for TISPAN R1 | 808d? | 2003-11-05 A | 2006-12-08 A | 100% | 2003-11-05 | 2006-12-08 | 808d? | finish no earlier than 2006-12-08 | C3 | 6464h | 6464h | FBI-TIS1 | Siemens | peter.leis@nsn.com | Rel-7 | Gwiho | 29.163, 29.209 |  |
| 907 | 279.1.2.3 | CT4 aspects of FBI for TISPAN R1 | 301d? | 2006-01-13 A | 2007-03-09 A | 100% | 2006-01-13 | 2007-03-09 | 301d? | finish no earlier than 2007-03-09 | C4 | 2408h | 2408h | FBI-TIS1-st3-c4 | Siemens | peter.leis@nsn.com | Rel-7 | Kimmo | 29.229 |  |
| 908 | 279.1.3 | Security Enhancements for FBI | 118d? | 2005-06-28 A | 2005-12-08 A | 100% | 2005-06-28 | 2005-12-08 | 118d? | start no earlier than 2005-06-28 | S3 | 944h | 944h | FBI-ISE | Ericsson | Bengt.Sahlin@ericsson.com | Rel-7 | Dionisio | 33.203 |  |
| 909 | 279.2 | **PacketCable Related aspects** | 291d? | 2006-02-01 A | 2007-03-14 A | 100% | 2006-02-01 | 2007-03-14 | 291d? |  | S2,S5,C1 | 5088h | 5088h | FBI-PCBL | CableLabs | Bernie McKibben | Rel-7 | Maurice |  |  |
| 910 | 279.2.1 | Stage 1,2 of FBI for PacketCable | 228d? | 2006-02-01 A | 2006-12-15 A | 100% | 2006-02-01 | 2006-12-15 | 228d? | finish no earlier than 2006-12-15 | S2 | 1824h | 1824h | FBI-PCBL | CableLabs | Bernie McKibben | Rel-7 | Maurice | 22.228, 23.228 |  |
| 911 | 279.2.2 | Protocol impact of FBI for PacketCable | 228d? | 2006-05-01 A | 2007-03-14 A | 100% | 2006-05-01 | 2007-03-14 | 228d? | finish no earlier than 2007-03-15 | C1 | 1824h | 1824h | FBI-PCBL |  |  | Rel-7 | Frederic |  |  |
| 912 | 279.2.3 | SA5 Charging aspects of FBI for PacketCable | 180d? | 2006-03-31 A | 2006-12-07 A | 100% | 2006-03-31 | 2006-12-07 | 180d? | finish no earlier than 2006-12-07 | S5 | 1440h | 1440h | FBI-PCBL-CH | CableLabs | Bernie McKibben | Rel-7 | Dionisio | 32.240, 32.260, 32.298, 32.299 |  |
| 913 | 280 | **Support of SMS over generic 3GPP IP access** | 696d? | 2004-10-14 A | 2007-06-14 A | 100% | 2004-10-14 | 2007-06-14 | 696d? |  | S2,C4,C1 | 12408h | 12408h | SMSIP | Huawei | zhangwenlin@huawei.com | Rel-7 | Maurice |  |  |
| 914 | 280.1 | FS on SMSIP | 173d? | 2004-10-14 A | 2005-06-13 A | 100% | 2004-10-14 | 2005-06-13 | 173d? | start no earlier than 2004-10-14 | S2 | 1384h | 1384h | SMSIP | Huawei | zhangwenlin@huawei.com | Rel-7 | Maurice | 23.804 |  |
| 915 | 280.2 | Stage 2 for SMSIP | 333d? | 2005-06-08 A | 2006-09-15 A | 100% | 2005-06-08 | 2006-09-15 | 333d? | finish no earlier than 2006-09-15 | S2 | 2664h | 2664h | SMSIP | Huawei | zhangwenlin@huawei.com | Rel-7 | Maurice | 23.204 |  |
| 916 | 280.3 | **Stage 3 for SMSIP** | 527d? | 2005-06-08 A | 2007-06-14 A | 100% | 2005-06-08 | 2007-06-14 | 527d? |  | C4,C1 | 8360h | 8360h | SMSIP-St3 | Nokia | jari.jansson@nokia.com | Rel-7 | Kimmo |  |  |
| 917 | 280.3.1 | CT1 aspects for SMSIP | 527d? | 2005-06-08 A | 2007-06-14 A | 100% | 2005-06-08 | 2007-06-14 | 527d? | finish no earlier than 2007-06-15 | C1 | 4216h | 4216h | SMSIP | Nokia | jari.jansson@nokia.com | Rel-7 | Frederic | 23.040, 24.229 |  |
| 918 | 280.3.2 | CT4 aspects for SMSIP | 518d? | 2005-06-08 A | 2007-06-01 A | 100% | 2005-06-08 | 2007-06-01 | 518d? | finish no earlier than 2007-06-01 | C4 | 4144h | 4144h | SMSIP-St3-c4 | Nokia | jari.jansson@nokia.com | Rel-7 | Kimmo | 23.008, 29.002 |  |
| 919 | 281 | **Evolution of Policy Control and Charging** | 817d? | 2004-10-14 A | 2007-11-30 A | 100% | 2004-10-14 | 2007-11-30 | 817d? |  | S2,S5,C3,C1 | 30336h | 30336h | PCC | Nokia | balazs.bertenyi@nsn.com | Rel-7 | Maurice |  |  |
| 920 | 281.1 | Deleted - TR for PCC | 315d? | 2004-10-14 A | 2005-12-29 A | 100% | 2004-10-14 | 2005-12-29 | 315d? | finish no earlier than 2005-12-28 | S2 | 2520h | 2520h | PCC | Nokia | balazs.bertenyi@nsn.com | Rel-7 | Maurice | 23.803 | SP-33 |
| 921 | 281.2 | Stage 2 for PCC | 315d? | 2005-07-04 A | 2006-09-15 A | 100% | 2005-07-04 | 2006-09-15 | 315d? | finish no earlier than 2006-09-15 | S2 | 2520h | 2520h | PCC | Nokia | balazs.bertenyi@nsn.com | Rel-7 | Maurice | 23.203 |  |
| 922 | 281.3 | Evolution of policy control and flow based bearer level charging | 109d? | 2006-08-01 A | 2006-12-29 A | 100% | 2006-08-01 | 2006-12-29 | 109d? | start no earlier than 2006-08-01 | S2 | 872h | 872h | PCC | Nokia | balazs.bertenyi@nsn.com | Rel-7 | Maurice | 23.207, 23.002, 23.228 |  |
| 923 | 281.4 | SA5 Charging aspects of PCC | 316d? | 2006-03-31 A | 2007-06-15 A | 100% | 2006-03-31 | 2007-06-15 | 316d? | finish no earlier than 2007-06-15 | S5 | 2528h | 2528h | PCC-CH | Orange | alain.bibas@orange-ft.com | Rel-7 | Dionisio | 32.250, 32.251, 32.298, 32.299 |  |
| 924 | 281.5 | Gx reference point for Policy and Charging Control | 521d? | 2005-12-02 A | 2007-11-30 A | 100% | 2005-12-02 | 2007-11-30 | 521d? | finish no earlier than 2007-09-14 | C3 | 4168h | 4168h | PCC-Gx | Siemens | Thomas.Belling@nsn.com | Rel-7 | Gwiho | 29.212 (not progressed to Rel-7: 29.210, 29.207, 29.208) |  |
| 925 | 281.6 | **Rx reference point for PCC CT3 aspects** | 521d? | 2005-12-02 A | 2007-11-30 A | 100% | 2005-12-02 | 2007-11-30 | 521d? |  | C3,C1 | 11192h | 11192h | PCC-Rx | Ericsson | j.javier.pastor@ericsson.com | Rel-7 | Gwiho |  |  |
| 926 | 281.6.1 | PCC-Rx CT3 aspects | 521d? | 2005-12-02 A | 2007-11-30 A | 100% | 2005-12-02 | 2007-11-30 | 521d? | finish no earlier than 2007-09-14 | C3 | 4168h | 4168h | PCC-Rx-c3 | Ericsson | j.javier.pastor@ericsson.com | Rel-7 | Gwiho | 29.213, 29.214 (not progressed to Rel-7: 29.209, 29.211) |  |
| 927 | 281.6.2 | PCC-Rx CT1 aspects | 357d? | 2005-12-02 A | 2007-06-15 A | 100% | 2005-12-02 | 2007-06-15 | 357d? | finish no earlier than 2007-06-15 | C1 | 2856h | 2856h | PCC-Rx-Gx-c1 | Ericsson | j.javier.pastor@ericsson.com | Rel-7 | Frederic | 24.229 |  |

Notes:
- 904: -
- 905: end date updated by CT1-chairman after CP#33
- 906: -
- 907: CT4#32: a set of CRs on FBI for cable labs
- 908: Duplicated entry ("ACCSEC2", "Access Security Enhancements", SP-040865) deleted by A.Sultan
- 909: -
- 910: -
- 911: -
- 912: 03/2006 SP#31 WID approved
- 913: SP#33 updated WID (removed MMS)
- 914: SP#33 updated WID
- 915: SP#33 updated WID
- 916: CP#34 updated WID
- 917: CP#34 updated WID
- 918: CP#34 updated WID
- 919: SP-29 approved WID. SP-31 updated WID adding SA5 charging. 23.125 will be discontinued from Rel-7.
- 920: SP-30: S2 has no intention for TR completion
- 921: SP-29 approved WID. SP-31 updated WID. 23.125 will be discontinued from Rel-7.
- 922: SP-29 approved WID. SP-31 updated WID. 23.125 will be discontinued from Rel-7.
- 923: SP-31 updated WID with SA5 charging.
- 924: -
- 925: WID approved at CP#30, Revised at CP#31, Revised at CP#33
- 926: -
- 927: -

| ID | WBS | Task | Type | Duration | Start | Finish | Complete | Baseline start | Baseline finish | Baseline duration | Constraint | Resources | Work | Actual work | Text1 | Text4 | Text5 | Text6 | Text8 | Text3 | Text12 |
| --- | --- | --- | --- | --- | --- | --- | --- | --- | --- | --- | --- | --- | --- | --- | --- | --- | --- | --- | --- | --- | --- |
| 928 | 282 | **Voice call continuity between CS and IMS (incl. I-WLAN)** |  | 641d? | 2004-12-31 A | 2007-06-15 A | 100% | 2004-12-31 | 2007-06-15 | 641d? |  | S2,S1,S5,C1,C4 | 12224h | 12224h | VCC | Alcatel-Lucent | Keith Drage (drage@alcatel-lucent.com) | Rel-7 | Maurice |  |  |
| 929 | 282.1 | TR for VCC |  | 245d? | 2004-12-31 A | 2005-12-08 A | 100% | 2004-12-31 | 2005-12-08 | 245d? | finish no earlier than 2005-12-08 | S2 | 1960h | 1960h | VCC | Alcatel-Lucent | Andy Bennett (andybennett@alcatel-lucent.com) | Rel-7 | Maurice | 23.806 |  |
| 930 | 282.2 | Stage 1 for VCC |  | 140d? | 2005-03-17 A | 2005-09-28 A | 100% | 2005-03-17 | 2005-09-28 | 140d? | finish no earlier than 2005-09-28 | S1 | 1120h | 1120h | VCC | Alcatel-Lucent | Andy Bennett (andybennett@alcatel-lucent.com) | Rel-7 | Alain | 22.101 |  |
| 931 | 282.3 | Stage 2 for VCC |  | 264d? | 2005-09-06 A | 2006-09-08 A | 100% | 2005-09-06 | 2006-09-08 | 264d? | finish no earlier than 2006-09-08 | S2 | 2112h | 2112h | VCC | Alcatel-Lucent | Andy Bennett (andybennett@alcatel-lucent.com) | Rel-7 | Maurice | 23.206 |  |
| 932 | 282.4 | SA5 Charging aspects of VCC |  | 325d? | 2006-03-17 A | 2007-06-14 A | 100% | 2006-03-17 | 2007-06-14 | 325d? | finish no earlier than 2007-06-14 | S5 | 2600h | 2600h | VCC-CH | Orange | alain.bibas@orange-ft.com | Rel-7 | Dionisio | 32.250, 32.260 |  |
| 933 | 282.5 | **Stage 3 for VCC** |  | 358d? | 2006-02-01 A | 2007-06-15 A | 100% | 2006-02-01 | 2007-06-15 | 358d? |  | C1,C4 | 4432h | 4432h | VCC | Alcatel-Lucent | Keith Drage (drage@alcatel-lucent.com) | Rel-7 | Frederic |  |  |
| 934 | 282.5.1 | CT1 aspects of VCC |  | 358d? | 2006-02-01 A | 2007-06-15 A | 100% | 2006-02-01 | 2007-06-15 | 358d? | finish no earlier than 2007-06-15 | C1 | 2864h | 2864h | VCC | Alcatel-Lucent | Keith Drage (drage@alcatel-lucent.com) | Rel-7 | Frederic | 24.206, 24.216 |  |
| 935 | 282.5.2 | CT4 aspects of VCC |  | 196d? | 2006-06-09 A | 2007-03-09 A | 100% | 2006-06-09 | 2007-03-09 | 196d? | start no earlier than 2006-06-09 | C4 | 1568h | 1568h | VCC-St3-c4 | Alcatel-Lucent | Keith Drage (drage@alcatel-lucent.com) | Rel-7 | Kimmo | 23.003 |  |
| 936 | 282.5.3 | Deleted - CT3 aspects of VCC | milestone | 0d? | 2006-11-02 A | 2006-11-02 A | 100% | 2006-11-02 | 2006-11-02 | 0d? | finish no earlier than 2006-11-02 | C3 |  |  | VCC | Alcatel-Lucent | Keith Drage (drage@alcatel-lucent.com) | Rel-7 | Gwiho | 29.163 | CP-33 |
| 937 | 283 | **One Tunnel solution for Optimisation of Packet Data Traffic** |  | 418d? | 2006-03-27 A | 2007-10-31 A | 100% | 2006-03-27 | 2007-10-31 | 418d? |  | S2 | 7048h | 7048h | OPTUNEL | Nokia | antti.j.pasanen@nokia.com | Rel-7 | Maurice |  |  |
| 938 | 283.1 | Deleted - Study on Stage 2 for One Tunnel solution |  | 125d? | 2006-03-27 A | 2006-09-15 A | 100% | 2006-03-27 | 2006-09-15 | 125d? | finish no earlier than 2005-09-12 | S2 | 1000h | 1000h | OPTUNEL-Study | Nokia | antti.j.pasanen@nokia.com | Rel-7 | Maurice | 23.809 | SP-34 |
| 939 | 283.2 | One Tunnel Deployment Guideline |  | 268d? | 2006-10-23 A | 2007-10-31 A | 100% | 2006-10-23 | 2007-10-31 | 268d? | finish no earlier than 2007-10-31 | S2 | 2144h | 2144h | OPTUNEL-Guide | Huawei | lan.liu@huawei.com | Rel-7 | Maurice | 23.919 |  |
| 940 | 283.3 | Stage 2 specification for One Tunnel solution |  | 70d? | 2006-09-11 A | 2006-12-15 A | 100% | 2006-09-11 | 2006-12-15 | 70d? | finish no earlier than 2006-12-15 | S2 | 560h | 560h | OPTUNEL-Stage2 | Nokia | antti.j.pasanen@nokia.com | Rel-7 | Maurice | 23.060 |  |
| 941 | 284 | **CSI Terminating Session handling** |  | 267d? | 2006-06-08 A | 2007-06-15 A | 100% | 2006-06-08 | 2007-06-15 | 267d? |  | S2,C1 | 4728h | 4728h | CSItermS | Samsung | Osok Song | Rel-7 | Maurice |  |  |
| 942 | 284.1 | Stage 2 of CStermS |  | 192d? | 2006-06-08 A | 2007-03-02 A | 100% | 2006-06-08 | 2007-03-02 | 192d? | start no earlier than 2006-06-08 | S2 | 1536h | 1536h | CSItermS | Samsung | Osok Song | Rel-7 | Maurice | 23.279 |  |
| 943 | 284.2 | Stage 3 of CStermS |  | 132d? | 2006-12-14 A | 2007-06-15 A | 100% | 2006-12-14 | 2007-06-15 | 132d? | finish no earlier than 2007-06-15 | C1 | 1056h | 1056h | CSItermS | Samsung | chenho.chin@samsung.com | Rel-7 | Frederic | 24.229, 24.279 |  |
| 944 | 284.3 | Deleted - duplicated with UID 340015 -Stage 3 CSI Terminating Session handling | milestone | 0d? | 2007-03-09 A | 2007-03-09 A | 100% | 2007-03-09 | 2007-03-09 | 0d? | start no earlier than 2007-03-09 | C1 |  |  | CSItermS | Samsung | chenho.chin@samsung.com | Rel-7 | Frederic | 24.229, 24.179, 24.279 | CP-34 |
| 945 | 285 | Liberty Alliance and 3GPP Security Interworking |  | 451d? | 2005-03-10 A | 2006-11-30 A | 100% | 2005-03-10 | 2006-11-30 | 451d? | finish no earlier than 2006-11-30 | S3 | 3608h | 3608h | LibSec | Nokia | Silke.Holtmanns@NOKIA.COM | Rel-7 | Dionisio | 33.980 |  |
| 946 | 286 | Trust Requirements for Open Platforms in 3GPP |  | 499d? | 2005-01-03 A | 2006-11-30 A | 100% | 2005-01-03 | 2006-11-30 | 499d? | finish no earlier than 2006-11-30 | S3 | 3992h | 3992h | TrustOP | Nokia | Silke.Holtmanns@NOKIA.COM | Rel-7 | Dionisio | 33.905 |  |
| 947 | 287 | Development of UEA2 and UIA2 |  | 268d? | 2004-12-01 A | 2005-12-09 A | 100% | 2004-12-01 | 2005-12-09 | 268d? | finish no earlier than 2005-12-09 | S3 | 2144h | 2144h | AlgUEA2 | TeliaSonera | per.christoffersson@teliasonera.com | Rel-7 | Dionisio | 35.919, 35.215, 35.216, 35.217, 35.218 |  |
| 948 | 288 | Lawful Interception in the 3GPP Rel-7 architecture |  | 118d? | 2005-06-28 A | 2005-12-08 A | 100% | 2005-06-28 | 2005-12-08 | 118d? | start no earlier than 2005-06-28 | S3 | 944h | 944h | LI-7A | BMWI | berthold.wilhelm@regtp.de | Rel-7 | Dionisio | 33.106, 33.107, 33.108 |  |
| 949 | 289 | Key establishment between a UICC and a terminal |  | 201.45d? | 2005-12-07 A | 2006-09-28 A | 100% | 2005-12-07 | 2006-09-28 | 201.45d? | finish no earlier than 2006-09-28 | S3 | 1611.6h | 1611.6h | KeyEstUTerm | Gemalto | mireille.pauliac@gemplus.com | Rel-7 | Dionisio | 33.110 |  |
| 950 | 290 | NDS Authentication Framework Extension for Transport Layer Security |  | 50d? | 2006-09-28 A | 2006-12-06 A | 100% | 2006-09-28 | 2006-12-06 | 50d? | finish no earlier than 2006-09-28 | S3 | 400h | 400h | NDSAFTLS | Nokia | tiina.s.koskinen@nokia.com | Rel-7 | Dionisio | 33.310 |  |
| 951 | 291 | **Security enhancements** |  | 319d? | 2005-09-12 A | 2006-11-30 A | 100% | 2005-09-12 | 2006-11-30 | 319d? |  | S3,C1,C4 | 4856h | 4856h | SEC7 |  |  | Rel-7 | Dionisio |  |  |
| 952 | 291.1 | HTTPS connection between a UICC and a NAF |  | 1d? | 2005-09-12 A | 2005-09-12 A | 100% | 2005-09-12 | 2005-09-12 | 1d? | start no earlier than 2005-09-12 | S3,C1 | 8h | 8h | SEC7-HSUN | Gemalto | JSeif@axalto.com, mireille.pauliac@gemplus.com | Rel-7 | Dionisio | 33.918, 33.222, 24.109 |  |
| 953 | 291.2 | 2G GBA: 2G SIM usage in 3GPP GAA framework |  | 61d? | 2005-09-12 A | 2005-12-05 A | 100% | 2005-09-12 | 2005-12-05 | 61d? | finish no earlier than 2005-12-05 | S3 | 488h | 488h | SEC7-2GGBA | Nokia | Silke.Holtmanns@nokia.com | Rel-7 | Dionisio | 33.920, 33.220 |  |
| 954 | 291.3 | Generic Authentication Architecture usage extensions and optimisations |  | 319d? | 2005-09-12 A | 2006-11-30 A | 100% | 2005-09-12 | 2006-11-30 | 319d? | finish no earlier than 2006-11-30 | S3 | 2552h | 2552h | SEC7-GAA2 | Nokia | Silke.Holtmanns@nokia.com | Rel-7 | Dionisio | 33.220, 29.109, 24.109, (33.223 goes to R8) |  |

Notes:
- 928: WID approved SP#27; updated SP#28; updated SP#32
- 929: -
- 930: -
- 931: -
- 932: 03/2006 SP#31 WID approved
- 933: -
- 934: -
- 935: -
- 936: -
- 937: -
- 938: S2#52 CREATED. TR for Info SP-33. SP-34: S2 Report intention to discontinue TR
- 939: SP#34 Approved and exception until 03/07
- 940: S2#52 CREATED
- 941: Triggered by the abandoned Study UID_32117
- 942: -
- 943: CP-34 approved WID. CP-35 updated WID
- 944: CP-34 approved WID
- 945: WID approved SP#27.
- 946: WID approved SP#26.
- 947: WID approved SP#26, Dependant on Funding Availability.
- 948: -
- 949: -
- 950: TLS profile is moved to Rel-8
- 951: -
- 952: -
- 953: -
- 954: 33.223 goes to R8

| ID | WBS | Task | Duration | Start | Finish | Complete | Baseline start | Baseline finish | Baseline duration | Total slack | Constraint | Resources | Work | Actual work | Text1 | Text4 | Text5 | Text6 | Text8 | Text3 | Text12 | Text2 | Text7 |
| --- | --- | --- | --- | --- | --- | --- | --- | --- | --- | --- | --- | --- | --- | --- | --- | --- | --- | --- | --- | --- | --- | --- | --- |
| 955 | 291.4 | **SS7 TCAP security Gateway** | 241d? | 2005-09-12 A | 2006-08-14 A | 100% | 2005-09-12 | 2006-08-14 | 241d? |  |  | S3,C4 | 1808h | 1808h | SEC7-NDS-TCAPsec | Siemens | marc.blommaert.ext@nsn.com | Rel-7 | Dionisio |  |  |  |  |
| 956 | 291.4.1 | SA3 aspects of SEC7-NDS-TCAPsec | 130d? | 2005-09-12 A | 2006-03-10 A | 100% | 2005-09-12 | 2006-03-10 | 130d? |  | finish no earlier than 2006-03-10 | S3 | 1040h | 1040h | SEC7-NDS-TCAPsec-SA3 | Siemens | marc.blommaert.ext@nsn.com | Rel-7 | Dionisio | 33.204 |  |  |  |
| 957 | 291.4.2 | TCAPsec Gateway | 96d? | 2006-04-03 A | 2006-08-14 A | 100% | 2006-04-03 | 2006-08-14 | 96d? |  | start no earlier than 2006-04-01 | C4 | 768h | 768h | SEC7-TCAP | Siemens | Ulrich.wiehe@gksag.de | Rel-7 | Kimmo | 29.204, 29.002 |  |  |  |
| 958 | 292 | IMS Stage 3 IETF Protocol alignment | 589d? | 2004-12-10 A | 2007-03-14 A | 100% | 2004-12-10 | 2007-03-14 | 589d? |  | finish no earlier than 2007-03-15 | C1 | 4712h | 4712h | IMSProtoc |  |  | Rel-7 | Frederic | 24.930 |  |  |  |
| 959 | 293 | **Interoperability between VGCS/VBS and A/Gb flexibility** | 253d? | 2006-03-22 A | 2007-03-09 A | 100% | 2006-03-22 | 2007-03-09 | 253d? |  |  | C1,C4 | 3296h | 3296h | VGCSFlex | Siemens | robert.zaus@nsn.com | Rel-7 | Frederic |  |  |  |  |
| 960 | 293.1 | CT1 aspects of VGCSFlex | 159d? | 2006-03-22 A | 2006-10-30 A | 100% | 2006-03-22 | 2006-10-30 | 159d? |  | finish no earlier than 2006-10-30 | C1 | 1272h | 1272h | VGCSFlex | Siemens | robert.zaus@nsn.com | Rel-7 | Frederic | 43.068, 43.069 |  |  |  |
| 961 | 293.2 | CT4 aspects of VGCSFlex | 253d? | 2006-03-22 A | 2007-03-09 A | 100% | 2006-03-22 | 2007-03-09 | 253d? |  | finish no earlier than 2007-03-09 | C4 | 2024h | 2024h | VGCSFlex-c4 | Siemens | robert.zaus@nsn.com | Rel-7 | Kimmo | 29.002 |  |  |  |
| 962 | 294 | DIAMETER on the GGSN Gi interface | 586d? | 2004-09-10 A | 2006-12-08 A | 100% | 2004-09-10 | 2006-12-08 | 586d? |  | finish no earlier than 2006-12-08 | C3 | 4688h | 4688h | DIAMGi | Vodafone | Nico.Gabriele@vodafone.com | Rel-7 | Gwiho | 29.061 |  |  |  |
| 963 | 295 | DIAMETER on the PDG Wi interface | 586d? | 2004-09-10 A | 2006-12-08 A | 100% | 2004-09-10 | 2006-12-08 | 586d? |  | finish no earlier than 2006-12-08 | C3 | 4688h | 4688h | DIAMWi | Vodafone | Nico.Gabriele@vodafone.com | Rel-7 | Gwiho | 29.161 |  |  |  |
| 964 | 296 | Interworking between the 3GPP CS domain with BICC or ISUP as signalling protocol and external SIP-I networks | 478d? | 2006-09-22 A | 2008-07-22 A | 100% | 2006-09-22 | 2008-07-22 | 478d? |  | finish no earlier than 2007-09-14 | C3 | 3824h | 3824h | ExtSIPI | Siemens | Thomas.Belling@nsn.com | Rel-7 | Gwiho | 29.164 |  |  |  |
| 965 | 297 | PDU multiplexing at Nb Interface with IP transport | 427d? | 2006-12-04 A | 2008-07-22 A | 100% | 2006-12-04 | 2008-07-22 | 427d? |  | start no earlier than 2006-12-04 | C3 | 3416h | 3416h | NbIPMux | Alcatel-Lucent | Jean.Rzeznik@alcatel-lucent.fr | Rel-7 | Gwiho | 29.414 |  |  |  |
| 966 | 298 | **Mp (MRFC - MRFP) interface** | 345d? | 2006-02-13 A | 2007-06-08 A | 100% | 2006-02-13 | 2007-06-08 | 345d? |  |  | C4,C1 | 4384h | 4384h | Mp | Ericsson | philip.hodges@ericsson.com | Rel-7 | Kimmo |  |  |  |  |
| 967 | 298.1 | CT1 aspects of Mp | 1d | 2006-02-13 A | 2006-02-13 A | 100% | 2006-02-13 | 2006-02-13 | 1d |  | finish no earlier than 2006-02-13 | C1 | 8h | 8h | Mp | Ericsson | philip.hodges@ericsson.com | Rel-7 | Frederic | 24.229 |  |  |  |
| 968 | 298.2 | Deleted - CT3 aspects of Mp | 1d | 2006-09-22 A | 2006-09-22 A | 100% | 2006-09-22 | 2006-09-22 | 1d |  | start no earlier than 2006-09-22 | C3 | 8h | 8h | Mp | Ericsson | philip.hodges@ericsson.com | Rel-7 | Gwiho | 29.162 | CP-33 |  |  |
| 969 | 298.3 | Procedures description | 201d? | 2006-06-02 A | 2007-03-09 A | 100% | 2006-06-02 | 2007-03-09 | 201d? |  | finish no earlier than 2007-03-09 | C4 | 1608h | 1608h | Mp-PROCc4 | Huawei | Chencheng@huawei.com | Rel-7 | Kimmo | 23.333 |  |  |  |
| 970 | 298.4 | Stage 3 | 345d | 2006-02-13 A | 2007-06-08 A | 100% | 2006-02-13 | 2007-06-08 | 345d |  | finish no earlier than 2007-06-08 | C4 | 2760h | 2760h | Mp-St3c4 | Ericsson | philip.hodges@ericsson.com | Rel-7 | Kimmo | 29.333 |  |  |  |
| 971 | 299 | Routeing of MT-SMS via the HPLMN | 71d? | 2006-12-01 A | 2007-03-09 A | 100% | 2006-12-01 | 2007-03-09 | 71d? |  | finish no earlier than 2007-03-09 | C4,C1 | 568h | 568h | SMSviaH | Vodafone | Nick.Russell@vodafone.com | Rel-7 | Kimmo | 23.040, 29.002 |  |  |  |
| 972 | 300 | Mobile Termination whilst the MS is moving to another MSC | 60d? | 2007-03-09 A | 2007-05-31 A | 100% | 2007-03-09 | 2007-05-31 | 60d? |  | start no earlier than 2007-03-09 | C4 | 480h | 480h | MTmovMS | Alcatel-Lucent | bruno.landais@alcatel-lucent.fr | Rel-7 | Kimmo | 23.008, 23.012, 23.018, 23.078, 23.079, 29.002 |  |  |  |
| 973 | 301 | ISIM API for Java Card | 620d? | 2005-03-14 A | 2007-07-27 A | 100% | 2005-03-14 | 2007-07-27 | 620d? |  | finish no earlier than 2007-07-27 | C6 | 4960h | 4960h | APIJAVA | Sun | Sebastian Hans | Rel-7 | Xavier | 31.103, 102 241 |  |  |  |
| 974 | 302 | Rel-7 (U)SIM API Testing | 206d? | 2009-05-30 | 2010-03-12 |  | 2009-05-30 | 2010-03-12 | 206d? | 656d | finish no earlier than 2010-03-12 | C6 | 1648h |  | USIM_API_test | Sagem Orga | gerrit.hartbrod@sagem-orga.com | Rel-7 | Xavier | 31.213 |  | PCG-23 | CP-44 |
| 975 | 303 | High speed interface between the UICC and the ME | 311d? | 2006-09-22 A | 2007-11-30 A | 100% | 2006-09-22 | 2007-11-30 | 311d? |  | finish no earlier than 2007-11-30 | C6 | 2488h | 2488h | HSI | Gemalto | jacques.seif@GEMALTO.COM | Rel-7 | Xavier | 31.101 |  |  |  |
| 976 | 304 | Video Codec Performance Requirements | 634d? | 2005-01-03 A | 2007-06-07 A | 100% | 2005-01-03 | 2007-06-07 | 634d? |  | finish no earlier than 2007-06-07 | S4 | 5072h | 5072h | VICPer | Siemens | juergen.pandel@siemens.com | Rel-7 | Paolo | 26.234, 26.235, 26.346, 26.140, 26.902 |  |  |  |
| 977 | 305 | Dynamic and Interactive Multimedia Scenes | 583d? | 2005-03-15 A | 2007-06-07 A | 100% | 2005-03-15 | 2007-06-07 | 583d? |  | finish no earlier than 2007-06-07 | S4 | 4664h | 4664h | DIMS | Streamezzo | gaelle.martin-cocher@streamezzo.com | Rel-7 | Paolo | 26.140, 26.142, 26.234, 26.244, 23.346 |  |  |  |
| 978 | 306 | 3G-324M Video Telephony Call Setup Times Improvements | 341d? | 2005-06-08 A | 2006-09-27 A | 100% | 2005-06-08 | 2006-09-27 | 341d? |  | finish no earlier than 2006-09-27 | S4 | 2728h | 2728h | VTCSTI | Vodafone | edward.hall@vodafone.co.uk | Rel-7 | Paolo | 26.911 |  |  |  |

Notes:
- 955: -
- 956: -
- 957: -
- 958: TR 24.930: Signalling flows for the session setup in the IM CN subsystem based on Session Initiation Protocol (SIP)
- 959: Voice Group Call Service
- 960: -
- 961: -
- 962: -
- 963: -
- 964: -
- 965: -
- 966: -
- 967: -
- 968: CP#34: CT3 not involved in Mp interface definition
- 969: -
- 970: -
- 971: WID approved in CP#34
- 972: -
- 973: -
- 974: Update of Rel-6 (U)SIM API for Java Card Testing UID_43007 under Rel-6 UICC/USIM enhancements and interworking UID_1800
- 975: Following ETSI publication of TS 102 600, expected to be completed at CT6 meeting 45
- 976: -
- 977: -
- 978: -

| ID | WBS | Task | Type | Duration | Start | Finish | Complete | Baseline start | Baseline finish | Baseline duration | Constraint | Resources | Work | Actual work | Text1 | Text4 | Text5 | Text6 | Text8 | Text12 |
| --- | --- | --- | --- | --- | --- | --- | --- | --- | --- | --- | --- | --- | --- | --- | --- | --- | --- | --- | --- | --- |
| 979 | 307 | **Optimizations for Multimedia Telephony over IMS** |  | 0d? | 2005-09-28 A | 2005-09-28 A | 100% | 2005-09-28 | 2005-09-28 | 0d? |  | S4 |  |  | OMTIMS | Ericsson | olle.franceschi@ericsson.com | Rel-7 | Paolo |  |
| 980 | 307.1 | Deleted - Characterisation of Adaptive Jitter Management Performance for VoIP Services | milestone | 0d? | 2005-09-28 A | 2005-09-28 A | 100% | 2005-09-28 | 2005-09-28 | 0d? | start no earlier than 2007-03-15 | S4 |  |  | OMTIMS-CAJMP | Lucent | dhuo@lucent.com | Rel-7 | Paolo | SP-35 |
| 981 | 308 | End-to-End Multimedia Services Performance Metrics |  | 382d? | 2005-09-28 A | 2007-03-15 A | 100% | 2005-09-28 | 2007-03-15 | 382d? | finish no earlier than 2007-03-15 | S4 | 3056h | 3056h | E2EMSPM | China Mobile | zhangyanyf@chinamobile.com | Rel-7 | Paolo |  |
| 982 | 309 | Packet Switched Streaming Enhancements |  | 261d? | 2006-06-08 A | 2007-06-07 A | 100% | 2006-06-08 | 2007-06-07 | 261d? | finish no earlier than 2007-06-07 | S4 | 2088h | 2088h | PSSe | Ericsson | olle.franceschi@ericsson.com | Rel-7 | Paolo |  |
| 983 | 310 | **OAM&P Rel-7** |  | 472.86d? | 2005-09-02 A | 2007-06-26 A | 100% | 2005-09-02 | 2007-06-26 | 472.86d? |  | S5 | 82725.8h | 82725.8h | OAM7 | Huawei | Christian.Toche@huawei.com | Rel-7 | Dionisio |  |
| 984 | 310.1 | **Network Infrastructure Management** |  | 465d? | 2005-09-02 A | 2007-06-14 A | 100% | 2005-09-02 | 2007-06-14 | 465d? |  | S5 | 41800h | 41800h | OAM7-NIM |  |  | Rel-7 | Dionisio |  |
| 985 | 310.1.1 | Enhance NRM to accommodate NGN (IMS as basis of the Next Generation Network) |  | 465d? | 2005-09-02 A | 2007-06-14 A | 100% | 2005-09-02 | 2007-06-14 | 465d? | finish no earlier than 2007-06-14 | S5 | 3720h | 3720h | OAM7-NIM | Motorola |  | Rel-7 | Dionisio |  |
| 986 | 310.1.2 | Co-operative Element Management interface (CO-OP) (Study + Implementation) |  | 400d? | 2005-09-02 A | 2007-03-15 A | 100% | 2005-09-02 | 2007-03-15 | 400d? | finish no earlier than 2007-03-15 | S5 | 3200h | 3200h | OAM7-NIM | Motorola |  | Rel-7 | Dionisio |  |
| 987 | 310.1.3 | Network Management (NM) Itf-N performance criteria |  | 465d? | 2005-09-02 A | 2007-06-14 A | 100% | 2005-09-02 | 2007-06-14 | 465d? | finish no earlier than 2007-06-14 | S5 | 3720h | 3720h | OAM7-NIM | China Mobile |  | Rel-7 | Dionisio |  |
| 988 | 310.1.4 | Delta synchronization between IRP Manager and IRP Agent (Study + Implementation) |  | 465d? | 2005-09-02 A | 2007-06-14 A | 100% | 2005-09-02 | 2007-06-14 | 465d? | finish no earlier than 2007-06-14 | S5 | 3720h | 3720h | OAM7-NIM | Siemens |  | Rel-7 | Dionisio |  |
| 989 | 310.1.5 | Subscription Management (SuM) IRP Solution Sets |  | 330d? | 2005-09-02 A | 2006-12-07 A | 100% | 2005-09-02 | 2006-12-07 | 330d? | finish no earlier than 2006-12-07 | S5 | 2640h | 2640h | OAM7-NIM | Ericsson |  | Rel-7 | Dionisio |  |
| 990 | 310.1.6 | Integration Reference Point (IRP) Security Management |  | 400d? | 2005-09-02 A | 2007-03-15 A | 100% | 2005-09-02 | 2007-03-15 | 400d? | finish no earlier than 2007-03-15 | S5 | 3200h | 3200h | OAM7-NIM | Huawei | Christian.Toche@huawei.com | Rel-7 | Dionisio |  |
| 991 | 310.1.7 | Partial suspension of Itf-N during maintenance/testing (Study + Implementation) |  | 465d? | 2005-09-02 A | 2007-06-14 A | 100% | 2005-09-02 | 2007-06-14 | 465d? | finish no earlier than 2007-06-14 | S5 | 3720h | 3720h | OAM7-NIM | Siemens |  | Rel-7 | Dionisio |  |
| 992 | 310.1.8 | Deleted - Management of Legacy Equipment |  | 336d? | 2005-09-02 A | 2006-12-15 A | 100% | 2005-09-02 | 2006-12-15 | 336d? | finish no earlier than 2006-12-15 | S5 | 2688h | 2688h | OAM7-NIM | Siemens |  | Rel-7 | Dionisio | SP-35 |
| 993 | 310.1.9 | Deleted - Rules for Vendor Specific Extensions |  | 400d? | 2005-09-02 A | 2007-03-15 A | 100% | 2005-09-02 | 2007-03-15 | 400d? | finish no earlier than 2007-03-15 | S5 | 3200h | 3200h | OAM7-NIM | Siemens |  | Rel-7 | Dionisio | SP-35 |
| 994 | 310.1.10 | Backward and Forward Compatibility of IRP systems |  | 465d? | 2005-09-02 A | 2007-06-14 A | 100% | 2005-09-02 | 2007-06-14 | 465d? | finish no earlier than 2007-06-14 | S5 | 3720h | 3720h | OAM7-NIM | Ericsson |  | Rel-7 | Dionisio |  |
| 995 | 310.1.11 | Repeater Network Resource Model (NRM) definition |  | 214d? | 2006-02-13 A | 2006-12-07 A | 100% | 2006-02-13 | 2006-12-07 | 214d? | finish no earlier than 2006-12-07 | S5 | 1712h | 1712h | OAM7-NIM | China Mobile |  | Rel-7 | Dionisio |  |
| 996 | 310.1.12 | UTRAN radio channel power monitoring |  | 284d? | 2006-02-13 A | 2007-03-15 A | 100% | 2006-02-13 | 2007-03-15 | 284d? | finish no earlier than 2007-03-15 | S5 | 2272h | 2272h | OAM7-NIM | China Mobile |  | Rel-7 | Dionisio |  |
| 997 | 310.1.13 | Notification XML Schema |  | 71d? | 2006-12-07 A | 2007-03-15 A | 100% | 2006-12-07 | 2007-03-15 | 71d? | finish no earlier than 2007-03-15 | S5 | 568h | 568h | OAM7-NIM | Huawei | Christian.Toche@huawei.com | Rel-7 | Dionisio |  |
| 998 | 310.2 | **Performance Management** |  | 465d? | 2005-09-02 A | 2007-06-14 A | 100% | 2005-09-02 | 2007-06-14 | 465d? |  | S5 | 22992h | 22992h | OAM7-PM |  |  | Rel-7 | Dionisio |  |
| 999 | 310.2.1 | Performance measurements definition for CN CS |  | 400d? | 2005-09-02 A | 2007-03-15 A | 100% | 2005-09-02 | 2007-03-15 | 400d? | finish no earlier than 2007-03-15 | S5 | 3200h | 3200h | OAM7-PM | China Mobile |  | Rel-7 | Dionisio |  |
| 1000 | 310.2.2 | Enhancement UTRAN performance measurements definition |  | 465d? | 2005-09-02 A | 2007-06-14 A | 100% | 2005-09-02 | 2007-06-14 | 465d? | finish no earlier than 2007-06-14 | S5 | 3720h | 3720h | OAM7-PM | China Mobile |  | Rel-7 | Dionisio |  |
| 1001 | 310.2.3 | Add TDD specific counters in Performance measurement |  | 330d? | 2005-09-02 A | 2006-12-07 A | 100% | 2005-09-02 | 2006-12-07 | 330d? | finish no earlier than 2006-12-15 | S5 | 2640h | 2640h | OAM7-PM | CATT |  | Rel-7 | Dionisio |  |
| 1002 | 310.2.4 | ATM bearer network Performance measurements |  | 400d? | 2005-09-02 A | 2007-03-15 A | 100% | 2005-09-02 | 2007-03-15 | 400d? | finish no earlier than 2007-03-15 | S5 | 3200h | 3200h | OAM7-PM | ZTE |  | Rel-7 | Dionisio |  |
| 1003 | 310.2.5 | Performance measurements definition for IMS |  | 465d? | 2005-09-02 A | 2007-06-14 A | 100% | 2005-09-02 | 2007-06-14 | 465d? | finish no earlier than 2007-06-14 | S5 | 3720h | 3720h | OAM7-PM | China Mobile |  | Rel-7 | Dionisio |  |
| 1004 | 310.2.6 | HSDPA performance measurements |  | 349d? | 2006-02-13 A | 2007-06-14 A | 100% | 2006-02-13 | 2007-06-14 | 349d? | finish no earlier than 2007-06-14 | S5 | 2792h | 2792h | OAM7-PM | China Mobile |  | Rel-7 | Dionisio |  |

Notes:
- 979: - / Text3: 26.235, 26.236
- 980: SP-35 stopped
- 981: - / Text3: 26.944
- 982: - / Text3: 26.234, 26.244
- 983: -
- 984: -
- 985: - / Text3: 32.731/2/3/5, 32.631/2/3/5
- 986: - / Text3: 32.806, 32.814, 32.101
- 987: - / Text3: 32.811
- 988: - / Text3: 32.391/2/3/5
- 989: - / Text3: 32.307/317/607/667/665, 32.101, 32.175
- 990: - / Text3: 32.372/3/5, 32.111,32.30x,32.32x,32.33x,32.34x,32.35x,32.36x,32.41x,32.60x,32.61x,32.66x
- 991: - / Text3: 32.381/2/3/5
- 992: Request to TSG#35 to STOP the WI / Text3: new 32.xxx
- 993: Request to TSG#35 to STOP the WI / Text3: 32.62n; For n = 1 to 5
- 994: - / Text3: 32.154
- 995: - / Text3: 32.721/2/3/5
- 996: - / Text3: 32.405, 32.64n; For n = 1 to 5
- 997: 12/2006 SP#34 WID approved / Text3: New 32.325/345/365/415, CR to 32.335/615/665
- 998: -
- 999: - / Text3: 32.407, 32.408
- 1000: - / Text3: 32.405
- 1001: - / Text3: 32.405
- 1002: - / Text3: No impact on 32.404, 32.405, 32.406, 32.407
- 1003: - / Text3: 32.404,32.409,32.437, 32.632/3/4/5
- 1004: - / Text3: 32.405

| ID | WBS | Task | Type | Duration | Start | Finish | Complete | Baseline start | Baseline finish | Baseline duration | Constraint | Resources | Work | Actual work | Text1 | Text4 | Text6 | Text8 | Text12 | Text5 | Text11 | Text9 |
| --- | --- | --- | --- | --- | --- | --- | --- | --- | --- | --- | --- | --- | --- | --- | --- | --- | --- | --- | --- | --- | --- | --- |
| 1005 | 44.5 | **Trace Management** |  | 472.86d? | 2005-09-02 A | 2007-06-26 A | 100% | 2005-09-02 | 2007-06-26 | 472.86d? |  | S5 | 14150.9h | 14150.9h | OAM7-Trace | Vodafone | Rel-7 | Dionisio |  |  |  |  |
| 1006 | 310.3.1 | End-to-end Service Level tracing for IMS |  | 350d? | 2005-11-11 A | 2007-03-15 A | 100% | 2005-11-11 | 2007-03-15 | 350d? | finish no earlier than 2007-03-15 | S5 | 2800h | 2800h | OAM7-Trace | Vodafone | Rel-7 | Dionisio | SP-31 |  |  |  |
| 1007 | 310.3.2 | Trace record content for UTRAN TDD |  | 330d? | 2005-09-02 A | 2006-12-07 A | 100% | 2005-09-02 | 2006-12-07 | 330d? | finish no earlier than 2006-12-07 | S5 | 2640h | 2640h | OAM7-Trace | Nokia | Rel-7 | Dionisio |  |  |  |  |
| 1008 | 310.3.3 | IRP for Subscriber and Equipment Trace Management |  | 465d? | 2005-09-02 A | 2007-06-14 A | 100% | 2005-09-02 | 2007-06-14 | 465d? | finish no earlier than 2007-06-14 | S5 | 3720h | 3720h | OAM7-Trace | Nokia | Rel-7 | Dionisio |  |  |  |  |
| 1009 | 310.3.4 | Deleted - SIP enhancements for trace | milestone | 0d? | 2007-06-15 A | 2007-06-26 A | 100% | 2007-06-15 | 2007-06-26 | 0d? | start no earlier than 2007-06-15 | C1 |  |  | OAM7-Trace |  | Rel-7 | Frederic | CP-32 |  |  |  |
| 1010 | 310.3.5 | Deleted - duplicated with UID 35063 - IRP for Subscriber and Equipment Trace Management |  | 336d? | 2005-09-02 A | 2006-12-15 A | 100% | 2005-09-02 | 2006-12-15 | 336d? | finish no earlier than 2006-12-15 | S5 | 2688h | 2688h | OAM7-Trace | Nokia | Rel-7 | Dionisio | SP-33 |  |  |  |
| 1011 | 311 | **Charging Management small Enhancements Rel-7** |  | 279d? | 2006-05-22 A | 2007-06-14 A | 100% | 2006-05-22 | 2007-06-14 | 279d? |  | S5 | 5952h | 5952h | CH7 | Orange | Rel-7 | Dionisio |  | alain.bibas@orange-ft.com |  |  |
| 1012 | 311.1 | Alternate Charged Party (ACP) for IMS |  | 279d? | 2006-05-22 A | 2007-06-14 A | 100% | 2006-05-22 | 2007-06-14 | 279d? | finish no earlier than 2007-06-14 | S5 | 2232h | 2232h | CH7-IMS-ACP | Lucent | Rel-7 | Dionisio |  | njmazzarella@alcatel-lucent.com |  |  |
| 1013 | 311.2 | Align 3GPP Charging with OMA PoC Enabler Release 2.0 |  | 186d? | 2006-09-28 A | 2007-06-14 A | 100% | 2006-09-28 | 2007-06-14 | 186d? | finish no earlier than 2007-06-14 | S5 | 1488h | 1488h | CH7-PoC | Siemens | Rel-7 | Dionisio |  | Gerald GÖRMER |  |  |
| 1014 | 8.5 | **Multiple Input Multiple Output antennas (MIMO)** |  | 1177d? | 2003-03-14 A | 2007-09-17 A | 100% | 2003-03-14 | 2007-09-17 | 1177d? |  | R1 | 40272h | 40272h | MIMO | Alcatel-Lucent | Rel-7 | Patrick |  | hchuang@Alcatel-Lucent.com | RP-070037, RP-070531 |  |
| 1015 | 312.1 | MIMO - Physical layer |  | 915d? | 2003-09-12 A | 2007-03-15 A | 100% | 2003-09-12 | 2007-03-15 | 915d? | finish no earlier than 2007-03-15 | R1 | 7320h | 7320h | MIMO-Phys | Alcatel-Lucent | Rel-7 | Patrick |  | hchuang@Alcatel-Lucent.com | RP-070037 |  |
| 1016 | 312.2 | MIMO - Layer 2,3 aspects |  | 915d? | 2003-09-12 A | 2007-03-15 A | 100% | 2003-09-12 | 2007-03-15 | 915d? | finish no earlier than 2007-03-15 | R2 | 7320h | 7320h | MIMO-L23 | Alcatel-Lucent | Rel-7 | Joern |  | hchuang@Alcatel-Lucent.com | RP-070037 |  |
| 1017 | 312.3 | MIMO - Iub/Iur Protocol Aspects |  | 1045d? | 2003-03-14 A | 2007-03-15 A | 100% | 2003-03-14 | 2007-03-15 | 1045d? | finish no earlier than 2007-03-15 | R3 | 8360h | 8360h | MIMO-IurIub | Alcatel-Lucent | Rel-7 | Juha |  | hchuang@Alcatel-Lucent.com | RP-070037 |  |
| 1018 | 312.4 | MIMO - RF Radio Transmission/Reception, System Performance Requirements and Conformance Testing |  | 982d? | 2003-12-12 A | 2007-09-17 A | 100% | 2003-12-12 | 2007-09-17 | 982d? | finish no earlier than 2007-09-17 | R4 | 7856h | 7856h | MIMO-RF | Alcatel-Lucent | Rel-7 | Stefania |  | ngm@Alcatel-Lucent.com | RP-070531 |  |
| 1019 | 313 | **Rel-7 Improvements of the Radio Interface** |  | 709d? | 2004-09-15 A | 2007-06-04 A | 100% | 2004-09-15 | 2007-06-04 | 709d? |  | RP | 29696h | 29696h | RInImp |  | Rel-7 | Stefania |  |  |  |  |
| 1020 | 313.1 | Extended UMTS 1.7/2.1 GHz |  | 198d? | 2006-03-15 A | 2006-12-15 A | 100% | 2006-03-15 | 2006-12-15 | 198d? | finish no earlier than 2006-12-15 | R4 | 1584h | 1584h | RInImp-UMTS1721Ext | Ericsson | Rel-7 | Stefania |  | Johan Sköld (johan.skold@ericsson.com) | RP-060681 |  |
| 1021 | 313.2 | UMTS 2.6 GHz 7.68 Mcps TDD |  | 67d? | 2006-06-15 A | 2006-09-15 A | 100% | 2006-06-15 | 2006-09-15 | 67d? | finish no earlier than 2006-09-15 | R4 | 536h | 536h | RInImp-UMTS26VHCRTDD | IPWireless | Rel-7 | Stefania |  | Shin Horng Wong (shwong@ipwireless.com) | RP-060451 |  |
| 1022 | 313.3 | UMTS 2.6 GHz |  | 195d? | 2004-09-15 A | 2005-06-14 A | 100% | 2004-09-15 | 2005-06-14 | 195d? | finish no earlier than 2005-06-14 | R4 | 1560h | 1560h | RInImp-UMTS2600 | Nokia | Rel-7 | Stefania |  | jussi.numminen@nokia.com | RP-050184 |  |
| 1023 | 313.4 | UMTS 2.6 GHz TDD |  | 261d? | 2004-12-15 A | 2005-12-14 A | 100% | 2004-12-15 | 2005-12-14 | 261d? | finish no earlier than 2005-12-15 | R4 | 2088h | 2088h | RInImp-UMTS2600TDD | IPWireless | Rel-7 | Stefania |  | Shin Horng Wong (shwong@ipwireless.com) | RP-050661 |  |
| 1024 | 313.5 | UMTS 900 MHz |  | 261d? | 2004-12-15 A | 2005-12-14 A | 100% | 2004-12-15 | 2005-12-14 | 261d? | finish no earlier than 2005-12-15 | R4 | 2088h | 2088h | RInImp-UMTS900 | Nortel | Rel-7 | Stefania |  | Yannick Li (yli@nortelnetworks.com) | RP-050662 |  |
| 1025 | 313.6 | UMTS 1700 MHz |  | 197d? | 2005-03-15 A | 2005-12-14 A | 100% | 2005-03-15 | 2005-12-14 | 197d? | finish no earlier than 2005-12-15 | R4 | 1576h | 1576h | RInImp-UMTS1700 | NTT DoCoMo | Rel-7 | Stefania |  | Takehiro Nakamura (nakamurata@nttdocomo.co.jp) | RP-050824 |  |
| 1026 | 313.7 | UE Antenna Performance Evaluation Method and Requirements |  | 644d? | 2004-12-15 A | 2007-06-04 A | 100% | 2004-12-15 | 2007-06-04 | 644d? | finish no earlier than 2007-06-04 | R4 | 5152h | 5152h | RInImp-UEAnt | TeliaSonera | Rel-7 | Stefania |  | Christian.Bergljung@TeliaSonera.com | RP-070281 |  |
| 1027 | 313.8 | Improved Performance Requirements for HSDPA UE based on Rx Diversity (type 1) & LMMSE equalizer (type 2) | milestone | 0d? | 2005-03-15 A | 2005-03-15 A | 100% | 2005-03-15 | 2005-03-15 | 0d? | finish no earlier than 2005-03-15 | R4 |  |  | RInImp-HSPerf-Type3 | Cingular | Rel-7 | Stefania |  | Marc Grant | RP-060015 |  |
| 1028 | 313.9 | **Additional minimum UE performance requirement for non-HSDPA channels based on type 1 enhanced receiver (Rx Diversity)** |  | 327d? | 2005-09-15 A | 2006-12-15 A | 100% | 2005-09-15 | 2006-12-15 | 327d? |  | R4 | 7344h | 7344h | RInImp-RxDiv | Qualcomm Europe | Rel-7 | Stefania |  | Serge Willenegger (sergew@qualcomm.com) |  |  |
| 1029 | 313.9.1 | Additional minimum UE performance requirement for DL physical channels in support of DCH/HS-DSCH operation based on type 1 enhanced receiver (RX-Diversity) |  | 195d? | 2005-09-15 A | 2006-06-14 A | 100% | 2005-09-15 | 2006-06-14 | 195d? | finish no earlier than 2006-06-15 | R4 | 1560h | 1560h | RInImp-RxDiv-DCH | Cingular | Rel-7 | Stefania |  | Marc Grant | RP-060235 |  |
| 1030 | 313.9.2 | Additional minimum UE performance requirement for downlink physical channels in support of MTCH and MCCH operation based on type 1 enhanced receiver (Rx-Diversity) |  | 198d? | 2006-03-15 A | 2006-12-15 A | 100% | 2006-03-15 | 2006-12-15 | 198d? | finish no earlier than 2006-12-15 | R4 | 1584h | 1584h | RInImp-RxDiv-MBMS | Qualcomm Europe | Rel-7 | Stefania |  | Serge Willenegger (sergew@qualcomm.com) | RP-060678 |  |
| 1031 | 313.9.3 | Additional minimum UE performance requirement for downlink physical channels in support of E-DCH operation based on type 1 enhanced receiver (Rx-Diversity) |  | 198d? | 2006-03-15 A | 2006-12-15 A | 100% | 2006-03-15 | 2006-12-15 | 198d? | finish no earlier than 2006-12-15 | R4 | 1584h | 1584h | RInImp-RxDiv-EDCH | Qualcomm Europe | Rel-7 | Stefania |  | Serge Willenegger (sergew@qualcomm.com) | RP-060679 |  |
| 1032 | 313.10 | Deleted Improved support of gaming over HSDPA/EDCH |  | 262d? | 2005-12-15 A | 2006-12-15 A | 100% | 2005-12-15 | 2006-12-15 | 262d? | finish no earlier than 2006-12-15 | R2 | 2096h | 2096h | RInImp-Gaming | Cingular | Rel-7 | Joern | RP-34 | Don Zelmer (dz1069@att.com) | RP-060680 |  |
| 1033 | 313.11 | Deleted (not approved at PCG) - UMTS 2.6 GHz FDD DL External | milestone | 0d? | 2005-09-15 A | 2005-09-15 A | 100% | 2005-09-15 | 2005-09-15 | 0d? | finish no earlier than 2005-09-15 | R4 |  |  | RInImp-UMTS2600Ext | T-mobile | Rel-7 | Stefania | RP-31 | han.van.bussel@t-mobile.de |  | PCG-16 |

Notes:
- 1005: -
- 1006: 07/2005: OMA (Stage 1), Stage 2/3 SA5, CT1/3/4 / Text3: CR 32.101, 32.421/2/3.
- 1007: - / Text3: CR 32.421/2/3.
- 1008: - / Text3: 32.441/2/3/5, CRs 32.632/3/5
- 1009: combined with UID 11067
- 1010: - / Text3: 32.421,32.422,32.423. 3 new 32.4x1,2,3
- 1011: -
- 1012: - / Text3: 32.240, 32.260, 32.298, 32.299
- 1013: 09/2006 SP#33 WID approved / Text3: 32.240, 32.272, 32.299, 32.298
- 1014: Completed Sep 2007; SR in RP-070037and RP-070531 / Text3: 25.876, 25.996
- 1015: Completed Sep 2007; SR in RP-070037 / Text3: 25.211, 25.212, 25.213, 25.214, 25.215, 25.221
- 1016: Completed Sep 2007; SR in RP-070037 / Text3: 25.876
- 1017: Completed Sep 2007; SR in RP-070037
- 1018: Completed Sep 2007; SR in RP-070531
- 1019: Generic feature
- 1020: SR in RP-060681. Introduction of Band X (Extended UMTS 1.7/2.1 GHz) in 25.307 / Text3: 25.806, 25.101, 25.104, 25.133, 24.141, 25.331, 25.306, 25.307, 25.423, 25.461, 25.463, 34.121
- 1021: Completed Sep 2006; SR in RP-060451 / Text3: 25.102, 25.105, 25.123, 25.113, 25.142, 34.124
- 1022: SR in RP-050184. Introduction of UMTS2600 internal band, Band VII in 25.307 / Text3: 25.101, 25.104, 25.133, 25.141, 25.331, 25.942, 25.306, 25.307, 34.121
- 1023: SR in RP-050661 / Text3: 25.102, 25.105, 25.113, 25.123, 25.142, 25.331, 25.942, 25.306, 25.307, 34.122, 34.124
- 1024: SR in RP-050662. Introduction of UMTS 900 (Band VIII) in 25.307 / Text3: 25.101, 25.104, 25.113, 25.133, 25.141, 25.331, 25.942, 25.306, 25.307, 34.121
- 1025: SR in RP-050824 / Text3: 25.101, 25.104, 25.113, 25.133, 25.141, 25.306, 25.307, 25.331, 34.121
- 1026: RP#36 (May 2007) completed. SR in RP-070281 / Text3: 25.101, 25.963
- 1027: Completed Mar 2006, SR in RP-060015 / Text3: 25.101
- 1028: - / Text3: 25.101
- 1029: Completed Jun 2006, SR in RP-060235 / Text3: 25.101
- 1030: Completed Dec 2006, SR in RP-060678 / Text3: 25.101
- 1031: Completed Dec 2006, SR in RP-060679 / Text3: 25.101
- 1032: RP#34 (Dec 2006) stopped. SR in RP-060680
- 1033: This item was conditionnaly approved pending decision of PCG 16 who decided not to approve it / Text3: 25.101, 25.104, 25.133, 25.141, 25.331, 25.942, 25.306, 25.307, 34.121

| ID | WBS | Task | Duration | Start | Finish | Complete | Baseline start | Baseline finish | Baseline duration | Constraint | Deadline | Resources | Work | Actual work | Text1 | Text6 | Text8 | Text4 | Text5 | Text10 | Text11 |
| --- | --- | --- | --- | --- | --- | --- | --- | --- | --- | --- | --- | --- | --- | --- | --- | --- | --- | --- | --- | --- | --- |
| 1034 | 314 | **Rel-7 Improvements of the Radio Interface - UE Conformance Testing** | 741d? | 2005-11-11 A | 2008-09-12 A | 100% | 2005-11-11 | 2008-09-12 | 741d? |  |  | R5 | 17568h | 17568h | RInImp-UEConTest | Rel-7 | Ingbert |  |  |  |  |
| 1035 | 16.5.1 | UE Conformance Test for UMTS 2600 MHz | 146d | 2005-11-11 A | 2006-06-02 A | 100% | 2005-11-11 | 2006-06-02 | 146d | finish no earlier than 2006-06-02 | 2006-06-02 | R5 | 1168h | 1168h | RInImp-UMTS2600_Test | Rel-7 | Ingbert | Nokia | Aleksi.Heino@nokia.com | Fri 7/11/05 |  |
| 1036 | 16.5.1 | UE Conformance Test for UMTS 900 MHz (band VIII) | 146d | 2005-11-11 A | 2006-06-02 A | 100% | 2005-11-11 | 2006-06-02 | 146d | finish no earlier than 2006-06-02 | 2006-06-02 | R5 | 1168h | 1168h | RInImp-UMTS900_Test | Rel-7 | Ingbert | Qualcomm Europe | hanye@qualcomm.com | Fri 11/03/05 |  |
| 1037 | 314.3 | Conformance Test Aspects – Improved Performance of HSDPA Receiver type 3 | 191d? | 2006-03-10 A | 2006-12-01 A | 100% | 2006-03-10 | 2006-12-01 | 191d? | finish no earlier than 2006-12-01 |  | R5 | 1528h | 1528h | RInImp-HSPerf-Type3_Test | Rel-7 | Ingbert | Motorola | carolyn.taylor@motorola.com |  |  |
| 1038 | 314.4 | UE antenna Over The Air (OTA) conformance testing | 518d? | 2006-09-20 A | 2008-09-12 A | 100% | 2006-09-20 | 2008-09-12 | 518d? | finish no earlier than 2008-09-12 |  | R5 | 4144h | 4144h | RInImp-UEAnt_Test | Rel-7 | Ingbert | Nokia | Aleksi.Heino@nokia.com |  | RP-080535 |
| 1039 | 314.5 | UE conformance testing for FDD Inter-Band Operation | 131d? | 2006-06-02 A | 2006-12-01 A | 100% | 2006-06-02 | 2006-12-01 | 131d? | finish no earlier than 2006-12-01 |  | R5 | 1048h | 1048h | RInImp-InterBand_Test | Rel-7 | Ingbert | NEC, Motorola | Jacob.John@motorola.com |  |  |
| 1040 | 314.6 | Conformance Test Aspects – Extended UMTS 1.7/2.1 GHz | 131d? | 2006-12-01 A | 2007-06-01 A | 100% | 2006-12-01 | 2007-06-01 | 131d? | finish no earlier than 2007-06-01 |  | R5 | 1048h | 1048h | RInImp-UEConTest_UMTS1721Ext | Rel-7 | Ingbert | Motorola | carolyn.taylor@motorola.com |  |  |
| 1041 | 314.7 | Conformance Test Aspects – Minimum UE performance requirement for downlink physical channels in support of E-DCH operation based on type 1 enhanced receiver (Rx-Diversity) | 136d? | 2007-06-01 A | 2007-12-07 A | 100% | 2007-06-01 | 2007-12-07 | 136d? | finish no earlier than 2007-12-07 |  | R5 | 1088h | 1088h | RInImp-UEConTest_RxDivEDCH | Rel-7 | Ingbert | Motorola | carolyn.taylor@motorola.com |  |  |
| 1042 | 314.8 | Conformance Test Aspects – Minimum UE performance requirement for downlink physical channels in support of MTCGH and MCCH operation based on type 1 enhanced receiver (Rx-Diversity) | 201d? | 2007-06-01 A | 2008-03-07 A | 100% | 2007-06-01 | 2008-03-07 | 201d? | finish no earlier than 2008-03-07 |  | R5 | 1608h | 1608h | RInImp-UEConTest_RxDivMBMS | Rel-7 | Ingbert | Ericsson | leif.mattisson@ericsson.com |  | RP-080056 |
| 1043 | 315 | **Rel-7 RAN improvements** | 653d? | 2004-12-15 A | 2007-06-15 A | 100% | 2004-12-15 | 2007-06-15 | 653d? |  |  | RP | 29920h | 29920h | RANimp | Rel-7 |  |  |  |  |  |
| 1044 | 315.1 | Optimisation of channelisation code utilisation for 1.28 Mcps TDD | 523d? | 2004-12-15 A | 2006-12-15 A | 100% | 2004-12-15 | 2006-12-15 | 523d? | finish no earlier than 2006-12-15 |  | R1 | 4184h | 4184h | RANimp-RABSE-CodOptLCRTDD | Rel-7 | Patrick | UTStarcom | Ka Leong Lo (kaleong.lo@UTSTAR.COM) |  | RP-060682 |
| 1045 | 315.2 | Delay optimisation for procedures applicable to CS and PS Connections | 394d? | 2005-03-15 A | 2006-09-15 A | 100% | 2005-03-15 | 2006-09-15 | 394d? | finish no earlier than 2006-09-15 |  | R2 | 3152h | 3152h | RANimp-DelayOpt | Rel-7 | Joern | Nokia | juho.pirskanen@nokia.com |  | RP-060453 |
| 1046 | 315.3 | Improved support of IMS Realtime Services using HSDPA/HSUPA | 197d? | 2005-03-15 A | 2005-12-14 A | 100% | 2005-03-15 | 2005-12-14 | 197d? | start no earlier than 2005-03-15 |  | R2 | 1576h | 1576h | RANimp-IMSRealTime | Rel-7 | Joern | Cingular | Don Zelmer (dz1069@att.com) |  | RP-050667 |
| 1047 | 315.4 | UE Performance Requirements for MBMS (TDD) | 328d? | 2005-03-15 A | 2006-06-15 A | 100% | 2005-03-15 | 2006-06-15 | 328d? | finish no earlier than 2006-06-15 |  | R4 | 2624h | 2624h | MBMS-RAN-RF-TDD | Rel-7 | Stefania | IPwireless | shwong@ipwireless.com |  | RP-060477 |
| 1048 | 315.5 | Continuous connectivity for packet data users | 524d? | 2005-03-14 A | 2007-03-15 A | 100% | 2005-03-14 | 2007-03-15 | 524d? | finish no earlier than 2007-03-15 |  | R1 | 4192h | 4192h | RANimp-CPC | Rel-7 | Patrick | Siemens | Joern.Krause@siemens.com |  | RP-070033 |
| 1049 | 315.6 | Extended WCDMA Cell Range | 198d? | 2006-03-15 A | 2006-12-15 A | 100% | 2006-03-15 | 2006-12-15 | 198d? | finish no earlier than 2006-12-15 |  | R3 | 1584h | 1584h | RANimp-ExtCell | Rel-7 | Juha | Ericsson | Muhammad Kazmi |  | RP-060685 |
| 1050 | 315.7 | 7.68 Mcps TDD Enhanced Uplink | 198d? | 2006-03-15 A | 2006-12-15 A | 100% | 2006-03-15 | 2006-12-15 | 198d? | finish no earlier than 2006-12-15 |  | R1 | 1584h | 1584h | RANimp-VHCRTDD-EDCH | Rel-7 | Patrick | IPwireless | nanderson@ipwireless.com |  | RP-060684 |
| 1051 | 315.8 | Enhanced CELL_FACH State in FDD | 181d? | 2006-09-25 A | 2007-06-04 A | 100% | 2006-09-25 | 2007-06-04 | 181d? | finish no earlier than 2007-06-04 |  | R2 | 1448h | 1448h | RANimp-EnhState | Rel-7 | Joern | Nokia | juho.pirskanen@nokia.com |  | RP-070286 |
| 1052 | 315.9 | 64QAM for HSDPA (FDD) | 110d? | 2006-12-15 A | 2007-06-04 A | 100% | 2006-12-15 | 2007-06-04 | 110d? | finish no earlier than 2007-06-04 |  | R1 | 880h | 880h | RANimp-64QamDownlink | Rel-7 | Patrick | Ericsson | Johan.Bergman@ericsson.com |  | RP-070287 |
| 1053 | 315.10 | Improved L2 support for high data rates | 122d? | 2006-12-15 A | 2007-06-04 A | 100% | 2006-12-15 | 2007-06-04 | 122d? | finish no earlier than 2007-06-04 |  | R2 | 976h | 976h | RANimp-L2DataRates | Rel-7 | Joern | Ericsson | Janne.Peisa@ericsson.com |  | RP-070289 |
| 1054 | 315.11 | Introduction of 16QAM in HSUPA (FDD) | 110d? | 2006-12-15 A | 2007-06-04 A | 100% | 2006-12-15 | 2007-06-04 | 110d? | finish no earlier than 2007-06-04 |  | R1 | 880h | 880h | RANimp-16QamUplink | Rel-7 | Patrick | Nokia | Karri.Ranta-aho@nsn.com |  | RP-070288 |
| 1055 | 315.12 | **Interface to control Tower Mounted Amplifiers (TMAs)** | 101d? | 2007-01-26 A | 2007-06-15 A | 100% | 2007-01-26 | 2007-06-15 | 101d? |  |  | R3 | 1616h | 1616h | RANImp-TMA | Rel-7 | Juha | Vodafone | alexej.kulakov@vodafone.com |  | RP-070140 |
| 1056 | 315.12.1 | OAM aspects to Interface to control TMAs | 101d? | 2007-01-26 A | 2007-06-15 A | 100% | 2007-01-26 | 2007-06-15 | 101d? | finish no earlier than 2007-06-15 |  | S5 | 808h | 808h | RANImp-TMA-OAM | Rel-7 | Dionisio | Vodafone | Adrian.Neal@vodafone.com |  |  |
| 1057 | 316 | **Rel-7 RAN improvements - UE Conformance Testing** | 784d? | 2006-09-20 A | 2009-09-18 A | 100% | 2006-09-20 | 2009-09-18 | 784d? |  |  | R5 | 25472h | 25472h | RANimp-UEConTest | Rel-7 | Ingbert |  |  |  |  |
| 1058 | 316.1 | Conformance Test Aspects - 3.84 Mcps and 7.68 Mcps TDD Enhanced Uplink | 518d? | 2006-09-20 A | 2008-09-12 A | 100% | 2006-09-20 | 2008-09-12 | 518d? | finish no earlier than 2008-09-12 |  | R5 | 4144h | 4144h | RANimp-UEConTest_EDCHTDH | Rel-7 | Ingbert | IPWireless | tspeight@ipwireless.com |  | RP-080536 |
| 1059 | 316.2 | Conformance Test Aspects – 64QAM for HSDPA (FDD) | 257d? | 2007-03-09 A | 2008-03-03 A | 100% | 2007-03-09 | 2008-03-03 | 257d? | finish no earlier than 2008-03-03 |  | R5 | 2056h | 2056h | RANimp-UEConTest_64QamDownlink | Rel-7 | Ingbert | Ericsson | leif.mattisson@ericsson.com |  | RP-080059 |
| 1060 | 316.3 | Conformance Test Aspects – 16QAM for HSUPA (FDD) | 321d? | 2007-03-09 A | 2008-05-30 A | 100% | 2007-03-09 | 2008-05-30 | 321d? | finish no earlier than 2008-05-30 |  | R5 | 2568h | 2568h | RANimp-UEConTest_16QamUplink | Rel-7 | Ingbert | Motorola | carolyn.taylor@motorola.com |  | RP-080281 |
| 1061 | 316.4 | Conformance Test Aspects – Improved L2 support for high data rates | 321d? | 2007-03-09 A | 2008-05-30 A | 100% | 2007-03-09 | 2008-05-30 | 321d? | finish no earlier than 2008-05-30 |  | R5 | 2568h | 2568h | RANimp-UEConTest_L2DataRates | Rel-7 | Ingbert | Ericsson | leif.mattisson@ericsson.com |  | RP-080256 |
| 1062 | 316.5 | Conformance Test Aspects – Continuous connectivity for packet data users | 321d? | 2007-03-09 A | 2008-05-30 A | 100% | 2007-03-09 | 2008-05-30 | 321d? | finish no earlier than 2008-05-30 |  | R5 | 2568h | 2568h | RANimp-UEConTest_CPC | Rel-7 | Ingbert | Nokia | jarkko.hellsten@nokia.com |  | RP-080282 |
| 1063 | 316.6 | Conformance Test Aspects – Enhanced CELL_FACH state in FDD | 662d? | 2007-03-09 A | 2009-09-18 A | 100% | 2007-03-09 | 2009-09-18 | 662d? | finish no earlier than 2009-09-18 |  | R5 | 5296h | 5296h | RANimp–UEConTest_EnhancedCellFACHState | Rel-7 | Ingbert | Nokia | jarkko.hellsten@nokia.com |  | RP-090711 |

Notes:
- 1034: 05/08: Linked to Feature UID_20028 (RInImp)
- 1035: - / Text3: 34.108, 34.121
- 1036: - / Text3: 34.108, 34.121
- 1037: - / Text3: 34.121, 34.108
- 1038: SR in RP-080535. RP#41 completed (GERAN aspects might need to be included later) / Text3: 34.114
- 1039: - / Text3: 34.108, 34.123-1, 34.123-2, 34.123-3
- 1040: - / Text3: 34.108, 34.121-1, 34.121-2
- 1041: -
- 1042: SR in RP-080056
- 1043: Generic feature
- 1044: Completed Dec 2006; SR in RP-060682
- 1045: Completed Sep 2006; SR in RP-060453 / Text3: 25.815, 25.321, 25.322, 25.331
- 1046: Closed Dec 2005; SR in RP-050667
- 1047: Completed Sep 2006; SR in RP-060477 / Text3: 25.102, 25.123
- 1048: Completed at Mar 2007; SR in RP-070033 / Text3: 25.903, 25.201, 25.211, 25.212, 25.214, 25.308, 25.321, 25.331, 25.423, 25.433, 25.101, 25.133
- 1049: Completed Dec 2006; SR in RP-060685 / Text3: 25.133, 25.423, 25.425, 25.433, 25.435, 25.453, 25.331
- 1050: Completed Dec 2006; SR in RP-060684 / Text3: 25.201, 25.202, 25.221, 25.222, 25.223, 25.224, 25.225, 25.331, 23.321, 25.306, 25.302, 25.401, 25.420, 25.423, 25.427, 25.433, 25.102, 25.105, 25.142
- 1051: Completed May 2007; SR in RP-070286 / Text3: 25.308, 25.304, 25.306, 25.321, 25.331, 25.433, 25.435, 25.423, 25.425,
- 1052: Completed May 2007; SR in RP-070287 / Text3: 25.308, 25.211, 25.212, 25.213, 25.306, 25.331, 25.433, 25.435, 25.423, 25.425, 25.101, 25.104, 25.141
- 1053: Completed May 2007; SR in RP-070289 / Text3: 25.301, 25.308,25.306, 25.321, 25.322, 25.331, 25.433, 25.435, 25.423, 25.425, 25.999
- 1054: Completed May 2007; SR in RP-070288 / Text3: 25.319, 25.101, 25.104, 25.133, 25.141, 25.211, 25.212, 25.213, 25.214, 25.306, 25.321, 25.331, 25.423, 25.433
- 1055: Completed Mar 2007; SR in RP-070140
- 1056: SP#36 Jun 2007 completed / Text3: 32.642/3/5 – Align with RAN 25.466
- 1057: 05/08: Linked to Feature UID_20029 (RANimp)
- 1058: SR in RP-080536. RP#41 completed / Text3: 34.108, 34.122, 34.123-1, 34.123-2, 34.123-3
- 1059: SR in RP-080059. RP#39 completed. / Text3: 34.108, 34.121-1, 34.121-2, 34.123-1, 34.123-2, 34.123-3
- 1060: SR in RP-080281. RP#40 completed / Text3: 34.108, 34.121-1, 34.121-2, 34.123-1, 34.123-2, 34.123-3
- 1061: SR in RP-080256. RP#40 completed / Text3: 34.108, 34.123-1, 34.123-2, 34.123-3
- 1062: SR in RP-080282. RP#40 completed / Text3: 34.108, 34.121-1, 34.121-2, 34.123-1, 34.123-2, 34.123-3
- 1063: RP#45 completed / Text3: 34.108, 34.123-1, 34.123-2, 34.123-3

| ID | WBS | Task | Type | Duration | Start | Finish | Complete | Baseline start | Baseline finish | Baseline duration | Constraint | Resources | Work | Actual work | Text1 | Text4 | Text5 | Text6 | Text8 | Text11 | Text12 |
| --- | --- | --- | --- | --- | --- | --- | --- | --- | --- | --- | --- | --- | --- | --- | --- | --- | --- | --- | --- | --- | --- |
| 1064 | 317 | **7.68 Mcps TDD option** |  | 457d? | 2004-09-15 A | 2006-06-15 A | 100% | 2004-09-15 | 2006-06-15 | 457d? |  | RP | 19824h | 19824h | VHCRTDD | IPwireless | Martin Beale (mbeale@ipwireless.com) | Rel-7 | Stefania | RP-060684 |  |
| 1065 | 317.1 | VHCRTDD: Stage 2 |  | 391d? | 2004-09-15 A | 2006-03-15 A | 100% | 2004-09-15 | 2006-03-15 | 391d? | finish no earlier than 2006-03-15 | R1 | 3128h | 3128h | VHCRTDD-Stage2 | IPwireless | Martin Beale (mbeale@ipwireless.com) | Rel-7 | Patrick |  |  |
| 1066 | 317.2 | VHCRTDD: Physical Layer |  | 391d? | 2004-09-15 A | 2006-03-15 A | 100% | 2004-09-15 | 2006-03-15 | 391d? | finish no earlier than 2006-03-15 | R1 | 3128h | 3128h | VHCRTDD-Phys | IPwireless | Martin Beale (mbeale@ipwireless.com) | Rel-7 | Patrick |  |  |
| 1067 | 317.3 | VHCRTDD: Layer 2 and layer 3 protocol aspects |  | 391d? | 2004-09-15 A | 2006-03-15 A | 100% | 2004-09-15 | 2006-03-15 | 391d? | finish no earlier than 2006-03-15 | R2 | 3128h | 3128h | VHCRTDD-L23 | IPwireless | drichards@ipwireless.com | Rel-7 | Joern |  |  |
| 1068 | 317.4 | VHCRTDD: UTRAN Iub/Iur Protocol Aspects |  | 391d? | 2004-09-15 A | 2006-03-15 A | 100% | 2004-09-15 | 2006-03-15 | 391d? | finish no earlier than 2006-03-15 | R3 | 3128h | 3128h | VHCRTDD-IurIub | IPwireless | Peter Legg (plegg@ipwireless.com) | Rel-7 | Juha |  |  |
| 1069 | 317.5 | VHCRTDD: RF Radio Transmission/ Reception, System Performance Requirements and Conformance Testing |  | 457d? | 2004-09-15 A | 2006-06-15 A | 100% | 2004-09-15 | 2006-06-15 | 457d? | finish no earlier than 2006-06-15 | R4 | 3656h | 3656h | VHCRTDD-RF | IPwireless | Shin Horng Wong (shwong@ipwireless.com) | Rel-7 | Stefania |  |  |
| 1070 | 318 | **3.84 Mcps TDD Enhanced Uplink** |  | 394d? | 2005-03-15 A | 2006-09-15 A | 100% | 2005-03-15 | 2006-09-15 | 394d? |  | RP | 18384h | 18384h | EDCHTDD | IPwireless | nanderson@ipwireless.com | Rel-7 | Stefania | RP-060684 |  |
| 1071 | 318.1 | EDCHTDD: Stage 2 |  | 328d? | 2005-03-15 A | 2006-06-15 A | 100% | 2005-03-15 | 2006-06-15 | 328d? | finish no earlier than 2006-06-15 | R2 | 2624h | 2624h | EDCHTDD-Stage2 | IPwireless | nanderson@ipwireless.com | Rel-7 | Joern |  |  |
| 1072 | 318.2 | EDCHTDD: Physical Layer |  | 394d? | 2005-03-15 A | 2006-09-15 A | 100% | 2005-03-15 | 2006-09-15 | 394d? | finish no earlier than 2006-09-15 | R1 | 3152h | 3152h | EDCHTDD-Phys | IPwireless | nanderson@ipwireless.com | Rel-7 | Patrick |  |  |
| 1073 | 318.3 | EDCHTDD: Layer 2 and 3 Protocol Aspects |  | 394d? | 2005-03-15 A | 2006-09-15 A | 100% | 2005-03-15 | 2006-09-15 | 394d? | finish no earlier than 2006-09-15 | R2 | 3152h | 3152h | EDCHTDD-L23 | IPwireless | drichards@ipwireless.com | Rel-7 | Joern |  |  |
| 1074 | 318.4 | EDCHTDD: UTRAN Iub/Iur Protocol Aspects |  | 394d? | 2005-03-15 A | 2006-09-15 A | 100% | 2005-03-15 | 2006-09-15 | 394d? | finish no earlier than 2006-09-15 | R3 | 3152h | 3152h | EDCHTDD-IurIub | Interdigital | jim.miller@interdigital.com | Rel-7 | Juha |  |  |
| 1075 | 318.5 | EDCHTDD: RF Radio Transmission/ Reception, System Performance Requirements and Conformance Testing |  | 394d? | 2005-03-15 A | 2006-09-15 A | 100% | 2005-03-15 | 2006-09-15 | 394d? | finish no earlier than 2006-09-15 | R4 | 3152h | 3152h | EDCHTDD-RF | IPwireless | Shin Horng Wong (shwong@ipwireless.com) | Rel-7 | Stefania |  |  |
| 1076 | 319 | **1.28 Mcps TDD Enhanced Uplink** |  | 328d? | 2006-03-15 A | 2007-06-15 A | 100% | 2006-03-15 | 2007-06-15 | 328d? |  | RP | 11536h | 11536h | LCRTDD-EDCH | CATT | Haijing Hu | Rel-7 | Stefania | RP-070296 |  |
| 1077 | 319.1 | 1.28 Mcps TDD Enhanced Uplink: Physical Layer |  | 262d? | 2006-03-15 A | 2007-03-15 A | 100% | 2006-03-15 | 2007-03-15 | 262d? | finish no earlier than 2007-03-15 | R1 | 2096h | 2096h | LCRTDD-EDCH-Phys | CATT | Ke Wang | Rel-7 | Patrick |  |  |
| 1078 | 319.2 | 1.28 Mcps TDD Enhanced Uplink: Layer 2 and 3 Protocol Aspects |  | 262d? | 2006-03-15 A | 2007-03-15 A | 100% | 2006-03-15 | 2007-03-15 | 262d? | finish no earlier than 2007-03-15 | R2 | 2096h | 2096h | LCRTDD-EDCH-L23 | CATT | Haiyang Quan | Rel-7 | Joern |  |  |
| 1079 | 319.3 | 1.28 Mcps TDD Enhanced Uplink: UTRAN Iub/Iur Protocol Aspects |  | 262d? | 2006-03-15 A | 2007-03-15 A | 100% | 2006-03-15 | 2007-03-15 | 262d? | finish no earlier than 2007-03-15 | R3 | 2096h | 2096h | LCRTDD-EDCH-IubIur | CATT | Yincheng Zhang | Rel-7 | Juha |  |  |
| 1080 | 319.4 | 1.28 Mcps TDD Enhanced Uplink: RF Radio Transmission/ Reception, System Performance Requirements and Conformance Testing |  | 328d? | 2006-03-15 A | 2007-06-15 A | 100% | 2006-03-15 | 2007-06-15 | 328d? | finish no earlier than 2007-06-15 | R4 | 2624h | 2624h | LCRTDD-EDCH-RF | CATT | Yuexia Song | Rel-7 | Stefania |  |  |
| 1081 | 320 | 1.28 Mcps TDD Enhanced Uplink - UE Conformance Testing |  | 257d? | 2007-09-20 A | 2008-09-12 A | 100% | 2007-09-20 | 2008-09-12 | 257d? | finish no earlier than 2008-09-11 | R5 | 624h | 624h | LCRTDD-EDCH-UEConTest | CATT | chenxiaozhong@datangmobile.cn | Rel-7 | Ingbert | RP-080539 |  |
| 1082 | 321 | MS Antenna Performance Evaluation Method and Requirements |  | 731d? | 2005-01-28 A | 2007-11-16 A | 100% | 2005-01-28 | 2007-11-16 | 731d? | finish no earlier than 2007-11-16 | GP | 5848h | 5848h | APEMR | TeliaSonera | Ulf.Tegth@teliasonera.com | Rel-7 | Paolo |  |  |
| 1083 | 322 | **Lower 700 MHz Inclusion in the GERAN Specifications** |  | 390d? | 2005-01-03 A | 2006-06-30 A | 100% | 2005-01-03 | 2006-06-30 | 390d? |  | GP | 7632h | 7632h | GSM710 | UTC | dcotton@mtview.union-tel.com | Rel-7 | Paolo |  |  |
| 1084 | 322.1 | Inclusion of the 698 – 746 MHz band into GERAN core specifications |  | 129d? | 2005-01-03 A | 2005-06-30 A | 100% | 2005-01-03 | 2005-06-30 | 129d? | finish no earlier than 2005-06-30 | G1 | 1032h | 1032h | GSM710-core |  |  | Rel-7 | Paolo |  |  |
| 1085 | 322.2 | G1 aspects of GSM710 |  | 217.5d? | 2005-08-31 A | 2006-06-30 A | 100% | 2005-08-31 | 2006-06-30 | 217.5d? | finish no earlier than 2006-06-30 | G1 | 1740h | 1740h | GSM-710-test |  |  | Rel-7 | Paolo |  |  |
| 1086 | 322.3 | G3 aspects of GSM710 |  | 217.5d? | 2005-08-31 A | 2006-06-30 A | 100% | 2005-08-31 | 2006-06-30 | 217.5d? | finish no earlier than 2006-06-30 | G3new | 1740h | 1740h | GSM-710-test |  |  | Rel-7 | Ingbert |  |  |
| 1087 | 323 | **Support of Conversational Services in A/Gb mode via the PS domain** |  | 626d? | 2005-04-08 A | 2007-08-31 A | 100% | 2005-04-08 | 2007-08-31 | 626d? |  | GP | 15442.8h | 15442.8h | SCSAGB | Ericsson | gunnar.hedby@ericsson.com | Rel-7 | Paolo |  |  |
| 1088 | 323.1 | Minimise the transfer delay between the SGSN and the MS |  | 604.95d? | 2005-04-08 A | 2007-08-31 A | 100% | 2005-04-08 | 2007-08-31 | 604.95d? | finish no earlier than 2007-08-31 | GP | 4839.6h | 4839.6h | SCSAGB-MTD | Ericsson | gunnar.hedby@ericsson.com | Rel-7 | Paolo |  |  |
| 1089 | 323.2 | Definition of radio resource management functionality |  | 626d? | 2005-04-08 A | 2007-08-31 A | 100% | 2005-04-08 | 2007-08-31 | 626d? | finish no earlier than 2007-08-31 | G1 | 5008h | 5008h | SCSAGB-RRM | Ericsson | gunnar.hedby@ericsson.com | Rel-7 | Paolo |  |  |
| 1090 | 323.3 | Support of Conversational Services in A/Gb mode via the PS domain – RLC Non-Persistent mode |  | 101d? | 2006-06-30 A | 2006-11-17 A | 100% | 2006-06-30 | 2006-11-17 | 101d? | finish no earlier than 2006-11-17 | G2 | 808h | 808h | SCSAGB-RLCNP | Ericsson | gunnar.hedby@ericsson.com | Rel-7 | Gert |  |  |
| 1091 | 323.4 | Deleted- Radio Channel Support | milestone | 0d? | 2006-07-17 A | 2006-07-17 A | 100% | 2006-07-17 | 2006-07-17 | 0d? | start no earlier than 2006-07-17 | G2 |  |  | SCSAGB-RCHS | Ericsson | gunnar.hedby@ericsson.com | Rel-7 | Gert |  | SP-32 |
| 1092 | 323.5 | Deleted- Modifications to FLO | milestone | 0d? | 2006-07-17 A | 2006-07-17 A | 100% | 2006-07-17 | 2006-07-17 | 0d? | start no earlier than 2006-07-17 | G2 |  |  | SCSAGB-FLO | Ericsson | gunnar.hedby@ericsson.com | Rel-7 | Gert |  | SP-32 |

Notes:
- 1064: Completed Dec 2006, SR in RP-060684
- 1065: Feature completed and closed at RP#33 with the presentation of the test WI / Text3: 25.202
- 1066: Feature completed and closed at RP#33 with the presentation of the test WI / Text3: 25.221, 25.222, 25.223, 25.224,25.225
- 1067: Feature completed and closed at RP#33 with the presentation of the test WI / Text3: 25.301, 25.302, 25.305, 25.306, 25.321, 25.331
- 1068: Feature completed and closed at RP#33 with the presentation of the test WI / Text3: 25.401, 25.420, 25.423, 25.425, 25.427, 25.430, 25.433, 25.435
- 1069: Feature completed and closed at RP#33 with the presentation of the test WI / Text3: 25.102, 25.105, 25.123, 25.133, 25.142
- 1070: Completed Dec 2006, SR in RP-060684
- 1071: -
- 1072: - / Text3: 25.201, 25.221,25.222, 25.223, 25.224, 25.225
- 1073: - / Text3: 25.301, 25.302, 25.306, 25.321, 25.331
- 1074: - / Text3: 25.401, 25.420, 25.423, 25.427, 25.430, 25.433, 25.435
- 1075: - / Text3: 25.102, 25.105, 25.123, 25.142
- 1076: Completed May 2007; SR in RP-070038 and RP-070296
- 1077: - / Text3: 25.201, 25.221, 25.222, 25.223, 25.224, 25.225
- 1078: - / Text3: 25.301, 25.302, 25.306, 25.321, 25.331
- 1079: - / Text3: 25.401, 25.420, 25.423, 25.425, 25.427, 25.430, 25.433, 25.435
- 1080: - / Text3: 25.102, 25.105, 25.123, 25.142
- 1081: UID_350046->350146. 05/08: Linked to Feature UID_20055 (LCRTDD-EDCH). SR in RP-080539. RP#41 completed / Text3: 34.108, 34.122, 34.123-1/2/3
- 1082: GP#36 completed for R7 / Text3: 25.914, 25.144, 45.005
- 1083: - / Text3: 24.008, 43.022, 44.018, 44.118, 45, 001, 45.005, 51.010, 51.021
- 1084: Completed / Text3: 24.008, 43.022, 44.018, 44.118, 45, 001, 45.005,
- 1085: - / Text3: 51.021
- 1086: - / Text3: 51.010
- 1087: Originally started Nov. 2003 as GP-030443
- 1088: -
- 1089: -
- 1090: - / Text3: 43.955, 43.064, 44.060, 45.001, 45.002, 45.003, 45.005, 45.010, 51.010, 51.021
- 1091: -
- 1092: -

| ID | WBS | Task | Duration | Start | Finish | Complete | Baseline start | Baseline finish | Baseline duration | Constraint | Resources | Work | Actual work | Text1 | Text4 | Text5 | Text6 | Text8 | Text12 |
| --- | --- | --- | --- | --- | --- | --- | --- | --- | --- | --- | --- | --- | --- | --- | --- | --- | --- | --- | --- |
| 1093 | 324 | **Addition of new frequency band to GSM (T-GSM810)** | 626d? | 2005-04-08 A | 2007-08-31 A | 100% | 2005-04-08 | 2007-08-31 | 626d? |  | GP | 12112h | 12112h | TGSM810 | Huawei | chende@huawei.com | Rel-7 | Paolo |  |
| 1094 | 324.1 | Changes to core specification | 106d? | 2005-04-08 A | 2005-09-02 A | 100% | 2005-04-08 | 2005-09-02 | 106d? | finish no earlier than 2005-09-02 | GP | 848h | 848h | TGSM810-Core | Huawei | chende@huawei.com | Rel-7 | Paolo |  |
| 1095 | 324.2 | Changes to MS testing specification | 626d? | 2005-04-08 A | 2007-08-31 A | 100% | 2005-04-08 | 2007-08-31 | 626d? | finish no earlier than 2007-08-31 | G3new | 5008h | 5008h | TGSM810-MStest | Huawei | chende@huawei.com | Rel-7 | Ingbert |  |
| 1096 | 324.3 | Changes to BTS testing specification | 156d? | 2005-04-08 A | 2005-11-11 A | 100% | 2005-04-08 | 2005-11-11 | 156d? | finish no earlier than 2005-11-11 | G1 | 1248h | 1248h | TGSM810-BTStest | Huawei | chende@huawei.com | Rel-7 | Paolo |  |
| 1097 | 325 | **Handover of dedicated and shared resources while in Dual Transfer Mode** | 421d? | 2005-04-08 A | 2006-11-17 A | 100% | 2005-04-08 | 2006-11-17 | 421d? |  | GP | 12672h | 12672h | HODSRDTM | Nokia | rami.vaittinen@nokia.com | Rel-7 | Paolo |  |
| 1098 | 325.1 | Handover of dedicated and shared resources while in Dual Transfer Mode | 321d? | 2005-04-08 A | 2006-06-30 A | 100% | 2005-04-08 | 2006-06-30 | 321d? | finish no earlier than 2006-06-30 | G2 | 2568h | 2568h | HODSRDTM-G2 | Nokia | rami.vaittinen@nokia.com | Rel-7 | Gert |  |
| 1099 | 325.2 | Deleted - MS Conformance Testing | 421d? | 2005-04-08 A | 2006-11-17 A | 100% | 2005-04-08 | 2006-11-17 | 421d? | finish no earlier than 2006-11-17 | G3new | 3368h | 3368h | HODSRDTM-Mstest | Nokia | rami.vaittinen@nokia.com | Rel-7 | Ingbert | GP-32 |
| 1100 | 325.3 | Deleted - BTS conformance testing | 421d? | 2005-04-08 A | 2006-11-17 A | 100% | 2005-04-08 | 2006-11-17 | 421d? | finish no earlier than 2006-11-17 | G1 | 3368h | 3368h | HODSRDTM-BTStest | Nokia | rami.vaittinen@nokia.com | Rel-7 | Paolo | GP-32 |
| 1101 | 326 | **Mobile Station Receive Diversity (DARP Phase II)** | 526d? | 2005-11-11 A | 2007-11-16 A | 100% | 2005-11-11 | 2007-11-16 | 526d? |  | GP | 16360h | 16360h | MSRD2 | Nokia | kent.pedersen@nokia.com | Rel-7 | Paolo |  |
| 1102 | 326.1 | Performance Requirements for Mobile Station Receive Diversity, DARP Phase II | 331d? | 2005-11-11 A | 2007-02-16 A | 100% | 2005-11-11 | 2007-02-16 | 331d? | finish no earlier than 2007-02-16 | GP | 2648h | 2648h | MSRD2-PerfReq | Nokia | kent.pedersen@nokia.com | Rel-7 | Paolo |  |
| 1103 | 326.2 | Capability signalling of Mobile Station Receive Diversity, DARP Phase II | 331d? | 2005-11-11 A | 2007-02-16 A | 100% | 2005-11-11 | 2007-02-16 | 331d? | finish no earlier than 2007-02-16 | GP | 2648h | 2648h | MSRD2-CapSig | Nokia | kent.pedersen@nokia.com | Rel-7 | Paolo |  |
| 1104 | 326.3 | Test Scenarios for Mobile Station Receive Diversity, DARP Phase II | 331d? | 2005-11-11 A | 2007-02-16 A | 100% | 2005-11-11 | 2007-02-16 | 331d? | finish no earlier than 2007-02-16 | GP | 2648h | 2648h | MSRD2-TestSc | Nokia | kent.pedersen@nokia.com | Rel-7 | Paolo |  |
| 1105 | 326.4 | MS conformance test of DARP Phase II (MSRD) | 526d? | 2005-11-11 A | 2007-11-16 A | 100% | 2005-11-11 | 2007-11-16 | 526d? | finish no earlier than 2007-11-16 | GP | 4208h | 4208h | MSRD2-Msconf | Nokia | kent.pedersen@nokia.com | Rel-7 | Ingbert |  |
| 1106 | 327 | **Downlink Dual Carrier** | 421d? | 2006-01-20 A | 2007-08-31 A | 100% | 2006-01-20 | 2007-08-31 | 421d? |  | GP | 7664h | 7664h | GDCDL | Nokia Siemens Networks | leonardo.provvedi@roke.co.uk | Rel-7 | Paolo |  |
| 1107 | 327.1 | Downlink Dual Carrier Stage 2 | 116d? | 2006-01-20 A | 2006-06-30 A | 100% | 2006-01-20 | 2006-06-30 | 116d? | finish no earlier than 2006-06-30 | G1 | 928h | 928h | GDCDL-Stage2 | Nokia Siemens Networks | leonardo.provvedi@roke.co.uk | Rel-7 | Paolo |  |
| 1108 | 327.2 | Downlink Dual Carrier Stage 3 | 421d? | 2006-01-20 A | 2007-08-31 A | 100% | 2006-01-20 | 2007-08-31 | 421d? | finish no earlier than 2007-08-31 | G1 | 3368h | 3368h | GDCDL-Stage2 | Nokia Siemens Networks | leonardo.provvedi@roke.co.uk | Rel-7 | Paolo |  |
| 1109 | 328 | **Downlink Dual Carrier – MS Conformance Test** | 947d? | 2006-01-20 A | 2009-09-04 A | 100% | 2006-01-20 | 2009-09-04 | 947d? |  | G3new | 11150.6h | 11150.6h | GDCDL-Stage3 | Nokia Siemens Networks | leonardo.provvedi@roke.co.uk | Rel-7 | Ingbert |  |
| 1110 | 328.1 | Downlink Dual Carrier – MS Conformance Test | 446.82d? | 2006-01-20 A | 2009-09-04 A | 100% | 2006-01-20 | 2009-09-04 | 446.82d? | finish no earlier than 2009-09-04 | G3new | 3574.6h | 3574.6h | GDCDL-Stage3 | Nokia Siemens Networks | leonardo.provvedi@roke.co.uk | Rel-7 | Ingbert |  |
| 1111 | 329 | Support of SIGTRAN in GERAN | 116d? | 2006-01-20 A | 2006-06-30 A | 100% | 2006-01-20 | 2006-06-30 | 116d? | finish no earlier than 2006-06-30 | G3new | 928h | 928h | GDCDL-MStest | Ericsson | peter.ostrup@ericsson.com | Rel-7 | Ingbert |  |
| 1112 | 330 | **Latency Reductions** | 306d? | 2006-06-30 A | 2007-08-31 A | 100% | 2006-06-30 | 2007-08-31 | 306d? |  | GP | 7344h | 7344h | LATRED | Ericsson | Hakan.Persson@Ericsson.com | Rel-7 | Paolo |  |
| 1113 | 330.1 | Improved Ack/Nack reporting | 306d? | 2006-06-30 A | 2007-08-31 A | 100% | 2006-06-30 | 2007-08-31 | 306d? | finish no earlier than 2007-08-31 | G2 | 2448h | 2448h | LATRED-ACKNAR | Ericsson | Hakan.Persson@Ericsson.com | Rel-7 | Gert |  |
| 1114 | 330.2 | Reduced TTI | 306d? | 2006-06-30 A | 2007-08-31 A | 100% | 2006-06-30 | 2007-08-31 | 306d? | finish no earlier than 2007-08-31 | G2 | 2448h | 2448h | LATRED-REDTTI | Ericsson | Hakan.Persson@Ericsson.com | Rel-7 | Gert |  |
| 1115 | 331 | PS Handover between GERAN/UTRAN mode and GAN Mode | 166d? | 2006-06-30 A | 2007-02-16 A | 100% | 2006-06-30 | 2007-02-16 | 166d? | finish no earlier than 2007-02-16 | G2 | 1328h | 1328h | GUGAN | Ericsson | John.Diachina@Ericsson.com | Rel-7 | Gert |  |
| 1116 | 332 | **Higher Uplink performance for GERAN Evolution** | 516d? | 2006-09-08 A | 2008-08-29 A | 100% | 2006-09-08 | 2008-08-29 | 516d? |  | GP | 15440h | 15440h | HUGE | Nokia Siemens Networks, Ericsson | eddie.riddington@nokia.com, stefan.g.eriksson@ericsson.com | Rel-7 | Paolo |  |
| 1117 | 332.1 | Stage 2 of HUGE | 261d? | 2006-09-08 A | 2007-09-07 A | 100% | 2006-09-08 | 2007-09-07 | 261d? | finish no earlier than 2007-09-07 | G1 | 2088h | 2088h | HUGE-Stage2 | Nokia Siemens Networks, Ericsson | eddie.riddington@nokia.com, stefan.g.eriksson@ericsson.com | Rel-7 | Paolo |  |
| 1118 | 332.2 | Layer 1 Support of HUGE | 381d? | 2006-09-08 A | 2008-02-22 A | 100% | 2006-09-08 | 2008-02-22 | 381d? | finish no earlier than 2008-02-22 | G1 | 3048h | 3048h | HUGE-Layer1 | Nokia Siemens Networks, Ericsson | eddie.riddington@nokia.com, stefan.g.eriksson@ericsson.com | Rel-7 | Paolo |  |
| 1119 | 332.3 | Layer 2/3 Support of HUGE | 256d? | 2006-09-08 A | 2007-08-31 A | 100% | 2006-09-08 | 2007-08-31 | 256d? | finish no earlier than 2007-08-31 | G2 | 2048h | 2048h | HUGE-Layer23 | Nokia Siemens Networks, Ericsson | eddie.riddington@nokia.com, stefan.g.eriksson@ericsson.com | Rel-7 | Gert |  |
| 1120 | 332.4 | Performance requirements | 516d? | 2006-09-08 A | 2008-08-29 A | 100% | 2006-09-08 | 2008-08-29 | 516d? | finish no earlier than 2008-08-29 | G1 | 4128h | 4128h | HUGE-Perfreq | Nokia Siemens Networks, Ericsson | eddie.riddington@nokia.com, stefan.g.eriksson@ericsson.com | Rel-7 | Paolo |  |

Notes:
- 1093: - / Text3: 45.005, 45.050, 24.008, 45.008, 45.001, 43.022, 43.030, 44.018, 44.060, 51.010-1, 51.021
- 1094: - / Text3: 45.005, 45.050, 24.008, 45.008, 45.001, 43.022, 43.030, 44.018, 44.060
- 1095: - / Text3: 51010-1
- 1096: - / Text3: 51021
- 1097: GP#30 completed. Started at GP#24
- 1098: GP#30 completed / Text3: 43.055, 44.018, 44.060
- 1099: Stopped, no work done. 12/2008 Marked as stopped ("deleted") / Text3: 51-010
- 1100: Stopped, no work done. 12/2008 Marked as stopped ("deleted") / Text3: 51.026
- 1101: GP#36 completed / Text3: 24.008, 45.005, 51.010
- 1102: GP#33 completed / Text3: 45.005
- 1103: GP#33 completed / Text3: 24.008
- 1104: GP#33 completed / Text3: 45.005
- 1105: GP#36 completed / Text3: 51.010
- 1106: GP#35 completed
- 1107: GP#30 completed / Text3: 43.055, 43.064
- 1108: GP#35 completed / Text3: 24.008, 44.018, 44.060, 45.001, 45.002, 45.005, 45.008
- 1109: GP#43 completed / Text3: 51.010
- 1110: GP#43 completed / Text3: 51.010
- 1111: GP#30 completed / Text3: 48.001, 48.006, 43.059, 49.031
- 1112: GP#35 completed / Text3: 45.001, 45.002, 45.003, 45.005, 45.010, 43.055, 43.064, 44.060, 51.010-1, 51.021
- 1113: GP#35 completed / Text3: 45.001, 45.002, 45.003, 45.005, 45.010, 43.055, 43.064, 44.060, 51.010-1, 51.021
- 1114: GP#35 completed / Text3: 45.001, 45.002, 45.003, 45.005, 45.010, 43.055, 43.064, 44.060, 51.010-1, 51.021
- 1115: GP#33 completed / Text3: 43.318, 44.318, 43.129, 25.306, 24.008, 44.060, 25.331, 51.010
- 1116: GP#39 completed. SP#42 split core from testing specification work.
- 1117: GP#35 completed / Text3: 43.055, 43.064
- 1118: GP#37 completed / Text3: 45.001, 45.002, 45.003, 45.004, 45.008
- 1119: GP#35 completed / Text3: 24.008, 44.018, 44.060
- 1120: GP#39 completed / Text3: 45.005

| ID | WBS | Task | Type | Duration | Start | Finish | Complete | Remaining | Baseline start | Baseline finish | Baseline duration | Total slack | Constraint | Resources | Work | Actual work | Text1 | Text4 | Text5 | Text6 | Text8 | Text12 |
| --- | --- | --- | --- | --- | --- | --- | --- | --- | --- | --- | --- | --- | --- | --- | --- | --- | --- | --- | --- | --- | --- | --- |
| 1121 | 333 | **HUGE Conformance Testing** |  | 902d? | 2006-09-08 A | 2010-02-19 | 50% | 449.09d? | 2006-09-08 | 2010-02-19 | 902d? | 671d |  | G1,G3new | 20672h | 7112.96h | HUGE | Nokia Siemens Networks, Ericsson | eddie.riddington@nokia.com, stefan.g.eriksson@ericsson.com | Rel-7 | Paolo |  |
| 1122 | 333.1 | HUGE - MS Conformance Test |  | 901d? | 2006-09-08 A | 2010-02-19 | 7% | 837.93d? | 2006-09-08 | 2010-02-19 | 901d? | 671d | finish no earlier than 2010-02-19 | G3new | 7208h | 504.56h | HUGE-Mstest | Nokia Siemens Networks, Ericsson | eddie.riddington@nokia.com, stefan.g.eriksson@ericsson.com | Rel-7 | Ingbert |  |
| 1123 | 333.2 | HUGE - BTS Conformance Test |  | 782d? | 2006-09-08 A | 2009-09-04 A | 100% |  | 2006-09-08 | 2009-09-04 | 782d? |  | finish no earlier than 2009-09-04 | G1 | 6248h | 6248h | HUGE-BTStest | Nokia Siemens Networks, Ericsson | eddie.riddington@nokia.com, stefan.g.eriksson@ericsson.com | Rel-7 | Paolo |  |
| 1124 | 334 | **REduced symbol Duration, Higher Order modulation and Turbo coding (RED HOT) for downlink** |  | 391d? | 2006-11-17 A | 2008-05-16 A | 100% |  | 2006-11-17 | 2008-05-16 | 391d? |  |  | GP | 7904h | 7904h | REDHOT | Ericsson, Nokia Siemens Networks, Marvell | stefan.g.eriksson@ericsson.com | Rel-7 | Paolo |  |
| 1125 | 334.1 | Stage 2 for REDHOT |  | 206d? | 2006-11-17 A | 2007-08-31 A | 100% |  | 2006-11-17 | 2007-08-31 | 206d? |  | finish no earlier than 2007-08-31 | G1 | 1648h | 1648h | REDHOT-Stage2 | Ericsson, Nokia Siemens Networks, Marvell | stefan.g.eriksson@ericsson.com | Rel-7 | Paolo |  |
| 1126 | 334.2 | Stage 3 for REDHOT |  | 391d? | 2006-11-17 A | 2008-05-16 A | 100% |  | 2006-11-17 | 2008-05-16 | 391d? |  | finish no earlier than 2008-05-16 | G1 | 3128h | 3128h | REDHOT-Stage3 | Ericsson, Nokia Siemens Networks, Marvell | stefan.g.eriksson@ericsson.com | Rel-7 | Paolo |  |
| 1127 | 335 | **REDHOT Conformance Testing** |  | 852d? | 2006-11-17 A | 2010-02-19 | 47% | 448.93d? | 2006-11-17 | 2010-02-19 | 852d? | 671d |  | G1,G3new | 18832h | 6024.96h | REDHOT | Ericsson, Nokia Siemens Networks, Marvell | stefan.g.eriksson@ericsson.com | Rel-7 | Paolo |  |
| 1128 | 335.1 | REDHOT - MS Conformance Tests |  | 851d? | 2006-11-17 A | 2010-02-19 | 7% | 791.43d? | 2006-11-17 | 2010-02-19 | 851d? | 671d | finish no earlier than 2010-02-19 | G3new | 6808h | 476.56h | REDHOT-Mstest | Ericsson | stefan.g.eriksson@ericsson.com | Rel-7 | Ingbert |  |
| 1129 | 335.2 | BTS Conformance Tests |  | 651d? | 2006-11-17 A | 2009-05-15 A | 100% |  | 2006-11-17 | 2009-05-15 | 651d? |  | finish no earlier than 2009-05-15 | G1 | 5208h | 5208h | REDHOT-BTStest | Ericsson, Nokia Siemens Networks, Marvell | stefan.g.eriksson@ericsson.com | Rel-7 | Paolo |  |
| 1130 | 336 | (Small) Technical Enhancements and Improvements for Rel-7 | milestone | 0d? | 2007-03-26 A | 2007-03-26 A | 100% |  | 2007-03-26 | 2007-03-26 | 0d? |  | start no earlier than 2007-03-26 | All |  |  | TEI7 |  |  | Rel-7 |  |  |
| 1131 | 337 | **Deleted - PS domain and IMS support for IMS Emergency sessions** |  | 63.69d? | 2006-06-23 A | 2006-09-21 A | 100% |  | 2006-06-23 | 2006-09-21 | 63.69d? |  |  | S2 |  |  | IMS-EMER | Nokia | curt.c.wong@nokia.com | Rel-7 | Maurice | SP-30 |
| 1132 | 337.1 | Deleted - IMS aspects to support IMS Emergency sessions | milestone | 0d? | 2006-06-23 A | 2006-09-21 A | 100% |  | 2006-06-23 | 2006-09-21 | 0d? |  | start no earlier than 2006-06-23 | S2 |  |  | IMS-EMER | Nokia | curt.c.wong@nokia.com | Rel-7 | Maurice | SP-30 |
| 1133 | 337.2 | Deleted - PS domain aspects to support IMS Emergency sessions | milestone | 0d? | 2006-06-23 A | 2006-09-21 A | 100% |  | 2006-06-23 | 2006-09-21 | 0d? |  | start no earlier than 2006-06-23 | S2 |  |  | IMS-EMER | Nokia | curt.c.wong@nokia.com | Rel-7 | Maurice | SP-30 |
| 1134 | 338 | Deleted - Covered by SI - Personal Network (PN) and Personal Area Network (PAN) | milestone | 0d? | 2005-12-08 A | 2005-12-20 A | 100% |  | 2005-12-08 | 2005-12-20 | 0d? |  | start no earlier than 2005-12-08 | S1 |  |  | PNPAN | Vodafone | armin.toepfer@vodafone.com | Rel-7 | Alain | SP-30 |
| 1135 | 339 | Deleted - Covered by SI - Multimedia Telephony Capabilities for IMS | milestone | 0d? | 2005-12-08 A | 2005-12-20 A | 100% |  | 2005-12-08 | 2005-12-20 | 0d? |  | start no earlier than 2005-12-08 | S1 |  |  | MITE | Ericsson | peter.bleckert@ericsson.com | Rel-7 | Alain | SP-30 |
| 1136 | 340 | Deleted - Covered by SI - Transferring of emergency Call data | milestone | 0d? | 2005-12-08 A | 2005-12-08 A | 100% |  | 2005-12-08 | 2005-12-08 | 0d? |  | start no earlier than 2005-12-08 | S1 |  |  | eCALL | Motorola | steven.vardy@motorola.com | Rel-7 | Alain | SP-30 |
| 1137 | 341 | Deleted - Covered by SI - MBMS Enhancements | milestone | 0d? | 2005-12-08 A | 2005-12-08 A | 100% |  | 2005-12-08 | 2005-12-08 | 0d? |  | start no earlier than 2005-12-08 | S1 |  |  | MBMSE | China Mobile | liuhongyfw@chinamobile.com | Rel-7 | Alain | SP-30 |
| 1138 | 342 | **Deleted - VoIMS bearer related enhancements** |  | 0d? | 2006-07-21 A | 2006-07-21 A | 100% |  | 2006-07-21 | 2006-07-21 | 0d? |  |  | S2 |  |  | VoIMS |  |  | Rel-7 | Maurice | SP-32 |
| 1139 | 342.1 | Deleted - FS on enhancement of radio performance for VoIMS | milestone | 0d? | 2006-07-21 A | 2006-07-21 A | 100% |  | 2006-07-21 | 2006-07-21 | 0d? |  | start no earlier than 2006-07-21 | S2 |  |  | VoIMS | Nortel | Laurence Lautier (lautierl@nortel.com) | Rel-7 | Maurice | SP-32 |
| 1140 | 343 | Release 7 Studies |  | 1d? | 2000-01-03 | 2000-01-03 |  |  | 2000-01-03 | 2000-01-03 | 1d? | 3317d |  | CP,GP,RP,SP | 8h |  |  |  |  | Rel-7 |  |  |
| 1141 | 344 | **Study on Multimedia Telephony Capabilities for IMS** |  | 276d? | 2005-07-11 A | 2006-07-31 A | 100% |  | 2005-07-11 | 2006-07-31 | 276d? |  |  | S1 | 4353.6h | 4353.6h | MITE | Ericsson | peter.bleckert@ericsson.com | Rel-7 | Alain |  |
| 1142 | 344.1 | Deleted covered by UID_31082 - Study of (MITe) - IMS Multimedia Telephony Communication Enabler and supplementary services |  | 276d? | 2005-07-11 A | 2006-07-31 A | 100% |  | 2005-07-11 | 2006-07-31 | 276d? |  | start no earlier than 2005-07-11 | S1 | 2208h | 2208h | MITE | Ericsson | peter.bleckert@ericsson.com | Rel-7 | Alain | SP-28 |
| 1143 | 345 | Study on Behaviour of Multi system UEs |  | 384d? | 2004-06-28 A | 2005-12-15 A | 100% |  | 2004-06-28 | 2005-12-15 | 384d? |  | start no earlier than 2004-06-28 | S1 | 3072h | 3072h | BMSU | Qualcomm Europe | dwilliams@qualcomm.com | Rel-7 | Alain |  |
| 1144 | 346 | Study on Combining CS calls and IMS sessions |  | 189d? | 2004-06-28 A | 2005-03-17 A | 100% |  | 2004-06-28 | 2005-03-17 | 189d? |  | start no earlier than 2004-06-28 | S1 | 1512h | 1512h | IRTSD-CS_IMS |  | Robert Frank | Rel-7 | Alain |  |
| 1145 | 347 | Study on All-IP Network |  | 188d? | 2004-06-28 A | 2005-03-16 A | 100% |  | 2004-06-28 | 2005-03-16 | 188d? |  | start no earlier than 2004-06-28 | S1 | 1504h | 1504h | FS_AIPN | NTT DoCoMo | c.masyu@nttdocomo.co.jp | Rel-7 | Alain |  |
| 1146 | 348 | Study on Videotelephony teleservice |  | 231d? | 2005-03-01 A | 2006-01-17 A | 100% |  | 2005-03-01 | 2006-01-17 | 231d? |  |  | S1 | 1848h | 1848h | VidTel | T-Mobile | kurt.bischinger@t-mobile.at | Rel-7 | Alain |  |
| 1147 | 349 | Study on Network Selection Principles |  | 193d? | 2005-03-15 A | 2005-12-08 A | 100% |  | 2005-03-15 | 2005-12-08 | 193d? |  |  | S1 | 1544h | 1544h | NetSel | O2 | chris.friel@o2.com | Rel-7 | Alain |  |
| 1148 | 350 | Study on Multimedia Priority Service |  | 851d? | 2003-03-28 A | 2006-06-30 A | 100% |  | 2003-03-28 | 2006-06-30 | 851d? |  | finish no earlier than 2005-12-16 | S1 | 6808h | 6808h | PRIOR-MM | Telcordia | jgarraha@telcordia.com | Rel-7 | Alain |  |
| 1149 | 351 | Study on Transferring of emergency Call data |  | 190d? | 2005-07-11 A | 2006-03-31 A | 100% |  | 2005-07-11 | 2006-03-31 | 190d? |  | finish no earlier than 2005-12-08 | S1 | 1520h | 1520h | eCALL | Motorola | steven.vardy@motorola.com | Rel-7 | Alain |  |
| 1150 | 352 | Study on Enhancement of E2E QoS |  | 281.4d? | 2004-06-28 A | 2005-09-15 A | 100% |  | 2004-06-28 | 2005-09-15 | 281.4d? |  | finish no earlier than 2005-12-01 | S2 | 2251.2h | 2251.2h | QoS7 | Huawei | Robert Jaksa | Rel-7 | Maurice |  |
| 1151 | 353 | Study on Bandwidth Saving at Nb Interface with IP transport |  | 261d? | 2006-03-10 A | 2007-03-09 A | 100% |  | 2006-03-10 | 2007-03-09 | 261d? |  | finish no earlier than 2007-03-09 | C3 | 2088h | 2088h | BSNbIP | Siemens | Thomas.Belling@nsn.com | Rel-7 | Gwiho |  |
| 1152 | 354 | Study on Routeing of MT-SMS via the HPLMN |  | 301d? | 2005-10-07 A | 2006-12-01 A | 100% |  | 2005-10-07 | 2006-12-01 | 301d? |  | finish no earlier than 2006-12-01 | C4 | 2408h | 2408h | SMS7 | Vodafone | Nick.Russell@vodafone.com | Rel-7 | Kimmo |  |
| 1153 | 355 | Study on the TCAPsec Gateway concept |  | 96d? | 2005-10-28 A | 2006-03-10 A | 100% |  | 2005-10-28 | 2006-03-10 | 96d? |  | finish no earlier than 2006-03-10 | C4 | 768h | 768h | SEC7-TCAP | Siemens | Ulrich.wiehe@gksag.de | Rel-7 | Kimmo |  |
| 1154 | 356 | Study on using M2PA in 3GPP network |  | 318d? | 2006-03-22 A | 2007-06-08 A | 100% |  | 2006-03-22 | 2007-06-08 | 318d? |  | finish no earlier than 2007-06-08 | C4 | 2544h | 2544h | FS-M2PA | China Mobile | zhaoyuyi@chinamobile.com | Rel-7 | Kimmo |  |

Notes:
- 1121: GP#40 Target completion 05/08=>11/08=>02/09. SP#42 split core from testing specification work.
- 1122: GP#41 target 02/09=>02/10 / Text3: 51.010
- 1123: GP#43 completed / Text3: 51.021
- 1124: GP#38 completed. SP#42 split core from testing specification work.
- 1125: GP#35 completed / Text3: 43.055, 43.064
- 1126: GP#38 completed / Text3: 24.008, 44.018, 44.060, 45.001, 45.002, 45.003, 45.004, 45.005, 45.008
- 1127: GP#40 completion target 05/08=>11/08=>02/09. SP#42 split core from testing specification work.
- 1128: GP#41 completion 02/09=>02/10 / Text3: 51.010
- 1129: GP#42 completed / Text3: 51.021
- 1130: - / Text3: CP-070260
- 1131: Approved at SP#29 / Text3: 23.867, 23.abc, 23.060, 23.002, 23.271
- 1132: Approved at SP#29 / Text3: 23.867, 23.abc, 23.060, 23.002, 23.271
- 1133: Approved at SP#29 / Text3: 23.867, 23.abc, 23.060, 23.002, 23.271
- 1134: -
- 1135: -
- 1136: -
- 1137: -
- 1138: Created by MCC to group all VoIMS related items, after consultation of chairs
- 1139: WID approved SP#28: SA2#52: CLOSED - To be removed from the work plan / Text3: 23.807
- 1140: -
- 1141: Spin-off Feature UID_7038 (MTSI) / Text3: 22.973
- 1142: Duplicate entry with 31082 / Text3: 22.973
- 1143: - / Text3: 22.936
- 1144: - / Text3: 22.979
- 1145: 25/07/08 Moved as FS to Rel-7 out of the stopped Rel-8 Feature UID_31067 Deleted - All-IP Network (AIPN) / Text3: 22.978
- 1146: - / Text3: 22.903
- 1147: Spin-off Feature Network selection enhancements (NSP-CR) UID_7041 / Text3: 22.811
- 1148: Spin-off Feature PRIOR UID_340044 / Text3: 22.953
- 1149: - / Text3: 22.967
- 1150: - / Text3: 23.802
- 1151: Moved to FS at CT32 (in line with slides) / Text3: 29.814
- 1152: Previously known as "Study of a SMS Centre for MT SMS" / Text3: 23.840
- 1153: TR 29.800 content moved to TS 29.204 under implementation WI UID_310005 TCAPsec Gateway / Text3: 29.800
- 1154: - / Text3: 29.801

| ID | WBS | Task | Type | Duration | Start | Finish | Complete | Baseline start | Baseline finish | Baseline duration | Total slack | Constraint | Resources | Work | Actual work | Text1 | Text3 | Text4 | Text5 | Text6 | Text8 | Text11 | Text12 |
| --- | --- | --- | --- | --- | --- | --- | --- | --- | --- | --- | --- | --- | --- | --- | --- | --- | --- | --- | --- | --- | --- | --- | --- |
| 1155 | 357 | **Study on Support of (G)MSC-S - (G)MSC-S Nc Interface based on the SIP-I protocol** |  | 350d? | 2006-05-15 A | 2007-09-14 A | 100% | 2006-05-15 | 2007-09-14 | 350d? |  |  | C4 | 7800h | 7800h | NcSIP | 29.802 | Vodafone | david.hutton@vodafone.com | Rel-7 | Kimmo |  |  |
| 1156 | 357.1 | CT4 aspects of NcSIP |  | 275d? | 2006-05-15 A | 2007-06-01 A | 100% | 2006-05-15 | 2007-06-01 | 275d? |  | finish no earlier than 2007-06-01 | C4 | 2200h | 2200h | NcSIP | 29.802 | Vodafone | david.hutton@vodafone.com | Rel-7 | Kimmo |  |  |
| 1157 | 357.2 | CT3 aspects of NcSIP |  | 350d? | 2006-05-15 A | 2007-09-14 A | 100% | 2006-05-15 | 2007-09-14 | 350d? |  | finish no earlier than 2007-09-14 | C3 | 2800h | 2800h | NcSIP | 29.802 | Ericsson | ragnar.huslende@ericsson.com | Rel-7 | Gwiho |  |  |
| 1158 | 358 | Study on SOAP/HTTP IRP Solution Sets |  | 330d? | 2005-09-02 A | 2006-12-07 A | 100% | 2005-09-02 | 2006-12-07 | 330d? |  | finish no earlier than 2006-12-07 | S5 | 2640h | 2640h | OAM7-NIM-XML | 32.809 | Nortel |  | Rel-7 | Dionisio |  |  |
| 1159 | 359 | Study on Itf-N Implementation Conformance Statement (ICS) template |  | 400d? | 2005-09-02 A | 2007-03-15 A | 100% | 2005-09-02 | 2007-03-15 | 400d? |  | finish no earlier than 2007-03-15 | S5 | 3200h | 3200h | OAM7-NIM-ICS | 32.812 | China Mobile |  | Rel-7 | Dionisio |  |  |
| 1160 | 360 | Study on IRP Information Model |  | 400d? | 2005-09-02 A | 2007-03-15 A | 100% | 2005-09-02 | 2007-03-15 | 400d? |  | finish no earlier than 2007-03-15 | S5 | 3200h | 3200h | OAM7-NIM-IM | 32.810 | Motorola |  | Rel-7 | Dionisio |  |  |
| 1161 | 361 | Study on Evolved UTRA and UTRAN |  | 458d? | 2004-12-15 A | 2006-09-15 A | 100% | 2004-12-15 | 2006-09-15 | 458d? |  | finish no earlier than 2006-09-15 | RP | 3664h | 3664h | RANFS-Evo | 25.912 | NTT DoCoMo | nakamurata@NTTDOCOMO.CO.JP | Rel-7 | Stefania | RP-060472 |  |
| 1162 | 362 | Study on Performance Evaluation of the UE behaviour in high speed trains with speeds up to 350 kmph |  | 328d? | 2005-03-15 A | 2006-06-15 A | 100% | 2005-03-15 | 2006-06-15 | 328d? |  | finish no earlier than 2006-06-15 | R4 | 2624h | 2624h | RANFS-HSTrains | none | Vodafone | Mike.vogel@vodafone.com,tim.frost@vodafone.com | Rel-7 | Stefania | RP-060412 |  |
| 1163 | 363 | Study on UTRA Tower Mounted Amplifier (FDD) |  | 195d? | 2005-06-15 A | 2006-03-14 A | 100% | 2005-06-15 | 2006-03-14 | 195d? |  | finish no earlier than 2006-03-15 | R4 | 1560h | 1560h | RANFS-TMA | 25.818 | Ericsson | Klas.Sjerling@ericsson.com | Rel-7 | Stefania | RP-060035 |  |
| 1164 | 364 | Study on Continuous connectivity for packet data users |  | 132d? | 2005-03-15 A | 2005-09-14 A | 100% | 2005-03-15 | 2005-09-14 | 132d? |  | finish no earlier than 2005-09-15 | R1 | 1056h | 1056h | RANFS-cont-packet | none | Siemens | joerg.gustrau@siemens.com | Rel-7 | Patrick | RP-050427 |  |
| 1165 | 365 | Study on Improvement of the Multimedia Broadcast Multicast Service (MBMS) in UTRAN |  | 262d? | 2005-12-15 A | 2006-12-15 A | 100% | 2005-12-15 | 2006-12-15 | 262d? |  | finish no earlier than 2006-12-15 | R2 | 2096h | 2096h | RANFS-MBMSImp | 25.905 | LG Electronics | leego@lge.com | Rel-7 | Joern | RP-060692 |  |
| 1166 | 366 | Study on Performance Improvements in Small Cells using HSDPA/EDCH |  | 131d? | 2005-12-15 A | 2006-06-15 A | 100% | 2005-12-15 | 2006-06-15 | 131d? |  | finish no earlier than 2006-06-15 | R4 | 1048h | 1048h | SMALLCELLS | none | Cingular | Marc Grant | Rel-7 | Stefania | RP-060263 |  |
| 1167 | 367 | Study on Further Improved Performance Requirements for UMTS/HSDPA UE (FDD) |  | 383d? | 2005-12-15 A | 2007-06-04 A | 100% | 2005-12-15 | 2007-06-04 | 383d? |  | finish no earlier than 2007-06-04 | R4 | 3064h | 3064h | RANFS-IC | 25.963 | Cingular | Marc Grant | Rel-7 | Stefania | RP-070499 |  |
| 1168 | 368 | Study on Scope of future FDD HSPA Evolution |  | 394d? | 2006-03-15 A | 2007-09-17 A | 100% | 2006-03-15 | 2007-09-17 | 394d? |  | finish no earlier than 2007-09-17 | RP | 3152h | 3152h | RANFS-HSPAEvo | 25.999 | Cingular | Don Zelmer (dz1069@att.com) | Rel-7 | Stefania | RP-070533 |  |
| 1169 | 369 | Study on Dynamically reconfiguring a FDD UE receiver to reduce power consumption when desired Quality of Service is met | milestone | 0d? | 2007-06-22 A | 2007-06-22 A | 100% | 2007-06-22 | 2007-06-22 | 0d? |  |  | R4 |  |  | FSUEPow | 25.906 | Nokia | Chris.callender@nokia.com, tiina.s.koskinen@nokia.com | Rel-7 | Stefania | RP-070534 |  |
| 1170 | 370 | Study on Future GERAN Evolution |  | 486d? | 2005-04-08 A | 2007-02-16 A | 100% | 2005-04-08 | 2007-02-16 | 486d? |  | finish no earlier than 2007-02-16 | GP | 3888h | 3888h | FGE | 45.912 | Nokia | eddie.riddington@nokia.com | Rel-7 | Paolo |  |  |
| 1171 | 371 | Study on GAN Enhancements | milestone | 0d? | 2007-08-31 A | 2007-08-31 A | 100% | 2007-08-31 | 2007-08-31 | 0d? |  | start no earlier than 2007-08-31 | GP |  |  | EGAN | 43.902 | T-Mobile | janne.linkola@t-mobile.com | Rel-7 | Paolo |  |  |
| 1172 | 372 | Deleted - covered by UID33027 - IMS security extensions | milestone | 0d? | 2005-12-08 A | 2005-12-08 A | 100% | 2005-12-08 | 2005-12-08 | 0d? |  | start no earlier than 2005-12-08 | S3 |  |  | IMS-SE |  | Ericsson | Bengt.Sahlin@ericsson.com | Rel-7 | Dionisio |  | SP-30 |
| 1173 | 373 | Deleted - covered by 32108 - Study of work on an LCS architecture for I-WLAN | milestone | 0d? | 2006-12-08 A | 2006-12-08 A | 100% | 2006-12-08 | 2006-12-08 | 0d? |  | start no earlier than 2006-12-08 | S2 |  |  | IMS-SE |  | LG Electronics | Donghee Shim dhshim@lge.com ; phede@lge.com | Rel-7 | Maurice |  | SP-33 |
| 1174 | 374 | **Deleted: Study on applicability of GALILEO for LCS** |  | 0d? | 2005-06-30 A | 2005-06-30 A | 100% | 2005-06-30 | 2005-06-30 | 0d? |  |  | S2 |  |  | Galileo |  |  |  | Rel-7 | Maurice |  | SP-25 |
| 1175 | 374.1 | Deleted - TR on Stage 2 | milestone | 0d? | 2005-06-30 A | 2005-06-30 A | 100% | 2005-06-30 | 2005-06-30 | 0d? |  | finish no earlier than 2005-06-30 | S2 |  |  | Galileo |  |  |  | Rel-7 | Maurice |  | SP-25 |
| 1176 | 374.2 | Deleted - GERAN review of the TR | milestone | 0d? | 2005-06-30 A | 2005-06-30 A | 100% | 2005-06-30 | 2005-06-30 | 0d? |  | start no earlier than 2005-06-30 | GP |  |  | Galileo |  |  |  | Rel-7 | Paolo |  | SP-26 |
| 1177 | 16.7 | **Deleted - IMS Local services** |  | 0d? | 2006-01-06 A | 2006-01-06 A | 100% | 2006-01-06 | 2006-01-06 | 0d? |  |  | S2 |  |  | IMSLocal | 23.228 |  |  | Rel-7 | Maurice |  | SP-28 |
| 1178 | 16.7.1 | Deleted - Stage 2 | milestone | 0d | 2006-01-06 A | 2006-01-06 A | 100% | 2006-01-06 | 2006-01-06 | 0d |  | start no earlier than 2006-01-06 | S2 |  |  | IMSLocal |  |  |  | Rel-7 | Maurice |  | SP-26 |
| 1179 | 375.2 | Deleted - Stage 3 for IMS Local services | milestone | 0d? | 2006-01-06 A | 2006-01-06 A | 100% | 2006-01-06 | 2006-01-06 | 0d? |  | finish no earlier than 2006-01-06 | C1 |  |  | IMSLocal |  | Lucent | Keith Drage (drage@alcatel-lucent.com) | Rel-7 | Frederic |  | SP-25 |
| 1180 | 376 | Deleted - IMS Phase 3 | milestone | 0d? | 2006-01-06 A | 2006-01-06 A | 100% | 2006-01-06 | 2006-01-06 | 0d? |  | start no earlier than 2006-01-06 | S2 |  |  |  |  |  |  | Rel-7 | Maurice |  | SP-25 |
| 1181 | 377 | Deleted - Improvements of Radio Interface | milestone | 0d? | 2004-09-15 A | 2004-09-15 A | 100% | 2004-09-15 | 2004-09-15 | 0d? |  | start no earlier than 2004-09-15 | RP |  |  | RInImp |  |  |  | Rel-7 | Stefania |  | SP-24 |
| 1182 | 378 | Deleted: Generic User Profile Phase 2 | milestone | 0d | 2005-08-08 A | 2006-06-30 A | 100% | 2005-08-08 | 2006-06-30 | 0d |  |  | C4 |  |  |  |  |  |  | Rel-7 | Kimmo |  | SP-27 |
| 1183 | 30.4 | Deleted - Stage 3 - Common objects | milestone | 0d | 2005-08-08 A | 2006-06-30 A | 100% | 2005-08-08 | 2006-06-30 | 0d |  | finish no earlier than 2006-06-30 | C4 |  |  |  | 24.241 |  |  | Rel-7 | Kimmo |  | SP-27 |
| 1184 | 380 | Delete was duplicated- Study of Customised Alerting Tone (CAT) Requirements | milestone | 0d? | 2006-06-30 A | 2006-06-30 A | 100% | 2006-06-30 | 2006-06-30 | 0d? |  | start no earlier than 2006-06-30 | S1 |  |  | CAT |  |  |  | Rel-7 | Alain |  | SP-31 |
| 1185 | 381 | Deleted - FS of enhanced support of Video Telephony | milestone | 0d? | 2006-06-30 A | 2006-06-30 A | 100% | 2006-06-30 | 2006-06-30 | 0d? |  | start no earlier than 2006-06-30 | GP |  |  | VIDGER |  | Ericsson | stefan.g.eriksson@ericsson.com | Rel-7 | Paolo |  | SP-32 |
| 1186 | 382 | Deleted (moved to Rel8) - Study on Transferring of emergency call data – in-band modem solution | milestone | 0d? | 2007-06-22 A | 2007-06-22 A | 100% | 2007-06-22 | 2007-06-22 | 0d? |  | start no earlier than 2007-06-22 | S4 |  |  | eCALLIBMS | 26.967 | Airbiquity | lhong@airbiquity.com | Rel-7 | Paolo |  | SP-38 |
| 1187 | 383 | Deleted - covered by UID 20053 - Study on Interference Cancellation for UTRA FDD UE |  | 1d? | 2007-03-28 A | 2007-03-28 A | 100% | 2007-03-28 | 2007-03-28 | 1d? |  | start no earlier than 2007-03-28 | R4 | 8h | 8h | RANFS-InterfCanc |  |  |  | Rel-7 | Stefania |  | SP-38 |
| 1188 | 384 | Deleted - Study of Personal Network and Personal Area Network | milestone | 0d? | 2006-10-20 A | 2006-10-20 A | 100% | 2006-10-20 | 2006-10-20 | 0d? |  | finish no earlier than 2006-10-20 | S1 |  |  | PNPAN |  |  |  | Rel-7 | Alain |  | SP-31 |
| 1189 | 385 | Deleted - Study on IMS with real time services deployment |  | 316d? | 2004-06-28 A | 2005-09-12 A | 100% | 2004-06-28 | 2005-09-12 | 316d? |  |  | S1 | 2528h | 2528h | IRTSD |  |  |  | Rel-7 | Alain |  | SP-30 |
| 1190 | 386 | Deleted - Study on Stage 2 (IMS services using CS bearers) |  | 316d? | 2004-06-28 A | 2005-09-12 A | 100% | 2004-06-28 | 2005-09-12 | 316d? |  | finish no earlier than 2005-09-12 | S2 | 2528h | 2528h | IRTSD-IMSCS | 23.899 | Nortel | Mark Watson | Rel-7 | Maurice |  | SP-30 |
| 1191 | 387 | Deleted - Study on IMS enhancements and optimisations for real time communication. |  | 430d? | 2005-10-10 A | 2007-06-01 A | 100% | 2005-10-10 | 2007-06-01 | 430d? |  | finish no earlier than 2007-06-01 | S2 | 3440h | 3440h | IMS-RT | 23.818 | Ericsson | stephen.terrill@ericsson.com | Rel-7 | Maurice |  | SP-35 |
| 1192 | 388 | Deleted - Study on Terminating Session handling |  | 255d? | 2006-01-09 A | 2006-12-29 A | 100% | 2006-01-09 | 2006-12-29 | 255d? |  | finish no earlier than 2006-12-29 | S2 | 2040h | 2040h | CSIterm | 23.819 | Samsung |  | Rel-7 | Maurice |  | SP-32 |
| 1193 | 389 | Deleted - Study on IRP usage scenarios |  | 330d? | 2005-09-02 A | 2006-12-07 A | 100% | 2005-09-02 | 2006-12-07 | 330d? |  | finish no earlier than 2006-12-07 | S5 | 2640h | 2640h | OAM-Study | 32.8xy | Lucent |  | Rel-7 | Dionisio |  | SP-32 |
| 1194 | 390 | Release 6 Features |  | 1d? | 2000-01-03 | 2000-01-03 |  | 2000-01-03 | 2000-01-03 | 1d? | 3317d |  | NP,GP, RP,SP,TP | 8h |  |  |  |  |  | Rel-6 |  |  |  |

Notes:
- 1155: -
- 1156: -
- 1157: -
- 1158: SP#34 completed
- 1159: SP#35 completed
- 1160: SP#35 completed
- 1161: RP#33 (Sep 2006) completed. SR in RP-060472
- 1162: RP#32 (Jun 2006) completed. SR in RP-060412
- 1163: RP#31 (Mar 2006) completed. SR in RP-060035
- 1164: RP#29 (Sep 2006) completed. SR in RP-050427
- 1165: RP#34 (Dec 2006) completed. SR in RP-060692
- 1166: RP#32 (Jun 2006) closed (no progress). SR in RP-060263
- 1167: RP#36 (May 2007) completed. SR in RP-070499
- 1168: RP#37 (Sep 2007) completed. SR in RP-070533
- 1169: RP#37 (Sep 2007) completed. SR in RP-070534
- 1170: GP#33 completed
- 1171: GP#35 completed
- 1172: -
- 1173: S2#52: Entry created
- 1174: -
- 1175: -
- 1176: -
- 1177: -
- 1178: DAB - Not yet required in SA2 as it exists in previous releases
- 1179: -
- 1180: -
- 1181: Stage 2 description of Interim conclusion
- 1182: Created at TSG#27 by A. Sultan because of the move to Rel-7 of "Common Objects".
- 1183: No progress in CN4#26. This have to be moved to Rel-7. It was deleted from WID
- 1184: Awaiting MCC SA3 input
- 1185: FS CLOSED at G#28 (no input)
- 1186: SP-38 stopped
- 1187: Deleted. Same as FS on Further Improved Performance Requirements for UMTS/HSDPA UE (FDD)
- 1188: Moved from FS section Feb 06
- 1189: -
- 1190: SP-30: S2 has no intention for TR completion
- 1191: abandoned at 65%
- 1192: SP#32 Jun 2006 Study abandoned => spin-off Implementation work UID_320029
- 1193: -
- 1194: -

| ID | WBS | Task | Duration | Start | Finish | Complete | Baseline start | Baseline finish | Baseline duration | Constraint | Resources | Work | Actual work | Text1 | Text6 | Text8 | Text4 | Text5 | Text3 | Text10 | Text12 |
| --- | --- | --- | --- | --- | --- | --- | --- | --- | --- | --- | --- | --- | --- | --- | --- | --- | --- | --- | --- | --- | --- |
| 1195 | 8 | **Rel-6 Improvements of Radio Interface** | 1393d? | 2000-08-14 A | 2005-12-14 A | 100% | 2000-08-14 | 2005-12-14 | 1393d? |  | RP | 38664h | 38664h | RInImp | Rel-6 | Stefania |  |  |  |  |  |
| 1196 | 391.1 | Improved support of IMS Realtime Services using HSDPA/EDCH | 197d? | 2005-03-15 A | 2005-12-14 A | 100% | 2005-03-15 | 2005-12-14 | 197d? | finish no earlier than 2005-12-14 | R2 | 1576h | 1576h | RInImp-IMSRealTime | Rel-6 | Joern | Cingular | Don Zelmer (dz1069@att.com) |  |  |  |
| 1197 | 391.2 | Improving Receiver Performance Requirements for the FDD UE | 401d | 2002-03-08 A | 2003-09-19 A | 100% | 2002-03-08 | 2003-09-19 | 401d | start no earlier than 2002-03-08 | R4 | 3208h | 3208h | RInImp-UERecPerf | Rel-6 | Stefania | Intel | shimon.moshavi@INTEL.COM | 25.101 |  |  |
| 1198 | 8.2 | **Base station classification** | 603d | 2000-08-14 A | 2002-12-04 A | 100% | 2000-08-14 | 2002-12-04 | 603d |  | R4 | 9648h | 9648h | RInImp-BSClass | Rel-6 | Stefania |  |  |  |  |  |
| 1199 | 8.2.1 | FDD Base station classification | 603d | 2000-08-14 A | 2002-12-04 A | 100% | 2000-08-14 | 2002-12-04 | 603d | finish no earlier than 2002-12-04 | R4 | 4824h | 4824h | RInImp-BSClass-FDD | Rel-6 | Stefania | Nokia | antti.toskala@nokia.com | 25.104, 25.141 |  |  |
| 1200 | 391.4 | UMTS-850 | 266d | 2002-12-06 A | 2003-12-12 A | 100% | 2002-12-06 | 2003-12-12 | 266d | finish no earlier than 2003-12-15 | R4 | 2128h | 2128h | RInImp-UMTS850 | Rel-6 | Stefania | Cingular | Don Zelmer (dz1069@att.com) | 25.101, 25.104, 25.133, 25.141, 25.307, 25.331, 25.942 |  |  |
| 1201 | 391.5 | DS-CDMA introduction in the 800 MHz band | 196d | 2003-03-14 A | 2003-12-12 A | 100% | 2003-03-14 | 2003-12-12 | 196d | finish no earlier than 2003-12-15 | R4 | 1568h | 1568h | RInImp-UMTS800 | Rel-6 | Stefania | NTT DoCoMo | Takehiro Nakamura (nakamurata@nttdocomo.co.jp) | 25.101, 25.104, 25.133, 25.141, 25.307, 25.331 |  |  |
| 1202 | 391.6 | UMTS 1.7/2.1 GHz | 261d | 2003-03-14 A | 2004-03-12 A | 100% | 2003-03-14 | 2004-03-12 | 261d | finish no earlier than 2004-03-15 | R4 | 2088h | 2088h | RInImp-UMTS1721 | Rel-6 | Stefania | Nokia | jussi.numminen@NOKIA.COM | 25.101, 25.104, 25.133, 25.141, 25.307, 25.331 |  |  |
| 1203 | 391.7 | **Improved Receiver Performance Requirements for HSDPA** | 392d? | 2003-12-15 A | 2005-06-14 A | 100% | 2003-12-15 | 2005-06-14 | 392d? |  | R4 | 7304h | 7304h | RInImp-HSPerf | Rel-6 | Stefania | Nokia | jussi.numminen@NOKIA.COM |  |  |  |
| 1204 | 391.7.1 | Improved Minimum Performance Requirements for HSDPA UE categories 7 and 8 | 195d? | 2004-09-15 A | 2005-06-14 A | 100% | 2004-09-15 | 2005-06-14 | 195d? | finish no earlier than 2005-06-14 | R4 | 1560h | 1560h | RInImp-HSPerf-10code | Rel-6 | Stefania | Nokia | jussi.numminen@nokia.com | 25.101 |  |  |
| 1205 | 391.7.2 | Performance Requirements of Receive Diversity for HSDPA | 326d | 2003-12-15 A | 2005-03-14 A | 100% | 2003-12-15 | 2005-03-14 | 326d | finish no earlier than 2005-03-14 | R4 | 2608h | 2608h | RInImp-HSPerf-RxDiv | Rel-6 | Stefania | NTT DoCoMo | Takehiro Nakamura (nakamurata@nttdocomo.co.jp) | 25.101 |  |  |
| 1206 | 392 | **Rel-6 RAN Feasibility Studies** | 1196d? | 2000-08-14 A | 2005-03-14 A | 100% | 2000-08-14 | 2005-03-14 | 1196d? |  | RP | 43048h | 43048h |  | Rel-6 | Stefania |  |  |  |  |  |
| 1207 | 392.1 | FS of the improved access to UE measurement data for CRNC to support TDD RRM | 270d? | 2002-12-06 A | 2003-12-18 A | 100% | 2002-12-06 | 2003-12-18 | 270d? | finish no earlier than 2003-09-19 | R3 | 2160h | 2160h | RANimp-RRMopt-FSUEMsD | Rel-6 | Juha | Interdigital | jim.miller@interdigital.com |  | SP-24 |  |
| 1208 | 392.2 | FS on Radio link performance enhancements | 1067d | 2000-08-14 A | 2004-09-14 A | 100% | 2000-08-14 | 2004-09-14 | 1067d | finish no earlier than 2004-09-14 | R1 | 8536h | 8536h | RInImp-Rlperf | Rel-6 | Patrick | Nokia | antti.toskala@nokia.com | 25.899 |  |  |
| 1209 | 392.3 | FS on Improvement of inter-frequency and inter-system measurements for 1.28 Mcps TDD | 461d | 2001-12-14 A | 2003-09-19 A | 100% | 2001-12-14 | 2003-09-19 | 461d | start no earlier than 2001-12-14 | R1 | 3688h | 3688h | RInImp-IfIsMLCR | Rel-6 | Patrick | Samsung | Li Xiao Qiang (xqli@samsung.co.kr) | 25.888 |  |  |
| 1210 | 392.4 | FS for the analysis of OFDM for UTRAN enhancement | 526d | 2002-06-10 A | 2004-06-14 A | 100% | 2002-06-10 | 2004-06-14 | 526d | start no earlier than 2002-06-10 | R1 | 4208h | 4208h | RInImp-FSOFDM | Rel-6 | Patrick | Nortel | Sarah Boumendil | 25.892 |  |  |
| 1211 | 392.5 | FS on Uplink Enhancements for Dedicated Transport Channels | 396d | 2002-09-06 A | 2004-03-12 A | 100% | 2002-09-06 | 2004-03-12 | 396d | finish no earlier than 2004-03-12 | R1 | 3168h | 3168h | RInImp-FSUpDTrCh | Rel-6 | Patrick | Nokia | Karri.Ranta-aho@nsn.com | 25.896 |  |  |
| 1212 | 392.6 | FS on Analysis on Higher Chip Rates for UTRA TDD evolutions | 528d | 2002-09-06 A | 2004-09-14 A | 100% | 2002-09-06 | 2004-09-14 | 528d | finish no earlier than 2004-09-14 | R1 | 4224h | 4224h | RInImp-FSVHCRTDD | Rel-6 | Patrick | IPWireless | mbeale@ipwireless.com | 25.895 |  |  |
| 1213 | 392.7 | FS on Low Output Powers for general purpose FDD BSs | 128d | 2003-06-13 A | 2004-03-12 A | 100% | 2003-06-13 | 2004-03-12 | 128d | finish no earlier than 2004-03-12 | R3 | 1024h | 1024h | RInImp-FSLoPw | Rel-6 | Juha | Telefonica | Ana Burgos (burgos_a@tsm.es) | 25.807 |  |  |
| 1214 | 392.8 | FS on Uplink enhancements for UTRA TDD | 462d | 2003-06-06 A | 2005-03-14 A | 100% | 2003-06-06 | 2005-03-14 | 462d | finish no earlier than 2005-03-14 | R1 | 3696h | 3696h | RInImp-FSUpEnhTDD | Rel-6 | Patrick | Interdigital | Marian.Rudolf@InterDigital.com | 25.804 |  |  |
| 1215 | 8.8 | FS on UE antenna efficiency test methods performance requirements (2) | 131d | 2002-03-08 A | 2002-09-06 A | 100% | 2002-03-08 | 2002-09-06 | 131d | finish no earlier than 2002-09-06 | R4 | 1048h | 1048h | RInImp-UEAnTM2 | Rel-6 | Stefania | Allgon | Alf Ahlström |  |  |  |
| 1216 | 9.4 | Deleted - FS on the evolution of the UTRAN architecture | 592d | 2002-09-09 A | 2004-12-14 A | 100% | 2002-09-09 | 2004-12-14 | 592d | finish no earlier than 2004-12-15 | R3 | 4736h | 4736h | RANimp-FSEvo | Rel-6 | Juha | Nokia | woonhee.hwang@nsn.com, Antti.Toskala@nokia.com |  |  | RP-26 |
| 1217 | 393 | **FDD Enhanced Uplink** | 393d | 2004-03-15 A | 2005-09-14 A | 100% | 2004-03-15 | 2005-09-14 | 393d |  | RP | 14128h | 14128h | EDCH | Rel-6 | Stefania | Ericsson | Joakim Bergström |  |  |  |
| 1218 | 393.1 | FDD Enhanced Uplink - Stage 2 | 197d | 2004-03-15 A | 2004-12-14 A | 100% | 2004-03-15 | 2004-12-14 | 197d | finish no earlier than 2004-12-14 | R2 | 1576h | 1576h | EDCH-Stage2 | Rel-6 | Joern |  |  | 25.309 |  |  |
| 1219 | 393.2 | FDD Enhanced Uplink - Physical Layer | 261d | 2004-03-15 A | 2005-03-14 A | 100% | 2004-03-15 | 2005-03-14 | 261d | finish no earlier than 2005-03-14 | R1 | 2088h | 2088h | EDCH-Phys | Rel-6 | Patrick | Nokia | Karri.Ranta-aho@nsn.com | 25.211, 25.212, 25.213, 25.214, 25.215 |  |  |
| 1220 | 393.3 | FDD Enhanced Uplink - Layer 2 and 3 Protocol Aspects | 261d | 2004-03-15 A | 2005-03-14 A | 100% | 2004-03-15 | 2005-03-14 | 261d | finish no earlier than 2005-03-14 | R2 | 2088h | 2088h | EDCH-L23 | Rel-6 | Joern | Ericsson | Joakim Bergström | 25.301, 25.302, 25.306, 25.321, 25.331 |  |  |
| 1221 | 393.4 | FDD Enhanced Uplink - UTRAN Iub/Iur Protocol Aspects | 261d | 2004-03-15 A | 2005-03-14 A | 100% | 2004-03-15 | 2005-03-14 | 261d | finish no earlier than 2005-03-14 | R3 | 2088h | 2088h | EDCH-IurIub | Rel-6 | Juha | Nortel | Saso Stojanovski | 25.401, 25.420, 25.423, 25.430, 25.433 |  |  |
| 1222 | 393.5 | FDD Enhanced Uplink - RF Radio Transmission/ Reception, System Performance Requirements and Conformance Testing | 393d | 2004-03-15 A | 2005-09-14 A | 100% | 2004-03-15 | 2005-09-14 | 393d | finish no earlier than 2005-09-15 | R4 | 3144h | 3144h | EDCH-RF | Rel-6 | Stefania | Ericsson | thomas.unshelm@ERICSSON.COM | 25.101, 25.104, 25.133, 25.141 |  |  |

Notes:
- 1195: This is a generic feature without particular end date
- 1196: -
- 1197: -
- 1198: -
- 1199: -
- 1200: Introduction of UMTS850 (Band V) in 25.307
- 1201: Introduction of UMTS800 in 25.307
- 1202: Introduction of UMTS1700/2100 (Band IV)
- 1203: -
- 1204: Approved at RP#25 as RP-040375
- 1205: -
- 1206: -
- 1207: -
- 1208: Study finished at RP#25
- 1209: -
- 1210: -
- 1211: -
- 1212: Study finished at RP#25
- 1213: -
- 1214: -
- 1215: The RInImp-UEAnTM FS was re-opened at TSG RP#15 upon request from WG4
- 1216: Study Closed, work will continue within the FS on evolved UTRA and UTRAN
- 1217: -
- 1218: -
- 1219: -
- 1220: -
- 1221: -
- 1222: -

| ID | WBS | Task | Type | Duration | Start | Finish | Complete | Baseline start | Baseline finish | Baseline duration | Constraint | Resources | Work | Actual work | Text1 | Text6 | Text8 | Text3 | Text4 | Text5 | Text12 | Text10 |
| --- | --- | --- | --- | --- | --- | --- | --- | --- | --- | --- | --- | --- | --- | --- | --- | --- | --- | --- | --- | --- | --- | --- |
| 1223 | 394 | **Rel-6 RAN improvements** |  | 656d? | 2002-09-09 A | 2005-03-14 A | 100% | 2002-09-09 | 2005-03-14 | 656d? |  | RP | 28312h | 28312h | RANimp | Rel-6 | Stefania |  |  |  |  |  |
| 1224 | 9.2 | **RAB support enhancement** |  | 522d? | 2003-03-14 A | 2005-03-14 A | 100% | 2003-03-14 | 2005-03-14 | 522d? |  | R2 | 9360h | 9360h | RANimp-RABSE | Rel-6 | Joern | 25.862 | Nokia | Jussi Kähtävä (juha.mikola@nokia.com) |  |  |
| 1225 | 394.1.1 | Optimisation of downlink channelisation code utilisation |  | 262d | 2004-03-12 A | 2005-03-14 A | 100% | 2004-03-12 | 2005-03-14 | 262d | finish no earlier than 2005-03-14 | R1 | 2096h | 2096h | RANimp-RABSE-CodeOptFDD | Rel-6 | Patrick |  | Nortel | Sarah Boumendil |  |  |
| 1226 | 394.1.2 | Optimisation of channelisation code utilisation for 3.84 Mcps TDD |  | 261d | 2004-03-15 A | 2005-03-14 A | 100% | 2004-03-15 | 2005-03-14 | 261d | finish no earlier than 2005-03-15 | R1 | 2088h | 2088h | RANimp-RABSE-CodOptTDD | Rel-6 | Patrick |  | IPWireless | Nicholas Anderson |  |  |
| 1227 | 394.1.3 | HS-DPCCH ACK/NACK Enhancement |  | 65d? | 2004-09-15 A | 2004-12-14 A | 100% | 2004-09-15 | 2004-12-14 | 65d? | finish no earlier than 2004-12-15 | R1 | 520h | 520h | RANimp-RABSE-ACKNACK | Rel-6 | Patrick | 25.212, 25.214, 24.331, 25.433 | Nokia | Jussi Kähtävä (juha.mikola@nokia.com) |  |  |
| 1228 | 394.1.4 | Deleted - Iu enhancements for IMS support in RAN |  | 320d? | 2003-03-14 A | 2004-06-03 A | 100% | 2003-03-14 | 2004-06-03 | 320d? | start no earlier than 2003-03-14 | R3 | 2560h | 2560h | RANimp-RABSE-IuEnhIMS | Rel-6 | Juha |  | Nortel | Philippe.Godin@nortelnetworks.com | RP-24 |  |
| 1229 | 394.1.5 | Deleted - Improvement of RRM across RNS and RNS/BSS | milestone | 0d? | 2003-12-05 A | 2003-12-05 A | 100% | 2003-12-05 | 2003-12-05 | 0d? | finish no earlier than 2003-12-05 | R3 |  |  | RANimp-RRM1 | Rel-6 | Juha |  | Nokia | antti.toskala@nokia.com | RP-23 |  |
| 1230 | 9.1 | Beamforming Enhancements |  | 66d | 2003-09-19 A | 2003-12-19 A | 100% | 2003-09-19 | 2003-12-19 | 66d | finish no earlier than 2004-03-12 | R1 | 528h | 528h | RANimp-BFE | Rel-6 | Patrick | 24.215, 25.423, 25.425, 25.433, 25.435 | Nokia | Jussi Kähtävä (juha.mikola@nokia.com) |  |  |
| 1231 | 394.3 | **Rel6 RRM optimization for Iur and Iub** |  | 126d | 2003-09-19 A | 2004-03-12 A | 100% | 2003-09-19 | 2004-03-12 | 126d |  | R3 | 2016h | 2016h | RANimp-RRMopt | Rel-6 | Juha |  | Ericsson | Gert-Jan.van.Lieshout@eln.ericsson.se |  |  |
| 1232 | 394.3.1 | Improved access to UE measurement data for CRNC to support TDD RRM |  | 126d | 2003-09-19 A | 2004-03-12 A | 100% | 2003-09-19 | 2004-03-12 | 126d | finish no earlier than 2004-03-15 | R3 | 1008h | 1008h | RANimp-RRMopt-UEMsD | Rel-6 | Juha | 25.423 | Interdigital | jim.miller@interdigital.com | RP-22 |  |
| 1233 | 394.4 | **Remote Control of Electrical Tilting Antennas** |  | 395d? | 2003-03-14 A | 2004-09-16 A | 100% | 2003-03-14 | 2004-09-16 | 395d? |  | R3 | 7464h | 7464h | RANimp-TiltAnt | Rel-6 | Juha |  | Vodafone | Andreas.Hauser@vodafone.com |  |  |
| 1234 | 394.4.1 | Tilting Antenna - RAN aspects |  | 393d? | 2003-03-14 A | 2004-09-14 A | 100% | 2003-03-14 | 2004-09-14 | 393d? | finish no earlier than 2004-09-14 | R3 | 3144h | 3144h | RANimp-TiltAnt | Rel-6 | Juha | 25.460, 25.461, 25.462, 25.463 | Vodafone | Andreas.Hauser@vodafone.com |  |  |
| 1235 | 394.4.2 | OAM&P impacts |  | 145d | 2004-02-27 A | 2004-09-16 A | 100% | 2004-02-27 | 2004-09-16 | 145d | finish no earlier than 2004-09-16 | S5 | 1160h | 1160h | RANimp-TiltAnt-OAM | Rel-6 | Dionisio | 32.804, 32.64x | Vodafone | Adrian.Neal@vodafone.com |  | SP-24 |
| 1236 | 394.5 | Network Assisted Cell Change (NACC) from UTRAN to GERAN - network-side aspects |  | 462d? | 2002-09-09 A | 2004-06-15 A | 100% | 2002-09-09 | 2004-06-15 | 462d? | finish no earlier than 2004-06-15 | R3 | 3696h | 3696h | RANimp-NACC | Rel-6 | Juha |  | Vodafone | Brendan.McWilliams@gb.vodafone.co.uk |  |  |
| 1237 | 12 | **Location Services enhancements 2** |  | 1024d? | 2001-01-15 A | 2004-12-16 A | 100% | 2001-01-15 | 2004-12-16 | 1024d? |  | S2,S5,N4,RP | 78152h | 78152h | LCS2 | Rel-6 | Maurice | 23.271 |  |  |  |  |
| 1238 | 12.1 | **Improvement on Le interface** |  | 653d? | 2002-06-17 A | 2004-12-15 A | 100% | 2002-06-17 | 2004-12-15 | 653d? |  | S2 | 9872h | 9872h |  | Rel-6 | Maurice |  |  |  |  |  |
| 1239 | 395.1.1 | Stage 2 |  | 331d? | 2002-06-17 A | 2003-09-22 A | 100% | 2002-06-17 | 2003-09-22 | 331d? | start no earlier than 2002-06-17 | S2 | 2648h | 2648h |  | Rel-6 | Maurice |  |  |  |  |  |
| 1240 | 395.1.2 | Stage 3 - impacts MLP (Mobile Location Protocol) |  | 250d? | 2004-01-01 A | 2004-12-15 A | 100% | 2004-01-01 | 2004-12-15 | 250d? | finish no earlier than 2004-12-15 | OMA | 2000h | 2000h |  | Rel-6 |  |  |  | OMA-LIAISON@mail.openmobilealliance.org |  |  |
| 1241 | 12.2 | **Enhanced support for anonymity and user privacy** |  | 638d? | 2002-07-08 A | 2004-12-15 A | 100% | 2002-07-08 | 2004-12-15 | 638d? |  | S2 | 9144h | 9144h |  | Rel-6 | Maurice |  |  |  |  |  |
| 1242 | 395.2.1 | Stage 2 |  | 255d? | 2002-07-08 A | 2003-06-27 A | 100% | 2002-07-08 | 2003-06-27 | 255d? | finish no earlier than 2003-06-27 | S2 | 2040h | 2040h |  | Rel-6 | Maurice |  |  |  |  |  |
| 1243 | 395.2.2 | Stage 3 - impacts MLP and RLP |  | 250d? | 2004-01-01 A | 2004-12-15 A | 100% | 2004-01-01 | 2004-12-15 | 250d? | finish no earlier than 2004-12-15 | OMA | 2000h | 2000h |  | Rel-6 |  |  |  | OMA-LIAISON@mail.openmobilealliance.org |  |  |
| 1244 | 12.3 | **Enhanced inter-GMLC interface** |  | 648d? | 2002-06-24 A | 2004-12-15 A | 100% | 2002-06-24 | 2004-12-15 | 648d? |  | S2 | 9704h | 9704h |  | Rel-6 | Maurice |  |  |  |  |  |
| 1245 | 395.3.1 | Stage 2 |  | 315d? | 2002-06-24 A | 2003-09-05 A | 100% | 2002-06-24 | 2003-09-05 | 315d? | finish no earlier than 2003-09-05 | S2 | 2520h | 2520h |  | Rel-6 | Maurice |  |  |  |  |  |
| 1246 | 395.3.2 | Stage 3 - definition of RLP and PCP |  | 250d? | 2004-01-01 A | 2004-12-15 A | 100% | 2004-01-01 | 2004-12-15 | 250d? | finish no earlier than 2004-12-15 | OMA | 2000h | 2000h |  | Rel-6 |  |  |  | OMA-LIAISON@mail.openmobilealliance.org |  |  |

Notes:
- 1223: Generic feature
- 1224: building block without particular end date
- 1225: -
- 1226: WIDS modified in RP#26, RP-040551
- 1227: Approved at RP#25 as RP-040390
- 1228: Closed RP#24 due to the lack of progress
- 1229: abandoned RP-23
- 1230: -
- 1231: -
- 1232: -
- 1233: -
- 1234: Finished at RP#25
- 1235: SP#25 09/2004 completed
- 1236: -
- 1237: -
- 1238: -
- 1239: -
- 1240: Updated according to SP-040232
- 1241: -
- 1242: -
- 1243: Updated according to SP-040232
- 1244: -
- 1245: -
- 1246: Updated according to SP-040232

| ID | WBS | Task | Type | Duration | Start | Finish | Complete | Baseline start | Baseline finish | Baseline duration | Constraint | Resources | Work | Actual work | Text6 | Text8 | Text5 | Text1 | Text4 | Text12 |
| --- | --- | --- | --- | --- | --- | --- | --- | --- | --- | --- | --- | --- | --- | --- | --- | --- | --- | --- | --- | --- |
| 1247 | 12.4 | **Location Services support for IMS public identities** |  | 473d? | 2003-02-24 A | 2004-12-15 A | 100% | 2003-02-24 | 2004-12-15 | 473d? |  | S2 | 7704h | 7704h | Rel-6 | Maurice |  |  |  |  |
| 1248 | 395.4.1 | Stage 2 |  | 240d? | 2003-02-24 A | 2004-01-23 A | 100% | 2003-02-24 | 2004-01-23 | 240d? | finish no earlier than 2004-01-23 | S2 | 1920h | 1920h | Rel-6 | Maurice |  |  |  |  |
| 1249 | 395.4.2 | Stage 3 - impacts MLP, RLP and PCP |  | 250d? | 2004-01-01 A | 2004-12-15 A | 100% | 2004-01-01 | 2004-12-15 | 250d? | finish no earlier than 2004-12-15 | OMA | 2000h | 2000h | Rel-6 |  | OMA-LIAISON@mail.openmobilealliance.org |  |  |  |
| 1250 | 12.5 | **New area event for location service triggering reports** |  | 663d? | 2002-06-03 A | 2004-12-15 A | 100% | 2002-06-03 | 2004-12-15 | 663d? |  | S2 | 11416h | 11416h | Rel-6 | Maurice |  |  |  |  |
| 1251 | 395.5.1 | Stage 2 |  | 280d? | 2002-06-03 A | 2003-06-27 A | 100% | 2002-06-03 | 2003-06-27 | 280d? | finish no earlier than 2003-06-27 | S2 | 2240h | 2240h | Rel-6 | Maurice |  |  |  |  |
| 1252 | 395.5.2 | Stage 3 for UE-CN signalling |  | 234d? | 2003-10-09 A | 2004-08-31 A | 100% | 2003-10-09 | 2004-08-31 | 234d? | start no earlier than 2003-10-09 | N4 | 1872h | 1872h | Rel-6 | Kimmo |  |  |  |  |
| 1253 | 395.5.3 | Stage 3 - impacts MLP, RLP and PCP |  | 250d? | 2004-01-01 A | 2004-12-15 A | 100% | 2004-01-01 | 2004-12-15 | 250d? | finish no earlier than 2004-12-15 | OMA | 2000h | 2000h | Rel-6 |  | OMA-LIAISON@mail.openmobilealliance.org |  |  |  |
| 1254 | 12.7 | **UE positioning** |  | 957d? | 2001-01-15 A | 2004-09-14 A | 100% | 2001-01-15 | 2004-09-14 | 957d? |  | RP | 18480h | 18480h | Rel-6 | Stefania |  | LCS2-UEpos |  |  |
| 1255 | 12.8 | Open SMLC-SRNC Interface within the UTRAN to support UTRAN Rel4 positioning methods |  | 700d? | 2001-01-15 A | 2003-09-19 A | 100% | 2001-01-15 | 2003-09-19 | 700d? | finish no earlier than 2003-09-19 | R2 | 5600h | 5600h | Rel-6 | Joern | Meik.Kottkamp@siemens.com | LCS-Rel4Pos | Siemens |  |
| 1256 | 395.6.2 | A-GPS minimum performance specification |  | 333d? | 2003-06-06 A | 2004-09-14 A | 100% | 2003-06-06 | 2004-09-14 | 333d? | finish no earlier than 2004-09-14 | R4 | 2664h | 2664h | Rel-6 | Stefania | donglin.shen@attws.com | LCS-UEPos-AGPSPerf | AT&T Wireless |  |
| 1257 | 12.7.2 | FS on Enhancements to OTDOA Positioning using advanced blanking methods |  | 320d | 2002-07-01 A | 2003-09-19 A | 100% | 2002-07-01 | 2003-09-19 | 320d | finish no earlier than 2003-09-19 | R2 | 2560h | 2560h | Rel-6 | Joern | david.bartlett@cursor-system.com | LCS2-UEpos-FSBlank | Cambridge Positioning Systems |  |
| 1258 | 395.6.4 | Deleted - UE positioning enhancements - other methods | milestone | 0d? | 2003-09-26 A | 2003-09-26 A | 100% | 2003-09-26 | 2003-09-26 | 0d? | finish no earlier than 2003-09-26 | R2 |  |  | Rel-6 | Joern | Meik.Kottkamp@siemens.com | LCS2-UEpos-enh | Siemens | RP-24 |
| 1259 | 395.7 | LCS charging |  | 455d? | 2003-03-21 A | 2004-12-16 A | 100% | 2003-03-21 | 2004-12-16 | 455d? | start no earlier than 2003-03-21 | S5 | 3640h | 3640h | Rel-6 | Dionisio | alain.bibas@orange-ft.com | LCS2-CH | France Telecom |  |
| 1260 | 14 | **Rel-6 Security enhancements** |  | 1018d? | 2001-01-03 A | 2004-11-26 A | 100% | 2001-01-03 | 2004-11-26 | 1018d? |  | S3 | 28824h | 28824h | Rel-6 | Dionisio | Peter.Howard@vodafone.com | SEC1 | Vodafone |  |
| 1261 | 14.1 | **Enhanced HE control of security (including positive authentication reporting)** |  | 712d | 2001-01-03 A | 2003-09-25 A | 100% | 2001-01-03 | 2003-09-25 | 712d |  | S3 | 14064h | 14064h | Rel-6 | Dionisio | Peter.Howard@vodafone.com |  | Vodafone |  |
| 1262 | 14.1.1 | Deleted - Stage 2 |  | 378d | 2001-01-03 A | 2002-06-14 A | 100% | 2001-01-03 | 2002-06-14 | 378d | finish no earlier than 2002-06-14 | S3 | 3024h | 3024h | Rel-6 | Dionisio |  |  |  | SP-16 |
| 1263 | 14.1.3 | **Network domain security** |  | 334d | 2002-06-17 A | 2003-09-25 A | 100% | 2002-06-17 | 2003-09-25 | 334d |  | S3 | 5344h | 5344h | Rel-6 | Dionisio | Geir-myrdahl.koien@telenor.com | SEC1-NDS | Telenor |  |
| 1264 | 14.1.3.1 | IP network layer security (NDS/IP) |  | 334d | 2002-06-17 A | 2003-09-25 A | 100% | 2002-06-17 | 2003-09-25 | 334d | finish no earlier than 2003-09-25 | S3 | 2672h | 2672h | Rel-6 | Dionisio |  | SEC1-NDS-IP |  |  |
| 1265 | 396.2 | Network Domain Security; Authentication Framework (NDS/AF) |  | 521d? | 2002-02-15 A | 2004-02-13 A | 100% | 2002-02-15 | 2004-02-13 | 521d? | finish no earlier than 2004-02-13 | S3 | 4168h | 4168h | Rel-6 | Dionisio | tommi.viitanen@nokia.com | SEC1-NDS-AF | Nokia |  |
| 1266 | 396.3 | Key Management of group keys for Voice Group Call Services |  | 306d | 2003-09-26 A | 2004-11-26 A | 100% | 2003-09-26 | 2004-11-26 | 306d | finish no earlier than 2004-11-26 | S3 | 2448h | 2448h | Rel-6 | Dionisio | benno.tietz@vodafone.com | SECGKYV | Vodafone |  |
| 1267 | 16 | **IMS Phase 2** |  | 1395d? | 2000-08-28 A | 2005-12-30 A | 100% | 2000-08-28 | 2005-12-30 | 1395d? |  | S1,S2,S3,S5,NP | 130248h | 130248h | Rel-6 | Alain |  | IMS2 |  |  |
| 1268 | 397.1 | Enhancements to the Cx and Sh interfaces |  | 323d? | 2003-06-06 A | 2004-08-31 A | 100% | 2003-06-06 | 2004-08-31 | 323d? | finish no earlier than 2004-08-31 | N4 | 2584h | 2584h | Rel-6 | Kimmo |  | IMS2-CCR |  |  |
| 1269 | 16.12 | **IMS Group Management** |  | 715d? | 2002-03-14 A | 2004-12-08 A | 100% | 2002-03-14 | 2004-12-08 | 715d? |  | S1 | 12680h | 12680h | Rel-6 | Alain | juha.kalliokulju@nokia.com | IMSGM | Nokia |  |
| 1270 | 16.12.1 | Stage 1 - TS on IMS group management |  | 193d | 2002-03-14 A | 2002-12-09 A | 100% | 2002-03-14 | 2002-12-09 | 193d | finish no earlier than 2002-12-09 | S1 | 1544h | 1544h | Rel-6 | Alain | juha.kalliokulju@nokia.com |  | Nokia |  |
| 1271 | 397.2.2 | Stage 2 |  | 158d? | 2003-05-26 A | 2003-12-31 A | 100% | 2003-05-26 | 2003-12-31 | 158d? | finish no earlier than 2003-12-31 | S2 | 1264h | 1264h | Rel-6 | Maurice |  |  |  |  |
| 1272 | 397.2.3 | Stage 3 for IMS Group management (e.g. chat) |  | 519d? | 2002-12-13 A | 2004-12-08 A | 100% | 2002-12-13 | 2004-12-08 | 519d? | finish no earlier than 2004-12-08 | N1 | 4152h | 4152h | Rel-6 | Frederic | Keith Drage (drage@alcatel-lucent.com) |  | Lucent |  |

Notes:
- 1247: -
- 1248: -
- 1249: Updated according to SP-040232
- 1250: -
- 1251: -
- 1252: 31/10/2003 work has started. Current stage 3 fullfills the requirements of stage 2. ......
- 1253: Updated according to SP-040232
- 1254: -
- 1255: - / Text3: 25.305, 25.401, 25.450, 25.452, 25.453
- 1256: Finished at RP#25 / Text3: 25.171
- 1257: -
- 1258: building block without particular end date
- 1259: SP#26 12/2004 completed / Text3: 32.271
- 1260: Added BB UE authentication and rapporteur added.
- 1261: Added by SP-000575 without any dates. 18/10/00: Change of WI title, added hyperlink rapporteur new end date 03/01. New end date and correct Release to be decided S3#18
- 1262: New end date and correct Release to be decided S3#18. Marked as stopped 12/2008
- 1263: WID approved for Rel-6 at SP#17. Completed 2004-12
- 1264: Should be complete after SA3#27. Completed 2004-12 / Text3: 33.210
- 1265: WID approved SP#19. Work started after FS approved SP#18
- 1266: Approved TSG#21. Completed 2004-12 / Text3: 42.068, 43.068, 44.068, 42.069, 43.069, 44.069, 31.102, 24.008, 48.008, 42.009, 43.020
- 1267: Not yet available: verbally approved at SA15, actual WID to be provided at SA16 by Lucent / Text3: 23.228
- 1268: Shared public user identities need to be solved. If email approval CR is accepted. Work 100% done....
- 1269: -
- 1270: -
- 1271: -
- 1272: Depends on CN decision on CPCP in Rel-6. Complete, if unresolved IETF dependencies are dropped (-> LS to CN plenary)

| ID | WBS | Task | Type | Duration | Start | Finish | Complete | Baseline start | Baseline finish | Baseline duration | Constraint | Resources | Work | Actual work | Text6 | Text8 | Text4 | Text5 | Text1 | Text3 | Text12 |
| --- | --- | --- | --- | --- | --- | --- | --- | --- | --- | --- | --- | --- | --- | --- | --- | --- | --- | --- | --- | --- | --- |
| 1273 | 397.3 | **IMS Conferencing** |  | 548d? | 2002-11-04 A | 2004-12-08 A | 100% | 2002-11-04 | 2004-12-08 | 548d? |  | N1 | 10960h | 10960h | Rel-6 | Frederic |  |  |  |  |  |
| 1274 | 397.3.1 | Stage 2 |  | 303d? | 2002-11-04 A | 2003-12-31 A | 100% | 2002-11-04 | 2003-12-31 | 303d? | finish no earlier than 2003-12-31 | S2 | 2424h | 2424h | Rel-6 | Maurice |  |  |  |  |  |
| 1275 | 397.3.2 | Stage 3 |  | 519d? | 2002-12-13 A | 2004-12-08 A | 100% | 2002-12-13 | 2004-12-08 | 519d? | finish no earlier than 2004-12-08 | N1 | 4152h | 4152h | Rel-6 | Frederic | Lucent | Keith Drage (drage@alcatel-lucent.com) |  |  |  |
| 1276 | 16.11 | **IMS Messaging** |  | 992d? | 2002-03-14 A | 2005-12-30 A | 100% | 2002-03-14 | 2005-12-30 | 992d? |  | S1 | 23912h | 23912h | Rel-6 | Alain | Nokia | juha.kalliokulju@nokia.com | IMSM |  |  |
| 1277 | 16.11.1 | TR on support of messaging in the IMS |  | 193d | 2002-03-14 A | 2002-12-09 A | 100% | 2002-03-14 | 2002-12-09 | 193d | finish no earlier than 2002-12-09 | S1 | 1544h | 1544h | Rel-6 | Alain | Nokia | juha.kalliokulju@nokia.com | IMSM-TR |  |  |
| 1278 | 397.4.2 | Stage 1 22.340 |  | 23d? | 2002-11-11 A | 2002-12-11 A | 100% | 2002-11-11 | 2002-12-11 | 23d? | finish no earlier than 2002-12-11 | S1 | 184h | 184h | Rel-6 | Alain | Nokia | juha.kalliokulju@nokia.com | IMSM-TS | 22.340 |  |
| 1279 | 397.4.3 | CRs to 22.140 & 22.228 |  | 263d? | 2002-03-14 A | 2003-03-17 A | 100% | 2002-03-14 | 2003-03-17 | 263d? | finish no earlier than 2003-03-17 | S1 | 2104h | 2104h | Rel-6 | Alain | Nokia | juha.kalliokulju@nokia.com | IMSM-CR | 22.140,22.228 |  |
| 1280 | 16.11.3 | Stage 2 |  | 477d | 2002-11-04 A | 2004-08-31 A | 100% | 2002-11-04 | 2004-08-31 | 477d | finish no earlier than 2004-08-31 | S2 | 3816h | 3816h | Rel-6 | Maurice |  |  |  |  |  |
| 1281 | 397.4.5 | Stage 3 for IMS Messaging |  | 519d? | 2002-12-13 A | 2004-12-08 A | 100% | 2002-12-13 | 2004-12-08 | 519d? | finish no earlier than 2004-12-08 | N1 | 4152h | 4152h | Rel-6 | Frederic | Lucent | Keith Drage (drage@alcatel-lucent.com) |  |  |  |
| 1282 | 397.4.6 | SIP/SIMPLE Instant messaging |  | 522d? | 2004-01-01 A | 2005-12-30 A | 100% | 2004-01-01 | 2005-12-30 | 522d? | finish no earlier than 2005-06-30 | OMA | 4176h | 4176h | Rel-6 |  |  | OMA-LIAISON@mail.openmobilealliance.org |  |  |  |
| 1283 | 397.5 | **Additional SIP Capabilities support not covered by Rel-5** |  | 680d? | 2002-11-11 A | 2005-06-17 A | 100% | 2002-11-11 | 2005-06-17 | 680d? |  | N1 | 13392h | 13392h | Rel-6 | Frederic |  |  |  |  |  |
| 1284 | 397.5.1 | Stage 2 for add SIP cap (e.g. forking) |  | 335d? | 2002-11-11 A | 2004-02-20 A | 100% | 2002-11-11 | 2004-02-20 | 335d? | finish no earlier than 2004-02-20 | S2 | 2680h | 2680h | Rel-6 | Maurice |  |  |  |  |  |
| 1285 | 397.5.2 | Stage 3 for Additional SIP Capabilities |  | 454d? | 2002-12-13 A | 2004-09-08 A | 100% | 2002-12-13 | 2004-09-08 | 454d? | finish no earlier than 2004-09-08 | N1 | 3632h | 3632h | Rel-6 | Frederic | Lucent | Keith Drage (drage@alcatel-lucent.com) |  |  |  |
| 1286 | 397.5.3 | Procedured associated with IMS-ALG |  | 205d? | 2004-09-06 A | 2005-06-17 A | 100% | 2004-09-06 | 2005-06-17 | 205d? | start no earlier than 2004-09-06 | N1 | 1640h | 1640h | Rel-6 | Frederic |  |  |  |  |  |
| 1287 | 397.6 | Review additional SIP Capabilities against IMS |  | 454d? | 2002-12-13 A | 2004-09-08 A | 100% | 2002-12-13 | 2004-09-08 | 454d? | finish no earlier than 2004-09-08 | N1 | 3632h | 3632h | Rel-6 | Frederic | Lucent | Keith Drage (drage@alcatel-lucent.com) |  |  |  |
| 1288 | 16.5 | **Interworking between IMS and IP networks** |  | 1118d? | 2000-08-28 A | 2004-12-08 A | 100% | 2000-08-28 | 2004-12-08 | 1118d? |  | N3 | 31712h | 31712h | Rel-6 | Gwiho | BT | nigel.holland@bt.com | IMS-CCR-IWIP | 23.821, 29.061, 29.162 |  |
| 1289 | 16.5.1 | Interworking for 3GPP_SIP and IETF_SIP |  | 730d | 2000-08-28 A | 2003-06-13 A | 100% | 2000-08-28 | 2003-06-13 | 730d | finish no earlier than 2003-06-13 | N3 | 5840h | 5840h | Rel-6 | Gwiho | Siemens | Thomas.Belling@nsn.com |  | New 29.962 |  |
| 1290 | 16.5.2 | Interworking for IPv6 to IPv4 |  | 1118d | 2000-08-28 A | 2004-12-08 A | 100% | 2000-08-28 | 2004-12-08 | 1118d | finish no earlier than 2004-12-08 | N3 | 8944h | 8944h | Rel-6 | Gwiho |  |  |  | 29.163 |  |
| 1291 | 397.7.3 | Interworking for IPv6 to IPv4 (SIP / SDP aspects) |  | 87d? | 2004-05-11 A | 2004-09-08 A | 100% | 2004-05-11 | 2004-09-08 | 87d? | finish no earlier than 2004-09-08 | N1 | 696h | 696h | Rel-6 | Frederic |  |  |  |  |  |
| 1292 | 16.8.1 | stage 3 of interworking with non-IMS IP networks |  | 911d | 2001-03-14 A | 2004-09-08 A | 100% | 2001-03-14 | 2004-09-08 | 911d | finish no earlier than 2004-09-08 | N1 | 7288h | 7288h | Rel-6 | Frederic |  |  |  |  |  |
| 1293 | 16.6.1 | Interworking between IMS and CS networks |  | 929d? | 2000-08-28 A | 2004-03-18 A | 100% | 2000-08-28 | 2004-03-18 | 929d? | finish no earlier than 2004-03-18 | N3 | 7432h | 7432h | Rel-6 | Gwiho | Vodafone | Brendan.McWilliams@gb.vodafone.co.uk | IMS-CCR-IWCS | 29.163, 29.061, 24.228, and new CN4 specification |  |
| 1294 | 16.10 | Mn interface (IM-MGW to MGCF) enhancements (CN4 Part) |  | 418d | 2001-08-07 A | 2004-09-01 A | 100% | 2001-08-07 | 2004-09-01 | 418d | finish no earlier than 2004-09-01 | N4 | 3344h | 3344h | Rel-6 | Kimmo |  |  | IMS-CCR-Mn |  |  |
| 1295 | 397.10 | Study of subscriber and operators relationship in IMS and related ISIM requirements for Rel 6” |  | 20d? | 2002-11-15 A | 2002-12-12 A | 100% | 2002-11-15 | 2002-12-12 | 20d? | finish no earlier than 2002-12-12 | S1 | 160h | 160h | Rel-6 | Alain | Nokia | juha.kalliokulju@nokia.com |  |  |  |
| 1296 | 397.11 | Lawful Interception in the 3GPP Rel-6 architecture |  | 269d? | 2002-12-09 A | 2003-12-18 A | 100% | 2002-12-09 | 2003-12-18 | 269d? | finish no earlier than 2003-12-18 | S3 | 2152h | 2152h | Rel-6 | Dionisio | Reg TP | berthold.wilhelm@regtp.de | SEC1-LI | 33.106, 33.107, 33.108 |  |
| 1297 | 397.12 | IMS Subscription and access scenarios |  | 130d? | 2002-12-16 A | 2003-06-13 A | 100% | 2002-12-16 | 2003-06-13 | 130d? | start no earlier than 2002-12-16 | S1 | 1040h | 1040h | Rel-6 | Alain |  |  |  | 22.800 |  |
| 1298 | 397.13 | IMS charging |  | 455d? | 2003-03-21 A | 2004-12-16 A | 100% | 2003-03-21 | 2004-12-16 | 455d? | finish no earlier than 2004-12-16 | S5 | 3640h | 3640h | Rel-6 | Dionisio |  |  | IMS2-CH | 32.260 |  |
| 1299 | 397.14 | IMS Management objects |  | 306d? | 2004-09-03 A | 2005-11-04 A | 100% | 2004-09-03 | 2005-11-04 | 306d? | finish no earlier than 2005-03-04 | N1 | 2448h | 2448h | Rel-6 | Frederic |  |  |  | 24.167 |  |
| 1300 | 397.15 | Deleted - Stage 2 of IMS Phase 2 | milestone | 0d? | 2003-09-19 A | 2003-09-19 A | 100% | 2003-09-19 | 2003-09-19 | 0d? | finish no earlier than 2003-09-19 | S2 |  |  | Rel-6 | Maurice |  |  |  |  | SP-21 |

Notes:
- 1273: -
- 1274: -
- 1275: Depends on CN decision on IETF dependencies in Rel-6. Higher figure if CPCP is dropped (-> LS to CN plenary)
- 1276: -
- 1277: -
- 1278: -
- 1279: -
- 1280: -
- 1281: -
- 1282: Updated according to SP-040232
- 1283: -
- 1284: -
- 1285: -
- 1286: -
- 1287: -
- 1288: [DAB 14.02.02] - end date pushed back to March 2003
- 1289: [DAB - 20.08.03] - CN Part of TR Complete @ CN#20
- 1290: -
- 1291: -
- 1292: -
- 1293: [DAB - 25.05.04] - CN3 consider this work to be complete
- 1294: TISPAN issue is open
- 1295: -
- 1296: -
- 1297: -
- 1298: SP#26 12/2004 completed
- 1299: -
- 1300: -

| ID | WBS | Task | Type | Duration | Start | Finish | Complete | Baseline start | Baseline finish | Baseline duration | Constraint | Resources | Work | Actual work | Text1 | Text3 | Text4 | Text5 | Text6 | Text8 | Text10 | Text12 |
| --- | --- | --- | --- | --- | --- | --- | --- | --- | --- | --- | --- | --- | --- | --- | --- | --- | --- | --- | --- | --- | --- | --- |
| 1301 | 398 | **3GPP Enablers for services like Push to Talk over Cellular (PoC)** |  | 459d? | 2003-09-08 A | 2005-06-09 A | 100% | 2003-09-08 | 2005-06-09 | 459d? |  | S2,S4,S5 | 10696h | 10696h | PoC | 23.979 | Ericsson | Shabnam Sultana | Rel-6 | Maurice |  |  |
| 1302 | 398.1 | Feasibility Study |  | 322d? | 2003-09-08 A | 2004-11-30 A | 100% | 2003-09-08 | 2004-11-30 | 322d? | finish no earlier than 2004-11-30 | S2 | 2576h | 2576h | PoC | 23.979 | Ericsson | Shabnam Sultana | Rel-6 | Maurice | SP-24 |  |
| 1303 | 398.2 | Dependencies on OMA PoC |  | 303d? | 2004-01-01 A | 2005-02-28 A | 100% | 2004-01-01 | 2005-02-28 | 303d? | finish no earlier than 2004-12-30 | OMA | 2424h | 2424h | PoC |  |  | OMA-LIAISON@mail.openmobilealliance.org | Rel-6 |  | SP-24 |  |
| 1304 | 398.3 | Selection of one or more PoC codec(s) for PoC |  | 69d? | 2004-09-13 A | 2004-12-16 A | 100% | 2004-09-13 | 2004-12-16 | 69d? | start no earlier than 2004-09-13 | S4 | 552h | 552h | PoC | 26.235, 26.236 |  |  | Rel-6 | Paolo | SP-25 |  |
| 1305 | 398.4 | PoC charging |  | 184d? | 2004-09-27 A | 2005-06-09 A | 100% | 2004-09-27 | 2005-06-09 | 184d? | finish no earlier than 2005-06-09 | S5 | 1472h | 1472h | PoC-CH | 32.272 |  |  | Rel-6 | Dionisio |  |  |
| 1306 | 399 | Interworking aspects and migration scenarios for IPv4 based IMS Implementations (Study) |  | 210d? | 2003-09-08 A | 2004-06-25 A | 100% | 2003-09-08 | 2004-06-25 | 210d? | finish no earlier than 2004-06-25 | S2 | 1680h | 1680h | IPv4IMS | 23.881 | Siemens | Alexander Milinski | Rel-6 | Maurice |  |  |
| 1307 | 16.3 | **Interoperability and Commonality between IMS using different "IP-connectivity Networks"** |  | 325d? | 2002-09-16 A | 2003-12-12 A | 100% | 2002-09-16 | 2003-12-12 | 325d? |  | S2 | 9176h | 9176h | IMSCOOP | 23.864 |  |  | Rel-6 | Maurice |  |  |
| 1308 | 16.3.1 | Stage 2 for Interoperability |  | 272d | 2002-09-16 A | 2003-09-30 A | 100% | 2002-09-16 | 2003-09-30 | 272d | finish no earlier than 2003-09-30 | S2 | 2176h | 2176h |  | 23.864 | Nokia | balazs.bertenyi@nsn.com | Rel-6 | Maurice |  |  |
| 1309 | 400.2 | Stage 2 for commonality |  | 265d? | 2002-09-16 A | 2003-09-19 A | 100% | 2002-09-16 | 2003-09-19 | 265d? | start no earlier than 2002-09-16 | S2 | 2120h | 2120h |  | 23.864 | Nokia | balazs.bertenyi@nsn.com | Rel-6 | Maurice |  |  |
| 1310 | 16.3.2 | Stage 3 |  | 305d | 2002-10-14 A | 2003-12-12 A | 100% | 2002-10-14 | 2003-12-12 | 305d | finish no earlier than 2003-12-12 | N1 | 2440h | 2440h |  |  | Lucent | Keith Drage (drage@alcatel-lucent.com) | Rel-6 | Frederic |  |  |
| 1311 | 17 | **Support of Push Services** |  | 823d | 2001-01-03 A | 2004-02-27 A | 100% | 2001-01-03 | 2004-02-27 | 823d |  | S1 | 11390.6h | 11390.6h | PUSH | 23.976 | NTT Comware | Yoshinori Kitada | Rel-6 | Alain |  |  |
| 1312 | 17.1 | Stage 1 |  | 378d | 2001-01-03 A | 2002-06-14 A | 100% | 2001-01-03 | 2002-06-14 | 378d | finish no earlier than 2002-06-14 | S1 | 3024h | 3024h |  |  |  |  | Rel-6 | Alain |  |  |
| 1313 | 17.3 | TR 23.976 on Push Architecture |  | 340d | 2002-11-11 A | 2004-02-27 A | 100% | 2002-11-11 | 2004-02-27 | 340d | finish no earlier than 2004-02-27 | S2 | 2720h | 2720h |  | 23.976 | RIM | Nick Alfano | Rel-6 | Maurice |  |  |
| 1314 | 18 | **Multimedia Messaging (MMS) enhancements** |  | 865d? | 2002-08-15 A | 2005-12-07 A | 100% | 2002-08-15 | 2005-12-07 | 865d? |  | T2,S1,S4,S5 | 31936h | 31936h | MMS6 |  | Siemens | Josef.Laumen@SAL.SIEMENS.DE | Rel-6 | Kimmo |  |  |
| 1315 | 18.1 | **Definition of service requirements** |  | 286d? | 2002-11-15 A | 2003-12-19 A | 100% | 2002-11-15 | 2003-12-19 | 286d? |  | S1 | 4576h | 4576h | MMS6-SR | 22.140 |  |  | Rel-6 | Alain |  |  |
| 1316 | 402.1.1 | Definition of service requirements charging |  | 286d? | 2002-11-15 A | 2003-12-19 A | 100% | 2002-11-15 | 2003-12-19 | 286d? | finish no earlier than 2003-12-20 | S1 | 2288h | 2288h |  | 22.140 | Siemens | Josef.Laumen@SAL.SIEMENS.DE | Rel-6 | Alain |  |  |
| 1317 | 18.2 | Technical realization |  | 591d | 2002-09-06 A | 2004-12-10 A | 100% | 2002-09-06 | 2004-12-10 | 591d | finish no earlier than 2004-12-10 | T2 | 4728h | 4728h |  | 23.140 | Siemens | Josef.Laumen@SAL.SIEMENS.DE | Rel-6 | Kimmo |  |  |
| 1318 | 18.3 | OMA dependencies |  | 446d | 2003-08-15 A | 2005-04-29 A | 100% | 2003-08-15 | 2005-04-29 | 446d | finish no earlier than 2004-12-10 | OMA | 3568h | 3568h |  | OMA specs |  |  | Rel-6 | Kimmo |  |  |
| 1319 | 18.4 | MMS formats and codecs |  | 865d | 2002-08-15 A | 2005-12-07 A | 100% | 2002-08-15 | 2005-12-07 | 865d | finish no earlier than 2005-12-07 | S4 | 6920h | 6920h | MMS6-Codec | 26.140, 26.936 | Nokia | roberto.castagno@nokia.com | Rel-6 | Paolo |  |  |
| 1320 | 402.5 | Handling of private addressing schemes in MMS |  | 263d | 2003-12-10 A | 2004-12-10 A | 100% | 2003-12-10 | 2004-12-10 | 263d | finish no earlier than 2004-12-10 | T2 | 2104h | 2104h |  | 23.140 | T-Mobile | Steffen.Habermann@T-MOBILE.DE | Rel-6 | Kimmo |  |  |
| 1321 | 402.6 | MMS charging |  | 390d? | 2003-03-21 A | 2004-09-16 A | 100% | 2003-03-21 | 2004-09-16 | 390d? | start no earlier than 2003-03-21 | S5 | 3120h | 3120h | MMS6-CH | 32.270 |  |  | Rel-6 | Dionisio |  |  |
| 1322 | 402.7 | Deleted - FS Multiple MMS Relay/Server Architecture | milestone | 0d | 2004-12-10 A | 2004-12-10 A | 100% | 2004-12-10 | 2004-12-10 | 0d | finish no earlier than 2004-12-10 | T2 |  |  |  | probably Annex to 23.140 | Telefónica Móviles | Juan Gorospe (gorospe_j@tsm.es) | Rel-6 | Kimmo |  | TP-26 |
| 1323 | 19 | **Rel-6 MExE enhancements** |  | 326d | 2002-03-08 A | 2003-06-06 A | 100% | 2002-03-08 | 2003-06-06 | 326d |  | T2 | 7328h | 7328h | MEXE6 |  |  |  | Rel-6 | Kimmo |  |  |
| 1324 | 19.1 | MExE Rel-6 Improvements and Investigations |  | 264d | 2002-03-08 A | 2003-03-12 A | 100% | 2002-03-08 | 2003-03-12 | 264d | finish no earlier than 2003-03-12 | T2 | 2112h | 2112h | MEXE6-ENHANC | 22.057, 23.057 | TTPCom | Lars Brenk ( (lsb_ttpcom@HOTMAIL.COM) | Rel-6 |  |  |  |
| 1325 | 19.2 | MExE Run-Time Independent Framework Feasibility Study |  | 326d | 2002-03-08 A | 2003-06-06 A | 100% | 2002-03-08 | 2003-06-06 | 326d | finish no earlier than 2003-06-06 | T2 | 2608h | 2608h | MEXE6-RTIF | 22.857 | Intel | Aaron.Cohen@intel.com | Rel-6 |  |  |  |
| 1326 | 21 | Subscription Management |  | 650d | 2002-09-20 A | 2005-03-17 A | 100% | 2002-09-20 | 2005-03-17 | 650d | finish no earlier than 2005-03-17 | S5 | 5200h | 5200h | SuM | 32.140/1, 32.171/2/5, 32.803 | T-Mobile | istvan.aba@t-mobile.at | Rel-6 | Dionisio |  |  |

Notes:
- 1301: -
- 1302: -
- 1303: Updated according to SP-040232
- 1304: Completed
- 1305: SP#28 06/2005 completed
- 1306: -
- 1307: -
- 1308: No contributions assumed that no more will be done in 3GPP hence work may need to be done in 3GPP2
- 1309: -
- 1310: -
- 1311: Changed from FS to actual support of Push
- 1312: -
- 1313: -
- 1314: -
- 1315: -
- 1316: -
- 1317: -
- 1318: -
- 1319: -
- 1320: -
- 1321: SP#25 09/2004 completed
- 1322: originally it was intended to create a FS TR but most likely the work will become an Annex of 23.140
- 1323: -
- 1324: -
- 1325: -
- 1326: SP#27 03/2005 completed

| ID | WBS | Task | Duration | Start | Finish | Complete | Baseline start | Baseline finish | Baseline duration | Constraint | Resources | Work | Actual work | Text1 | Text4 | Text5 | Text6 | Text8 | Text3 |
| --- | --- | --- | --- | --- | --- | --- | --- | --- | --- | --- | --- | --- | --- | --- | --- | --- | --- | --- | --- |
| 1327 | 22 | **Presence Capability** | 1233d? | 2001-03-19 A | 2005-12-07 A | 100% | 2001-03-19 | 2005-12-07 | 1233d? |  | S1 | 37112h | 37112h | PRESNC | Motorola | Mark Cataldo | Rel-6 | Alain |  |
| 1328 | 22.1 | Stage 1 | 610d | 2001-03-19 A | 2003-07-18 A | 100% | 2001-03-19 | 2003-07-18 | 610d | finish no earlier than 2003-07-18 | S1 | 4880h | 4880h |  |  |  | Rel-6 | Alain | 22.141 |
| 1329 | 22.2 | Stage 2 | 268d | 2001-09-12 A | 2002-09-20 A | 100% | 2001-09-12 | 2002-09-20 | 268d | finish no earlier than 2002-09-20 | S2 | 2144h | 2144h |  | Nokia | balazs.bertenyi@nsn.com | Rel-6 | Maurice |  |
| 1330 | 22.3 | Stage 3 | 703d | 2002-04-01 A | 2004-12-08 A | 100% | 2002-04-01 | 2004-12-08 | 703d | finish no earlier than 2004-12-08 | N1 | 5624h | 5624h |  | Lucent | Keith Drage (drage@alcatel-lucent.com) | Rel-6 | Frederic |  |
| 1331 | 405.4 | Stage 3 (CN3 Part Pk interface) | 770d? | 2002-04-01 A | 2005-03-11 A | 100% | 2002-04-01 | 2005-03-11 | 770d? | finish no earlier than 2005-03-11 | N3 | 6160h | 6160h |  |  |  | Rel-6 | Gwiho |  |
| 1332 | 405.5 | Media Codecs and Formats for IMS Messaging and Presence | 650d? | 2003-06-12 A | 2005-12-07 A | 100% | 2003-06-12 | 2005-12-07 | 650d? | finish no earlier than 2005-12-07 | S4 | 5200h | 5200h | PRESNC-COFIMP | Nokia | harri.honko@nokia.com | Rel-6 | Paolo | 26.141, 26.936 |
| 1333 | 22.4 | Security issues | 79d | 2002-08-26 A | 2002-12-12 A | 100% | 2002-08-26 | 2002-12-12 | 79d | finish no earlier than 2002-12-12 | S3 | 632h | 632h |  |  |  | Rel-6 | Dionisio |  |
| 1334 | 405.7 | SIMPLE Presence | 326d? | 2004-01-01 A | 2005-03-31 A | 100% | 2004-01-01 | 2005-03-31 | 326d? | finish no earlier than 2004-12-30 | OMA | 2608h | 2608h |  |  | OMA-LIAISON@mail.openmobilealliance.org | Rel-6 |  |  |
| 1335 | 25 | **Enhanced A/Gb feasibility study** | 51d? | 2002-08-30 A | 2002-11-08 A | 100% | 2002-08-30 | 2002-11-08 | 51d? |  | GP | 3264h | 3264h | AGbEnFS | Vodafone | jose-luis.carrizo@vodafone.co.uk | Rel-6 | Paolo |  |
| 1336 | 25.1 | **Feasibility study on A/Gb enhancements** | 51d? | 2002-08-30 A | 2002-11-08 A | 100% | 2002-08-30 | 2002-11-08 | 51d? |  | G2 | 2856h | 2856h | AGbEnFS-FS |  |  | Rel-6 | Gert |  |
| 1337 | 25.1.1 | Requirements for the support of conversational services | 51d | 2002-08-30 A | 2002-11-08 A | 100% | 2002-08-30 | 2002-11-08 | 51d | finish no earlier than 2002-11-08 | GP | 408h | 408h |  |  |  | Rel-6 | Paolo |  |
| 1338 | 406.1.2 | Identification of the different building blocks for the provision of conversational services on the existing A/Gb protocol stack | 51d? | 2002-08-30 A | 2002-11-08 A | 100% | 2002-08-30 | 2002-11-08 | 51d? | finish no earlier than 2002-11-08 | GP | 408h | 408h |  |  |  | Rel-6 | Paolo |  |
| 1339 | 406.1.3 | Outline of impact and feasibility of these building blocks and their different solutions | 51d? | 2002-08-30 A | 2002-11-08 A | 100% | 2002-08-30 | 2002-11-08 | 51d? | finish no earlier than 2002-11-08 | GP | 408h | 408h |  |  |  | Rel-6 | Paolo |  |
| 1340 | 25.1.4 | Impact on 3GPP architecture and requirement to co-ordinatge with other TSGs (CN, SA) | 51d | 2002-08-30 A | 2002-11-08 A | 100% | 2002-08-30 | 2002-11-08 | 51d | finish no earlier than 2002-11-08 | GP | 408h | 408h |  |  |  | Rel-6 | Paolo |  |
| 1341 | 25.1.5 | Standardisation effort | 51d | 2002-08-30 A | 2002-11-08 A | 100% | 2002-08-30 | 2002-11-08 | 51d | finish no earlier than 2002-11-08 | GP | 408h | 408h |  |  |  | Rel-6 | Paolo |  |
| 1342 | 25.1.6 | Dependency to other features | 51d | 2002-08-30 A | 2002-11-08 A | 100% | 2002-08-30 | 2002-11-08 | 51d | finish no earlier than 2002-11-08 | GP | 408h | 408h |  |  |  | Rel-6 | Paolo |  |
| 1343 | 26 | **Flexible Layer One for GERAN** | 1171d | 2000-01-03 A | 2004-06-25 A | 100% | 2000-01-03 | 2004-06-25 | 1171d |  | GP | 71551h | 71551h | FLOGER | Nokia | benoist.sebire@nokia.com | Rel-6 | Paolo |  |
| 1344 | 26.1 | **Realisation of a Flexible Layer One** | 1126d | 2000-01-03 A | 2004-04-23 A | 100% | 2000-01-03 | 2004-04-23 | 1126d |  | GP | 42816h | 42816h | FLOGER-Real | Nokia | benoist.sebire@nokia.com | Rel-6 | Paolo |  |
| 1345 | 26.1.1 | Technical Report | 471d | 2002-04-19 A | 2004-02-06 A | 100% | 2002-04-19 | 2004-02-06 | 471d | finish no earlier than 2004-02-06 | GP | 3768h | 3768h |  |  |  | Rel-6 | Paolo |  |
| 1346 | 26.1.2 | Architecture in 45.001 and 43.051 | 526d | 2002-04-19 A | 2004-04-23 A | 100% | 2002-04-19 | 2004-04-23 | 526d | finish no earlier than 2004-04-23 | G1 | 4208h | 4208h |  |  |  | Rel-6 |  |  |
| 1347 | 26.1.3 | Multiplexing in 45.002 | 526d | 2002-04-19 A | 2004-04-23 A | 100% | 2002-04-19 | 2004-04-23 | 526d | finish no earlier than 2004-04-23 | G1 | 4208h | 4208h |  |  |  | Rel-6 |  |  |
| 1348 | 26.1.4 | Channel Coding in 45.003 | 526d | 2002-04-19 A | 2004-04-23 A | 100% | 2002-04-19 | 2004-04-23 | 526d | finish no earlier than 2004-04-23 | G1 | 4208h | 4208h |  |  |  | Rel-6 |  |  |
| 1349 | 26.1.5 | Performance Requirements in 45.005 | 1126d | 2000-01-03 A | 2004-04-23 A | 100% | 2000-01-03 | 2004-04-23 | 1126d | finish no earlier than 2004-04-23 | G1 | 9000h | 9000h |  |  |  | Rel-6 |  |  |
| 1350 | 26.1.6 | Radio subsystem link control in 45.008 | 526d | 2002-04-19 A | 2004-04-23 A | 100% | 2002-04-19 | 2004-04-23 | 526d | finish no earlier than 2004-04-23 | G1 | 4208h | 4208h |  |  |  | Rel-6 |  |  |
| 1351 | 26.1.7 | Requirements in 44.004 | 526d | 2002-04-19 A | 2004-04-23 A | 100% | 2002-04-19 | 2004-04-23 | 526d | finish no earlier than 2004-04-23 | G2 | 4208h | 4208h |  |  |  | Rel-6 | Gert |  |

Notes:
- 1327: merged "Presence Service Enhancements" (UID31028, PRES1) to this feature as no answer was provided on why Presence and Presence Encmts had same target completion date
- 1328: -
- 1329: -
- 1330: Dependency to 2 IETF drafts, no known work at the moment
- 1331: No Contributions so far - only requires a little work
- 1332: -
- 1333: LSs handled in SA3. WID approved SP#17 Contribution at S3#25 & following e-mail discussion. Marked as closed 12/2008 (was marked 90% complete)
- 1334: Updated according to SP-040232
- 1335: -
- 1336: -
- 1337: -
- 1338: -
- 1339: -
- 1340: -
- 1341: -
- 1342: -
- 1343: -
- 1344: -
- 1345: -
- 1346: -
- 1347: -
- 1348: -
- 1349: -
- 1350: -
- 1351: -

| ID | WBS | Task | Type | Duration | Start | Finish | Complete | Baseline start | Baseline finish | Baseline duration | Constraint | Resources | Work | Actual work | Text1 | Text4 | Text5 | Text6 | Text8 | Text12 | Text3 |
| --- | --- | --- | --- | --- | --- | --- | --- | --- | --- | --- | --- | --- | --- | --- | --- | --- | --- | --- | --- | --- | --- |
| 1352 | 26.2 | **Signalling and protocol support for a Flexible Layer One** |  | 571d | 2002-04-19 A | 2004-06-25 A | 100% | 2002-04-19 | 2004-06-25 | 571d |  | G2 | 13704h | 13704h | FLOGER-SigPro | Nokia | benoist.sebire@nokia.com | Rel-6 | Gert |  |  |
| 1353 | 26.2.1 | Modifications to RLC/MAC in 44.060 and 44.160 |  | 571d | 2002-04-19 A | 2004-06-25 A | 100% | 2002-04-19 | 2004-06-25 | 571d | finish no earlier than 2004-06-25 | G2 | 4568h | 4568h |  |  |  | Rel-6 | Gert |  |  |
| 1354 | 26.2.2 | Modifications to RRC in 44.118 and 44.018 |  | 571d | 2002-04-19 A | 2004-06-25 A | 100% | 2002-04-19 | 2004-06-25 | 571d | finish no earlier than 2004-06-25 | G2 | 4568h | 4568h |  |  |  | Rel-6 | Gert |  |  |
| 1355 | 26.3 | **Security for a Flexible Layer One** |  | 356d | 2002-04-19 A | 2003-08-29 A | 100% | 2002-04-19 | 2003-08-29 | 356d |  | S3, G2 | 5663.03h | 5663.03h | FLOGER-SecFLO | Nokia | benoist.sebire@nokia.com | Rel-6 | Dionisio |  |  |
| 1356 | 26.3.1 | Ciphering in 44.160,44.118, 44.060 and 44.018 |  | 356d | 2002-04-19 A | 2003-08-29 A | 100% | 2002-04-19 | 2003-08-29 | 356d | finish no earlier than 2003-08-29 | S3, G2 | 2848h | 2848h |  |  |  | Rel-6 | Dionisio |  |  |
| 1357 | 26.4 | **Deleted at TSG#27 - GERAN MS Conformance test for the Flexible Layer One - DELETE** |  | 0d | 2004-02-06 A | 2004-02-06 A | 100% | 2004-02-06 | 2004-02-06 | 0d |  | G4,G5 |  |  | FLOGER-Msconf | Nokia | benoist.sebire@nokia.com | Rel-6 | Paolo | GP-22 |  |
| 1358 | 26.4.1 | Deleted at TSG #27 - MS Test in 51.010 | milestone | 0d | 2004-02-06 A | 2004-02-06 A | 100% | 2004-02-06 | 2004-02-06 | 0d | finish no earlier than 2004-02-06 | G4,G5 |  |  |  |  |  | Rel-6 | Paolo | GP-22 |  |
| 1359 | 26.5 | **Deleted at TSG#27 - GERAN BTS Conformance test for the Flexible Layer One - DELETE** |  | 0d | 2004-02-06 A | 2004-02-06 A | 100% | 2004-02-06 | 2004-02-06 | 0d |  | G3new |  |  | FLOGER-BTSconf | Nokia | benoist.sebire@nokia.com | Rel-6 | Ingbert | GP-22 |  |
| 1360 | 26.5.1 | Deleted at TGS #27 - BTS Test in 51.021 - DELETE | milestone | 0d | 2004-02-06 A | 2004-02-06 A | 100% | 2004-02-06 | 2004-02-06 | 0d | finish no earlier than 2004-02-06 | G3new |  |  |  |  |  | Rel-6 | Ingbert | GP-22 |  |
| 1361 | 27 | Uplink TDOA feasibility study |  | 151d | 2001-11-30 A | 2002-06-28 A | 100% | 2001-11-30 | 2002-06-28 | 151d | finish no earlier than 2002-06-28 | GP | 1208h | 1208h | TDOAF | TruePosition | Bob Gross (rlgross@trueposition.com) | Rel-6 | Paolo |  | 45.811 |
| 1362 | 28 | **Multimedia Broadcast and Multicast Service** |  | 1781d? | 2001-05-11 A | 2008-03-07 A | 100% | 2001-05-11 | 2008-03-07 | 1781d? |  | S1,S2,S4,S5,T1,RP,GP | 158712h | 158712h | MBMS |  |  | Rel-6 | Alain |  |  |
| 1363 | 28.1 | Stage 1 |  | 232d | 2001-05-11 A | 2002-04-01 A | 100% | 2001-05-11 | 2002-04-01 | 232d | finish no earlier than 2002-04-01 | S1 | 1856h | 1856h | MBMS |  |  | Rel-6 | Alain |  | 22.146, 22.101 |
| 1364 | 28.2 | **Stage 2** |  | 648d | 2001-09-24 A | 2004-03-17 A | 100% | 2001-09-24 | 2004-03-17 | 648d |  | S2 | 10408h | 10408h | MBMS |  |  | Rel-6 | Maurice |  |  |
| 1365 | 28.2.1 | TR on Architectural Study |  | 240d | 2001-09-24 A | 2002-08-23 A | 100% | 2001-09-24 | 2002-08-23 | 240d | finish no earlier than 2002-08-23 | S2 | 1920h | 1920h | MBMS |  |  | Rel-6 | Maurice |  | 23.846 |
| 1366 | 28.2.2 | Stage 2 Specification Work |  | 413d | 2002-08-19 A | 2004-03-17 A | 100% | 2002-08-19 | 2004-03-17 | 413d | finish no earlier than 2004-03-17 | S2 | 3304h | 3304h | MBMS |  |  | Rel-6 | Maurice |  | 23.246 |
| 1367 | 28.3 | **Introduction of MBMS in RAN** |  | 967d? | 2002-01-01 A | 2005-09-14 A | 100% | 2002-01-01 | 2005-09-14 | 967d? |  | R2 | 15992h | 15992h | MBMS-RAN | Nokia | juho.pirskanen@nokia.com | Rel-6 | Joern |  | 25.346, 25.304, 25.321, 25.322, 25.323, 25.331 |
| 1368 | 409.3.1 | Introduction of MBMS in RAN (physical & upper layers, access network interfaces) |  | 771d? | 2002-01-01 A | 2004-12-14 A | 100% | 2002-01-01 | 2004-12-14 | 771d? | finish no earlier than 2004-12-14 | R2 | 6168h | 6168h | MBMS-RAN | Nokia | juho.pirskanen@nokia.com | Rel-6 | Joern |  | 25.346, 25.304, 25.321, 25.322, 25.323 |
| 1369 | 409.3.2 | UE Performance Requirements for MBMS |  | 261d? | 2004-09-15 A | 2005-09-14 A | 100% | 2004-09-15 | 2005-09-14 | 261d? | finish no earlier than 2005-09-15 | R4 | 2088h | 2088h | MBMS-RAN-RF | Ericsson | Torgny.Palenius@ericsson.com | Rel-6 | Stefania |  | 25.101, 25.133 |
| 1370 | 28.4 | Support of the MBMS in CN protocols |  | 647d | 2002-06-18 A | 2004-12-08 A | 100% | 2002-06-18 | 2004-12-08 | 647d | finish no earlier than 2004-12-08 | N1 | 5176h | 5176h | MBMS |  |  | Rel-6 | Frederic |  |  |
| 1371 | 409.5 | Gmb interface for MBMS (CN3 part) |  | 334d | 2003-08-29 A | 2004-12-08 A | 100% | 2003-08-29 | 2004-12-08 | 334d | finish no earlier than 2004-12-08 | N3 | 2672h | 2672h | MBMS |  |  | Rel-6 | Gwiho |  | 29.061 |
| 1372 | 28.5 | Security Aspects of MBMS |  | 710d | 2002-07-01 A | 2005-03-18 A | 100% | 2002-07-01 | 2005-03-18 | 710d | finish no earlier than 2005-03-18 | S3 | 5680h | 5680h | MBMS |  | adrian.escott@three.co.uk | Rel-6 | Dionisio |  |  |
| 1373 | 28.6 | **Support of MBMS in GERAN** |  | 892d? | 2001-08-30 A | 2005-01-28 A | 100% | 2001-08-30 | 2005-01-28 | 892d? |  | GP | 71040h | 71040h | MBMS-GERAN |  |  | Rel-6 | Paolo |  |  |
| 1374 | 28.6.1 | Impact on the logical and physical channels |  | 631d | 2002-08-30 A | 2005-01-28 A | 100% | 2002-08-30 | 2005-01-28 | 631d | finish no earlier than 2005-01-28 | GP | 5048h | 5048h | MBMS-GERAN |  |  | Rel-6 | Paolo |  |  |
| 1375 | 28.6.4 | Re-synchronisation at cell change |  | 631d | 2002-08-30 A | 2005-01-28 A | 100% | 2002-08-30 | 2005-01-28 | 631d | finish no earlier than 2005-01-28 | G2 | 5048h | 5048h | MBMS-GERAN |  |  | Rel-6 | Gert |  |  |
| 1376 | 409.7.3 | Simultaneous support of MBMS services |  | 631d? | 2002-08-30 A | 2005-01-28 A | 100% | 2002-08-30 | 2005-01-28 | 631d? | finish no earlier than 2005-01-28 | GP | 5048h | 5048h | MBMS-GERAN |  |  | Rel-6 | Paolo |  |  |
| 1377 | 409.7.4 | Simultaneous support of MBMS and non-MBMS services |  | 892d? | 2001-08-30 A | 2005-01-28 A | 100% | 2001-08-30 | 2005-01-28 | 892d? | finish no earlier than 2005-01-28 | GP | 7136h | 7136h | MBMS-GERAN |  |  | Rel-6 | Paolo |  |  |
| 1378 | 409.7.5 | Resynchronisation at cell change |  | 892d? | 2001-08-30 A | 2005-01-28 A | 100% | 2001-08-30 | 2005-01-28 | 892d? | finish no earlier than 2005-01-28 | GP | 7136h | 7136h | MBMS-GERAN |  |  | Rel-6 | Paolo |  |  |
| 1379 | 28.6.5 | Decision making process between point-to-point or pont-to-multipoint configurations |  | 631d | 2002-08-30 A | 2005-01-28 A | 100% | 2002-08-30 | 2005-01-28 | 631d | finish no earlier than 2005-01-28 | GP | 5048h | 5048h | MBMS-GERAN |  |  | Rel-6 | Paolo |  |  |
| 1380 | 28.6.6 | MBMS channel allocations procedures to multiple MSs |  | 631d | 2002-08-30 A | 2005-01-28 A | 100% | 2002-08-30 | 2005-01-28 | 631d | finish no earlier than 2005-01-28 | GP | 5048h | 5048h | MBMS-GERAN |  |  | Rel-6 | Paolo |  |  |
| 1381 | 28.6.7 | Changes to the Gb interface |  | 631d | 2002-08-30 A | 2005-01-28 A | 100% | 2002-08-30 | 2005-01-28 | 631d | finish no earlier than 2005-01-28 | GP | 5048h | 5048h | MBMS-GERAN |  |  | Rel-6 | Paolo |  |  |
| 1382 | 28.6.8 | GERAN specific changes to the Iu-ps interface |  | 631d | 2002-08-30 A | 2005-01-28 A | 100% | 2002-08-30 | 2005-01-28 | 631d | finish no earlier than 2005-01-28 | GP | 5048h | 5048h | MBMS-GERAN |  |  | Rel-6 | Paolo |  |  |
| 1383 | 28.6.9 | Interaction between MBMS and Iu-flex |  | 631d | 2002-08-30 A | 2005-01-28 A | 100% | 2002-08-30 | 2005-01-28 | 631d | finish no earlier than 2005-01-28 | GP | 5048h | 5048h | MBMS-GERAN |  |  | Rel-6 | Paolo |  |  |
| 1384 | 28.6.10 | Security aspects |  | 631d | 2002-08-30 A | 2005-01-28 A | 100% | 2002-08-30 | 2005-01-28 | 631d | finish no earlier than 2005-01-28 | GP | 5048h | 5048h | MBMS-GERAN |  |  | Rel-6 | Paolo |  |  |
| 1385 | 409.7.12 | MBMS-GERAN - MS conformance tests |  | 786d? | 2002-01-25 A | 2005-01-28 A | 100% | 2002-01-25 | 2005-01-28 | 786d? | finish no earlier than 2005-01-28 | G3new | 6288h | 6288h | MBMS-GERAN |  |  | Rel-6 | Ingbert |  |  |
| 1386 | 409.7.13 | Deleted - MS conformance tests - G5 | milestone | 0d? | 2003-06-27 A | 2003-06-27 A | 100% | 2003-06-27 | 2003-06-27 | 0d? | start no earlier than 2003-06-27 | G5 |  |  | MBMS-GERAN |  |  | Rel-6 | Paolo | GP-19 |  |

Notes:
- 1352: -
- 1353: -
- 1354: -
- 1355: -
- 1356: -
- 1357: -
- 1358: -
- 1359: -
- 1360: -
- 1361: -
- 1362: Title renamed at SP#13
- 1363: This may or may not be a separate stage 1. In the meantime, CRs are proposed for 22.101
- 1364: -
- 1365: -
- 1366: -
- 1367: -
- 1368: Was "Introduction of MBMS in RAN" before RP#25. Created w/o WIDS after RAN approved the WT for RF aspects.Take WIDS from the parent BB
- 1369: Approved at RP#25 as RP-040370
- 1370: -
- 1371: -
- 1372: WID approved SP#17. 2004-12: Expected completion March 2005
- 1373: -
- 1374: -
- 1375: -
- 1376: -
- 1377: -
- 1378: -
- 1379: -
- 1380: -
- 1381: -
- 1382: -
- 1383: -
- 1384: -
- 1385: -
- 1386: -

| ID | WBS | Task | Type | Duration | Start | Finish | Complete | Baseline start | Baseline finish | Baseline duration | Constraint | Deadline | Resources | Work | Actual work | Text1 | Text6 | Text8 | Text4 | Text5 | Text10 | Text12 |
| --- | --- | --- | --- | --- | --- | --- | --- | --- | --- | --- | --- | --- | --- | --- | --- | --- | --- | --- | --- | --- | --- | --- |
| 1387 | 28.1 | **MBMS User Services** |  | 743d? | 2003-05-13 A | 2006-03-16 A | 100% | 2003-05-13 | 2006-03-16 | 743d? |  |  | S1 | 13576h | 13576h | MBMS | Rel-6 | Alain |  |  |  |  |
| 1388 | 28.1 | MBMS User Services Stage 1 |  | 233d | 2003-05-13 A | 2004-04-01 A | 100% | 2003-05-13 | 2004-04-01 | 233d | start no earlier than 2003-05-13 |  | S1 | 1864h | 1864h | MBMS | Rel-6 | Alain |  |  |  |  |
| 1389 | 409.8.2 | Definition of MBMS user services, media codecs, formats and transport/application protocols using MBMS |  | 721d? | 2003-06-12 A | 2006-03-16 A | 100% | 2003-06-12 | 2006-03-16 | 721d? | finish no earlier than 2006-03-16 |  | S4 | 5768h | 5768h | MBMS-TSMBMS | Rel-6 | Paolo | Nokia | igor.curcio@nokia.com |  |  |
| 1390 | 409.9 | MBMS charging |  | 108d? | 2005-01-11 A | 2005-06-09 A | 100% | 2005-01-11 | 2005-06-09 | 108d? | start no earlier than 2005-01-11 |  | S5 | 864h | 864h | MBMS-CH | Rel-6 | Dionisio |  |  |  |  |
| 1391 | 409.10 | **MBMS UE Conformance Testing** |  | 521d? | 2006-03-10 A | 2008-03-07 A | 100% | 2006-03-10 | 2008-03-07 | 521d? |  |  | R5,T1 | 17200h | 17200h | MBMS-UEConTest | Rel-6 | Ingbert |  |  |  |  |
| 1392 | 16.5.1 | RF/RRM Conformance Test Aspects – MBMS (FDD) |  | 461d | 2006-06-02 A | 2008-03-07 A | 100% | 2006-06-02 | 2008-03-07 | 461d | finish no earlier than 2008-03-07 | 2006-06-02 | R5,T1 | 3688h | 3688h | MBMS-RAN-RF_Test | Rel-6 | Ingbert | Ericsson | leif.mattisson@ericsson.com | Fri 11/03/05 |  |
| 1393 | 409.10.2 | Conformance Test Aspects - MBMS for 3.84 Mcps and 7.68 Mcps TDD |  | 318d? | 2006-09-20 A | 2007-12-07 A | 100% | 2006-09-20 | 2007-12-07 | 318d? | finish no earlier than 2007-12-07 |  | R5,T1 | 2544h | 2544h | MBMS-UEConTest_TDH | Rel-6 | Ingbert | IPWireless | Timothy Speight (tspeight@ipwireless.com) |  |  |
| 1394 | 409.10.3 | Signalling Conformance Test Aspects – MBMS for LCR TDD |  | 318d? | 2006-09-20 A | 2007-12-07 A | 100% | 2006-09-20 | 2007-12-07 | 318d? | finish no earlier than 2007-12-07 |  | R5,T1 | 2544h | 2544h | MBMS-UEConTest_SIGTDL | Rel-6 | Ingbert | DATANG | zhaojian@datangmobile.cn |  |  |
| 1395 | 409.10.4 | Conformance Test Aspects – MBMS |  | 396d? | 2006-03-10 A | 2007-09-14 A | 100% | 2006-03-10 | 2007-09-14 | 396d? | finish no earlier than 2007-09-14 |  | R5,T1 | 3168h | 3168h | MBMS_Test | Rel-6 | Ingbert | Qualcomm Europe | Shubhang Vora (svora@qualcomm.com) |  |  |
| 1396 | 16.5.1 | Conformance Test Aspects - 1.28 Mcps TDD MBMS RF/RRM |  | 136d | 2007-06-01 A | 2007-12-07 A | 100% | 2007-06-01 | 2007-12-07 | 136d | finish no earlier than 2007-12-07 | 2006-06-02 | R5,T1 | 1088h | 1088h | MBMS-UEConTest_RFTDL | Rel-6 | Ingbert | Datang Mobile | chenxiaozhong@datangmobile.cn | Fri 11/03/05 |  |
| 1397 | 29 | **Speech Recognition and Speech Enabled Services** |  | 1105d? | 2001-10-08 A | 2005-12-30 A | 100% | 2001-10-08 | 2005-12-30 | 1105d? |  |  | S1 | 20176h | 20176h | SRSES | Rel-6 | Alain |  |  |  |  |
| 1398 | 29.1 | Speech Enabled Services Based on Distributed Speech Recognition (DSR) |  | 115d | 2001-10-08 A | 2002-03-15 A | 100% | 2001-10-08 | 2002-03-15 | 115d | finish no earlier than 2002-03-15 |  | S1 | 920h | 920h | DSR | Rel-6 | Alain | Qualcomm Europe | Dwilliams@qualcomm.com |  |  |
| 1399 | 29.2 | TR on Architectural impacts |  | 212d | 2003-05-12 A | 2004-03-02 A | 100% | 2003-05-12 | 2004-03-02 | 212d | finish no earlier than 2004-03-02 |  | S2 | 1696h | 1696h |  | Rel-6 |  |  |  |  |  |
| 1400 | 410.3 | Codec Work to Support Speech Recognition Framework for Automated Voice Services |  | 568d? | 2002-10-15 A | 2004-12-16 A | 100% | 2002-10-15 | 2004-12-16 | 568d? | finish no earlier than 2004-12-16 |  | S4 | 4544h | 4544h | SRSES-Codec | Rel-6 | Paolo | Motorola | David Pearce (bdp003@motorola.com) |  |  |
| 1401 | 410.4 | Multimodal support |  | 522d? | 2004-01-01 A | 2005-12-30 A | 100% | 2004-01-01 | 2005-12-30 | 522d? | finish no earlier than 2005-06-30 |  | OMA | 4176h | 4176h |  | Rel-6 |  |  | OMA-LIAISON@mail.openmobilealliance.org | SP-24 |  |
| 1402 | 410.5 | Deleted - SES codec negotiation at SDP | milestone | 0d? | 2003-06-04 A | 2003-06-04 A | 100% | 2003-06-04 | 2003-06-04 | 0d? | start no earlier than 2003-06-04 |  | N1 |  |  |  | Rel-6 | Frederic |  |  |  | NP-23 |
| 1403 | 30 | **Generic User Profile Rel-6** |  | 889d | 2001-10-08 A | 2005-03-03 A | 100% | 2001-10-08 | 2005-03-03 | 889d |  |  | S1 | 24295.8h | 24295.8h | GUP | Rel-6 | Alain |  |  |  |  |
| 1404 | 30.1 | Stage 1 - Requirements |  | 430d | 2001-10-08 A | 2003-05-30 A | 100% | 2001-10-08 | 2003-05-30 | 430d | finish no earlier than 2002-12-09 |  | S1 | 3440h | 3440h |  | Rel-6 | Alain | T-Mobile | kurt.bischinger@t-mobile.at |  |  |
| 1405 | 30.3 | Stage 2 - Architecture |  | 355d | 2002-01-28 A | 2003-06-06 A | 100% | 2002-01-28 | 2003-06-06 | 355d | finish no earlier than 2003-06-06 |  | S2 | 2840h | 2840h |  | Rel-6 | Maurice | Nokia | harri.o.koskinen@nokia.com |  |  |
| 1406 | 30.2 | Stage 2 - Data Description Method |  | 586d | 2002-12-05 A | 2005-03-03 A | 100% | 2002-12-05 | 2005-03-03 | 586d | finish no earlier than 2005-03-03 |  | N4 | 4688h | 4688h |  | Rel-6 | Kimmo | T-Mobile | kurt.bischinger@t-mobile.at |  |  |
| 1407 | 30.5 | Stage 3 - Network |  | 468.98d | 2003-05-19 A | 2005-03-03 A | 100% | 2003-05-19 | 2005-03-03 | 468.98d | finish no earlier than 2005-03-03 |  | N4 | 3751.83h | 3751.83h |  | Rel-6 | Kimmo |  |  |  |  |
| 1408 | 30.6 | Security Aspects |  | 308d | 2002-07-16 A | 2003-09-18 A | 100% | 2002-07-16 | 2003-09-18 | 308d | finish no earlier than 2003-09-18 |  | S3 | 2464h | 2464h |  | Rel-6 | Dionisio | Lucent | Owen, Bradley (bvowen@lucent.com) |  |  |
| 1409 | 31 | **Digital Rights Management** |  | 690d? | 2001-10-08 A | 2004-05-28 A | 100% | 2001-10-08 | 2004-05-28 | 690d? |  |  | S1 | 10152h | 10152h | DRM | Rel-6 | Alain |  |  |  |  |
| 1410 | 31.1 | Requirements |  | 179d | 2001-10-08 A | 2002-06-13 A | 100% | 2001-10-08 | 2002-06-13 | 179d | finish no earlier than 2002-06-13 |  | S1 | 1432h | 1432h |  | Rel-6 | Alain | Openwave | nicholas.wood@openwave.com |  |  |
| 1411 | 412.2 | Stage 2 |  | 107d? | 2004-01-01 A | 2004-05-28 A | 100% | 2004-01-01 | 2004-05-28 | 107d? | finish no earlier than 2004-05-28 |  | OMA | 856h | 856h |  | Rel-6 |  |  | OMA-LIAISON@mail.openmobilealliance.org | SP-24 |  |
| 1412 | 412.3 | Stage 3 |  | 107d? | 2004-01-01 A | 2004-05-28 A | 100% | 2004-01-01 | 2004-05-28 | 107d? | finish no earlier than 2004-05-28 |  | OMA | 856h | 856h |  | Rel-6 |  |  | OMA-LIAISON@mail.openmobilealliance.org | SP-24 |  |
| 1413 | 31.3 | Security |  | 186d | 2002-06-17 A | 2003-03-03 A | 100% | 2002-06-17 | 2003-03-03 | 186d | finish no earlier than 2003-03-03 |  | OMA | 1488h | 1488h |  | Rel-6 |  |  |  |  |  |
| 1414 | 412.5 | Deleted - Monitoring of Stages 2 and 3 progress (actual work to be done by OMA) | milestone | 0d? | 2003-03-21 A | 2003-03-21 A | 100% | 2003-03-21 | 2003-03-21 | 0d? | start no earlier than 2002-08-19 |  | S1 |  |  |  | Rel-6 | Alain |  |  |  | SP-19 |

Notes:
- 1387: - / Text3: 22.246
- 1388: - / Text3: 22.246
- 1389: TR26.946 tbc by March 06 / Text3: 26.346, 26.936, 26.946
- 1390: SP#28 06/2005 completed / Text3: 32.273
- 1391: BB place holder for a number of RAN5 Tasks. Moved in from the Stoyan/Testing WP / Text3: 34.108, 34.109, 34.121-1, 34.121-2, 34.122, 34.123-1, 34.123-2, 34.123-3
- 1392: TS 34.109 is under RAN2; RAN5 need to identify possible new requirements on UE test loop functionality to enable testing / Text3: 34.108, 34.109, 34.121-1, 34.121-2
- 1393: - / Text3: 34.108, 34.122, 34.123-1, 34.123-2, 34.123-3
- 1394: - / Text3: 34.108, 34.123-1, 34.123-2, 34.123-3
- 1395: - / Text3: 34.108, 34.123-1, 34.123-2, 34.123-3
- 1396: - / Text3: 34.108, 34.109, 34.122
- 1397: -
- 1398: - / Text3: 22.941, 23.207, 22.243
- 1399: - / Text3: 23.877
- 1400: - / Text3: 26.235, 26.236, 26.243, 26.177, 26.943
- 1401: -
- 1402: Abandoned NP-23
- 1403: -
- 1404: - / Text3: 22.240, 22.228
- 1405: - / Text3: 23.240
- 1406: TR approved in CN#26 / Text3: 23.241
- 1407: 17 May no activity in CN4............ / Text3: 29.240
- 1408: WID approved SP#17. SA WG3 progress slow, depends on progress in other groups. / Text3: 33.102, 33.203, 33.210
- 1409: Foreseen start and completion dates introduced by MCC (no indication at all on the WID)
- 1410: -
- 1411: -
- 1412: -
- 1413: SA3 acknowledge role in WI at SA3#20. Active contribution S3#24, S3#25. S3 WID approved SP#17
- 1414: Replaced by UID 60005 and 60006

| ID | WBS | Task | Duration | Start | Finish | Complete | Baseline start | Baseline finish | Baseline duration | Constraint | Resources | Work | Actual work | Text1 | Text4 | Text5 | Text6 | Text8 | Text3 | Text10 |
| --- | --- | --- | --- | --- | --- | --- | --- | --- | --- | --- | --- | --- | --- | --- | --- | --- | --- | --- | --- | --- |
| 1415 | 32 | **WLAN-UMTS Interworking Rel-6** | 1495d? | 2000-01-03 A | 2005-09-22 A | 100% | 2000-01-03 | 2005-09-22 | 1495d? |  | S1 | 48472h | 48472h | WLAN | Telenor | frederic.paint@telenor.com | Rel-6 | Alain |  |  |
| 1416 | 32.1 | Technical Report | 901d? | 2000-01-03 A | 2003-06-13 A | 100% | 2000-01-03 | 2003-06-13 | 901d? | finish no earlier than 2003-06-13 | S1 | 7200h | 7200h | WLAN-TR | Telenor | frederic.paint@telenor.com | Rel-6 | Alain | 22.934, 22.101, 22.105 |  |
| 1417 | 413.2 | **Stage 1** | 375d? | 2003-01-06 A | 2004-06-11 A | 100% | 2003-01-06 | 2004-06-11 | 375d? |  | S1 | 3920h | 3920h | WLAN-TS | Telenor | frederic.paint@telenor.com | Rel-6 | Alain | 22.234 | SP-24 |
| 1418 | 413.2.1 | Global stage 1 | 375d? | 2003-01-06 A | 2004-06-11 A | 100% | 2003-01-06 | 2004-06-11 | 375d? | finish no earlier than 2004-06-11 | S1 | 3000h | 3000h | WLAN-TS | Telenor | frederic.paint@telenor.com | Rel-6 | Alain | 22.234 | SP-24 |
| 1419 | 32.2 | Architecture Definition for scenarii 2 and 3 | 571d | 2002-03-25 A | 2004-05-31 A | 100% | 2002-03-25 | 2004-05-31 | 571d | finish no earlier than 2004-05-31 | S2 | 4568h | 4568h |  |  |  | Rel-6 | Maurice | 23.234 |  |
| 1420 | 32.3 | Security | 125d | 2002-09-30 A | 2003-03-21 A | 100% | 2002-09-30 | 2003-03-21 | 125d | finish no earlier than 2003-03-21 | S3 | 1000h | 1000h |  | Ericsson | luis.lopez-soria@ece.ericsson.se | Rel-6 | Dionisio | 21.133, 33.106, 33.107, 33.108, 33.200, 33.203, 33.210 |  |
| 1421 | 413.5 | Stage 3 - CN4 aspects | 334d? | 2003-05-23 A | 2004-09-01 A | 100% | 2003-05-23 | 2004-09-01 | 334d? | finish no earlier than 2004-09-01 | N4 | 2672h | 2672h | WLAN-IW | Nokia | raquel.rodriguez@nokia.com | Rel-6 | Kimmo | 29.234, 29.061 |  |
| 1422 | 413.6 | Stage 3 - CN3 aspects (Wi Interface for Scenario 3) | 355d? | 2003-05-23 A | 2004-09-30 A | 100% | 2003-05-23 | 2004-09-30 | 355d? | start no earlier than 2003-05-23 | N3 | 2840h | 2840h | WLAN |  |  | Rel-6 | Gwiho | 29.161 | SP-24 |
| 1423 | 413.7 | Stage 3 for scenario 2 | 339d? | 2003-05-23 A | 2004-09-08 A | 100% | 2003-05-23 | 2004-09-08 | 339d? | finish no earlier than 2004-09-08 | N1 | 2712h | 2712h |  |  |  | Rel-6 | Frederic |  |  |
| 1424 | 413.8 | Stage 3 for scenario 3 | 404d? | 2003-05-23 A | 2004-12-08 A | 100% | 2003-05-23 | 2004-12-08 | 404d? | finish no earlier than 2004-12-08 | N1 | 3232h | 3232h |  |  |  | Rel-6 | Frederic |  | SP-24 |
| 1425 | 413.9 | WLAN charging | 655d? | 2003-03-21 A | 2005-09-22 A | 100% | 2003-03-21 | 2005-09-22 | 655d? | finish no earlier than 2005-09-22 | S5 | 5240h | 5240h | WLAN-CH | Nokia | Benni ALEXANDER | Rel-6 | Dionisio | 32.252 |  |
| 1426 | 413.10 | USIM enhancements for WLAN Interworking | 391d? | 2003-09-05 A | 2005-03-04 A | 100% | 2003-09-05 | 2005-03-04 | 391d? | finish no earlier than 2005-03-04 | T3 | 3128h | 3128h |  | Axalto | Jabellan@axalto.com | Rel-6 |  |  |  |
| 1427 | 33 | **Priority Service** | 347d? | 2002-05-30 A | 2003-09-26 A | 100% | 2002-05-30 | 2003-09-26 | 347d? |  | S1 | 6464h | 6464h | NTShar |  |  | Rel-6 | Alain |  |  |
| 1428 | 33.1 | Feasibility Study | 1d | 2002-06-14 A | 2002-06-14 A | 100% | 2002-06-14 | 2002-06-14 | 1d | finish no earlier than 2002-06-14 | S1 | 8h | 8h | PRIOR-FS | Telcordia | Biplab K. Pramanik (bpramani@telcordia.com) | Rel-6 | Alain | 22.950 |  |
| 1429 | 33.2 | Stage 1 - Requirements | 340d | 2002-05-30 A | 2003-09-17 A | 100% | 2002-05-30 | 2003-09-17 | 340d | finish no earlier than 2003-09-17 | S1 | 2720h | 2720h | PRIOR-SR | Telcordia | James J. Garrahan (bpramani@telcordia.com) | Rel-6 | Alain |  |  |
| 1430 | 414.3 | Priority service implementation guide | 131d? | 2003-03-28 A | 2003-09-26 A | 100% | 2003-03-28 | 2003-09-26 | 131d? | finish no earlier than 2003-09-26 | S1 | 1048h | 1048h |  | Telcordia | Biplab K. Pramanik (bpramani@telcordia.com) | Rel-6 | Alain | 22.952 |  |
| 1431 | 34 | **Network Sharing** | 498d? | 2003-01-20 A | 2004-12-15 A | 100% | 2003-01-20 | 2004-12-15 | 498d? |  | S1 | 16608h | 16608h | NTShar |  |  | Rel-6 | Alain |  |  |
| 1432 | 34.1 | Technical Report | 240d? | 2003-01-20 A | 2003-12-19 A | 100% | 2003-01-20 | 2003-12-19 | 240d? |  | S1 | 1920h | 1920h | NTShar-TR |  |  | Rel-6 | Alain | 22.951 |  |
| 1433 | 415.2 | Stage 1 - CRs to implement Network Sharing | 240d? | 2003-01-20 A | 2003-12-19 A | 100% | 2003-01-20 | 2003-12-19 | 240d? | finish no earlier than 2003-12-19 | S1 | 1920h | 1920h | NTShar-CR |  |  | Rel-6 | Alain | 22.011, 22.101, 22.115, 22.129 |  |
| 1434 | 415.3 | Stage 2 | 372d? | 2003-02-27 A | 2004-07-30 A | 100% | 2003-02-27 | 2004-07-30 | 372d? | finish no earlier than 2004-07-30 | S2 | 2976h | 2976h |  |  |  | Rel-6 | Maurice | 23.251 |  |
| 1435 | 415.4 | Network sharing - stage 3 | 404d? | 2003-05-23 A | 2004-12-08 A | 100% | 2003-05-23 | 2004-12-08 | 404d? | finish no earlier than 2004-12-08 | N1 | 3232h | 3232h |  |  |  | Rel-6 | Frederic |  |  |
| 1436 | 415.5 | Enhancement of the support of network sharing in the UTRAN | 324d | 2003-09-19 A | 2004-12-15 A | 100% | 2003-09-19 | 2004-12-15 | 324d | finish no earlier than 2004-12-15 | R2 | 2592h | 2592h | NTShar-UTRANEnh | TeliaSonera | Anders.Dahlen@TeliaSonera.com | Rel-6 | Joern | 25.401, 25.413, 25.331, 25.304 |  |
| 1437 | 35 | **QoS Improvements** | 628d? | 2002-07-15 A | 2004-12-08 A | 100% | 2002-07-15 | 2004-12-08 | 628d? |  | S2 | 13128h | 13128h | QoS1 | Nokia |  | Rel-6 | Maurice |  |  |
| 1438 | 35.1 | FS on Dynamic Policy control enhancements for end-to-end QoS | 465d | 2002-07-15 A | 2004-04-23 A | 100% | 2002-07-15 | 2004-04-23 | 465d | finish no earlier than 2004-04-23 | S2 | 3720h | 3720h | QoS1 | Nortel | Claire Mousset | Rel-6 | Maurice | 23.917 |  |
| 1439 | 416.2 | Definition of the Gq interface | 214d? | 2003-07-01 A | 2004-04-23 A | 100% | 2003-07-01 | 2004-04-23 | 214d? | finish no earlier than 2004-04-23 | S2 | 1712h | 1712h |  |  | Janne Rinne | Rel-6 |  | 23.221 |  |
| 1440 | 416.3 | Gq interface specification for Dynamic Policy control enhancements – Stage 3 | 334d | 2003-08-29 A | 2004-12-08 A | 100% | 2003-08-29 | 2004-12-08 | 334d | finish no earlier than 2004-12-08 | N3 | 2672h | 2672h |  | Nokia | Anna.Sillanpaai@nokia.com | Rel-6 | Gwiho | 24,228, 29.207, 29.208 |  |

Notes:
- 1415: -
- 1416: -
- 1417: -
- 1418: -
- 1419: -
- 1420: Active contribution S3#24, S3#25. WID approved SP#17
- 1421: WID approved at CN#19
- 1422: -
- 1423: -
- 1424: -
- 1425: SP#28: delayed 09/2005. WT also under SA5 BB 35017 Charging Management for Bearer level
- 1426: -
- 1427: -
- 1428: -
- 1429: -
- 1430: -
- 1431: -
- 1432: -
- 1433: -
- 1434: -
- 1435: -
- 1436: -
- 1437: -
- 1438: -
- 1439: -
- 1440: [DAB - 25.05.04] - Delayed to Sept - possibly Dec 2004

| ID | WBS | Task | Type | Duration | Start | Finish | Complete | Baseline start | Baseline finish | Baseline duration | Constraint | Resources | Work | Actual work | Text1 | Text4 | Text5 | Text6 | Text8 | Text10 | Text12 |
| --- | --- | --- | --- | --- | --- | --- | --- | --- | --- | --- | --- | --- | --- | --- | --- | --- | --- | --- | --- | --- | --- |
| 1441 | 36 | **Subscriber certificates** |  | 728d? | 2002-02-25 A | 2004-12-08 A | 100% | 2002-02-25 | 2004-12-08 | 728d? |  | S3 | 12888h | 12888h | SEC1-SC | Nokia | valtteri.niemi@nokia.com | Rel-6 | Maurice |  |  |
| 1442 | 36.1 | Stage 1 |  | 144d | 2002-02-25 A | 2002-09-12 A | 100% | 2002-02-25 | 2002-09-12 | 144d | finish no earlier than 2002-09-12 | S3 | 1152h | 1152h |  |  |  | Rel-6 | Dionisio |  |  |
| 1443 | 36.2 | Architecture review |  | 24d | 2002-10-14 A | 2002-11-14 A | 100% | 2002-10-14 | 2002-11-14 | 24d | finish no earlier than 2002-11-14 | S2 | 192h | 192h |  |  |  | Rel-6 | Maurice |  |  |
| 1444 | 417.3 | Stage 3 |  | 313d? | 2003-09-19 A | 2004-11-30 A | 100% | 2003-09-19 | 2004-11-30 | 313d? | finish no earlier than 2004-11-30 | N4 | 2504h | 2504h | SEC1-SC | Nokia | Lauri Laitinen | Rel-6 | Kimmo |  |  |
| 1445 | 417.4 | Stage 3 Ua & Ub interfaces |  | 288d? | 2003-11-03 A | 2004-12-08 A | 100% | 2003-11-03 | 2004-12-08 | 288d? | finish no earlier than 2004-12-08 | N1 | 2304h | 2304h |  |  |  | Rel-6 | Frederic |  |  |
| 1446 | 417.5 | OMA dependencies on Subscriber certificates |  | 114d? | 2004-01-01 A | 2004-06-08 A | 100% | 2004-01-01 | 2004-06-08 | 114d? | finish no earlier than 2004-06-08 | OMA | 912h | 912h |  |  | OMA-LIAISON@mail.openmobilealliance.org | Rel-6 |  | SP-24 |  |
| 1447 | 418 | **Rel-6 OSA enhancements** |  | 616d? | 2002-10-31 A | 2005-03-10 A | 100% | 2002-10-31 | 2005-03-10 | 616d? |  | N5 | 22576h | 22576h | OSA3 | Alcatel | Chelo.Abarca@alcatel.fr | Rel-6 | Kimmo |  |  |
| 1448 | 418.1 | Scope of the Open Service Access Release 6 |  | 66d? | 2003-03-28 A | 2003-06-27 A | 100% | 2003-03-28 | 2003-06-27 | 66d? | finish no earlier than 2003-06-27 | S1 | 528h | 528h |  |  |  | Rel-6 | Alain |  |  |
| 1449 | 418.2 | OSA Stage 2 |  | 150d? | 2004-08-13 A | 2005-03-10 A | 100% | 2004-08-13 | 2005-03-10 | 150d? | finish no earlier than 2005-03-10 | N5 | 1200h | 1200h |  |  |  | Rel-6 | Kimmo |  |  |
| 1450 | 418.3 | Multi Media Messaging function |  | 487d? | 2002-10-31 A | 2004-09-10 A | 100% | 2002-10-31 | 2004-09-10 | 487d? | finish no earlier than 2004-09-10 | N5 | 3896h | 3896h |  |  |  | Rel-6 | Kimmo |  |  |
| 1451 | 418.4 | Policy management extensions |  | 292d? | 2002-10-31 A | 2003-12-12 A | 100% | 2002-10-31 | 2003-12-12 | 292d? | finish no earlier than 2003-12-12 | N5 | 2336h | 2336h |  |  |  | Rel-6 | Kimmo |  |  |
| 1452 | 418.5 | TS on Presence and Availability Management (from the PRESNC WI) |  | 367d? | 2002-10-31 A | 2004-03-26 A | 100% | 2002-10-31 | 2004-03-26 | 367d? | finish no earlier than 2004-03-26 | N5 | 2936h | 2936h |  |  |  | Rel-6 | Kimmo |  |  |
| 1453 | 418.6 | OSA interfaces at different levels of abstractions (Parlay X, Web services) |  | 305d? | 2003-07-14 A | 2004-09-10 A | 100% | 2003-07-14 | 2004-09-10 | 305d? | finish no earlier than 2004-09-10 | N5 | 2440h | 2440h |  |  |  | Rel-6 | Kimmo |  |  |
| 1454 | 418.7 | Introduction of migration support mechanism |  | 290d? | 2002-10-31 A | 2003-12-10 A | 100% | 2002-10-31 | 2003-12-10 | 290d? | finish no earlier than 2003-12-12 | N5 | 2320h | 2320h |  |  |  | Rel-6 | Kimmo |  |  |
| 1455 | 418.8 | Framework Function for Federation |  | 225d? | 2003-02-03 A | 2003-12-12 A | 100% | 2003-02-03 | 2003-12-12 | 225d? | finish no earlier than 2003-12-12 | N5 | 1800h | 1800h |  |  |  | Rel-6 | Kimmo |  |  |
| 1456 | 418.9 | OMA potential overlaps with 3GPP OSA Stage 3 (Web services) |  | 196d? | 2003-12-18 A | 2004-09-16 A | 100% | 2003-12-18 | 2004-09-16 | 196d? | start no earlier than 2003-12-18 | OMA | 1568h | 1568h |  |  |  | Rel-6 |  | SP-24 |  |
| 1457 | 418.10 | Deleted - TR on Presence and Availability Management (from the PRESNC WI) | milestone | 0d? | 2004-09-17 A | 2004-09-17 A | 100% | 2004-09-17 | 2004-09-17 | 0d? | start no earlier than 2004-09-17 | N5 |  |  |  |  |  | Rel-6 | Kimmo |  | NP-24 |
| 1458 | 39 | **Addition of frequency bands to GSM (TAPS)** |  | 676d | 2002-06-28 A | 2005-01-28 A | 100% | 2002-06-28 | 2005-01-28 | 676d |  | GP | 16640h | 16640h | TAPS | Nokia | Torben Themsen | Rel-6 | Paolo |  |  |
| 1459 | 39.1 | **Addition of frequency bands to GSM – Changes to core specs** |  | 26d | 2002-11-15 A | 2002-12-20 A | 100% | 2002-11-15 | 2002-12-20 | 26d |  | G1 | 416h | 416h | TAPS-Specs | Nokia | Torben Themsen | Rel-6 |  |  |  |
| 1460 | 39.1.1 | Changes to core specs |  | 26d | 2002-11-15 A | 2002-12-20 A | 100% | 2002-11-15 | 2002-12-20 | 26d | finish no earlier than 2002-12-20 | G1 | 208h | 208h |  |  |  | Rel-6 |  |  |  |
| 1461 | 39.2 | **Deleted at TSG #27 - Addition of frequency bands to GSM – Changes for conformance tests** |  | 676d | 2002-06-28 A | 2005-01-28 A | 100% | 2002-06-28 | 2005-01-28 | 676d |  | G4 | 10816h | 10816h | TAPS-Conf | Nokia | Torben Themsen | Rel-6 | Paolo |  | GP-23 |
| 1462 | 39.2.1 | Deleted at TSG #27 - 51.010-1 Add testing |  | 676d | 2002-06-28 A | 2005-01-28 A | 100% | 2002-06-28 | 2005-01-28 | 676d | finish no earlier than 2005-01-28 | G4 | 5408h | 5408h |  |  |  | Rel-6 | Paolo |  | GP-23 |
| 1463 | 40 | **Seamless support of streaming services in A/Gb mode** |  | 1426d? | 2000-01-03 A | 2005-06-17 A | 100% | 2000-01-03 | 2005-06-17 | 1426d? |  | GP | 53096h | 53096h | SSStrea | Vodafone | José Luis Carrizo Martínez | Rel-6 | Paolo |  |  |
| 1464 | 40.1 | **Identification of requirements for streaming** |  | 46d? | 2003-06-27 A | 2003-08-29 A | 100% | 2003-06-27 | 2003-08-29 | 46d? |  | G1 | 736h | 736h |  |  |  | Rel-6 |  |  |  |
| 1465 | 420.1.1 | Requirements |  | 46d? | 2003-06-27 A | 2003-08-29 A | 100% | 2003-06-27 | 2003-08-29 | 46d? | finish no earlier than 2003-08-29 | G1 | 368h | 368h |  |  |  | Rel-6 |  |  |  |

Notes:
- 1441: Approved at SP#14. This may require BBs from CN1, CN4, SA5 and T3 / Text3: 33.102
- 1442: Contribution received S3#24, S3#25
- 1443: -
- 1444: Finished in CN4#26
- 1445: -
- 1446: Updated according to SP-040420
- 1447: CN#25: Updated WID NP-040351 replaces NP-040144. / Text3: 22.127, 23.198, 29.198, 29.199, 29.998
- 1448: -
- 1449: Inherited by CN5 from SA2 at TSG#25 Sep 2004. SA2's 23.127 (OSA/VHE Stage 2) replaced from Rel-6 onwards by a new CN5 TS 23.198 (Stage 2 OSA-only). / Text3: 23.198 OSA Stage 2-ONLY replaces 23.127 (OSA/VHE) from Rel-6 onwards
- 1450: - / Text3: 29.198-15
- 1451: - / Text3: 29.198, 29.998
- 1452: N5#26: Split WI into TS & TR. / Text3: 29.198-14
- 1453: - / Text3: 29.199
- 1454: - / Text3: 29.198, 29.998
- 1455: - / Text3: 29.198, 29.998
- 1456: TSG#25 Approved CN5 29.199 Parlay X Web services. Ongoing 3GPP/OMA co-ordination to avoid OMA producing conflicting/OVERLAPING specs (NP-040283/SP-040493).
- 1457: N5#26:TR Completion 09/04; consistent with CN1 delayed Rel-6 completion.
- 1458: -
- 1459: -
- 1460: -
- 1461: -
- 1462: -
- 1463: -
- 1464: -
- 1465: -

| ID | WBS | Task | Duration | Start | Finish | Complete | Baseline start | Baseline finish | Baseline duration | Constraint | Resources | Work | Actual work | Text6 | Text8 | Text3 | Text4 | Text5 | Text1 |
| --- | --- | --- | --- | --- | --- | --- | --- | --- | --- | --- | --- | --- | --- | --- | --- | --- | --- | --- | --- |
| 1466 | 40.2 | **Performance study of cell change mechanisms** | 956d? | 2000-01-03 A | 2003-08-29 A | 100% | 2000-01-03 | 2003-08-29 | 956d? |  | G1 | 30568h | 30568h | Rel-6 |  |  |  |  |  |
| 1467 | 420.2.1 | Performance of NACC | 956d? | 2000-01-03 A | 2003-08-29 A | 100% | 2000-01-03 | 2003-08-29 | 956d? | finish no earlier than 2003-08-29 | G1 | 7640h | 7640h | Rel-6 |  |  |  |  |  |
| 1468 | 420.2.2 | Performance of cell change in DTM for the PS domain | 956d? | 2000-01-03 A | 2003-08-29 A | 100% | 2000-01-03 | 2003-08-29 | 956d? | finish no earlier than 2003-08-29 | G1 | 7640h | 7640h | Rel-6 |  |  |  |  |  |
| 1469 | 420.2.3 | Handover | 956d? | 2000-01-03 A | 2003-08-29 A | 100% | 2000-01-03 | 2003-08-29 | 956d? | finish no earlier than 2003-08-29 | G1 | 7640h | 7640h | Rel-6 |  |  |  |  |  |
| 1470 | 40.3 | **Reduction of service interruption times and packet loss during mobility procedures** | 516d? | 2003-06-27 A | 2005-06-17 A | 100% | 2003-06-27 | 2005-06-17 | 516d? |  | G2 | 10800h | 10800h | Rel-6 | Gert |  |  |  |  |
| 1471 | 420.3.1 | Optimisations of existing mechanisms/procedures | 106d? | 2003-06-27 A | 2003-11-21 A | 100% | 2003-06-27 | 2003-11-21 | 106d? | finish no earlier than 2003-11-21 | G2 | 848h | 848h | Rel-6 | Gert |  |  |  |  |
| 1472 | 420.3.2 | Inter-system NACC | 106d? | 2003-06-27 A | 2003-11-21 A | 100% | 2003-06-27 | 2003-11-21 | 106d? | finish no earlier than 2003-11-21 | G2 | 848h | 848h | Rel-6 | Gert |  |  |  |  |
| 1473 | 420.3.3 | PS Handover (within GERAN and between GERAN and UTRAN) | 516d? | 2003-06-27 A | 2005-06-17 A | 100% | 2003-06-27 | 2005-06-17 | 516d? | finish no earlier than 2003-11-21 | G2 | 4128h | 4128h | Rel-6 | Gert |  |  |  |  |
| 1474 | 420.3.4 | Dependency to other features | 106d? | 2003-06-27 A | 2003-11-21 A | 100% | 2003-06-27 | 2003-11-21 | 106d? | finish no earlier than 2003-11-21 | G2 | 848h | 848h | Rel-6 | Gert |  |  |  |  |
| 1475 | 40.5 | **Deleted - MS conformance testing** | 31d? | 2003-12-19 A | 2004-01-30 A | 100% | 2003-12-19 | 2004-01-30 | 31d? |  | G3new | 248h | 248h | Rel-6 | Ingbert |  |  |  |  |
| 1476 | 420.4.1 | Deleted - MS conformance tests | 31d? | 2003-12-19 A | 2004-01-30 A | 100% | 2003-12-19 | 2004-01-30 | 31d? | finish no earlier than 2004-01-30 | G4,G5 | 248h | 248h | Rel-6 | Paolo |  |  |  |  |
| 1477 | 420.5 | GERAN A/Gb mode security enhancements | 612d? | 2002-09-26 A | 2005-01-28 A | 100% | 2002-09-26 | 2005-01-28 | 612d? | finish no earlier than 2005-01-28 | S3 | 4896h | 4896h | Rel-6 | Dionisio | 33.102 | Vodafone | peter.howard@vodafone.com |  |
| 1478 | 41 | Performance characterisation of default codecs for PS conversational multimedia application | 455d | 2002-09-13 A | 2004-06-10 A | 100% | 2002-09-13 | 2004-06-10 | 455d | finish no earlier than 2004-06-10 | S4 | 3640h | 3640h | Rel-6 | Paolo | 26.935 | Nokia | pasi.s.ojala@nokia.com | CODCAR |
| 1479 | 43 | Study on Privacy Capability | 83d | 2003-11-10 A | 2004-03-03 A | 100% | 2003-11-10 | 2004-03-03 | 83d | start no earlier than 2003-11-10 | S1 | 664h | 664h | Rel-6 | Alain | 21.949 | Lucent | Liz Daniel | PrivCap |
| 1480 | 44 | **OAM&P Rel-6** | 652d? | 2002-09-12 A | 2005-03-11 A | 100% | 2002-09-12 | 2005-03-11 | 652d? |  | S5 | 30819.5h | 30819.5h | Rel-6 | Dionisio |  | Motorola |  | OAM |
| 1481 | 44.1 | Principles, high level Requirements and Architecture | 526d | 2002-09-12 A | 2004-09-16 A | 100% | 2002-09-12 | 2004-09-16 | 526d | finish no earlier than 2004-09-16 | S5 | 4208h | 4208h | Rel-6 | Dionisio | 32.101, 32.102 | Motorola |  | OAM-AR |
| 1482 | 44.2 | Performance Management | 591d | 2002-09-12 A | 2004-12-16 A | 100% | 2002-09-12 | 2004-12-16 | 591d | finish no earlier than 2004-12-16 | S5 | 4728h | 4728h | Rel-6 | Dionisio | 32.401/3, 52.402, 32.411/2/3, 32.432/5/6 | Nortel |  | OAM-PM |
| 1483 | 44.4 | Network Infrastructure Management | 591d | 2002-09-12 A | 2004-12-16 A | 100% | 2002-09-12 | 2004-12-16 | 591d | finish no earlier than 2004-12-16 | S5 | 4728h | 4728h | Rel-6 | Dionisio | 32.15x, 32.3/6/7xy | Ericsson | thomas.tovinger@ericsson.com | OAM-NIM |
| 1484 | 44.5 | **Trace Management Rel-6** | 646d? | 2002-09-20 A | 2005-03-11 A | 100% | 2002-09-20 | 2005-03-11 | 646d? |  | S5 | 12061.9h | 12061.9h | Rel-6 | Dionisio | 32.42x, 52.008 | Nokia | kari.t.ronka@nokia.com | OAM-Trace |
| 1485 | 423.4.1 | Subscriber and UE trace management | 585d | 2002-09-20 A | 2004-12-16 A | 100% | 2002-09-20 | 2004-12-16 | 585d | finish no earlier than 2004-12-16 | S5 | 4680h | 4680h | Rel-6 | Dionisio | 32.421/2/3, 52.008 | Nokia | kari.t.ronka@nokia.com | OAM-Trace |
| 1486 | 423.4.2 | Subscriber and equipment trace in UTRAN | 268d? | 2003-06-06 A | 2004-06-15 A | 100% | 2003-06-06 | 2004-06-15 | 268d? | finish no earlier than 2004-06-15 | R3 | 2144h | 2144h | Rel-6 | Juha | 25.413, 25.420, 25.423 | Nortel | Yann Sehedi (sehedic@nortelnetworks.com) | OAM-Trace-RAN |
| 1487 | 423.4.3 | Trace Management, Stage3 | 193.74d? | 2004-06-09 A | 2005-03-11 A | 100% | 2004-06-09 | 2005-03-11 | 193.74d? | finish no earlier than 2005-03-11 | N4 | 1549.92h | 1549.92h | Rel-6 | Kimmo | 23.205, 29.232, 29.060, 29.002, 29.228 | Nokia | seppo.kauntola@nokia.com | OAM-Trace |
| 1488 | 424 | **Charging Management** | 666d? | 2002-11-21 A | 2005-06-09 A | 100% | 2002-11-21 | 2005-06-09 | 666d? |  | S5 | 55320h | 55320h | Rel-6 | Dionisio | 32.2xy | T-Mobile | karl-heinz.nenner@t-mobile.de | CH |
| 1489 | 424.1 | Charging architecture and principles | 390d? | 2003-03-21 A | 2004-09-16 A | 100% | 2003-03-21 | 2004-09-16 | 390d? | start no earlier than 2003-03-21 | S5 | 3120h | 3120h | Rel-6 | Dionisio | 32.240 |  |  | CH |
| 1490 | 424.2 | Charging Data Record (CDR) file format and transfer | 260d? | 2003-03-21 A | 2004-03-18 A | 100% | 2003-03-21 | 2004-03-18 | 260d? | start no earlier than 2003-03-21 | S5 | 2080h | 2080h | Rel-6 | Dionisio | 32.297 |  |  | CH |
| 1491 | 424.3 | CDR parameter description | 580d? | 2003-03-21 A | 2005-06-09 A | 100% | 2003-03-21 | 2005-06-09 | 580d? | finish no earlier than 2005-06-09 | S5 | 4640h | 4640h | Rel-6 | Dionisio | 32.298 |  |  | CH |
| 1492 | 424.4 | Diameter charging applications | 390d? | 2003-03-21 A | 2004-09-16 A | 100% | 2003-03-21 | 2004-09-16 | 390d? | start no earlier than 2003-03-21 | S5 | 3120h | 3120h | Rel-6 | Dionisio | 32.299 |  |  | CH |
| 1493 | 424.5 | Online Charging System (OCS) architecture study | 130d? | 2003-03-21 A | 2003-09-18 A | 100% | 2003-03-21 | 2003-09-18 | 130d? | start no earlier than 2003-03-21 | S5 | 1040h | 1040h | Rel-6 | Dionisio | 32.815 |  |  | CH |
| 1494 | 424.6 | OCS: Applications and interfaces | 455d? | 2003-03-21 A | 2004-12-16 A | 100% | 2003-03-21 | 2004-12-16 | 455d? | start no earlier than 2003-03-21 | S5 | 3640h | 3640h | Rel-6 | Dionisio | 32.296 |  |  | CH |

Notes:
- 1466: -
- 1467: -
- 1468: -
- 1469: -
- 1470: Completed at GERP#17
- 1471: -
- 1472: -
- 1473: -
- 1474: -
- 1475: Marked as stopped 10/2009
- 1476: Marked as stopped 10/2009
- 1477: Possible changes to 33.102 or new specification needed
- 1478: -
- 1479: -
- 1480: SP#26: Updated WID SP-040766 was SP-020445. Completion delayed 12/04->03/05 due to OAM-Trace in CN1/4.
- 1481: SP#25 09/2004 completed
- 1482: SP#26 12/2004 completed
- 1483: SP#26 12/2004 completed
- 1484: SP#26 12/2004 SA5 completed 12/04. Signalling Based Trace Activation for IMS (SIP) moved to Rel-7. Reason: CN1 cannot complete 24.229 trace without IETF dependency => estimate 05/2005.
- 1485: SP#26 12/2004 completed
- 1486: -
- 1487: -
- 1488: SP#28 Target 09/2005 for WLAN Charging 32.252
- 1489: SP#25 09/2004 completed
- 1490: SP#23 03/2004 completed
- 1491: SP#28 06/2005 completed
- 1492: SP#25 09/2004 completed
- 1493: SP#21 09/2003 completed
- 1494: SP#26 12/2004 completed

| ID | WBS | Task | Duration | Start | Finish | Complete | Baseline start | Baseline finish | Baseline duration | Constraint | Resources | Work | Actual work | Text1 | Text4 | Text5 | Text6 | Text8 | Text10 | Text12 |
| --- | --- | --- | --- | --- | --- | --- | --- | --- | --- | --- | --- | --- | --- | --- | --- | --- | --- | --- | --- | --- |
| 1495 | 424.7 | **Charging Management for Bearer level** | 390d? | 2003-03-21 A | 2004-09-16 A | 100% | 2003-03-21 | 2004-09-16 | 390d? |  | S5 | 11440h | 11440h | CH-BC | Nokia | Benni ALEXANDER | Rel-6 | Dionisio |  |  |
| 1496 | 424.7.1 | CS domain charging | 260d? | 2003-03-21 A | 2004-03-18 A | 100% | 2003-03-21 | 2004-03-18 | 260d? | start no earlier than 2003-03-21 | S5 | 2080h | 2080h | CH |  |  | Rel-6 | Dionisio |  |  |
| 1497 | 424.7.2 | PS domain charging | 390d? | 2003-03-21 A | 2004-09-16 A | 100% | 2003-03-21 | 2004-09-16 | 390d? | start no earlier than 2003-03-21 | S5 | 3120h | 3120h | CH |  |  | Rel-6 | Dionisio |  |  |
| 1498 | 424.7.3 | CDR transfer | 390d? | 2003-03-21 A | 2004-09-16 A | 100% | 2003-03-21 | 2004-09-16 | 390d? | start no earlier than 2003-03-21 | S5 | 3120h | 3120h | CH |  |  | Rel-6 | Dionisio |  |  |
| 1499 | 424.8 | Charging Management for the IMS | 455d? | 2003-03-21 A | 2004-12-16 A | 100% | 2003-03-21 | 2004-12-16 | 455d? | finish no earlier than 2004-12-16 | S5 | 3640h | 3640h | IMS2-CH | Ericsson | Patrik TEPPO | Rel-6 | Dionisio |  |  |
| 1500 | 424.9 | Charging Management for the Service domain | 580d? | 2003-03-21 A | 2005-06-09 A | 100% | 2003-03-21 | 2005-06-09 | 580d? | finish no earlier than 2005-06-09 | S5 | 4640h | 4640h | CH | Siemens | Gerald GÖRMER | Rel-6 | Dionisio |  |  |
| 1501 | 424.10 | **Overall architectural aspects of IP flow based bearer level charging** | 602d? | 2002-11-21 A | 2005-03-11 A | 100% | 2002-11-21 | 2005-03-11 | 602d? |  | S2 | 12632h | 12632h | CH-FBC |  |  | Rel-6 | Maurice |  |  |
| 1502 | 424.10.1 | Overall definition of FBC architecture | 334d? | 2002-11-21 A | 2004-03-02 A | 100% | 2002-11-21 | 2004-03-02 | 334d? | start no earlier than 2002-11-21 | S2 | 2672h | 2672h |  |  |  | Rel-6 | Maurice | SP-24 |  |
| 1503 | 424.10.2 | Study on providing policy control with FBC | 130d? | 2004-02-02 A | 2004-07-30 A | 100% | 2004-02-02 | 2004-07-30 | 130d? | start no earlier than 2004-02-01 | S2 | 1040h | 1040h |  |  |  | Rel-6 | Maurice | SP-24 |  |
| 1504 | 424.10.3 | Gx interface for flow based charging | 223d? | 2004-02-02 A | 2004-12-08 A | 100% | 2004-02-02 | 2004-12-08 | 223d? | start no earlier than 2004-02-01 | N3 | 1784h | 1784h | CH-FBC | Nokia | juha.a.rasanen@nokia.com | Rel-6 | Gwiho | SP-25 |  |
| 1505 | 424.10.4 | Rx interface for flow based charging | 290d? | 2004-02-02 A | 2005-03-11 A | 100% | 2004-02-02 | 2005-03-11 | 290d? | finish no earlier than 2005-03-11 | N3 | 2320h | 2320h | CH-FBC | Nortel | Javier Gonzalez Gallego | Rel-6 | Gwiho | SP-25 |  |
| 1506 | 13 | **Rel-6 UICC/USIM enhancements and interworking** | 1164d? | 2000-09-25 A | 2005-03-10 A | 100% | 2000-09-25 | 2005-03-10 | 1164d? |  | T3 | 43088h | 43088h | USAT1 |  |  | Rel-6 | Xavier |  |  |
| 1507 | 13.1 | **UICC API** | 777d | 2002-03-20 A | 2005-03-10 A | 100% | 2002-03-20 | 2005-03-10 | 777d |  | T3 | 15024h | 15024h | USAT1-API |  |  | Rel-6 | Xavier |  |  |
| 1508 | 13.1.1 | Java API Test specification | 59d | 2002-03-20 A | 2002-06-10 A | 100% | 2002-03-20 | 2002-06-10 | 59d | finish no earlier than 2002-09-20 | T3 | 472h | 472h |  | Microelectrónica Española | Mario Pérez | Rel-6 |  |  |  |
| 1509 | 425.1.2 | 2G/3G Java Card™ API based applet interworking | 255d | 2003-03-17 A | 2004-03-05 A | 100% | 2003-03-17 | 2004-03-05 | 255d | finish no earlier than 2004-02-19 | T3 | 2040h | 2040h | USAT1-API | Oberthur Card Systems | Stéphane Andrau | Rel-6 |  |  |  |
| 1510 | 425.1.3 | (U)SIM API for Java Card Testing | 519d | 2003-03-17 A | 2005-03-10 A | 100% | 2003-03-17 | 2005-03-10 | 519d | finish no earlier than 2005-03-10 | T3 | 4152h | 4152h |  | Axalto | Christophe Begassat (cbegassat@axalto.com) | Rel-6 | Xavier |  |  |
| 1511 | 13.1.2 | Deleted - Java API Test specification (TS 43.019 Rel-5) | 268d | 2002-05-30 A | 2003-06-09 A | 100% | 2002-05-30 | 2003-06-09 | 268d | finish no earlier than 2003-09-17 | T3 | 2144h | 2144h |  | Microelectrónica Española | Mario Pérez | Rel-6 |  |  | TP-20 |
| 1512 | 425.2 | **Rel-6 USIM toolkit enhancements** | 1160d? | 2000-09-25 A | 2005-03-04 A | 100% | 2000-09-25 | 2005-03-04 | 1160d? |  | T3 | 21848h | 21848h |  |  |  | Rel-6 | Xavier |  |  |
| 1513 | 425.2.1 | **C SIM API** | 525d | 2000-09-25 A | 2002-09-27 A | 100% | 2000-09-25 | 2002-09-27 | 525d |  | T3 | 9960h | 9960h | USAT1-API-MULTOS |  |  | Rel-6 |  |  |  |
| 1514 | 425.2.1.1 | Specification | 525d | 2000-09-25 A | 2002-09-27 A | 100% | 2000-09-25 | 2002-09-27 | 525d | finish no earlier than 2002-09-27 | T3 | 4200h | 4200h |  | Aspects Software | Neil Livingston | Rel-6 |  |  |  |
| 1515 | 425.2.1.2 | Test specification | 195d | 2001-01-01 A | 2001-09-28 A | 100% | 2001-01-01 | 2001-09-28 | 195d | finish no earlier than 2001-09-28 | T3 | 1560h | 1560h |  | Aspects Software | Neil Livingston | Rel-6 |  |  |  |
| 1516 | 425.2.2 | USIM application toolkit Conformance Test Specification for Mobile Equipments | 326d? | 2003-12-05 A | 2005-03-04 A | 100% | 2003-12-05 | 2005-03-04 | 326d? | start no earlier than 2003-12-05 | T3 | 2608h | 2608h |  | Gemplus | Eric.laffont@gemplus.com | Rel-6 |  |  |  |
| 1517 | 426 | **Packet Switched Streaming Services Rel-6** | 798d? | 2002-11-18 A | 2005-12-07 A | 100% | 2002-11-18 | 2005-12-07 | 798d? |  | S4 | 11579.4h | 11579.4h | PSSrel6 | Ericsson | olle.franceschi@ericsson.com | Rel-6 | Paolo |  |  |
| 1518 | 426.1 | Stage 1 | 86d? | 2002-11-18 A | 2003-03-17 A | 100% | 2002-11-18 | 2003-03-17 | 86d? | finish no earlier than 2003-03-17 | S1 | 688h | 688h |  |  |  | Rel-6 | Alain |  |  |
| 1519 | 426.2 | Stage 3 | 779d? | 2002-12-13 A | 2005-12-07 A | 100% | 2002-12-13 | 2005-12-07 | 779d? | finish no earlier than 2005-12-07 | S4 | 6232h | 6232h | PSSrel6-Stage3 | Ericsson | olle.franceschi@ericsson.com | Rel-6 | Paolo |  |  |
| 1520 | 427 | AMR-WB extension for high audio quality | 779d | 2002-12-13 A | 2005-12-07 A | 100% | 2002-12-13 | 2005-12-07 | 779d | finish no earlier than 2005-12-07 | S4 | 6232h | 6232h | AMRWB+ | Nokia | janne.m.vainio@nokia.com | Rel-6 | Paolo |  |  |
| 1521 | 428 | Codec Enhancements for Packet Switched Conversational Multimedia Applications | 198d? | 2004-03-16 A | 2004-12-16 A | 100% | 2004-03-16 | 2004-12-16 | 198d? | finish no earlier than 2004-12-16 | S4 | 1584h | 1584h | CEPSCM | Nokia | miska.hannuksela@nokia.com | Rel-6 | Paolo |  |  |
| 1522 | 429 | 3G-324M Improvements | 198d? | 2004-03-16 A | 2004-12-16 A | 100% | 2004-03-16 | 2004-12-16 | 198d? | finish no earlier than 2004-12-16 | S4 | 1584h | 1584h | 3G-324MI | Ericsson | bo.burman@ericsson.com | Rel-6 | Paolo |  |  |
| 1523 | 430 | Single Antenna Receiver Interference Cancellation (SAIC) | 420.92d? | 2002-11-15 A | 2004-06-25 A | 100% | 2002-11-15 | 2004-06-25 | 420.92d? | finish no earlier than 2004-08-27 | GP,G1 | 3367.36h | 3367.36h | SAIC | Cingular | Marc Grant | Rel-6 | Paolo |  |  |

Notes:
- 1495: SP#28 Target 09/2005 for WLAN Charging 32.252
- 1496: SP#23 03/2004 completed / Text3: 32.250
- 1497: SP#25 09/2004 completed / Text3: 32.251
- 1498: SP#25 09/2004 completed / Text3: 32.295
- 1499: SP#26 12/2004 completed / Text3: 32.260
- 1500: SP#26: Updated WID SP-040778 was SP-030050. Target completion 06/2005. Consisting of MMS-CH, LCS-CH, WLAN-CH, POC-CH, MBMS-CH / Text3: 32.252, 32.270, 32.271, 32.272
- 1501: - / Text3: 23.125
- 1502: -
- 1503: -
- 1504: - / Text3: 29.210
- 1505: - / Text3: 29.209
- 1506: -
- 1507: 8/3/2001: test spec is based on R99 core spec, so deleted from Workplan
- 1508: -
- 1509: -
- 1510: - / Text3: 31.213
- 1511: MOVED to Rel-5 WP
- 1512: -
- 1513: -
- 1514: -
- 1515: -
- 1516: - / Text3: 31.124
- 1517: -
- 1518: 2nd resp SA4 / Text3: 22.233
- 1519: TR tbc by Sept. 05 / Text3: 26.233, 26.234, 26.244, 26.245, 26.246, 26.401, 26.402, 26.403, 26.404, 26.405, 26.406, 26.410, 26.411, 26.412, 26.273, 26.290, 26.304, 26.412, 26.274, 26.936
- 1520: TR tbc by Sept. 05 / Text3: 26.290, 26.304, 26.273, 26.274, 26.412, 26.936
- 1521: - / Text3: 26.235, 26.236
- 1522: - / Text3: 26.111, 26.911
- 1523: -

| ID | WBS | Task | Type | Duration | Start | Finish | Complete | Baseline start | Baseline finish | Baseline duration | Constraint | Resources | Work | Actual work | Text1 | Text4 | Text5 | Text6 | Text8 | Text3 | Text12 |
| --- | --- | --- | --- | --- | --- | --- | --- | --- | --- | --- | --- | --- | --- | --- | --- | --- | --- | --- | --- | --- | --- |
| 1524 | 431 | **Enhancement of dialled service for CAMEL** |  | 199d | 2003-03-28 A | 2003-12-31 A | 100% | 2003-03-28 | 2003-12-31 | 199d |  | S1 | 3184h | 3184h | EDCAMEL | Samsung | Craig Bishop | Rel-6 | Alain |  |  |
| 1525 | 431.1 | Stages 2 and 3 |  | 199d | 2003-03-28 A | 2003-12-31 A | 100% | 2003-03-28 | 2003-12-31 | 199d | finish no earlier than 2003-09-19 | N4 | 1592h | 1592h |  |  |  | Rel-6 | Kimmo |  |  |
| 1526 | 432 | Bandwidth and resource savings in CS networks |  | 273d? | 2003-06-01 A | 2004-06-16 A | 100% | 2003-06-01 | 2004-06-16 | 273d? | finish no earlier than 2004-06-16 | S2 | 2184h | 2184h | BARS |  |  | Rel-6 | Maurice | 23.977 |  |
| 1527 | 433 | FS on (U)SIM Security Reuse by Peripheral Devices on Local Interfaces |  | 127d? | 2003-07-03 A | 2003-12-26 A | 100% | 2003-07-03 | 2003-12-26 | 127d? | finish no earlier than 2003-12-26 | S3 | 1016h | 1016h |  | Toshiba | Raziq Yaqub (ryaqub@tari.toshiba.com) | Rel-6 | Dionisio |  |  |
| 1528 | 434 | **Multiple TBF in A/Gb mode** |  | 736d? | 2002-04-05 A | 2005-01-28 A | 100% | 2002-04-05 | 2005-01-28 | 736d? |  | GP,G2 | 17600h | 17600h | MULTBF | Ericsson | gunnar.mildh@era.ericsson.se | Rel-6 | Paolo |  |  |
| 1529 | 434.1 | **Multiple TBF in A/Gb mode** |  | 366d? | 2002-04-05 A | 2003-08-29 A | 100% | 2002-04-05 | 2003-08-29 | 366d? |  | GP,G2 | 11712h | 11712h | MULTBF-Agbmode | Ericsson | gunnar.mildh@era.ericsson.se | Rel-6 | Paolo |  |  |
| 1530 | 434.1.1 | Multiple TBF Concept paper |  | 366d? | 2002-04-05 A | 2003-08-29 A | 100% | 2002-04-05 | 2003-08-29 | 366d? | finish no earlier than 2003-08-29 | GP,G2 | 2928h | 2928h |  |  |  | Rel-6 | Paolo |  |  |
| 1531 | 434.1.2 | Multiple TBF Stage 2 (43.064) CRs |  | 366d? | 2002-04-05 A | 2003-08-29 A | 100% | 2002-04-05 | 2003-08-29 | 366d? | finish no earlier than 2003-08-29 | GP,G2 | 2928h | 2928h |  |  |  | Rel-6 | Paolo |  |  |
| 1532 | 434.1.3 | Multiple TBF Stage 3 (44.060) CRs |  | 366d? | 2002-04-05 A | 2003-08-29 A | 100% | 2002-04-05 | 2003-08-29 | 366d? | finish no earlier than 2003-08-29 | GP,G2 | 2928h | 2928h |  |  |  | Rel-6 | Paolo |  |  |
| 1533 | 434.2 | Deleted at TGS # 27 - Multiple TBF in A/Gb mode – MS testing | milestone | 0d? | 2005-01-28 A | 2005-01-28 A | 100% | 2005-01-28 | 2005-01-28 | 0d? | start no earlier than 2005-01-28 | G3new |  |  | MULTBF-Testing | Ericsson | gunnar.mildh@era.ericsson.se | Rel-6 | Paolo |  | GP-23 |
| 1534 | 435 | **Alignment between the test-regimes for GERAN capable MS** |  | 526d? | 2003-08-29 A | 2005-09-02 A | 100% | 2003-08-29 | 2005-09-02 | 526d? |  | G3new | 4208h | 4208h | ALTERE | Ericsson | Toubassi | Rel-6 | Ingbert |  |  |
| 1535 | 435.1 | Determine the controversial test cases in the different test regimes and align them with 3GPP GERAN test specifications. Such test cases to be added to TS 51.010. |  | 526d? | 2003-08-29 A | 2005-09-02 A | 100% | 2003-08-29 | 2005-09-02 | 526d? | finish no earlier than 2005-09-02 | G3new | 4208h | 4208h | ALTERE-TC |  |  | Rel-6 | Ingbert |  |  |
| 1536 | 436 | Addition of U-TDOA in the CS domain |  | 111d? | 2003-11-21 A | 2004-04-23 A | 100% | 2003-11-21 | 2004-04-23 | 111d? | finish no earlier than 2004-04-23 | GP | 888h | 888h | UTDOACS | TruePosition | Bob Gross, Rhys Robinson (rlgross@trueposition.com) | Rel-6 | Paolo |  |  |
| 1537 | 437 | Addition of U-TDOA in the PS domain |  | 361d? | 2003-06-27 A | 2004-11-12 A | 100% | 2003-06-27 | 2004-11-12 | 361d? | finish no earlier than 2004-11-12 | GP | 2888h | 2888h | UTDOAPS | TruePosition | Bob Gross, Rhys Robinson (rlgross@trueposition.com) | Rel-6 | Paolo |  |  |
| 1538 | 438 | **Downlink Advanced Receiver Performance** |  | 466d? | 2003-11-21 A | 2005-09-02 A | 100% | 2003-11-21 | 2005-09-02 | 466d? |  | GP | 19160h | 19160h | DARP | Nokia | tommy.bysted@nokia.com | Rel-6 | Paolo |  |  |
| 1539 | 438.1 | DARP test scenarios |  | 201d? | 2003-11-21 A | 2004-08-27 A | 100% | 2003-11-21 | 2004-08-27 | 201d? | finish no earlier than 2004-08-27 | GP | 1608h | 1608h | DARP-TS | Nokia | tommy.bysted@nokia.com | Rel-6 | Paolo |  |  |
| 1540 | 438.2 | **DARP for GMSK modulated voice services** |  | 201d? | 2004-02-06 A | 2004-11-12 A | 100% | 2004-02-06 | 2004-11-12 | 201d? |  | GP | 4824h | 4824h | DARP-GMSK | Nokia | tommy.bysted@nokia.com | Rel-6 | Paolo |  |  |
| 1541 | 438.2.1 | Performance requirements in 45.005 |  | 201d? | 2004-02-06 A | 2004-11-12 A | 100% | 2004-02-06 | 2004-11-12 | 201d? | finish no earlier than 2004-11-12 | GP | 1608h | 1608h | DARP-GMSK-Perf |  |  | Rel-6 | Paolo |  |  |
| 1542 | 438.2.2 | Radio subsystem link control in 45.008 |  | 201d? | 2004-02-06 A | 2004-11-12 A | 100% | 2004-02-06 | 2004-11-12 | 201d? | finish no earlier than 2004-11-12 | GP | 1608h | 1608h | DARP-GMSK-LC |  |  | Rel-6 | Paolo |  |  |
| 1543 | 438.3 | **DARP for GPRS and EGPRS MCS1-MCS4** |  | 201d? | 2004-02-06 A | 2004-11-12 A | 100% | 2004-02-06 | 2004-11-12 | 201d? |  | GP | 4824h | 4824h | DARP-GPRSE | Nokia | tommy.bysted@nokia.com | Rel-6 | Paolo |  |  |
| 1544 | 438.3.1 | Performance requirements in 45.005 |  | 201d? | 2004-02-06 A | 2004-11-12 A | 100% | 2004-02-06 | 2004-11-12 | 201d? | finish no earlier than 2004-11-12 | GP | 1608h | 1608h | DARP-GPRSE-Perf |  |  | Rel-6 | Paolo |  |  |
| 1545 | 438.3.2 | Radio subsystem link control in 45.008 |  | 201d? | 2004-02-06 A | 2004-11-12 A | 100% | 2004-02-06 | 2004-11-12 | 201d? | finish no earlier than 2004-11-12 | GP | 1608h | 1608h | DARP-GPRSE-LC |  |  | Rel-6 | Paolo |  |  |
| 1546 | 438.4 | DARP Capability signalling |  | 256d? | 2003-11-21 A | 2004-11-12 A | 100% | 2003-11-21 | 2004-11-12 | 256d? | finish no earlier than 2004-11-12 | GP | 2048h | 2048h | DARP-CAPSIG | Nokia | tommy.bysted@nokia.com | Rel-6 | Paolo |  |  |
| 1547 | 438.5 | GERAN MS Conformance test for DARP |  | 266d? | 2004-08-27 A | 2005-09-02 A | 100% | 2004-08-27 | 2005-09-02 | 266d? | finish no earlier than 2005-06-24 | G3new | 2128h | 2128h | ARP-ConfTest | Nokia | tommy.bysted@nokia.com | Rel-6 | Ingbert |  |  |

Notes:
- 1524: -
- 1525: -
- 1526: -
- 1527: Approved TSG#20
- 1528: -
- 1529: -
- 1530: -
- 1531: -
- 1532: -
- 1533: -
- 1534: -
- 1535: -
- 1536: Completed, except for potential LMU performance specs
- 1537: -
- 1538: -
- 1539: -
- 1540: -
- 1541: -
- 1542: -
- 1543: -
- 1544: -
- 1545: -
- 1546: -
- 1547: -

| ID | WBS | Task | Type | Duration | Start | Finish | Complete | Baseline start | Baseline finish | Baseline duration | Constraint | Resources | Work | Actual work | Text1 | Text4 | Text5 | Text6 | Text8 | Text12 | Text3 | Text10 |
| --- | --- | --- | --- | --- | --- | --- | --- | --- | --- | --- | --- | --- | --- | --- | --- | --- | --- | --- | --- | --- | --- | --- |
| 1548 | 439 | **Reduction of PS service interruption in Dual Transfer Mode** |  | 416d? | 2003-11-21 A | 2005-06-24 A | 100% | 2003-11-21 | 2005-06-24 | 416d? |  | G2 | 8360h | 8360h | PSintDTM | Siemens | toby.proctor@roke.co.uk | Rel-6 | Gert |  |  |  |
| 1549 | 439.1 | Use case and requirement definition |  | 111d? | 2003-11-21 A | 2004-04-23 A | 100% | 2003-11-21 | 2004-04-23 | 111d? | finish no earlier than 2004-04-23 | G2 | 888h | 888h | PSintDTM-Req | Siemens | toby.proctor@roke.co.uk | Rel-6 | Gert |  |  |  |
| 1550 | 439.2 | Performance Study of Current Procedures |  | 111d? | 2003-11-21 A | 2004-04-23 A | 100% | 2003-11-21 | 2004-04-23 | 111d? | start no earlier than 2003-11-21 | G2 | 888h | 888h | PSintDTM-Perf | Siemens | toby.proctor@roke.co.uk | Rel-6 | Gert |  |  |  |
| 1551 | 439.3 | Reduction of service interruption times and packet loss during Dual Transfer Mode and mobility procedures |  | 146d? | 2004-04-23 A | 2004-11-12 A | 100% | 2004-04-23 | 2004-11-12 | 146d? | finish no earlier than 2004-11-12 | G2 | 1168h | 1168h | PSintDTM-Reduct | Siemens | toby.proctor@roke.co.uk | Rel-6 | Gert |  |  |  |
| 1552 | 439.4 | Deleted - MS Conformance testing |  | 261d? | 2004-06-25 A | 2005-06-24 A | 100% | 2004-06-25 | 2005-06-24 | 261d? | finish no earlier than 2005-06-24 | G3new | 2088h | 2088h | PSintDTM-ConfMS |  |  | Rel-6 | Ingbert | GP-25 |  |  |
| 1553 | 439.5 | Deleted - BTS Conformance testing | milestone | 0d? | 2005-06-24 A | 2005-06-24 A | 100% | 2005-06-24 | 2005-06-24 | 0d? | finish no earlier than 2005-06-24 | G3new |  |  | PSintDTM-ConfBTS |  |  | Rel-6 | Ingbert | GP-25 |  |  |
| 1554 | 440 | CAMEL prepay interworking with SCUDIF |  | 206d | 2003-12-08 A | 2004-10-05 A | 100% | 2003-12-08 | 2004-10-05 | 206d |  | N4 | 1648h | 1648h | SCCAMEL |  |  | Rel-6 | Kimmo |  |  |  |
| 1555 | 441 | **Circuit Switched Video and Voice Service Improvements** |  | 430d? | 2004-01-12 A | 2005-09-02 A | 100% | 2004-01-12 | 2005-09-02 | 430d? |  | S1 | 6536h | 6536h | CS_VSS | Vodafone | John Watson | Rel-6 | Alain |  | 23.801 |  |
| 1556 | 441.1 | Stage 1 - Requirements |  | 199d | 2004-01-12 A | 2004-10-14 A | 100% | 2004-01-12 | 2004-10-14 | 199d | finish no earlier than 2004-10-14 | S1 | 1592h | 1592h | CS_VSS | Vodafone | John Watson | Rel-6 | Alain |  |  |  |
| 1557 | 441.2 | Stage 2 Study on architecture alternatives |  | 155d? | 2004-01-12 A | 2004-08-13 A | 100% | 2004-01-12 | 2004-08-13 | 155d? | finish no earlier than 2004-08-13 | S2 | 1240h | 1240h | CS_VSS |  |  | Rel-6 | Maurice |  |  | SP-24 |
| 1558 | 441.3 | Stage 2 description on Redial |  | 164d? | 2004-05-03 A | 2004-12-16 A | 100% | 2004-05-03 | 2004-12-16 | 164d? | finish no earlier than 2004-12-16 | S2 | 1312h | 1312h | CS_VSS |  |  | Rel-6 | Maurice |  | 23.903 | SP-24 |
| 1559 | 441.4 | Switching between voice and video call - Redial solution |  | 120d? | 2005-01-03 A | 2005-06-17 A | 100% | 2005-01-03 | 2005-06-17 | 120d? | start no earlier than 2005-01-03 | C1 | 960h | 960h | CS_VSS |  |  | Rel-6 | Frederic |  |  |  |
| 1560 | 441.5 | Deleted - GERAN2 Part | milestone | 0d | 2005-09-02 A | 2005-09-02 A | 100% | 2005-09-02 | 2005-09-02 | 0d | start no earlier than 2005-09-02 | G2 |  |  | CS_VSS |  |  | Rel-6 | Gert | GP-26 |  |  |
| 1561 | 441.6 | Deleted - CN3 Part | milestone | 0d? | 2004-10-14 A | 2004-10-14 A | 100% | 2004-10-14 | 2004-10-14 | 0d? | start no earlier than 2004-10-14 | N3 |  |  | CS_VSS |  |  | Rel-6 | Gwiho | TP-26 |  |  |
| 1562 | 442 | Network Domain Security; MAP application layer security (NDS/MAPsec) |  | 127d? | 2004-07-06 A | 2004-12-29 A | 100% | 2004-07-06 | 2004-12-29 | 127d? | finish no earlier than 2003-12-26 | S3 | 1016h | 1016h | MAPSEC | Vodafone | Peter.Howard@vodafone.com | Rel-6 | Dionisio |  |  |  |
| 1563 | 443 | FS on Security for early IMS |  | 127d? | 2004-10-01 A | 2005-03-28 A | 100% | 2004-10-01 | 2005-03-28 | 127d? | finish no earlier than 2003-12-26 | S3 | 1016h | 1016h | SEC-IMS | Vodafone | Peter.Howard@vodafone.com | Rel-6 | Dionisio |  |  |  |
| 1564 | 444 | Reorganisation of CS Data Specifications |  | 14d? | 2004-11-19 A | 2004-12-08 A | 100% | 2004-11-19 | 2004-12-08 | 14d? | finish no earlier than 2004-12-24 | N3 | 112h | 112h | CS Data | Siemens | Thomas.Belling@nsn.com | Rel-6 | Gwiho |  |  |  |
| 1565 | 445 | **Generic Access to A/Gb Interface (GAAI)** |  | 411d? | 2004-06-25 A | 2006-01-20 A | 100% | 2004-06-25 | 2006-01-20 | 411d? |  | GP | 9160h | 9160h | GAAI | Motorola |  | Rel-6 | Paolo |  |  |  |
| 1566 | 445.1 | FS on GAAI |  | 46d? | 2004-06-25 A | 2004-08-27 A | 100% | 2004-06-25 | 2004-08-27 | 46d? | finish no earlier than 2004-08-27 | GP | 368h | 368h | GAAG | Motorola |  | Rel-6 | Paolo |  | 43.901 |  |
| 1567 | 445.2 | GAAI – Stage 2 |  | 161d? | 2004-08-27 A | 2005-04-08 A | 100% | 2004-08-27 | 2005-04-08 | 161d? | finish no earlier than 2005-04-08 | GP | 1288h | 1288h | GAAI-Stage2 | Ericsson | jari.vikberg@ericsson.com | Rel-6 | Paolo |  | 43.318 |  |
| 1568 | 445.3 | GAAI – Stage 3 |  | 161d? | 2004-08-27 A | 2005-04-08 A | 100% | 2004-08-27 | 2005-04-08 | 161d? | finish no earlier than 2005-04-08 | GP | 1288h | 1288h | GAAI-Stage3 |  |  | Rel-6 | Paolo |  | 44.318 |  |
| 1569 | 445.4 | MS Conformance Test for GAAI |  | 366d? | 2004-08-27 A | 2006-01-20 A | 100% | 2004-08-27 | 2006-01-20 | 366d? | finish no earlier than 2006-01-20 | GP | 2928h | 2928h | GAAI-CT |  |  | Rel-6 | Ingbert |  |  |  |
| 1570 | 446 | **Support of PS Handover for GERAN A/Gb mode** |  | 473d? | 2003-11-03 A | 2005-08-24 A | 100% | 2003-11-03 | 2005-08-24 | 473d? |  | GP,G2 | 11352h | 11352h | SPSHAGB | Ericsson | gunnar.hedby@ericsson.com | Rel-6 | Paolo |  |  |  |
| 1571 | 446.1 | Stage 2 |  | 473d? | 2003-11-03 A | 2005-08-24 A | 100% | 2003-11-03 | 2005-08-24 | 473d? | finish no earlier than 2005-09-02 | GP,G2 | 3784h | 3784h | SPSHAGB-Stage2 | Ericsson | gunnar.hedby@ericsson.com | Rel-6 | Paolo |  | 43.129 |  |
| 1572 | 446.2 | PS handover |  | 473d? | 2003-11-03 A | 2005-08-24 A | 100% | 2003-11-03 | 2005-08-24 | 473d? | finish no earlier than 2005-09-02 | GP,G2 | 3784h | 3784h | SPSHAGB-PSHO | Ericsson | gunnar.hedby@ericsson.com | Rel-6 | Paolo |  |  |  |
| 1573 | 446.3 | Definition of radio resource management functionality |  | 473d? | 2003-11-03 A | 2005-08-24 A | 100% | 2003-11-03 | 2005-08-24 | 473d? | finish no earlier than 2005-09-02 | GP,G2 | 3784h | 3784h | SPSHAGB-RRM | Ericsson | gunnar.hedby@ericsson.com | Rel-6 | Paolo |  |  |  |

Notes:
- 1548: -
- 1549: -
- 1550: -
- 1551: -
- 1552: -
- 1553: -
- 1554: -
- 1555: -
- 1556: -
- 1557: -
- 1558: -
- 1559: -
- 1560: -
- 1561: -
- 1562: Approved TSG#24. Marked as closed 12/2008 (was marked 20% complete)
- 1563: Approved TSG#24. TR 33.978 Approved at TSG SA #27
- 1564: Created at TSG#27 as 100 % complete
- 1565: -
- 1566: Feasibility Study
- 1567: -
- 1568: -
- 1569: Marked as closed 12/2008 (was marked 90% complete)
- 1570: Replaces SCSAGB- Originally Started Nov 2003 as GP-030443
- 1571: Replaces SCSAGB-Stage2
- 1572: Replaces SCSAGB-PSH
- 1573: Replaces SCSAGB-RRM

| ID | WBS | Task | Type | Duration | Start | Finish | Complete | Baseline start | Baseline finish | Baseline duration | Total slack | Constraint | Resources | Work | Actual work | Text1 | Text6 | Text3 | Text8 | Text4 | Text5 | Text12 |
| --- | --- | --- | --- | --- | --- | --- | --- | --- | --- | --- | --- | --- | --- | --- | --- | --- | --- | --- | --- | --- | --- | --- |
| 1574 | 447 | **small Technical Enhancements and Improvements for Rel-6** |  | 503d? | 2006-06-02 A | 2008-05-06 A | 100% | 2006-06-02 | 2008-05-06 | 503d? |  |  | All | 4024h | 4024h | TEI6 | Rel-6 |  |  |  |  |  |
| 1575 | 447.1 | Small Technical Enhancements and Improvements for Rel-6 Conformance Testing |  | 503d? | 2006-06-02 A | 2008-05-06 A | 100% | 2006-06-02 | 2008-05-06 | 503d? |  | start no earlier than 2006-06-02 | R5,T1 | 4024h | 4024h | TEI6_Test | Rel-6 | 34.108,34.121-1/2,34.122,34.123-1/2/3 | Ingbert |  |  |  |
| 1576 | 448 | Deleted - Study of Feature Interactions Requirements | milestone | 0d? | 2004-10-01 A | 2004-10-01 A | 100% | 2004-10-01 | 2004-10-01 | 0d? |  | finish no earlier than 2004-10-01 | S1 |  |  | FINTER | Rel-6 |  | Alain |  |  |  |
| 1577 | 449 | Deleted (moved to Rel7) - Enhancements of VGCS in public networks for communication of public authority officials |  | 7d? | 2005-08-24 A | 2005-09-02 A | 100% | 2005-08-24 | 2005-09-02 | 7d? |  | start no earlier than 2005-08-24 | GP,G2 | 56h | 56h | EVGCS | Rel-6 | 44.018, 44.068, 48.008 | Paolo | Siemens | kenneth.isaacs@roke.co.uk | GP-26 |
| 1578 | 450 | **Deleted - Support of Conversational Services in A/Gb mode via the PS domain** |  | 64d? | 2003-11-21 A | 2004-02-19 A | 100% | 2003-11-21 | 2004-02-19 | 64d? |  |  | GP | 512h | 512h | SCSAGB | Rel-6 |  | Paolo | Ericsson | David Bladsjö (david.bladsjo@ericsson.com) |  |
| 1579 | 450.1 | Delete - Creation of a TR | milestone | 0d? | 2003-11-21 A | 2003-11-21 A | 100% | 2003-11-21 | 2003-11-21 | 0d? |  | start no earlier than 2003-11-21 | GP |  |  | SCSAGB-TR | Rel-6 |  | Paolo | Ericsson | David Bladsjö (david.bladsjo@ericsson.com) | GP-17 |
| 1580 | 450.2 | Delete - Stage 2 | milestone | 0d? | 2003-11-21 A | 2003-11-21 A | 100% | 2003-11-21 | 2003-11-21 | 0d? |  | finish no earlier than 2003-11-21 | GP |  |  | SCSAGB-Stage2 | Rel-6 |  | Paolo | Ericsson | David Bladsjö (david.bladsjo@ericsson.com) | GP-17 |
| 1581 | 450.3 | Delete - Radio Channel Support | milestone | 0d? | 2003-11-21 A | 2003-11-21 A | 100% | 2003-11-21 | 2003-11-21 | 0d? |  | finish no earlier than 2003-11-21 | GP |  |  | SCSAGB-RCS | Rel-6 |  | Paolo | Ericsson | David Bladsjö (david.bladsjo@ericsson.com) | GP-17 |
| 1582 | 450.4 | Delete - Definition of radio resource management functionality | milestone | 0d? | 2003-11-21 A | 2003-11-21 A | 100% | 2003-11-21 | 2003-11-21 | 0d? |  | finish no earlier than 2003-11-21 | GP,G2 |  |  | SCSAGB-RRM | Rel-6 |  | Paolo | Ericsson | David Bladsjö (david.bladsjo@ericsson.com) | GP-17 |
| 1583 | 450.5 | Delete, replaced by 50561 - PS Handover |  | 64d | 2003-11-21 A | 2004-02-19 A | 100% | 2003-11-21 | 2004-02-19 | 64d |  | start no earlier than 2003-11-21 | GP,GP, N1 | 512h | 512h | SCSAGB-PSH | Rel-6 |  | Paolo | Ericsson | David Bladsjö (david.bladsjo@ericsson.com) | GP-18 |
| 1584 | 450.6 | Delete - Modifications to FLO | milestone | 0d? | 2003-11-21 A | 2003-11-21 A | 100% | 2003-11-21 | 2003-11-21 | 0d? |  | finish no earlier than 2003-11-21 | GP,G2 |  |  | SCSAGB-FLO | Rel-6 |  | Paolo | Ericsson | David Bladsjö (david.bladsjo@ericsson.com) | RP-29 |
| 1585 | 451 | Deleted - Rel-6 Evolutions of the transport in the UTRAN | milestone | 0d | 2003-12-31 A | 2003-12-31 A | 100% | 2003-12-31 | 2003-12-31 | 0d |  | start no earlier than 2003-12-31 | RP |  |  | ETRAN | Rel-6 |  | Stefania | Alcatel | Francois Courau | RP-22 |
| 1586 | 452 | Release 5 Features |  | 1d? | 2000-01-03 | 2000-01-03 |  | 2000-01-03 | 2000-01-03 | 1d? | 3317d |  | NP,GP, RP,SP,TP | 8h |  |  | Rel-5 |  |  |  |  |  |
| 1587 | 75 | IP transport in the UTRAN |  | 445d | 2000-07-17 A | 2002-03-29 A | 100% | 2000-07-17 | 2002-03-29 | 445d |  | finish no earlier than 2002-03-29 | R3 | 3560h | 3560h | ETRAN-IPtrans | Rel-5 |  | Juha | Alcatel | Nicolas Drevon |  |
| 1588 | 76 | FS on Usage of SUA |  | 205d | 2001-03-12 A | 2001-12-21 A | 100% | 2001-03-12 | 2001-12-21 | 205d |  | finish no earlier than 2001-12-21 | N4 | 1640h | 1640h | SS7IP | Rel-5 |  | Kimmo |  |  |  |
| 1589 | 77 | **High Speed Downlink Packet Access** |  | 570d | 2001-04-02 A | 2003-06-06 A | 100% | 2001-04-02 | 2003-06-06 | 570d |  |  | R2 | 15272h | 15272h | HSDPA | Rel-5 |  | Joern | Motorola | Ravi Kuchibhotla |  |
| 1590 | 77.1 | Physical Layer |  | 257d | 2001-04-05 A | 2002-03-29 A | 100% | 2001-04-05 | 2002-03-29 | 257d |  | finish no earlier than 2002-03-29 | R1 | 2056h | 2056h | HSDPA-Phys | Rel-5 |  | Patrick | Motorola | Amitava Ghosh |  |
| 1591 | 77.2 | Layer 2 and 3 aspects |  | 257d | 2001-04-05 A | 2002-03-29 A | 100% | 2001-04-05 | 2002-03-29 | 257d |  | finish no earlier than 2002-03-29 | R2 | 2056h | 2056h | HSDPA-L23 | Rel-5 |  | Joern | Motorola | Ravi Kuchibhotla |  |
| 1592 | 77.3 | Iub/Iur protocol aspects |  | 260d | 2001-04-02 A | 2002-03-29 A | 100% | 2001-04-02 | 2002-03-29 | 260d |  | finish no earlier than 2002-03-29 | R3 | 2080h | 2080h | HSDPA-IubIur | Rel-5 |  | Juha | Motorola | Mike Diesen |  |
| 1593 | 77.4 | RF Radio Transmission/ Reception, System Performance Requirements and Conformance Testing |  | 565d | 2001-04-09 A | 2003-06-06 A | 100% | 2001-04-09 | 2003-06-06 | 565d |  | finish no earlier than 2003-06-06 | R4 | 4520h | 4520h | HSDPA-RF | Rel-5 |  | Stefania | Motorola | Howard Benn |  |
| 1594 | 78 | **Rel-5 Improvements of Radio Interface** |  | 535d | 2000-08-14 A | 2002-08-30 A | 100% | 2000-08-14 | 2002-08-30 | 535d |  |  | RP | 30376h | 30376h | RInImp | Rel-5 |  | Stefania |  |  |  |
| 1595 | 78.1 | **Base station classification** |  | 480d | 2000-08-14 A | 2002-06-14 A | 100% | 2000-08-14 | 2002-06-14 | 480d |  |  | R4 | 9208h | 9208h | RInImp-BSClass | Rel-5 |  | Stefania | Nokia | antti.toskala@nokia.com |  |
| 1596 | 78.1.1 | TDD Base station classification |  | 410d | 2000-08-14 A | 2002-03-08 A | 100% | 2000-08-14 | 2002-03-08 | 410d |  | finish no earlier than 2002-03-08 | R4 | 3280h | 3280h | RInImp-BSClass-TDD | Rel-5 |  | Stefania | Nokia | antti.toskala@nokia.com |  |
| 1597 | 78.1.2 | Base Station Classification for 1.28 Mcps TDD option |  | 261d | 2001-06-15 A | 2002-06-14 A | 100% | 2001-06-15 | 2002-06-14 | 261d |  | finish no earlier than 2002-06-14 | R4 | 2088h | 2088h | RInImp-BSClass-LCRTDD | Rel-5 |  | Stefania | Siemens | Meik.Kottkamp@siemens.com |  |
| 1598 | 78.2 | Enhancement on the DSCH hard split mode |  | 271d | 2001-03-16 A | 2002-03-29 A | 100% | 2001-03-16 | 2002-03-29 | 271d |  | finish no earlier than 2002-03-29 | R1 | 2168h | 2168h | RInImp-DSCHhsp | Rel-5 |  | Patrick | Samsung | Jaeyoel KIM |  |
| 1599 | 78.3 | Hybrid ARQ II/III |  | 355d | 2000-08-21 A | 2001-12-28 A | 100% | 2000-08-21 | 2001-12-28 | 355d |  | finish no earlier than 2001-12-28 | R2 | 2840h | 2840h | RInImp-HARQ | Rel-5 |  | Joern | Siemens | A. Sitte | RP-14 |
| 1600 | 78.4 | FS on USTS |  | 355d | 2000-08-14 A | 2001-12-21 A | 100% | 2000-08-14 | 2001-12-21 | 355d |  | finish no earlier than 2001-12-21 | R1 | 2840h | 2840h | RInImp-USTS | Rel-5 |  | Patrick | SK Telecom | D. Kim |  |
| 1601 | 78.5 | FS on UE antenna efficency test method performance requirements |  | 255d | 2000-09-25 A | 2001-09-14 A | 100% | 2000-09-25 | 2001-09-14 | 255d |  | finish no earlier than 2001-09-14 | R4 | 2040h | 2040h | RInImp-UEAnTM | Rel-5 |  | Stefania | Allgon | O. Edvardsson |  |
| 1602 | 78.6 | FS on the re-introduction of the downlink SIR measurement |  | 200d | 2001-03-12 A | 2001-12-14 A | 100% | 2001-03-12 | 2001-12-14 | 200d |  | finish no earlier than 2001-12-14 | R4 | 1600h | 1600h | RInImp-SIR | Rel-5 |  | Stefania | Ericsson | Torgny.Palenius@ericsson.com |  |
| 1603 | 78.7 | FS on mitigating the effect of CPICH interference at the UE |  | 255d | 2001-03-19 A | 2002-03-08 A | 100% | 2001-03-19 | 2002-03-08 | 255d |  | finish no earlier than 2002-03-08 | R4 | 2040h | 2040h | RInImp-CPICH_Intf | Rel-5 |  | Stefania | Intel | shimon.moshavi@INTEL.COM |  |

Notes:
- 1574: "Joker" WI, to be used for a Rel 6 CR not related to any feature and with very limited impact on the system. Moved in from Stoyan/Testing WP
- 1575: "Joker" WI, to be used for small modifications applicable to Rel 4 conformance testing
- 1576: SP-23 - To be abandoned?
- 1577: Voice Group Call Service
- 1578: -
- 1579: -
- 1580: Started
- 1581: Not started
- 1582: Not started
- 1583: Started
- 1584: Not started
- 1585: Generic feature
- 1586: -
- 1587: -
- 1588: -
- 1589: -
- 1590: -
- 1591: -
- 1592: -
- 1593: -
- 1594: -
- 1595: -
- 1596: -
- 1597: -
- 1598: -
- 1599: Stopped at RP#14; work on this task was performed as part of High Speed Downlink Packet Access feature
- 1600: -
- 1601: -
- 1602: -
- 1603: -

| ID | WBS | Task | Duration | Start | Finish | Complete | Baseline start | Baseline finish | Baseline duration | Constraint | Resources | Work | Actual work | Text6 | Text8 | Text12 | Text1 | Text4 | Text5 | Text3 |
| --- | --- | --- | --- | --- | --- | --- | --- | --- | --- | --- | --- | --- | --- | --- | --- | --- | --- | --- | --- | --- |
| 1604 | 78.8 | **Deleted - Conformance Test Spec. improvements in Radio Interface** | 140d | 2002-02-18 A | 2002-08-30 A | 100% | 2002-02-18 | 2002-08-30 | 140d |  | T1 | 3360h | 3360h | Rel-5 | Ingbert | TP-22 |  |  |  |  |
| 1605 | 78.8.1 | Deleted - Testing improvement of inter-frequency and inter-system measurement | 140d | 2002-02-18 A | 2002-08-30 A | 100% | 2002-02-18 | 2002-08-30 | 140d | finish no earlier than 2002-08-30 | T1 | 1120h | 1120h | Rel-5 | Ingbert | TP-22 |  |  |  |  |
| 1606 | 78.8.2 | Deleted - Testing Hybrid ARQ II/III | 140d | 2002-02-18 A | 2002-08-30 A | 100% | 2002-02-18 | 2002-08-30 | 140d | finish no earlier than 2002-08-30 | T1 | 1120h | 1120h | Rel-5 | Ingbert | TP-22 |  |  |  |  |
| 1607 | 79 | **Rel-5 RAN improvements** | 772d? | 2001-03-16 A | 2004-03-01 A | 100% | 2001-03-16 | 2004-03-01 | 772d? |  | RP | 39984h | 39984h | Rel-5 | Stefania |  | RANimp |  |  |  |
| 1608 | 79.1 | **RRM optimization for Iur and Iub** | 318d | 2001-03-16 A | 2002-06-04 A | 100% | 2001-03-16 | 2002-06-04 | 318d |  | R3 | 8904h | 8904h | Rel-5 | Juha |  | RANimp-RRMopt | Ericsson | Gert-Jan.van.Lieshout@eln.ericsson.se |  |
| 1609 | 79.1.1 | Iur common transport channel efficiency optimisation | 271d | 2001-03-16 A | 2002-03-29 A | 100% | 2001-03-16 | 2002-03-29 | 271d | finish no earlier than 2002-03-29 | R3 | 2168h | 2168h | Rel-5 | Juha |  | RANimp-RRMopt-ctc | Ericsson | Shahrokh Amirijoo |  |
| 1610 | 79.1.2 | Iur neighbouring cell reporting efficiency optimisation | 271d | 2001-03-16 A | 2002-03-29 A | 100% | 2001-03-16 | 2002-03-29 | 271d | finish no earlier than 2002-03-29 | R3 | 2168h | 2168h | Rel-5 | Juha |  | RANimp-RRMopt-ncr | Ericsson | Shahrokh Amirijoo |  |
| 1611 | 79.1.3 | FS Introduction of direct transport bearers between SRNC and Node-B | 253d | 2001-06-15 A | 2002-06-04 A | 100% | 2001-06-15 | 2002-06-04 | 253d | finish no earlier than 2002-06-28 | R3 | 2024h | 2024h | Rel-5 | Juha |  | RAN-imp-RRMopt-DTB | Ericsson | Risto Sepponen |  |
| 1612 | 79.2 | RL Timing Adjustment | 271d | 2001-03-16 A | 2002-03-29 A | 100% | 2001-03-16 | 2002-03-29 | 271d | finish no earlier than 2002-03-29 | R3 | 2168h | 2168h | Rel-5 | Juha |  | RANimp-RLTA | Ericsson | Elena Voltolina |  |
| 1613 | 79.3 | Separation of resource reservation and radio link activation | 271d | 2001-03-16 A | 2002-03-29 A | 100% | 2001-03-16 | 2002-03-29 | 271d | finish no earlier than 2002-03-29 | R3 | 2168h | 2168h | Rel-5 | Juha |  | RANimp-SepRR | Ericsson | Gert-Jan.van.Lieshout@eln.ericsson.se |  |
| 1614 | 79.4 | FS SRNS Relocation Procedure Enhancement | 318d | 2001-06-15 A | 2002-09-03 A | 100% | 2001-06-15 | 2002-09-03 | 318d | finish no earlier than 2002-09-06 | R3 | 2544h | 2544h | Rel-5 | Juha |  | RANimp-SRNS | Nokia | Olivier Guyot |  |
| 1615 | 79.5 | FS Improvement of Radio Resource Management across RNS and RNS/PSS | 201d | 2001-03-16 A | 2001-12-21 A | 100% | 2001-03-16 | 2001-12-21 | 201d | finish no earlier than 2001-12-21 | R3 | 1608h | 1608h | Rel-5 | Juha |  | RANimp-ImpRRM | Nokia | antti.toskala@nokia.com |  |
| 1616 | 79.6 | Re-arrangements of Iub transport bearers | 271d | 2001-03-16 A | 2002-03-29 A | 100% | 2001-03-16 | 2002-03-29 | 271d | finish no earlier than 2002-03-29 | R3 | 2168h | 2168h | Rel-5 | Juha |  | RANimp-TTPS | Nokia | antti.toskala@nokia.com |  |
| 1617 | 79.7 | RAB support enhancement for Rel-5 | 325d | 2001-04-02 A | 2002-06-28 A | 100% | 2001-04-02 | 2002-06-28 | 325d | finish no earlier than 2002-06-28 | R2 | 2600h | 2600h | Rel-5 | Joern |  | RANimp-RABSE5 | Nokia | Juha Mikola |  |
| 1618 | 79.8 | Beamforming requirements for UE | 61d | 2001-09-21 A | 2001-12-14 A | 100% | 2001-09-21 | 2001-12-14 | 61d | finish no earlier than 2001-12-14 | R1 | 488h | 488h | Rel-5 | Patrick |  | RANimp-BFR-UE | Nokia | Jussi Kähtävä (juha.mikola@nokia.com) |  |
| 1619 | 79.9 | Support of Site Selection Diversity Transmission in UTRAN | 123d | 2001-12-14 A | 2002-06-04 A | 100% | 2001-12-14 | 2002-06-04 | 123d | finish no earlier than 2002-06-04 | R1 | 984h | 984h | Rel-5 | Patrick |  | RANimp-SSDT | NEC |  |  |
| 1620 | 79.10 | Node B Synchronisation for 1.28 Mcps TDD | 271d | 2001-03-16 A | 2002-03-29 A | 100% | 2001-03-16 | 2002-03-29 | 271d | finish no earlier than 2002-03-29 | R1 | 2168h | 2168h | Rel-5 | Patrick |  | RANimp-NBSLCR | CATT | Jinling HU |  |
| 1621 | 79.12 | **Deleted - Conformance Test Aspects - RAN Improvements** | 565d? | 2002-01-01 A | 2004-03-01 A | 100% | 2002-01-01 | 2004-03-01 | 565d? |  | T1 | 8008h | 8008h | Rel-5 | Ingbert |  |  |  |  | 0% |
| 1622 | 79.12.1 | Deleted - Testing Radio access bearer support enhancments | 175d | 2002-01-01 A | 2002-09-02 A | 100% | 2002-01-01 | 2002-09-02 | 175d | finish no earlier than 2002-09-02 | T1 | 1400h | 1400h | Rel-5 | Ingbert | TP-22 |  |  |  |  |
| 1623 | 457.11.2 | Deleted - General changes to TS34.121 and TS34.122 corresponding to release 5 | 261d? | 2003-03-03 A | 2004-03-01 A | 100% | 2003-03-03 | 2004-03-01 | 261d? | finish no earlier than 2004-03-01 | T1 | 2088h | 2088h | Rel-5 | Ingbert |  | RANimp-test |  |  | 34.108, 34.121, 34.122 |
| 1624 | 80 | UTRAN Sharing in Connected Mode | 197d | 2001-12-03 A | 2002-09-03 A | 100% | 2001-12-03 | 2002-09-03 | 197d | finish no earlier than 2002-09-06 | R3 | 1576h | 1576h | Rel-5 | Juha |  | NETSHARE | Ericsson | Martin Israelsson |  |
| 1625 | 81 | **Provisioning of IP-based multimedia services** | 1089d | 2000-01-03 A | 2004-03-03 A | 100% | 2000-01-03 | 2004-03-03 | 1089d |  | S1,S2,S5 | 187156h | 187156h | Rel-5 | Alain |  | IMS | Openwave | Mark Cataldo |  |
| 1626 | 81.1 | **Call control and roaming to support IMS in UMTS** | 641d | 2000-01-03 A | 2002-06-14 A | 100% | 2000-01-03 | 2002-06-14 | 641d |  | S2 | 82528h | 82528h | Rel-5 | Maurice |  | IMS-CCR | Lucent | Liz Daniel |  |
| 1627 | 81.1.1 | Stage 1 | 215d | 2000-02-21 A | 2000-12-15 A | 100% | 2000-02-21 | 2000-12-15 | 215d | finish no earlier than 2000-09-21 | S1 | 1720h | 1720h | Rel-5 | Alain |  | IMS-CCR | Motorola | Mark Cataldo | 22.228 |
| 1628 | 81.1.2 | Stage 2 (Architecture and Main flows) | 246d | 2000-04-14 A | 2001-03-23 A | 100% | 2000-04-14 | 2001-03-23 | 246d | finish no earlier than 2001-03-23 | S2 | 1968h | 1968h | Rel-5 | Maurice |  | IMS-CCR | Lucent | Liz Daniel | 23.228 |
| 1629 | 81.1.3 | Impact on MM/CC/SM | 400d | 2000-08-28 A | 2002-03-08 A | 100% | 2000-08-28 | 2002-03-08 | 400d | finish no earlier than 2002-03-08 | N1 | 3200h | 3200h | Rel-5 | Frederic |  | IMS-CCR-IWMM | Lucent | Keith Drage (drage@alcatel-lucent.com) |  |

Notes:
- 1604: Marked as stopped 12/2008
- 1605: start/finish dates set...Marked as stopped 12/2008
- 1606: start/finish dates set...Marked as stopped 12/2008
- 1607: -
- 1608: -
- 1609: -
- 1610: -
- 1611: FS was closed and introduction of WI not agreed at RAN #16
- 1612: -
- 1613: -
- 1614: -
- 1615: FS was closed and WI was introduced at RAN #14
- 1616: -
- 1617: RFC 3095 context relocation
- 1618: -
- 1619: RP-020356
- 1620: -
- 1621: Marked as stopped 12/2008
- 1622: duration set to 6 months (was 0)...Marked as stopped 12/2008
- 1623: Marked as stopped 12/2008
- 1624: Formerly 'Shared Network support in connected mode', renamed at RAN #16.
- 1625: S1 WI proposed S1-000290 / TR22.976, WI Rapporteur, Mark Cataldo, Motorola
- 1626: -
- 1627: Issues include e.g.: Roaming requirements, Requirements on supplementary services, Interworking requirements
- 1628: Issues include e.g.: Mobile IP, RAB selection principles, Optimized VoIP bearer mechanisms, SIP multimedia protocol
- 1629: Per 26/2-02: This is understood to be the PCO & TFT CRs which CN1 provides to TSGN #15 for approval. If this is correct understanding, then the task is 100 % complete.

| ID | WBS | Task | Duration | Start | Finish | Complete | Baseline start | Baseline finish | Baseline duration | Constraint | Resources | Work | Actual work | Text1 | Text3 | Text4 | Text5 | Text6 | Text8 |
| --- | --- | --- | --- | --- | --- | --- | --- | --- | --- | --- | --- | --- | --- | --- | --- | --- | --- | --- | --- |
| 1630 | 81.1.4 | **SIP Call Control protocol for the IMS** | 641d | 2000-01-03 A | 2002-06-14 A | 100% | 2000-01-03 | 2002-06-14 | 641d |  | N1 | 70808h | 70808h | IMS-CCR | 24.228, 24.229, 23.218 | Lucent | Keith Drage (drage@alcatel-lucent.com) | Rel-5 | Frederic |
| 1631 | 81.1.4.1 | IMS signalling flows | 385d | 2000-10-02 A | 2002-03-22 A | 100% | 2000-10-02 | 2002-03-22 | 385d | finish no earlier than 2002-03-22 | N1 | 3080h | 3080h | IMS-CCR | 24.228 |  |  | Rel-5 | Frederic |
| 1632 | 81.1.4.2 | IMS stage 3 | 385d | 2000-10-02 A | 2002-03-22 A | 100% | 2000-10-02 | 2002-03-22 | 385d | finish no earlier than 2002-03-22 | N1 | 3080h | 3080h | IMS-CCR | 24.229 |  |  | Rel-5 | Frederic |
| 1633 | 81.1.4.3 | IMS Session Handling; stage 2 | 385d | 2000-10-02 A | 2002-03-22 A | 100% | 2000-10-02 | 2002-03-22 | 385d | finish no earlier than 2002-03-22 | N1 | 3080h | 3080h | IMS-CCR | 23.218 |  |  | Rel-5 | Frederic |
| 1634 | 81.1.4.4 | **Main IETF dependencies** | 636d | 2000-01-03 A | 2002-06-07 A | 100% | 2000-01-03 | 2002-06-07 | 636d |  | NP | 45400h | 45400h | IMS |  |  |  | Rel-5 | Kimmo |
| 1635 | 81.1.4.4.1 | IETF: RFC 3261 (Session Initiation Protocol) | 346d | 2000-11-24 A | 2002-03-22 A | 100% | 2000-11-24 | 2002-03-22 | 346d | finish no earlier than 2002-03-22 | N1 | 2768h | 2768h | IMS |  |  |  | Rel-5 | Frederic |
| 1636 | 81.1.4.4.2 | IETF: RFC 3262 (Reliability of provisional responses) | 346d | 2000-11-24 A | 2002-03-22 A | 100% | 2000-11-24 | 2002-03-22 | 346d | finish no earlier than 2002-03-22 | N1 | 2768h | 2768h | IMS |  |  |  | Rel-5 | Frederic |
| 1637 | 81.1.4.4.3 | IETF: RFC 3312 (Without COMET)(Integration of resource management and SIP) | 382d | 2000-11-24 A | 2002-05-13 A | 100% | 2000-11-24 | 2002-05-13 | 382d | finish no earlier than 2002-05-13 | N1 | 3056h | 3056h | IMS |  |  |  | Rel-5 | Frederic |
| 1638 | 81.1.4.4.4 | IETF: RFC 3323 (SIP extensions for caller identity and privacy) | 382d | 2000-11-24 A | 2002-05-13 A | 100% | 2000-11-24 | 2002-05-13 | 382d | finish no earlier than 2002-05-13 | N1 | 3056h | 3056h | IMS |  |  |  | Rel-5 | Frederic |
| 1639 | 81.1.4.4.5 | IETF: RFC 3313 (SIP extensions for media authorization) | 382d | 2000-11-24 A | 2002-05-13 A | 100% | 2000-11-24 | 2002-05-13 | 382d | finish no earlier than 2002-05-13 | N1 | 3056h | 3056h | IMS |  |  |  | Rel-5 | Frederic |
| 1640 | 81.1.4.4.6 | IETF: RFC 3265 (specific event notification) | 346d | 2000-11-24 A | 2002-03-22 A | 100% | 2000-11-24 | 2002-03-22 | 346d | finish no earlier than 2002-03-22 | N1 | 2768h | 2768h | IMS |  |  |  | Rel-5 | Frederic |
| 1641 | 81.1.4.4.7 | IETF: RFC editor Queue (refer method) | 401d | 2000-11-24 A | 2002-06-07 A | 100% | 2000-11-24 | 2002-06-07 | 401d | finish no earlier than 2002-06-07 | N1 | 3208h | 3208h | IMS |  |  |  | Rel-5 | Frederic |
| 1642 | 81.1.4.4.8 | IETF: RFC editor Queue (DHCP options for SIP servers) | 382d | 2000-11-24 A | 2002-05-13 A | 100% | 2000-11-24 | 2002-05-13 | 382d | finish no earlier than 2002-05-13 | N1 | 3056h | 3056h | IMS |  |  |  | Rel-5 | Frederic |
| 1643 | 81.1.4.4.10 | IETF: RFC 3267 (AMR and AMR WB RTP and SDP) | 346d | 2000-11-24 A | 2002-03-22 A | 100% | 2000-11-24 | 2002-03-22 | 346d | finish no earlier than 2002-03-22 | N1 | 2768h | 2768h | IMS |  |  |  | Rel-5 | Frederic |
| 1644 | 81.1.4.4.11 | IETF: RFC 3266 (IPv6 support within SDP) | 581d | 2000-01-03 A | 2002-03-22 A | 100% | 2000-01-03 | 2002-03-22 | 581d | finish no earlier than 2002-03-22 | N1 | 4640h | 4640h | IMS |  |  |  | Rel-5 | Frederic |
| 1645 | 81.1.4.4.12 | IETF: RFC 3311 (The Update method) | 382d | 2000-11-24 A | 2002-05-13 A | 100% | 2000-11-24 | 2002-05-13 | 382d | finish no earlier than 2002-05-13 | N1 | 3056h | 3056h | IMS |  |  |  | Rel-5 | Frederic |
| 1646 | 81.1.4.4.13 | IETF: RFC 3324 (Network Asserted Identity) | 382d | 2000-11-24 A | 2002-05-13 A | 100% | 2000-11-24 | 2002-05-13 | 382d | finish no earlier than 2002-05-13 | N1 | 3056h | 3056h | IMS |  |  |  | Rel-5 | Frederic |
| 1647 | 81.1.4.4.14 | IETF: RFC editor Queue (Various 3GPP Private Extensions) | 382d | 2000-11-24 A | 2002-05-13 A | 100% | 2000-11-24 | 2002-05-13 | 382d | finish no earlier than 2002-05-13 | N1 | 3056h | 3056h | IMS |  |  |  | Rel-5 | Frederic |
| 1648 | 81.1.4.5 | **Addressing** | 380d | 2000-10-09 A | 2002-03-22 A | 100% | 2000-10-09 | 2002-03-22 | 380d |  | S2 | 7744h | 7744h | IMS |  |  |  | Rel-5 | Maurice |
| 1649 | 81.1.4.5.1 | Architectural issues | 235d | 2000-10-09 A | 2001-08-31 A | 100% | 2000-10-09 | 2001-08-31 | 235d | finish no earlier than 2001-03-16 | S2 | 1880h | 1880h | IMS |  |  |  | Rel-5 | Maurice |
| 1650 | 81.1.4.5.2 | Impact on HSS | 353d | 2000-11-15 A | 2002-03-22 A | 100% | 2000-11-15 | 2002-03-22 | 353d | finish no earlier than 2002-03-22 | N4 | 2824h | 2824h | IMS |  |  |  | Rel-5 | Kimmo |
| 1651 | 81.1.4.6 | **Service Examples (Work stopped)** | 304d | 2001-04-17 A | 2002-06-14 A | 100% | 2001-04-17 | 2002-06-14 | 304d |  | S1 | 4864h | 4864h | IMS-Sex | 22.928 | Motorola | Mark Cataldo | Rel-5 | Alain |
| 1652 | 81.1.4.6.1 | IMS Framework Report (work stopped) | 304d | 2001-04-17 A | 2002-06-14 A | 100% | 2001-04-17 | 2002-06-14 | 304d | finish no earlier than 2002-06-14 | S1 | 2432h | 2432h | IMS-FrWk | 22.941 | SBC | Randolph Wohlert (rwohlert@tri.sbc.com) | Rel-5 | Alain |
| 1653 | 81.2 | **Access Security for IMS** | 190d | 2001-10-08 A | 2002-06-28 A | 100% | 2001-10-08 | 2002-06-28 | 190d |  | S3 | 4120h | 4120h | IMS-ASEC |  | Ericsson | krister.boman@emw.ericsson.se | Rel-5 | Dionisio |
| 1654 | 81.2.2 | IMS impacts on UICC (ISIM application) | 185d | 2001-10-08 A | 2002-06-21 A | 100% | 2001-10-08 | 2002-06-21 | 185d | finish no earlier than 2002-06-21 | T3 | 1480h | 1480h |  |  | Vodafone | Jeremy Norris | Rel-5 |  |
| 1655 | 81.2.3 | SIP extensions for Integrity protection | 140d | 2001-12-17 A | 2002-06-28 A | 100% | 2001-12-17 | 2002-06-28 | 140d | finish no earlier than 2002-06-28 | N1 | 1120h | 1120h |  |  |  |  | Rel-5 | Frederic |
| 1656 | 81.3 | Security Aspects of Requirement for Network Configuration Independence | 130d | 2001-07-02 A | 2001-12-28 A | 100% | 2001-07-02 | 2001-12-28 | 130d | finish no earlier than 2001-12-28 | S3 | 1040h | 1040h | SEC1-NCI |  | AT&T Wireless | hugh.shieh@attws.com | Rel-5 | Dionisio |
| 1657 | 81.4 | Lawful interception | 410d | 2000-09-04 A | 2002-03-29 A | 100% | 2000-09-04 | 2002-03-29 | 410d | finish no earlier than 2002-03-29 | S3 | 3280h | 3280h | IMS-LI |  | Reg TP | berthold.wilhelm@regtp.de | Rel-5 | Dionisio |
| 1658 | 81.5 | Charging and OAM&P for IMS | 383d | 2000-12-25 A | 2002-06-12 A | 100% | 2000-12-25 | 2002-06-12 | 383d | finish no earlier than 2002-06-12 | S5 | 3064h | 3064h | IMS-OAM | 32-series | VoiceStream, Motorola |  | Rel-5 | Dionisio |

Notes:
- 1630: TSGN_10 approved the change:CN1 - SA2 SIP joint meeting spotted one more place for improvement: work tasks with ID 1998 and 1278 are actually subtasks under of single CN1 WT. One WI has been approved for the CN1 WT with title "SIP Call Control protocol...
- 1631: TS 24.228...
- 1632: TS 24.229...
- 1633: TS 23.218...
- 1634: -
- 1635: -
- 1636: -
- 1637: -
- 1638: -
- 1639: -
- 1640: -
- 1641: -
- 1642: -
- 1643: -
- 1644: -
- 1645: -
- 1646: -
- 1647: -
- 1648: -
- 1649: -
- 1650: 17th May, KK: This is cover by 29.228 & 29228. Work complete.
- 1651: -
- 1652: -
- 1653: TS33.203 will be presented for info at SP#14 and is scheduled for approval at SP#15. Dependencies on IETF exist. Approved SP#15
- 1654: -
- 1655: Per 26/2-02: CN1 is not aware of any requirements and is not doing anything on this task.
- 1656: Incorporated into IMS access security TS (33.203) which will be presented for info at SP#14 and is scheduled for approval at SP#15.Editors notes removed SP#16&17
- 1657: Rel-5 33.106 and 33.107 approved at SP#12.Revised WID including new Rel-5 specification (33.108) scheduled for approval at SP#14. 33.108 approved SP#16. CR at SP#17
- 1658: -

| ID | WBS | Task | Duration | Start | Finish | Complete | Baseline start | Baseline finish | Baseline duration | Constraint | Resources | Work | Actual work | Text1 | Text3 | Text4 | Text5 | Text6 | Text8 |
| --- | --- | --- | --- | --- | --- | --- | --- | --- | --- | --- | --- | --- | --- | --- | --- | --- | --- | --- | --- |
| 1659 | 81.6 | **Multimedia codecs and protocols for conversational PS services** | 568d | 2000-07-26 A | 2002-09-27 A | 100% | 2000-07-26 | 2002-09-27 | 568d |  | S4 | 15640h | 15640h | IMS-CODEC | 26.235, 26.236 | Toshiba, Nokia | B. Aronson (Toshiba), pasi.s.ojala@nokia.com | Rel-5 | Paolo |
| 1660 | 81.6.1 | Codecs | 427d | 2000-07-26 A | 2002-03-14 A | 100% | 2000-07-26 | 2002-03-14 | 427d | finish no earlier than 2001-03-21 | S4 | 3416h | 3416h |  | 26.235, 26.236 |  |  | Rel-5 | Paolo |
| 1661 | 81.6.2 | Transport protocols | 1d | 2002-03-12 A | 2002-03-12 A | 100% | 2002-03-12 | 2002-03-12 | 1d | finish no earlier than 2002-03-12 | S4 | 8h | 8h | IMS-CODEC | 26.236 | Nokia | P. Ojala | Rel-5 | Paolo |
| 1662 | 81.6.4 | recommendation for QoS parameter values for various media types | 195d | 2001-12-31 A | 2002-09-27 A | 100% | 2001-12-31 | 2002-09-27 | 195d | finish no earlier than 2002-09-27 | S4 | 1560h | 1560h |  |  |  |  | Rel-5 | Paolo |
| 1663 | 81.6.5 | IETF: RFC 3310 (HTTP Digest Authentication using AKA) | 382d | 2000-11-24 A | 2002-05-13 A | 100% | 2000-11-24 | 2002-05-13 | 382d | finish no earlier than 2002-05-13 | N1 | 3056h | 3056h |  |  |  |  | Rel-5 | Frederic |
| 1664 | 81.6.6 | IETF: RFC 3329 (Security mechanism agreement for SIP connections) | 382d | 2000-11-24 A | 2002-05-13 A | 100% | 2000-11-24 | 2002-05-13 | 382d | finish no earlier than 2002-05-13 | N1 | 3056h | 3056h |  |  |  |  | Rel-5 | Frederic |
| 1665 | 81.7 | **SIP message compression** | 185d | 2001-09-24 A | 2002-06-07 A | 100% | 2001-09-24 | 2002-06-07 | 185d |  | S2 | 3128h | 3128h |  |  |  |  | Rel-5 | Maurice |
| 1666 | 81.7.1 | Stage 2 | 25d | 2001-09-24 A | 2001-10-26 A | 100% | 2001-09-24 | 2001-10-26 | 25d | finish no earlier than 2001-10-26 | S2 | 200h | 200h |  |  |  |  | Rel-5 | Maurice |
| 1667 | 81.7.2 | Compression signalling | 181d | 2001-09-28 A | 2002-06-07 A | 100% | 2001-09-28 | 2002-06-07 | 181d | finish no earlier than 2002-06-07 | N1 | 1448h | 1448h |  |  |  |  | Rel-5 | Frederic |
| 1668 | 81.8 | **Stage 3 description of IMS interfaces** | 383d | 2001-03-14 A | 2002-08-30 A | 100% | 2001-03-14 | 2002-08-30 | 383d |  | NP | 29531.6h | 29531.6h |  |  |  |  | Rel-5 | Kimmo |
| 1669 | 81.8.1 | Cx interface (HSS to CSCF) | 135.95d | 2001-03-14 A | 2002-06-07 A | 100% | 2001-03-14 | 2002-06-07 | 135.95d | finish no earlier than 2002-06-07 | N4 | 1087.58h | 1087.58h |  |  |  |  | Rel-5 | Kimmo |
| 1670 | 81.8.2 | Mp interface (MRFC - MRFP) enhancements | 258d | 2001-03-14 A | 2002-03-08 A | 100% | 2001-03-14 | 2002-03-08 | 258d | finish no earlier than 2002-06-07 | N4 | 2064h | 2064h |  |  |  |  | Rel-5 | Kimmo |
| 1671 | 81.8.3 | Mw interface (CSCF to P-CSCF) | 323d | 2001-03-14 A | 2002-06-07 A | 100% | 2001-03-14 | 2002-06-07 | 323d | finish no earlier than 2002-06-07 | N1 | 2584h | 2584h |  |  |  |  | Rel-5 | Frederic |
| 1672 | 81.8.4 | Mr interface (CSCF to MRF) | 273d | 2001-03-14 A | 2002-03-29 A | 100% | 2001-03-14 | 2002-03-29 | 273d | finish no earlier than 2002-03-29 | N1 | 2184h | 2184h |  |  |  |  | Rel-5 | Frederic |
| 1673 | 81.8.5 | Dx interface (I-CSCF to SLF) | 323d | 2001-03-14 A | 2002-06-07 A | 100% | 2001-03-14 | 2002-06-07 | 323d | finish no earlier than 2002-06-07 | N4 | 2584h | 2584h |  |  |  |  | Rel-5 | Kimmo |
| 1674 | 81.8.6 | Go interface (GGSN to PCF) | 323d | 2001-03-14 A | 2002-06-07 A | 100% | 2001-03-14 | 2002-06-07 | 323d | finish no earlier than 2002-06-07 | N3 | 2584h | 2584h |  |  |  |  | Rel-5 | Gwiho |
| 1675 | 81.8.7 | ISC (IMS Service Control) Interface | 323d | 2001-03-14 A | 2002-06-07 A | 100% | 2001-03-14 | 2002-06-07 | 323d | finish no earlier than 2002-06-07 | N1 | 2584h | 2584h |  |  |  |  | Rel-5 | Frederic |
| 1676 | 81.8.8 | Sh interface (HSS to AS) | 82d | 2002-02-14 A | 2002-06-07 A | 100% | 2002-02-14 | 2002-06-07 | 82d | finish no earlier than 2002-06-07 | N4 | 656h | 656h |  |  |  |  | Rel-5 | Kimmo |
| 1677 | 81.8.9 | Si interface (HSS to IM-SSF) | 162.5d | 2002-01-16 A | 2002-08-30 A | 100% | 2002-01-16 | 2002-08-30 | 162.5d | finish no earlier than 2002-06-07 | N4 | 1300h | 1300h |  |  |  |  | Rel-5 | Kimmo |
| 1678 | 81.8.10 | Gm interface (UE to CSCF) | 323d | 2001-03-14 A | 2002-06-07 A | 100% | 2001-03-14 | 2002-06-07 | 323d | finish no earlier than 2002-06-07 | N1 | 2584h | 2584h |  |  |  |  | Rel-5 | Frederic |
| 1679 | 81.8.11 | Mi interface (CSCF to BGCF) | 323d | 2001-03-14 A | 2002-06-07 A | 100% | 2001-03-14 | 2002-06-07 | 323d | finish no earlier than 2002-06-07 | N1 | 2584h | 2584h |  |  |  |  | Rel-5 | Frederic |
| 1680 | 81.8.12 | Mj interface (BGCF to MGCF) | 323d | 2001-03-14 A | 2002-06-07 A | 100% | 2001-03-14 | 2002-06-07 | 323d | finish no earlier than 2002-06-07 | N1 | 2584h | 2584h |  |  |  |  | Rel-5 | Frederic |
| 1681 | 81.8.13 | Mk interface (BGCF to BGCF) | 323d | 2001-03-14 A | 2002-06-07 A | 100% | 2001-03-14 | 2002-06-07 | 323d | finish no earlier than 2002-06-07 | N1 | 2584h | 2584h |  |  |  |  | Rel-5 | Frederic |
| 1682 | 81.9 | Support of VHE/OSA by entities and protocols of the IMS (e.g. CSCF) | 186d | 2001-09-21 A | 2002-06-07 A | 100% | 2001-09-21 | 2002-06-07 | 186d | finish no earlier than 2002-06-07 | N5 | 1488h | 1488h | IMS-ONOSA | 29.198, 29.998 | Ericsson | Ard.Jan.Moerdijk@eln.ericsson.se | Rel-5 | Kimmo |

Notes:
- 1659: -
- 1660: -
- 1661: -
- 1662: -
- 1663: -
- 1664: -
- 1665: -
- 1666: -
- 1667: -
- 1668: -
- 1669: -
- 1670: [DAB 08-03-02] - No work required in CN4
- 1671: -
- 1672: -
- 1673: CN4#11 30/11/01: No inputs received in CN4 / 14/02/02 Completed(introduced in 29.228)
- 1674: [DAB - 23/05/03] - 100 % complete
- 1675: -
- 1676: CN4#11 30/11/01: No inputs received in CN4 / CN4#12bis 14/02/02: WID approved / 17th May 100% complete. 3GPP TS 29.329 will be sent for approval in CN#16
- 1677: SA16: Part of Rel5 only if completed in September 02. Marked as closed 12/2008 (was marked 72% complete)
- 1678: -
- 1679: -
- 1680: -
- 1681: -
- 1682: -

| ID | WBS | Task | Duration | Start | Finish | Predecessors | Complete | Baseline start | Baseline finish | Baseline duration | Constraint | Resources | Work | Actual work | Text1 | Text4 | Text5 | Text6 | Text8 | Text12 | Text3 |
| --- | --- | --- | --- | --- | --- | --- | --- | --- | --- | --- | --- | --- | --- | --- | --- | --- | --- | --- | --- | --- | --- |
| 1683 | 81.10 | **CAMEL control of IMS services** | 365d | 2001-04-16 A | 2002-09-06 A |  | 100% | 2001-04-16 | 2002-09-06 | 365d |  | N2 | 9952h | 9952h | IMS-CAMEL | Lucent | Angelica Remoquillo | Rel-5 | Kimmo |  |  |
| 1684 | 81.10.1 | Stage2 work 'general' | 365d | 2001-04-16 A | 2002-09-06 A |  | 100% | 2001-04-16 | 2002-09-06 | 365d | finish no earlier than 2002-09-06 | N2 | 2920h | 2920h |  |  |  | Rel-5 | Kimmo |  |  |
| 1685 | 81.10.2 | Stage3 work 'CAP' | 175d | 2002-01-07 A | 2002-09-06 A |  | 100% | 2002-01-07 | 2002-09-06 | 175d | finish no earlier than 2002-09-06 | N2 | 1400h | 1400h |  |  |  | Rel-5 | Kimmo |  |  |
| 1686 | 81.10.3 | Stage2 work 'Si interface' | 175d | 2002-01-07 A | 2002-09-06 A |  | 100% | 2002-01-07 | 2002-09-06 | 175d | finish no earlier than 2002-09-06 | N2 | 1400h | 1400h |  |  |  | Rel-5 | Kimmo |  |  |
| 1687 | 81.10.4 | Stage3 work 'Si interface' | 82d | 2002-02-14 A | 2002-06-07 A |  | 100% | 2002-02-14 | 2002-06-07 | 82d | finish no earlier than 2002-06-07 | N4 | 656h | 656h |  |  |  | Rel-5 | Kimmo |  |  |
| 1688 | 81.10.5 | Deleted - SDM issues for CAMEL control of IMS | 82d | 2002-02-14 A | 2002-06-07 A |  | 100% | 2002-02-14 | 2002-06-07 | 82d | finish no earlier than 2002-06-07 | N4 | 656h | 656h |  |  |  | Rel-5 | Kimmo | NP-21 |  |
| 1689 | 81.11 | Pre-pay/real-time charging in IMS | 196d | 2001-06-15 A | 2002-03-15 A |  | 100% | 2001-06-15 | 2002-03-15 | 196d | finish no earlier than 2002-03-15 | S1 | 1568h | 1568h |  |  |  | Rel-5 | Alain |  |  |
| 1690 | 81.12 | **Charging** | 289d | 2001-08-06 A | 2002-09-12 A |  | 100% | 2001-08-06 | 2002-09-12 | 289d |  | S2,S5 | 6632h | 6632h | OAM-CH | T-Mobile | karl-heinz.nenner@t-mobile.de | Rel-5 | Dionisio |  | 32.225 |
| 1691 | 81.12.1 | Charging Implications of IMS architecture | 75d | 2001-08-06 A | 2001-11-16 A |  | 100% | 2001-08-06 | 2001-11-16 | 75d | finish no earlier than 2001-11-16 | S2 | 600h | 600h |  |  |  | Rel-5 | Maurice |  |  |
| 1692 | 81.12.2 | Charging management for IMS (off-line & on-line) | 214d | 2001-11-19 A | 2002-09-12 A | 1691 | 100% | 2001-11-19 | 2002-09-12 | 214d | finish no earlier than 2002-09-12 | S5 | 1712h | 1712h | OAM-CH |  |  | Rel-5 | Dionisio |  | 32.225 |
| 1693 | 86.1.6.10 | Billing, accounting and call detail record aspects | 251d | 2001-09-27 A | 2002-09-12 A |  | 100% | 2001-09-27 | 2002-09-12 | 251d | finish no earlier than 2002-09-12 | S5 | 2008h | 2008h | OAM-CH | T-Mobile | Karl-Heinz.Nenner@T-MOBILE.DE | Rel-5 | Dionisio |  | 32.225 |
| 1694 | 81.13 | **Other IETF depencies** | 401d | 2000-11-24 A | 2002-06-07 A |  | 100% | 2000-11-24 | 2002-06-07 | 401d |  | NP | 9624h | 9624h |  |  |  | Rel-5 |  |  |  |
| 1695 | 81.13.1 | IETF: draft-ietf-aaa-diameter - should be CN4 | 401d | 2000-11-24 A | 2002-06-07 A |  | 100% | 2000-11-24 | 2002-06-07 | 401d | finish no earlier than 2002-06-07 | NP | 3208h | 3208h |  |  |  | Rel-5 |  |  |  |
| 1696 | 81.13.2 | IETF: draft-johansson-aaa-diameter-mm-app - should be CN4 | 401d | 2000-11-24 A | 2002-06-07 A |  | 100% | 2000-11-24 | 2002-06-07 | 401d | finish no earlier than 2002-06-07 | NP | 3208h | 3208h |  |  |  | Rel-5 |  |  |  |
| 1697 | 81.15 | Conformance Test Aspects - Provisioning of IMS | 205d | 2002-03-18 A | 2002-12-27 A |  | 100% | 2002-03-18 | 2002-12-27 | 205d | finish no earlier than 2002-12-27 | T1 | 1640h | 1640h | IMS-TEST |  |  | Rel-5 | Ingbert |  |  |
| 1698 | 81.16 | Testing of support for IMS - prose | 270d | 2002-09-18 A | 2003-09-30 A |  | 100% | 2002-09-18 | 2003-09-30 | 270d | finish no earlier than 2003-09-30 | T1 | 2160h | 2160h |  | Anritsu | dan.fox@eu.anritsu.com | Rel-5 | Ingbert |  | 34.108, 34.123 |
| 1699 | 81.17 | Testing of support for IMS - TTCN | 381d | 2002-09-18 A | 2004-03-03 A |  | 100% | 2002-09-18 | 2004-03-03 | 381d | finish no earlier than 2004-03-03 | T1 | 3048h | 3048h |  | Anritsu | dan.fox@eu.anritsu.com | Rel-5 | Ingbert |  | 34.108, 34.123 |
| 1700 | 82 | **Extended Transparent End-to-End PS Streaming Service** | 313d? | 2002-01-03 A | 2003-03-17 A |  | 100% | 2002-01-03 | 2003-03-17 | 313d? |  | S4 | 6224h | 6224h | PSS-E | Ericsson | olle.franceschi@ericsson.com | Rel-5 | Paolo |  | 26.233, 26.234 |
| 1701 | 82.1 | **Stage 1** | 86d? | 2002-11-18 A | 2003-03-17 A |  | 100% | 2002-11-18 | 2003-03-17 | 86d? |  | S1 | 1376h | 1376h |  | Vodafone | stephen.wolak@vodafone.com | Rel-5 | Alain |  | 22.233 |
| 1702 | 460.1.1 | Interaction with other services | 86d? | 2002-11-18 A | 2003-03-17 A |  | 100% | 2002-11-18 | 2003-03-17 | 86d? | finish no earlier than 2003-03-17 | S1 | 688h | 688h |  | Vodafone | stephen.wolak@vodafone.com | Rel-5 | Alain |  | 22.233 |
| 1703 | 82.2 | Stage 2 (version Rel5 of TS 26.234) | 51d | 2002-01-03 A | 2002-03-14 A |  | 100% | 2002-01-03 | 2002-03-14 | 51d | finish no earlier than 2002-03-26 | S4 | 408h | 408h |  |  |  | Rel-5 | Paolo |  | 26.234 |
| 1704 | 82.3 | RTP usage model | 242d | 2002-01-03 A | 2002-12-06 A |  | 100% | 2002-01-03 | 2002-12-06 | 242d | finish no earlier than 2002-12-06 | S4 | 1936h | 1936h |  |  |  | Rel-5 | Paolo |  | 26.937 |
| 1705 | 83 | **Rel-5 OSA enhancements** | 955d | 1999-04-27 A | 2002-12-20 A |  | 100% | 1999-04-27 | 2002-12-20 | 955d |  | S1 | 62480h | 62480h | OSA1 | Siemens | Joerg Swetina (joerg.swetina@nw.neclab.eu) | Rel-5 | Alain |  | 22.127, 23.127, 29.198-x, 29.998-x |
| 1706 | 83.1 | General Stage 2 for Rel5 | 194d | 2001-09-11 A | 2002-06-07 A |  | 100% | 2001-09-11 | 2002-06-07 | 194d |  | S2 | 1232h | 1232h |  |  |  | Rel-5 | Maurice |  |  |

Notes:
- 1683: SA16: Part of Rel5 only if Si completed in September 02
- 1684: DAB 12.12.01 split into cn4 and cn2 parts
- 1685: DAB 12.12.01 split into cn4 and cn2 parts
- 1686: DAB 12.12.01 split into cn4 and cn2 parts
- 1687: [DAB 08-03-02] - UID 12004 is MASTER of UID 14998 / 17 May need to be recearch possible impact on 23.008 & 23.016, changes to 29.002 are done.
- 1688: [DAB 08-03-02] - No activity on this in CN4. Marked as stopped 12/2008
- 1689: Marked as closed 12/2008 (was marked 60% complete)
- 1690: -
- 1691: -
- 1692: -
- 1693: -
- 1694: Was introduced at SP#13 by Ileana Leuca (exact position in the WP and related WG have to be defined)
- 1695: Marked as closed 12/2008 (was marked 90% complete)
- 1696: Marked as closed 12/2008 (was marked 50% complete)
- 1697: The task is a building block, individual work items are being considered but are constrained by lack of supporting companies. Marked as stopped 12/2008
- 1698: Marked as stopped 12/2008
- 1699: Marked as stopped 12/2008
- 1700: -
- 1701: 2nd resp SA4
- 1702: 2nd resp SA4. Marked as closed 12/2008 (was marked 65% complete)
- 1703: 2nd resp SA2
- 1704: Marked as closed 12/2008 (was marked 90% complete)
- 1705: -
- 1706: Marked as closed 12/2008 (was marked 47% complete)

| ID | WBS | Task | Duration | Start | Finish | Predecessors | Complete | Baseline start | Baseline finish | Baseline duration | Constraint | Resources | Work | Actual work | Text1 | Text6 | Text8 | Text3 | Text4 | Text5 |
| --- | --- | --- | --- | --- | --- | --- | --- | --- | --- | --- | --- | --- | --- | --- | --- | --- | --- | --- | --- | --- |
| 1707 | 83.2 | **OSA APIs for Multimedia Call Control** | 499d | 2000-07-11 A | 2002-06-07 A |  | 100% | 2000-07-11 | 2002-06-07 | 499d |  | S2 | 5960h | 5960h | OSA1-CSCF | Rel-5 | Maurice |  |  |  |
| 1708 | 83.2.1 | Stage 1 | 438d | 2000-07-11 A | 2002-03-14 A |  | 100% | 2000-07-11 | 2002-03-14 | 438d | finish no earlier than 2002-03-14 | S1 | 3504h | 3504h |  | Rel-5 | Alain | 22.127 | Siemens | Manfred.leitgeb@siemens.at |
| 1709 | 83.2.2 | (Multimedia) Call Control - Stages 2 and 3 | 194d | 2001-09-11 A | 2002-06-07 A |  | 100% | 2001-09-11 | 2002-06-07 | 194d | finish no earlier than 2002-06-07 | N5 | 1552h | 1552h |  | Rel-5 | Kimmo | 29.198-04 |  |  |
| 1710 | 83.3 | Generic user interaction - Stage 3 | 194d | 2001-09-11 A | 2002-06-07 A |  | 100% | 2001-09-11 | 2002-06-07 | 194d | finish no earlier than 2002-06-07 | N5 | 1552h | 1552h |  | Rel-5 | Kimmo | 29.198-05 |  |  |
| 1711 | 83.4 | Charging - Stage 3 | 194d | 2001-09-11 A | 2002-06-07 A |  | 100% | 2001-09-11 | 2002-06-07 | 194d | finish no earlier than 2002-06-07 | N5 | 1552h | 1552h |  | Rel-5 | Kimmo | 29.198-12 |  |  |
| 1712 | 83.5 | Call Control Service Mapping; Multiparty Call Control SIP - Stage 3 | 194d | 2001-09-11 A | 2002-06-07 A |  | 100% | 2001-09-11 | 2002-06-07 | 194d | finish no earlier than 2002-06-07 | N5 | 1552h | 1552h |  | Rel-5 | Kimmo | 29.998-04-4 |  |  |
| 1713 | 83.6 | WSDL APIs for SOAP/HTTP - Stage 3 | 455d | 2000-09-11 A | 2002-06-07 A |  | 100% | 2000-09-11 | 2002-06-07 | 455d | finish no earlier than 2002-06-07 | N5 | 3640h | 3640h |  | Rel-5 | Kimmo | 29.198, 29.998 |  |  |
| 1714 | 83.7 | **OSA security** | 639d | 2000-07-11 A | 2002-12-20 A |  | 100% | 2000-07-11 | 2002-12-20 | 639d |  | S3 | 15000h | 15000h | OSA1-SEC | Rel-5 | Dionisio |  | BT | colin.blanchard@bt.com |
| 1715 | 83.7.1 | Stage 1 | 349d | 2000-07-11 A | 2001-11-09 A |  | 100% | 2000-07-11 | 2001-11-09 | 349d | finish no earlier than 2001-11-09 | S1 | 2792h | 2792h |  | Rel-5 | Alain | 22.127 | Siemens | Manfred.leitgeb@siemens.at |
| 1716 | 83.7.2 | Stage 3 | 430d | 2000-10-23 A | 2002-06-14 A |  | 100% | 2000-10-23 | 2002-06-14 | 430d | finish no earlier than 2002-06-14 | S3 | 3440h | 3440h |  | Rel-5 | Dionisio |  |  |  |
| 1717 | 83.7.3 | security related SCF(s) definition | 186d | 2001-09-21 A | 2002-06-07 A |  | 100% | 2001-09-21 | 2002-06-07 | 186d | finish no earlier than 2002-06-07 | N5 | 1488h | 1488h |  | Rel-5 | Kimmo | 29.198, 29.998 | Ericsson | Ard.Jan.Moerdijk@eln.ericsson.se |
| 1718 | 83.7.4 | (possibly) changes required from supporting platforms, e.g. gsmSCF, HLR | 69d | 2000-09-11 A | 2000-12-14 A |  | 100% | 2000-09-11 | 2000-12-14 | 69d | finish no earlier than 2000-12-14 | S3 | 552h | 552h |  | Rel-5 | Dionisio |  |  |  |
| 1719 | 461.7.5 | Security (moved from Rel-6) | 202d | 2002-03-14 A | 2002-12-20 A |  | 100% | 2002-03-14 | 2002-12-20 | 202d | finish no earlier than 2002-12-20 | S3 | 1616h | 1616h |  | Rel-5 | Dionisio |  |  |  |
| 1720 | 83.8 | **Interactions OSA - e-commerce** | 815d | 1999-04-27 A | 2002-06-07 A |  | 100% | 1999-04-27 | 2002-06-07 | 815d |  | S2 | 6152h | 6152h | OSA1-ECOM | Rel-5 | Maurice |  |  |  |
| 1721 | 83.8.1 | Stage 1 | 439d | 1999-04-27 A | 2000-12-28 A |  | 100% | 1999-04-27 | 2000-12-28 | 439d | finish no earlier than 2000-12-28 | S1 | 3504h | 3504h |  | Rel-5 | Alain | 22.127 | Siemens | Joerg Swetina (joerg.swetina@nw.neclab.eu) |
| 1722 | 83.8.2 | Stages 2 and 3 | 186d | 2001-09-21 A | 2002-06-07 A |  | 100% | 2001-09-21 | 2002-06-07 | 186d | finish no earlier than 2002-06-07 | N5 | 1488h | 1488h |  | Rel-5 | Kimmo | 29.198, 29.998 | Ericsson | Ard.Jan.Moerdijk@eln.ericsson.se |
| 1723 | 83.9 | Policy Management - Stage 3 | 194d | 2001-09-11 A | 2002-06-07 A |  | 100% | 2001-09-11 | 2002-06-07 | 194d | finish no earlier than 2002-06-07 | N5 | 1552h | 1552h |  | Rel-5 | Kimmo | 29.198-13 |  |  |
| 1724 | 83.10 | Presence and Availability Management (PAM) - Stage 3 | 194d | 2001-09-11 A | 2002-06-07 A |  | 100% | 2001-09-11 | 2002-06-07 | 194d | finish no earlier than 2002-06-07 | N5 | 1552h | 1552h |  | Rel-5 | Kimmo | 29.198-14 |  |  |
| 1725 | 83.11 | **CHECK STATUS - LCS - OSA interfaces** | 455d | 2000-09-11 A | 2002-06-07 A |  | 100% | 2000-09-11 | 2002-06-07 | 455d |  | S1 | 5656h | 5656h | OSA1-LCSI | Rel-5 | Alain |  | Siemens | Joerg Swetina (joerg.swetina@nw.neclab.eu) |
| 1726 | 83.11.1 | Stage 1 | 65d | 2000-09-11 A | 2000-12-08 A |  | 100% | 2000-09-11 | 2000-12-08 | 65d | finish no earlier than 2000-12-08 | S1 | 520h | 520h |  | Rel-5 | Alain | 22.127 | Siemens | Joerg Swetina (joerg.swetina@nw.neclab.eu) |
| 1727 | 83.11.2 | Stage 2 | 1d | 2000-12-11 A | 2000-12-11 A | 1726 | 100% | 2000-12-11 | 2000-12-11 | 1d | finish no earlier than 2000-12-11 | S2 | 8h | 8h |  | Rel-5 | Maurice | 23.127 | Ericsson | Christophe GOURRAUD |
| 1728 | 83.11.3 | Stage 3 | 186d | 2001-09-21 A | 2002-06-07 A | 1727 | 100% | 2001-09-21 | 2002-06-07 | 186d | finish no earlier than 2002-06-07 | N5 | 1488h | 1488h |  | Rel-5 | Kimmo | 29.198, 29.998 | Ericsson | Ard.Jan.Moerdijk@eln.ericsson.se |
| 1729 | 461.12 | Access to User Profile | 145d | 2001-06-01 A | 2001-12-20 A |  | 100% | 2001-06-01 | 2001-12-20 | 145d | finish no earlier than 2001-12-20 | S1 | 1160h | 1160h | OSA2-UP | Rel-5 | Alain |  |  |  |
| 1730 | 461.13 | **Retrieval of Terminal capabilities** | 634d | 2000-07-11 A | 2002-12-13 A |  | 100% | 2000-07-11 | 2002-12-13 | 634d |  | S2 | 10808h | 10808h | OSA2-TC | Rel-5 | Maurice |  |  |  |
| 1731 | 461.13.1 | Stage 1 | 132d | 2000-07-11 A | 2001-01-10 A |  | 100% | 2000-07-11 | 2001-01-10 | 132d | finish no earlier than 2001-01-10 | S1 | 1056h | 1056h |  | Rel-5 | Alain | 22.127 | Siemens | Joerg Swetina (joerg.swetina@nw.neclab.eu) |
| 1732 | 461.13.2 | Stages 2 and 3 | 321d | 2001-09-21 A | 2002-12-13 A | 1731 | 100% | 2001-09-21 | 2002-12-13 | 321d | finish no earlier than 2002-12-13 | N5 | 2568h | 2568h |  | Rel-5 | Kimmo | 29.198, 29.998 | Ericsson | Ard.Jan.Moerdijk@eln.ericsson.se |
| 1733 | 461.13.3 | Provisionning of the terminal capabilities | 445d | 2001-04-02 A | 2002-12-13 A |  | 100% | 2001-04-02 | 2002-12-13 | 445d | finish no earlier than 2002-12-13 | T2 | 3560h | 3560h |  | Rel-5 |  | 23.057 |  |  |

Notes:
- 1707: For Rel5 even if completed by March
- 1708: -
- 1709: -
- 1710: -
- 1711: -
- 1712: -
- 1713: -
- 1714: CR to correct security specifications in 29.198 scheduled for approval at CN#15
- 1715: -
- 1716: Marked as closed 12/2008 (was marked 80% complete)
- 1717: -
- 1718: -
- 1719: Contribution at S3#25
- 1720: -
- 1721: Marked as closed 12/2008 (was marked 95% complete)
- 1722: -
- 1723: -
- 1724: -
- 1725: az: CN#13 - changed to Rel5
- 1726: -
- 1727: az 24/05/01: Rel4 completion 90->100%.
- 1728: -
- 1729: -
- 1730: -
- 1731: -
- 1732: -
- 1733: According to T2 SWG1 M. Cataldo this is automatically supported by the MExE support of UAProf therefore 100% complete

| ID | WBS | Task | Duration | Start | Finish | Predecessors | Complete | Baseline start | Baseline finish | Baseline duration | Constraint | Resources | Work | Actual work | Text1 | Text4 | Text5 | Text6 | Text8 | Text3 |
| --- | --- | --- | --- | --- | --- | --- | --- | --- | --- | --- | --- | --- | --- | --- | --- | --- | --- | --- | --- | --- |
| 1734 | 84 | **CAMEL phase 4** | 625d | 2000-04-17 A | 2002-09-06 A |  | 100% | 2000-04-17 | 2002-09-06 | 625d |  | S1 | 41104h | 41104h | CAMEL4 | Nokia | keijo.palviainen@nokia.com | Rel-5 | Alain |  |
| 1735 | 84.1 | Service requirements | 565d | 2000-04-17 A | 2002-06-14 A |  | 100% | 2000-04-17 | 2002-06-14 | 565d | finish no earlier than 2002-06-14 | S1 | 4520h | 4520h |  |  |  | Rel-5 | Alain |  |
| 1736 | 84.2 | Call Party Handling | 500d | 2000-07-10 A | 2002-06-07 A |  | 100% | 2000-07-10 | 2002-06-07 | 500d | finish no earlier than 2002-06-07 | N2 | 4000h | 4000h | CAMEL4-CPH |  |  | Rel-5 | Kimmo |  |
| 1737 | 84.3 | Mid call procedure for MO and MT calls | 495d | 2000-07-17 A | 2002-06-07 A |  | 100% | 2000-07-17 | 2002-06-07 | 495d | finish no earlier than 2002-06-07 | N2 | 3960h | 3960h | CAMEL4-MCP |  |  | Rel-5 | Kimmo |  |
| 1738 | 84.4 | Interactions with Optimal Routing | 430d | 2000-07-17 A | 2002-03-08 A |  | 100% | 2000-07-17 | 2002-03-08 | 430d | finish no earlier than 2002-03-08 | N2 | 3440h | 3440h | CAMEL4-IOR |  |  | Rel-5 | Kimmo |  |
| 1739 | 84.5 | Inclusion of flexible tone injection | 430d | 2000-07-17 A | 2002-03-08 A |  | 100% | 2000-07-17 | 2002-03-08 | 430d | finish no earlier than 2002-03-08 | N2 | 3440h | 3440h | CAMEL4-IFTI |  |  | Rel-5 | Kimmo |  |
| 1740 | 84.6 | CSE control over MT SMS | 430d | 2000-07-17 A | 2002-03-08 A |  | 100% | 2000-07-17 | 2002-03-08 | 430d | finish no earlier than 2002-03-08 | N2 | 3440h | 3440h | CAMEL4-CCSMS |  |  | Rel-5 | Kimmo |  |
| 1741 | 84.7 | Notification of GPRS mobility management to CSE | 331d | 2001-03-02 A | 2002-06-07 A |  | 100% | 2001-03-02 | 2002-06-07 | 331d | finish no earlier than 2002-06-07 | N2 | 2648h | 2648h | CAMEL4-NMM |  |  | Rel-5 | Kimmo |  |
| 1742 | 84.8 | Provision of location information of called subscriber | 266d | 2001-03-02 A | 2002-03-08 A |  | 100% | 2001-03-02 | 2002-03-08 | 266d | finish no earlier than 2002-03-08 | N2 | 2128h | 2128h | CAMEL4-LOCB |  |  | Rel-5 | Kimmo |  |
| 1743 | 84.9 | Inclusion of ODB data in the CSE_HLR interface | 175d | 2001-07-09 A | 2002-03-08 A |  | 100% | 2001-07-09 | 2002-03-08 | 175d | finish no earlier than 2002-03-08 | N2 | 1400h | 1400h | CAMEL4-ODB |  |  | Rel-5 | Kimmo |  |
| 1744 | 84.10 | Location information during an ongoing call (Handover DP) | 280d | 2001-05-14 A | 2002-06-07 A |  | 100% | 2001-05-14 | 2002-06-07 | 280d | finish no earlier than 2002-06-07 | N2 | 2240h | 2240h | CAMEL4-HODP |  |  | Rel-5 | Kimmo |  |
| 1745 | 84.11 | GPRS Any Time Interrogation | 240d | 2001-07-09 A | 2002-06-07 A |  | 100% | 2001-07-09 | 2002-06-07 | 240d | finish no earlier than 2002-06-07 | N2 | 1920h | 1920h | CAMEL4-ATI |  |  | Rel-5 | Kimmo |  |
| 1746 | 84.12 | Transfer of IMEI (with SW version) to CSE | 240d | 2001-07-09 A | 2002-06-07 A |  | 100% | 2001-07-09 | 2002-06-07 | 240d | finish no earlier than 2002-06-07 | N2 | 1920h | 1920h | CAMEL4-ATI |  |  | Rel-5 | Kimmo |  |
| 1747 | 84.13 | Handling of partial implementations of CAMEL4 | 131d | 2002-03-08 A | 2002-09-06 A |  | 100% | 2002-03-08 | 2002-09-06 | 131d | finish no earlier than 2002-06-07 | N2 | 1048h | 1048h | CAMEL4-SUB |  |  | Rel-5 | Kimmo |  |
| 1748 | 85 | **Rel-5 MExE enhancements** | 250d | 2001-03-26 A | 2002-03-08 A |  | 100% | 2001-03-26 | 2002-03-08 | 250d |  | T2 | 2880h | 2880h | MEXE5 |  |  | Rel-5 | Kimmo |  |
| 1749 | 85.1 | MExE Rel-5 Improvements and Investigations | 110d | 2001-03-26 A | 2002-03-08 A |  | 100% | 2001-03-26 | 2002-03-08 | 110d | finish no earlier than 2001-12-17 | T2 | 880h | 880h | MEXE5-ENHANC | Motorola | Mark Cataldo | Rel-5 |  | 22.057, 23.057 |
| 1750 | 86 | **Wideband Telephony Service - AMR** | 1036d | 2000-01-01 A | 2003-12-19 A |  | 100% | 2000-01-01 | 2003-12-19 | 1036d |  | S4 | 81496h | 81496h | AMRWB | Siemens | Imre.Varga@mch.siemens.de | Rel-5 | Paolo |  |
| 1751 | 86.1 | **Specification** | 636d | 2000-01-01 A | 2002-06-07 A |  | 100% | 2000-01-01 | 2002-06-07 | 636d |  | S4 | 19984h | 19984h |  |  |  | Rel-5 | Paolo |  |
| 1752 | 86.1.1 | Stage 1 | 125d | 2001-10-01 A | 2002-03-22 A |  | 100% | 2001-10-01 | 2002-03-22 | 125d | finish no earlier than 2002-03-22 | S1 | 1000h | 1000h |  |  |  | Rel-5 | Alain |  |
| 1753 | 86.1.2 | **Stage 2** | 77d | 2000-01-03 A | 2000-04-17 A |  | 100% | 2000-01-03 | 2000-04-17 | 77d |  | S4 | 1232h | 1232h |  |  |  | Rel-5 | Paolo |  |
| 1754 | 86.1.2.1 | Design Constraints | 27d | 2000-01-03 A | 2000-02-07 A |  | 100% | 2000-01-03 | 2000-02-07 | 27d |  | S4 [96.3%] | 208h | 208h |  |  |  | Rel-5 | Paolo |  |
| 1755 | 86.1.2.2 | General Description | 51d | 2000-02-07 A | 2000-04-17 A | 1754 | 100% | 2000-02-07 | 2000-04-17 | 51d | start no earlier than 2000-09-25 | S4 | 408h | 408h |  |  |  | Rel-5 | Paolo |  |
| 1756 | 86.1.3 | Feasibility Study | 26d | 2000-04-28 A | 2000-06-02 A | 1755 | 100% | 2000-04-28 | 2000-06-02 | 26d | finish no earlier than 2000-06-02 | S4 | 208h | 208h |  |  |  | Rel-5 | Paolo | 26.901 |
| 1757 | 86.1.4 | N1 Aspects | 66d | 2001-09-21 A | 2001-12-21 A |  | 100% | 2001-09-21 | 2001-12-21 | 66d | finish no earlier than 2001-12-21 | N1 | 528h | 528h |  |  |  | Rel-5 | Frederic |  |
| 1758 | 86.1.5 | N4 work | 83d | 2002-02-13 A | 2002-06-07 A |  | 100% | 2002-02-13 | 2002-06-07 | 83d | finish no earlier than 2002-06-07 | N4 | 664h | 664h |  |  |  | Rel-5 | Kimmo |  |

Notes:
- 1734: -
- 1735: -
- 1736: -
- 1737: -
- 1738: -
- 1739: -
- 1740: -
- 1741: -
- 1742: -
- 1743: Added on May 29, 2001
- 1744: -
- 1745: -
- 1746: -
- 1747: stage2 and stage3 CRs for approval at CN#17
- 1748: -
- 1749: -
- 1750: -
- 1751: -
- 1752: -
- 1753: -
- 1754: -
- 1755: -
- 1756: S4,TD SP-000024: TR 26.901 v.4.0.0
- 1757: Some of N1 tasks: Indication of supported codecs by the MS, Bearer cap negociation, codec indication to MS... / One common set of codec negotiation procedures will be specified as in ID1657.
- 1758: CN4#11 30/11/01: No inputs to CN4 at this meeting / 14/02/02 work started 50% reached / 17 May work is done 100%

| ID | WBS | Task | Duration | Start | Finish | Predecessors | Complete | Baseline start | Baseline finish | Baseline duration | Constraint | Resources | Work | Actual work | Text6 | Text8 | Text1 | Text3 | Text12 | Text4 | Text5 |
| --- | --- | --- | --- | --- | --- | --- | --- | --- | --- | --- | --- | --- | --- | --- | --- | --- | --- | --- | --- | --- | --- |
| 1759 | 86.1.6 | **Codec issues** | 636d | 2000-01-03 A | 2002-06-07 A |  | 100% | 2000-01-03 | 2002-06-07 | 636d |  | S4 | 9496h | 9496h | Rel-5 | Paolo |  |  |  |  |  |
| 1760 | 86.1.6.1 | Codec qualification | 86d | 2000-02-02 A | 2000-05-31 A |  | 100% | 2000-02-02 | 2000-05-31 | 86d | finish no earlier than 2000-05-31 | S4 | 688h | 688h | Rel-5 | Paolo |  |  |  |  |  |
| 1761 | 86.1.6.2 | Codec selection tests | 102d | 2000-06-01 A | 2000-10-20 A | 1760 | 100% | 2000-06-01 | 2000-10-20 | 102d | finish no earlier than 2000-10-20 | S4 | 816h | 816h | Rel-5 | Paolo |  |  |  |  |  |
| 1762 | 86.1.6.3 | Codec selection | 5d | 2000-10-23 A | 2000-10-27 A | 1761 | 100% | 2000-10-23 | 2000-10-27 | 5d | finish no earlier than 2000-10-27 | S4 | 40h | 40h | Rel-5 | Paolo |  |  |  |  |  |
| 1763 | 86.1.6.4 | TFO AMR-WB | 63d | 2001-12-18 A | 2002-03-14 A |  | 100% | 2001-12-18 | 2002-03-14 | 63d | finish no earlier than 2002-03-14 | S4 | 504h | 504h | Rel-5 | Paolo | AMRWB-TFO |  |  |  |  |
| 1764 | 86.1.6.5 | Other codec issues (verif., caracterisation) | 441d | 2000-09-29 A | 2002-06-07 A |  | 100% | 2000-09-29 | 2002-06-07 | 441d | finish no earlier than 2002-06-07 | S4 | 3528h | 3528h | Rel-5 | Paolo |  | 26.976 |  |  |  |
| 1765 | 86.1.6.6 | AMR-WB and narrrowband interworking | 121d | 2001-09-27 A | 2002-03-14 A |  | 100% | 2001-09-27 | 2002-03-14 | 121d | finish no earlier than 2002-03-14 | S4 | 968h | 968h | Rel-5 | Paolo | AMRWB-IWG |  |  |  |  |
| 1766 | 86.1.6.7 | Interworking with fixed broadband networks | 121d | 2001-09-27 A | 2002-03-14 A |  | 100% | 2001-09-27 | 2002-03-14 | 121d | finish no earlier than 2002-03-14 | S4 | 968h | 968h | Rel-5 | Paolo |  |  |  |  |  |
| 1767 | 86.1.6.8 | Tones and announcements | 121d | 2001-09-27 A | 2002-03-14 A |  | 100% | 2001-09-27 | 2002-03-14 | 121d | finish no earlier than 2002-03-14 | S4 | 968h | 968h | Rel-5 | Paolo |  |  |  |  |  |
| 1768 | 86.1.6.9 | Deleted - WB Conferencing and WB Voice Group calls | 1d | 2000-01-03 A | 2000-01-03 A |  | 100% | 2000-01-03 | 2000-01-03 | 1d | finish no earlier than 2000-01-03 | S1 | 8h | 8h | Rel-5 | Alain |  |  | SP-07 |  |  |
| 1769 | 86.1.8 | **Conformance tests (CRs to 34 series)** | 74d | 2000-01-01 A | 2000-04-12 A |  | 100% | 2000-01-01 | 2000-04-12 | 74d |  | T1 | 1768h | 1768h | Rel-5 | Ingbert |  |  |  |  |  |
| 1770 | 86.1.8.1 | **Terminal Acoustic Characteristics** | 74d | 2000-01-01 A | 2000-04-12 A |  | 100% | 2000-01-01 | 2000-04-12 | 74d |  | S4 | 1176h | 1176h | Rel-5 | Paolo |  |  |  |  |  |
| 1771 | 86.1.8.1.1 | Definition | 22d | 2000-01-01 A | 2000-01-31 A |  | 100% | 2000-01-01 | 2000-01-31 | 22d | finish no earlier than 2000-01-28 | S4 [95.5%] | 168h | 168h | Rel-5 | Paolo |  | 26.131 |  |  |  |
| 1772 | 86.1.8.1.2 | Test specification | 52d | 2000-02-01 A | 2000-04-12 A | 1771 | 100% | 2000-02-01 | 2000-04-12 | 52d | finish no earlier than 2000-03-13 | S4 | 416h | 416h | Rel-5 | Paolo |  | 26.132 |  |  |  |
| 1773 | 86.2 | Floating-point ANSI-C code for the AMR-WB speech codec | 123d | 2001-09-25 A | 2002-03-14 A |  | 100% | 2001-09-25 | 2002-03-14 | 123d | finish no earlier than 2002-03-14 | S4 | 984h | 984h | Rel-5 | Paolo | AMRWB-FP | 26.204 |  | Nokia | janne.m.vainio@nokia.com |
| 1774 | 86.3 | **Support of AMR-WB in GERAN: GMSK and 8PSK WB FR / HR** | 651d | 2000-01-03 A | 2002-06-28 A |  | 100% | 2000-01-03 | 2002-06-28 | 651d |  | GP | 23488h | 23488h | Rel-5 | Paolo | GAMRWB |  |  |  |  |
| 1775 | 86.3.1 | Channel coding in 45.003 | 591d | 2000-01-03 A | 2002-04-05 A |  | 100% | 2000-01-03 | 2002-04-05 | 591d |  | GP | 4720h | 4720h | Rel-5 | Paolo |  |  |  |  |  |
| 1776 | 86.3.2 | Signalling for the A interface | 391d | 2000-01-03 A | 2001-06-29 A |  | 100% | 2000-01-03 | 2001-06-29 | 391d | finish no earlier than 2001-06-29 | GP | 3120h | 3120h | Rel-5 | Paolo |  |  |  |  |  |
| 1777 | 86.3.3 | Signalling for Iu | 651d | 2000-01-03 A | 2002-06-28 A |  | 100% | 2000-01-03 | 2002-06-28 | 651d | finish no earlier than 2002-06-28 | GP | 5200h | 5200h | Rel-5 | Paolo |  |  |  |  |  |
| 1778 | 86.3.4 | Receiver performance in TS 45.005 | 325d | 2001-04-02 A | 2002-06-28 A |  | 100% | 2001-04-02 | 2002-06-28 | 325d | finish no earlier than 2002-06-28 | GP | 2600h | 2600h | Rel-5 | Paolo |  |  |  |  |  |
| 1779 | 86.3.5 | Link Adaptation in 45.009 | 330d | 2001-03-26 A | 2002-06-28 A |  | 100% | 2001-03-26 | 2002-06-28 | 330d | finish no earlier than 2002-06-28 | GP | 2640h | 2640h | Rel-5 | Paolo |  |  |  |  |  |
| 1780 | 86.4 | **Deleted - GERAN MS conformance test for AMR-WB** | 1036d | 2000-01-03 A | 2003-12-19 A |  | 100% | 2000-01-03 | 2003-12-19 | 1036d |  | GP | 16568h | 16568h | Rel-5 | Paolo |  |  |  |  |  |
| 1781 | 86.4.1 | Deleted - MS test | 1036d | 2000-01-03 A | 2003-12-19 A |  | 100% | 2000-01-03 | 2003-12-19 | 1036d | finish no earlier than 2003-12-19 | GP | 8280h | 8280h | Rel-5 | Paolo |  |  | GP-17 |  |  |
| 1782 | 86.5 | **GERAN BTS conformance test for AMR-WB** | 762d | 2000-01-03 A | 2002-12-02 A |  | 100% | 2000-01-03 | 2002-12-02 | 762d |  | GP | 12184h | 12184h | Rel-5 | Paolo |  |  |  |  |  |
| 1783 | 86.5.1 | BTS test | 762d | 2000-01-03 A | 2002-12-02 A |  | 100% | 2000-01-03 | 2002-12-02 | 762d | finish no earlier than 2002-12-02 | GP | 6088h | 6088h | Rel-5 | Paolo |  |  |  |  |  |

Notes:
- 1759: -
- 1760: -
- 1761: -
- 1762: -
- 1763: -
- 1764: ANSI C-Code , Test Sequences, Speech Transcoding Functions, Error Concealment of lost frames, Source Controlled Bit-Rate Operation, Voice Activity Detector, Frame Structure
- 1765: -
- 1766: -
- 1767: -
- 1768: -
- 1769: -
- 1770: -
- 1771: -
- 1772: -
- 1773: -
- 1774: -
- 1775: 50098 -> 50298
- 1776: -
- 1777: -
- 1778: -
- 1779: -
- 1780: Not started 02/2003. Marked as stopped 12/2008
- 1781: Marked as stopped 12/2008
- 1782: -
- 1783: -

| ID | WBS | Task | Duration | Start | Finish | Complete | Baseline start | Baseline finish | Baseline duration | Constraint | Resources | Work | Actual work | Text1 | Text6 | Text8 | Text3 | Text4 | Text5 |
| --- | --- | --- | --- | --- | --- | --- | --- | --- | --- | --- | --- | --- | --- | --- | --- | --- | --- | --- | --- |
| 1784 | 11 | **Terminal interfaces** | 223d | 2001-05-14 A | 2002-03-20 A | 100% | 2001-05-14 | 2002-03-20 | 223d |  | T2 | 3568h | 3568h | TI | Rel-5 | Kimmo |  |  |  |
| 1785 | 87 | Terminal local model enhancements | 223d | 2001-05-14 A | 2002-03-20 A | 100% | 2001-05-14 | 2002-03-20 | 223d | finish no earlier than 2002-03-20 | T2 | 1784h | 1784h | TLM5 | Rel-5 |  | 23.227 |  |  |
| 1786 | 88 | **Rel-5 Location Services enhancements** | 845d | 2000-04-03 A | 2003-06-27 A | 100% | 2000-04-03 | 2003-06-27 | 845d |  | S2,S5 | 86804h | 86804h | LCS1 | Rel-5 | Maurice |  | Nokia | Jan Kall |
| 1787 | 88.1 | **UE positioning** | 315d | 2001-01-15 A | 2002-03-29 A | 100% | 2001-01-15 | 2002-03-29 | 315d |  | RP | 5560h | 5560h | LCS1-UEpos | Rel-5 | Stefania |  |  |  |
| 1788 | 88.1.1 | UE positioning enhancements for 1.28 Mcps TDD | 255d | 2001-04-09 A | 2002-03-29 A | 100% | 2001-04-09 | 2002-03-29 | 255d | finish no earlier than 2002-03-29 | R2 | 2040h | 2040h | LCS-128Pos | Rel-5 | Joern |  | CATT | Xiaohua Mei |
| 1789 | 88.1.2 | Open SMLC-SRNC Interface within the UTRAN to support A-GPS Positioning | 195d | 2001-01-15 A | 2001-10-12 A | 100% | 2001-01-15 | 2001-10-12 | 195d |  | R2 | 1560h | 1560h | LCS-INTF | Rel-5 | Joern |  | Qualcomm Europe | Kirk Burroughs |
| 1790 | 88.2 | **Event based and Periodic LCS** | 535d | 2000-05-22 A | 2002-06-07 A | 100% | 2000-05-22 | 2002-06-07 | 535d |  | S1 | 6288h | 6288h | LCS1-EBP | Rel-5 | Alain |  |  |  |
| 1791 | 88.2.1 | Stage 1 | 130d | 2000-05-22 A | 2000-11-17 A | 100% | 2000-05-22 | 2000-11-17 | 130d | finish no earlier than 2000-07-21 | S1 | 1040h | 1040h |  | Rel-5 | Alain | 22.071 | Pacific Bell Wireless | Randolph Wohlert (rwohlert@tri.sbc.com) |
| 1792 | 88.2.2 | Stage 2 specification | 60d | 2000-11-06 A | 2001-01-26 A | 100% | 2000-11-06 | 2001-01-26 | 60d | finish no earlier than 2001-01-26 | S2 | 480h | 480h |  | Rel-5 | Maurice |  |  |  |
| 1793 | 88.2.3 | Impact on MAP | 61d | 2002-03-15 A | 2002-06-07 A | 100% | 2002-03-15 | 2002-06-07 | 61d | finish no earlier than 2002-06-07 | N4 | 488h | 488h |  | Rel-5 | Kimmo |  |  |  |
| 1794 | 88.3 | **Location Services for GERAN in A/Gb Mode** | 485d | 2000-04-03 A | 2002-02-08 A | 100% | 2000-04-03 | 2002-02-08 | 485d |  | GP | 14760h | 14760h | LCS-GERAN | Rel-5 | Paolo |  |  |  |
| 1795 | 88.3.1 | GERAN LCS Stage 2 (first release) | 485d | 2000-04-03 A | 2002-02-08 A | 100% | 2000-04-03 | 2002-02-08 | 485d | finish no earlier than 2002-02-08 | GP,S2,G1,G2 | 3880h | 3880h |  | Rel-5 | Paolo |  |  |  |
| 1796 | 88.3.2 | Gb interface support for LCS | 370d | 2000-04-03 A | 2001-08-31 A | 100% | 2000-04-03 | 2001-08-31 | 370d | finish no earlier than 2001-08-31 | GP | 2960h | 2960h |  | Rel-5 | Paolo |  |  |  |
| 1797 | 88.3.3 | L3 protocol support for LCS | 305d | 2000-04-03 A | 2001-06-01 A | 100% | 2000-04-03 | 2001-06-01 | 305d | finish no earlier than 2001-06-01 | GP | 2440h | 2440h |  | Rel-5 | Paolo |  |  |  |
| 1798 | 88.3.4 | Stage 3 specifications | 305d | 2000-04-03 A | 2001-06-01 A | 100% | 2000-04-03 | 2001-06-01 | 305d | finish no earlier than 2001-06-01 | GP | 2440h | 2440h |  | Rel-5 | Paolo |  |  |  |
| 1799 | 88.4 | **Location Services for GERAN in Iu Mode** | 585d | 2000-04-03 A | 2002-06-28 A | 100% | 2000-04-03 | 2002-06-28 | 585d |  | GP | 20996h | 20996h |  | Rel-5 | Paolo |  |  |  |
| 1800 | 88.4.1 | GERAN LCS Stage 2 | 585d | 2000-04-03 A | 2002-06-28 A | 100% | 2000-04-03 | 2002-06-28 | 585d | finish no earlier than 2002-06-28 | GP,R2,R3,S2,G1,G2 | 4680h | 4680h |  | Rel-5 | Paolo |  |  |  |
| 1801 | 88.4.2 | Iu-ps interface support for LCS | 585d | 2000-04-03 A | 2002-06-28 A | 100% | 2000-04-03 | 2002-06-28 | 585d | finish no earlier than 2002-06-28 | GP,R2,R3,S2,G1,G2 | 4680h | 4680h |  | Rel-5 | Paolo |  |  |  |
| 1802 | 88.4.3 | Iu-cs interface support for LCS | 585d | 2000-04-03 A | 2002-06-28 A | 100% | 2000-04-03 | 2002-06-28 | 585d | finish no earlier than 2002-06-28 | GP,R2,R3,S2,G1,G2 | 4680h | 4680h |  | Rel-5 | Paolo |  |  |  |
| 1803 | 88.4.4 | Iur-g interface support for LCS | 62.5d | 2002-01-23 A | 2002-04-19 A | 100% | 2002-01-23 | 2002-04-19 | 62.5d | finish no earlier than 2002-04-19 | GP,R2,R3,S2,G1,G2 | 500h | 500h |  | Rel-5 | Paolo |  |  |  |
| 1804 | 88.4.5 | RRC protocol support for LCS | 75d | 2001-08-20 A | 2001-11-30 A | 100% | 2001-08-20 | 2001-11-30 | 75d | finish no earlier than 2001-11-30 | GP,R2,R3,S2,G1,G2 | 600h | 600h |  | Rel-5 | Paolo |  |  |  |
| 1805 | 88.4.6 | Additional impacts on Broadcast of LCS data on packet channels | 77.5d | 2001-08-20 A | 2001-12-05 A | 100% | 2001-08-20 | 2001-12-05 | 77.5d | finish no earlier than 2001-12-05 | GP,R2,R3,S2,G1,G2 | 620h | 620h |  | Rel-5 | Paolo |  |  |  |
| 1806 | 88.4.7 | Stage 3 specifications | 69.5d | 2002-03-25 A | 2002-06-28 A | 100% | 2002-03-25 | 2002-06-28 | 69.5d | finish no earlier than 2002-06-28 | GP,R2,R3,S2,G1,G2 | 556h | 556h |  | Rel-5 | Paolo |  |  |  |
| 1807 | 88.5 | **GERAN MS Conformance test for LCS** | 280d | 2002-06-03 A | 2003-06-27 A | 100% | 2002-06-03 | 2003-06-27 | 280d |  | GP | 6720h | 6720h | LCS-GERAN-MSconf | Rel-5 | Paolo |  |  |  |
| 1808 | 88.5.1 | Develop LCS MS test case work plan (Release 98/99/4) | 280d | 2002-06-03 A | 2003-06-27 A | 100% | 2002-06-03 | 2003-06-27 | 280d | finish no earlier than 2003-06-27 | G4,G5 | 2240h | 2240h |  | Rel-5 | Paolo |  |  |  |
| 1809 | 88.5.2 | Develop LCS MS test cases | 280d | 2002-06-03 A | 2003-06-27 A | 100% | 2002-06-03 | 2003-06-27 | 280d | finish no earlier than 2003-06-27 | G4,G5 | 2240h | 2240h |  | Rel-5 | Paolo |  |  |  |

Notes:
- 1784: -
- 1785: -
- 1786: -
- 1787: -
- 1788: -
- 1789: Finished at RP#13
- 1790: -
- 1791: Evaluate Event based and Periodic LCS to be included in R00, corresponding Stage 1 description
- 1792: Marked as closed 12/2008 (was marked 51% complete)
- 1793: Possible impact on UTRAN of LCS quality level request / 17 May No stage 2 for event-based & periodic LCS. Work 100% completefor current stage 2
- 1794: -
- 1795: -
- 1796: -
- 1797: -
- 1798: -
- 1799: -
- 1800: -
- 1801: -
- 1802: -
- 1803: FFS
- 1804: -
- 1805: -
- 1806: -
- 1807: -
- 1808: Marked as closed 12/2008 (was marked 60% complete)
- 1809: Marked as closed 12/2008 (was marked 60% complete)

| ID | WBS | Task | Duration | Start | Finish | Predecessors | Complete | Baseline start | Baseline finish | Baseline duration | Constraint | Resources | Work | Actual work | Text1 | Text6 | Text8 | Text12 | Text3 | Text4 | Text5 |
| --- | --- | --- | --- | --- | --- | --- | --- | --- | --- | --- | --- | --- | --- | --- | --- | --- | --- | --- | --- | --- | --- |
| 1810 | 88.6 | **Deleted - GERAN BTS Conformance test for LCS** | 280d | 2002-06-03 A | 2003-06-27 A |  | 100% | 2002-06-03 | 2003-06-27 | 280d |  | GP | 6720h | 6720h | LCS-GERAN-BTSconf | Rel-5 | Paolo | GP-15 |  |  |  |
| 1811 | 88.6.1 | Deleted - Develop LCS BTS test case work plan (Release 98/99/4) | 280d | 2002-06-03 A | 2003-06-27 A |  | 100% | 2002-06-03 | 2003-06-27 | 280d | finish no earlier than 2003-06-27 | G4,G5 | 2240h | 2240h |  | Rel-5 | Paolo | GP-15 |  |  |  |
| 1812 | 88.6.2 | Deleted - Develop LCS BTS test cases | 280d | 2002-06-03 A | 2003-06-27 A |  | 100% | 2002-06-03 | 2003-06-27 | 280d | finish no earlier than 2003-06-27 | G4,G5 | 2240h | 2240h |  | Rel-5 | Paolo | GP-15 |  |  |  |
| 1813 | 88.7 | LCS interoperation stage 2 aspects | 480d | 2000-08-28 A | 2002-06-28 A |  | 100% | 2000-08-28 | 2002-06-28 | 480d |  | S2 | 3840h | 3840h |  | Rel-5 | Maurice |  |  |  |  |
| 1814 | 88.8 | **LCS interoperability aspects to GERAN** | 480d | 2000-08-28 A | 2002-06-28 A |  | 100% | 2000-08-28 | 2002-06-28 | 480d |  | GP,S5 | 7680h | 7680h | LCS-GERAN | Rel-5 | Paolo |  |  |  |  |
| 1815 | 88.8.1 | Co-ordinated development of GSM LCS Phase 2 and UMTS LCS, S2 and GERAN | 480d | 2000-08-28 A | 2002-06-28 A |  | 100% | 2000-08-28 | 2002-06-28 | 480d | finish no earlier than 2002-06-28 | GP,S2,S5,R2,R3,G2,G1 | 3840h | 3840h | LCS-GERAN | Rel-5 | Paolo |  |  |  |  |
| 1816 | 88.9 | FS on LCS support in the IMS | 90d | 2001-02-12 A | 2002-01-18 A |  | 100% | 2001-02-12 | 2002-01-18 | 90d | start no earlier than 2001-02-12 | S1 | 720h | 720h |  | Rel-5 | Alain |  |  |  |  |
| 1817 | 88.10 | Charging and OAM&P for LCS enhancements | 201d | 2001-09-21 A | 2002-06-28 A |  | 100% | 2001-09-21 | 2002-06-28 | 201d | finish no earlier than 2002-06-28 | S5 | 1608h | 1608h | LCS1-OAM | Rel-5 | Dionisio |  | 32-series | VoiceStream, Motorola |  |
| 1818 | 88.11 | New security aspects of LCS (not identified) | 446d | 2000-04-14 A | 2001-12-28 A |  | 100% | 2000-04-14 | 2001-12-28 | 446d | finish no earlier than 2001-12-28 | S3 | 3568h | 3568h | LCS1-SEC | Rel-5 | Dionisio |  |  | Nokia | valtteri.niemi@nokia.com |
| 1819 | 88.12 | Specification for the Le Interface | 45d | 2002-01-14 A | 2002-03-15 A |  | 100% | 2002-01-14 | 2002-03-15 | 45d | start no earlier than 2002-01-14 | S2 | 360h | 360h | LCS1-Le | Rel-5 | Maurice |  |  |  |  |
| 1820 | 88.13 | Deleted - CHECK STATUS - Inter-GMLC interface | 153d | 2002-05-30 A | 2002-12-30 A |  | 100% | 2002-05-30 | 2002-12-30 | 153d | finish no earlier than 2002-12-30 | S2 | 1224h | 1224h |  | Rel-5 | Maurice | SP-10 |  |  |  |
| 1821 | 89 | **Rel-5 Security enhancements** | 615d | 2000-02-21 A | 2002-06-28 A |  | 100% | 2000-02-21 | 2002-06-28 | 615d |  | S3 | 29974.9h | 29974.9h | SEC1 | Rel-5 | Dionisio |  |  | Vodafone | Peter.Howard@vodafone.com |
| 1822 | 89.1 | **Network domain security** | 615d | 2000-02-21 A | 2002-06-28 A |  | 100% | 2000-02-21 | 2002-06-28 | 615d |  | S3 | 25054.9h | 25054.9h | SEC1-NDS | Rel-5 | Dionisio |  |  | Telenor | Geir-myrdahl.koien@telenor.com |
| 1823 | 89.1.1 | **Deleted -Control plane protection in core network (e.g., GTP, CAP, MAP/IP, provided by IPsec)** | 541d | 2000-05-12 A | 2002-06-07 A |  | 100% | 2000-05-12 | 2002-06-07 | 541d |  | S3 | 7118.9h | 7118.9h |  | Rel-5 | Dionisio | SP-16 |  |  |  |
| 1824 | 89.1.1.1 | Deleted - Main aspects | 290d | 2000-05-12 A | 2001-06-21 A |  | 100% | 2000-05-12 | 2001-06-21 | 290d | finish no earlier than 2001-06-21 | S3 | 2320h | 2320h |  | Rel-5 | Dionisio | SP-12 |  |  |  |
| 1825 | 89.1.1.2 | Deleted -Integration of GTP signalling security architecture | 191d | 2001-09-14 A | 2002-06-07 A |  | 100% | 2001-09-14 | 2002-06-07 | 191d | finish no earlier than 2002-06-07 | N4 | 1528h | 1528h |  | Rel-5 | Kimmo | NP-16 |  |  |  |
| 1826 | 89.1.2 | **Deleted -User plane protection in core network (e.g., provided by IPsec)** | 615d | 2000-02-21 A | 2002-06-28 A |  | 100% | 2000-02-21 | 2002-06-28 | 615d |  | S3 | 9360h | 9360h |  | Rel-5 | Dionisio | SP-16 |  |  |  |
| 1827 | 89.1.2.1 | Deleted -Main aspects | 349d | 2000-02-21 A | 2001-06-21 A |  | 100% | 2000-02-21 | 2001-06-21 | 349d | finish no earlier than 2001-06-21 | S3 | 2792h | 2792h |  | Rel-5 | Dionisio | SP-12 |  |  |  |
| 1828 | 89.1.2.2 | Deleted -Integration of GTP signalling security architecture | 206d | 2001-09-14 A | 2002-06-28 A |  | 100% | 2001-09-14 | 2002-06-28 | 206d | finish no earlier than 2002-06-28 | N4 | 1648h | 1648h |  | Rel-5 | Kimmo | NP-16 |  |  |  |
| 1829 | 89.1.3 | IP network layer security (NDS/IP) | 457d | 2000-06-15 A | 2002-03-15 A |  | 100% | 2000-06-15 | 2002-03-15 | 457d | finish no earlier than 2002-03-15 | S3 | 3656h | 3656h | SEC1-NDS-IP | Rel-5 | Dionisio |  | 33.210 | Telenor | Geir-myrdahl.koien@telenor.com |
| 1830 | 90 | **Intra Domain Connection of RAN Nodes to Multiple CN Nodes** | 455d | 2000-10-02 A | 2002-06-28 A |  | 100% | 2000-10-02 | 2002-06-28 | 455d |  | S2 | 15136h | 15136h | IUFLEX | Rel-5 | Alain |  | 23.236 | Ericsson | stephen.terrill@ericsson.com |
| 1831 | 90.1 | Overall System Architecture | 188d | 2001-01-03 A | 2001-09-21 A |  | 100% | 2001-01-03 | 2001-09-21 | 188d | finish no earlier than 2001-06-01 | S2 | 1504h | 1504h |  | Rel-5 | Maurice |  |  |  |  |
| 1832 | 90.2 | Stage 3: RAN node selecting CN node | 130d | 2001-09-24 A | 2002-03-22 A | 1831 | 100% | 2001-09-24 | 2002-03-22 | 130d | finish no earlier than 2002-03-22 | R3 | 1040h | 1040h |  | Rel-5 | Juha |  |  | Vodafone | Brendan.McWilliams@gb.vodafone.co.uk |
| 1833 | 90.3 | N1 work | 205d | 2001-09-17 A | 2002-06-28 A |  | 100% | 2001-09-17 | 2002-06-28 | 205d | start no earlier than 2001-09-17 | N1 | 1640h | 1640h |  | Rel-5 | Frederic |  | 24.008 and check 29.018 |  |  |
| 1834 | 90.4 | N4 work | 375d | 2000-10-02 A | 2002-03-08 A |  | 100% | 2000-10-02 | 2002-03-08 | 375d | finish no earlier than 2002-03-15 | N4 | 3000h | 3000h |  | Rel-5 | Kimmo |  |  |  |  |

Notes:
- 1810: Not started 02/3003. Marked as stopped 12/2008
- 1811: Marked as stopped 12/2008
- 1812: Marked as stopped 12/2008
- 1813: Marked as closed 12/2008 (was marked 17% complete)
- 1814: -
- 1815: -
- 1816: Marked as closed 12/2008 (was marked 75% complete)
- 1817: -
- 1818: 14/09/00: WI may need to be split to improve on this date. S3#17 15% complete. No progress since S3#17
- 1819: -
- 1820: Marked as stopped 12/2008
- 1821: Added BB UE authentication and rapporteur added. TO BE DELETED
- 1822: S3#17: All due in Rel5. (WI Update at S3#18). Replaced by NDS-IP and NDS-MAP. TO BE DELETED OR MOVED TO HISTORY FILE
- 1823: Marked as stopped 12/2008
- 1824: TO BE DELETED. Marked as stopped 12/2008
- 1825: Waiting for input from SA3!.... Marked as stopped 12/2008
- 1826: TO BE DELETED. Marked as stopped 12/2008
- 1827: -
- 1828: 14/02/2002 requirements are not clear/not received...Marked as closed 12/2008 (was marked 95 complete)
- 1829: 2002/12: All IPsec RFCs are stable STD Track RFCs. WID updated SP#17
- 1830: No clear indication on the end date. Put to Rel5 by AS.
- 1831: -
- 1832: Not identified
- 1833: -
- 1834: DAB 12.12.01 - % complete to 66% / 14/02/02 Work completed

| ID | WBS | Task | Duration | Start | Finish | Complete | Baseline start | Baseline finish | Baseline duration | Constraint | Resources | Work | Actual work | Text1 | Text4 | Text5 | Text6 | Text8 | Text12 | Text3 |
| --- | --- | --- | --- | --- | --- | --- | --- | --- | --- | --- | --- | --- | --- | --- | --- | --- | --- | --- | --- | --- |
| 1835 | 90.5 | **GERAN work for Intra Domain Connection of RAN Nodes to Multiple CN Nodes** | 101d | 2002-02-08 A | 2002-06-28 A | 100% | 2002-02-08 | 2002-06-28 | 101d |  | GP | 4848h | 4848h | IDCRAN-GERAN | Ericsson | ingemar.backlund@era.ericsson.se | Rel-5 | Paolo |  |  |
| 1836 | 90.5.1 | Stage 2 (changes to ) | 101d | 2002-02-08 A | 2002-06-28 A | 100% | 2002-02-08 | 2002-06-28 | 101d | finish no earlier than 2002-06-28 | G1 | 808h | 808h |  |  |  | Rel-5 |  |  |  |
| 1837 | 90.5.2 | 43.051 Introduction of support for IDNNS in GERAN Iu mode | 101d | 2002-02-08 A | 2002-06-28 A | 100% | 2002-02-08 | 2002-06-28 | 101d | finish no earlier than 2002-06-28 | G1 | 808h | 808h |  |  |  | Rel-5 |  |  |  |
| 1838 | 90.5.3 | Stage 3 (changes to ) | 101d | 2002-02-08 A | 2002-06-28 A | 100% | 2002-02-08 | 2002-06-28 | 101d | finish no earlier than 2002-06-28 | G2 | 808h | 808h |  |  |  | Rel-5 | Gert |  |  |
| 1839 | 90.5.4 | 48.016 Use of Gb interface concepts when a network applies IDNNS | 101d | 2002-02-08 A | 2002-06-28 A | 100% | 2002-02-08 | 2002-06-28 | 101d | finish no earlier than 2002-06-28 | G2 | 808h | 808h |  |  |  | Rel-5 | Gert |  |  |
| 1840 | 90.5.5 | 48.018 Include MSC/VLR identity in CS IMSI paging | 101d | 2002-02-08 A | 2002-06-28 A | 100% | 2002-02-08 | 2002-06-28 | 101d | finish no earlier than 2002-06-28 | G2 | 808h | 808h |  |  |  | Rel-5 | Gert |  |  |
| 1841 | 91 | **Deleted - GERAN improvements 3 (new transport layer on interface A)** | 446d | 2001-04-06 A | 2002-12-20 A | 100% | 2001-04-06 | 2002-12-20 | 446d |  | GP | 14272h | 14272h | GEIMP3 |  |  | Rel-5 | Paolo |  |  |
| 1842 | 91.1 | **Deleted - Evolution of the transport for A** | 446d | 2001-04-06 A | 2002-12-20 A | 100% | 2001-04-06 | 2002-12-20 | 446d |  | GP | 10704h | 10704h | GEIMP3-EtA |  |  | Rel-5 | Paolo | GP-12 |  |
| 1843 | 91.1.1 | Deleted - Definition of a new A/Ater interface Transport Layer option based on the Iu Interface Transport Layer | 446d | 2001-04-06 A | 2002-12-20 A | 100% | 2001-04-06 | 2002-12-20 | 446d | finish no earlier than 2002-12-20 | GP | 3568h | 3568h |  |  |  | Rel-5 | Paolo | GP-12 |  |
| 1844 | 91.1.2 | Deleted - Adaptation of the Layer 3 BSSMAP procedures as required | 446d | 2001-04-06 A | 2002-12-20 A | 100% | 2001-04-06 | 2002-12-20 | 446d | finish no earlier than 2002-12-20 | GP | 3568h | 3568h |  |  |  | Rel-5 | Paolo | GP-12 |  |
| 1845 | 92 | **Rel-5 Charging and OAM&P** | 264d | 2001-09-10 A | 2002-09-12 A | 100% | 2001-09-10 | 2002-09-12 | 264d |  | S5 | 9976h | 9976h | OAM | VoiceStream, Motorola |  | Rel-5 | Dionisio |  |  |
| 1846 | 92.1 | Rel5 Principles, high level Requirements and Architecture | 205d | 2001-09-17 A | 2002-06-28 A | 100% | 2001-09-17 | 2002-06-28 | 205d | finish no earlier than 2002-06-28 | S5 | 1640h | 1640h | OAM-AR/PR | Motorola |  | Rel-5 | Dionisio |  | 32.101, 32.102 |
| 1847 | 92.2 | Rel5 Performance Management | 259d | 2001-09-17 A | 2002-09-12 A | 100% | 2001-09-17 | 2002-09-12 | 259d | finish no earlier than 2002-09-12 | S5 | 2072h | 2072h | OAM-PM | Nortel |  | Rel-5 | Dionisio |  | 32.4xy, 52.402 |
| 1848 | 92.3 | Rel5 Charging Management | 264d | 2001-09-10 A | 2002-09-12 A | 100% | 2001-09-10 | 2002-09-12 | 264d | finish no earlier than 2002-09-12 | S5 | 2112h | 2112h | OAM-CH | T-Mobile | Karl-Heinz.Nenner@T-MOBILE.DE | Rel-5 | Dionisio |  | 32.200, 32.205, 32.215, 32.225, 32.235 |
| 1849 | 92.4 | Rel5 Network Infrastructure Management | 255d | 2001-09-21 A | 2002-09-12 A | 100% | 2001-09-21 | 2002-09-12 | 255d | finish no earlier than 2002-09-12 | S5 | 2040h | 2040h | OAM-NIM | Ericsson | thomas.tovinger@ericsson.com | Rel-5 | Dionisio |  | 32.6xy, 32.3xy |
| 1850 | 93 | **GERAN enhancements for streaming services 1 (RLC enhancements)** | 430d | 2000-11-06 A | 2002-06-28 A | 100% | 2000-11-06 | 2002-06-28 | 430d |  | GP | 8944h | 8944h |  |  |  | Rel-5 | Paolo |  |  |
| 1851 | 93.1 | Concept | 258d | 2000-11-06 A | 2001-10-31 A | 100% | 2000-11-06 | 2001-10-31 | 258d | finish no earlier than 2001-10-31 | GP | 2064h | 2064h |  |  |  | Rel-5 | Paolo |  |  |
| 1852 | 93.2 | RLC protocol enhancement (SDU Discard) | 430d | 2000-11-06 A | 2002-06-28 A | 100% | 2000-11-06 | 2002-06-28 | 430d | finish no earlier than 2002-06-28 | GP | 3440h | 3440h |  |  |  | Rel-5 | Paolo |  |  |
| 1853 | 94 | **GERAN enhancements for streaming services 2 (usage of ECSD)** | 430d | 2000-11-06 A | 2002-06-28 A | 100% | 2000-11-06 | 2002-06-28 | 430d |  | GP | 19840h | 19840h |  | Ericsson | Frank Muller | Rel-5 | Paolo |  |  |
| 1854 | 94.1 | Usage of ECSD Concept | 380d | 2000-11-06 A | 2002-04-19 A | 100% | 2000-11-06 | 2002-04-19 | 380d | finish no earlier than 2002-04-19 | GP | 3040h | 3040h |  |  |  | Rel-5 | Paolo |  |  |
| 1855 | 94.2 | Stage 2 | 380d | 2000-11-06 A | 2002-04-19 A | 100% | 2000-11-06 | 2002-04-19 | 380d | finish no earlier than 2002-04-19 | GP | 3040h | 3040h |  |  |  | Rel-5 | Paolo |  |  |
| 1856 | 94.3 | Stage 3 | 430d | 2000-11-06 A | 2002-06-28 A | 100% | 2000-11-06 | 2002-06-28 | 430d | finish no earlier than 2002-06-28 | GP | 3440h | 3440h |  |  |  | Rel-5 | Paolo |  |  |
| 1857 | 94.4 | RLC PDU formats | 430d | 2000-11-06 A | 2002-06-28 A | 100% | 2000-11-06 | 2002-06-28 | 430d | finish no earlier than 2002-06-28 | GP | 3440h | 3440h |  |  |  | Rel-5 | Paolo |  |  |
| 1858 | 94.5 | MAC header | 430d | 2000-11-06 A | 2002-06-28 A | 100% | 2000-11-06 | 2002-06-28 | 430d | finish no earlier than 2002-06-28 | GP | 3440h | 3440h |  |  |  | Rel-5 | Paolo |  |  |

Notes:
- 1835: Accept changes Gb over IP
- 1836: -
- 1837: -
- 1838: -
- 1839: Closed, accept changes for Gb over IP
- 1840: -
- 1841: Terminated - not standardized. Marked as stopped 12/2008
- 1842: TERMINATED - NOT STANDARDIZED. Marked as stopped 12/2008
- 1843: TERMINATED - NOT STANDARDIZED. Marked as stopped 12/2008
- 1844: TERMINATED - NOT STANDARDIZED. Marked as stopped 12/2008
- 1845: -
- 1846: -
- 1847: -
- 1848: -
- 1849: -
- 1850: -
- 1851: -
- 1852: -
- 1853: AWS, Nokia, Ericsson, Nortel, Siemens, Motorola, Vodafone
- 1854: -
- 1855: -
- 1856: -
- 1857: -
- 1858: -

| ID | WBS | Task | Duration | Start | Finish | Predecessors | Complete | Baseline start | Baseline finish | Baseline duration | Constraint | Resources | Work | Actual work | Text1 | Text4 | Text5 | Text6 | Text8 |
| --- | --- | --- | --- | --- | --- | --- | --- | --- | --- | --- | --- | --- | --- | --- | --- | --- | --- | --- | --- |
| 1859 | 95 | **GERAN/UTRAN interface evolution 1 (evolution of Iu PS)** | 476d | 2000-09-01 A | 2002-06-28 A |  | 100% | 2000-09-01 | 2002-06-28 | 476d |  | GP,R3 | 10688h | 10688h | GERUEV1 | SBC | Marc Grant | Rel-5 | Paolo |
| 1860 | 95.1 | **Evolution of Iu ps** | 476d | 2000-09-01 A | 2002-06-28 A |  | 100% | 2000-09-01 | 2002-06-28 | 476d |  | GP,R3 | 7248h | 7248h | GERUEV1-IuPS |  |  | Rel-5 | Paolo |
| 1861 | 95.1.1 | Identification of GERAN requirements on Iu ps | 326d | 2000-09-01 A | 2001-11-30 A |  | 100% | 2000-09-01 | 2001-11-30 | 326d | finish no earlier than 2001-11-30 | GP,R3 | 2608h | 2608h |  |  |  | Rel-5 | Paolo |
| 1862 | 95.1.2 | Update of specifications | 150d | 2001-12-03 A | 2002-06-28 A | 1861 | 100% | 2001-12-03 | 2002-06-28 | 150d | finish no earlier than 2002-06-28 | GP,R3 | 1200h | 1200h |  |  |  | Rel-5 | Paolo |
| 1863 | 96 | **GERAN/UTRAN interface evolution 2 (evolution of Iu CS)** | 476d | 2000-09-01 A | 2002-06-28 A |  | 100% | 2000-09-01 | 2002-06-28 | 476d |  | GP,R3 | 12816h | 12816h | GERUEV2 |  |  | Rel-5 | Paolo |
| 1864 | 96.1 | **Evolution of Iu cs** | 476d | 2000-09-01 A | 2002-06-28 A |  | 100% | 2000-09-01 | 2002-06-28 | 476d |  | GP,R3 | 10016h | 10016h | GERUEV2-IuCS | Lucent | Krishna Balachandran | Rel-5 | Paolo |
| 1865 | 96.1.1 | Identification of GERAN requirements on Iu cs | 426d | 2000-09-01 A | 2002-06-24 A |  | 100% | 2000-09-01 | 2002-06-24 | 426d | finish no earlier than 2002-04-19 | GP,R3 | 3408h | 3408h |  |  |  | Rel-5 | Paolo |
| 1866 | 96.1.2 | Update of specifications | 476d | 2000-09-01 A | 2002-06-28 A |  | 100% | 2000-09-01 | 2002-06-28 | 476d | finish no earlier than 2002-06-28 | GP,R3 | 3808h | 3808h |  |  |  | Rel-5 | Paolo |
| 1867 | 97 | **End to End QoS for PS Domain including IMS** | 480d | 2000-08-28 A | 2002-06-28 A |  | 100% | 2000-08-28 | 2002-06-28 | 480d |  | S2 | 9856h | 9856h | E2EQoS | Ericsson | Johnson.oyama@era.ericcson.se | Rel-5 | Maurice |
| 1868 | 97.1 | E2E QoSConcept and Architecture | 178d | 2001-01-03 A | 2001-09-07 A |  | 100% | 2001-01-03 | 2001-09-07 | 178d | finish no earlier than 2001-09-07 | S2 | 1424h | 1424h |  |  |  | Rel-5 | Maurice |
| 1869 | 97.2 | E2E QoS interworking | 465d | 2000-08-28 A | 2002-06-07 A |  | 100% | 2000-08-28 | 2002-06-07 | 465d | finish no earlier than 2002-06-07 | N3 | 3720h | 3720h | E2EQoS-IW | Lucent | Daisuke Yokota (yokota@lucent.com) | Rel-5 | Gwiho |
| 1870 | 97.3 | QoS Management (Provisioning and Monitoring) | 201d | 2001-09-21 A | 2002-06-28 A |  | 100% | 2001-09-21 | 2002-06-28 | 201d | finish no earlier than 2002-06-28 | S5 | 1608h | 1608h | E2EQoS-OAM | VoiceStream, Motorola |  | Rel-5 | Dionisio |
| 1871 | 98 | **Messaging enhancements Rel-5** | 467d | 2001-06-15 A | 2003-03-31 A |  | 100% | 2001-06-15 | 2003-03-31 | 467d |  | T2 | 19000h | 19000h | MESS5 |  |  | Rel-5 | Kimmo |
| 1872 | 98.1 | **Multimedia Messaging (MMS) enhancements** | 467d | 2001-06-15 A | 2003-03-31 A |  | 100% | 2001-06-15 | 2003-03-31 | 467d |  | T2 | 11688h | 11688h | MESS5-MMS | Siemens | Josef.Laumen@SAL.SIEMENS.DE | Rel-5 | Alain |
| 1873 | 98.1.1 | Definition of service requirements | 196d | 2001-06-15 A | 2002-03-15 A |  | 100% | 2001-06-15 | 2002-03-15 | 196d | finish no earlier than 2002-03-15 | S1 | 1568h | 1568h | MESS5-SR | Siemens | Josef.Laumen@SAL.SIEMENS.DE | Rel-5 |  |
| 1874 | 98.1.2 | Technical realization | 256d | 2001-06-15 A | 2002-06-07 A |  | 100% | 2001-06-15 | 2002-06-07 | 256d | finish no earlier than 2002-06-07 | T2 | 2048h | 2048h |  | Siemens | Josef.Laumen@SAL.SIEMENS.DE | Rel-5 |  |
| 1875 | 98.1.3 | WAP Forum dependency: MM1 stage 3 | 467d | 2001-06-15 A | 2003-03-31 A |  | 100% | 2001-06-15 | 2003-03-31 | 467d | finish no earlier than 2003-03-31 | T2 | 3736h | 3736h |  |  |  | Rel-5 |  |
| 1876 | 98.1.4 | MMS formats and codecs | 75d | 2001-12-03 A | 2002-03-15 A |  | 100% | 2001-12-03 | 2002-03-15 | 75d | finish no earlier than 2002-03-15 | S4 | 600h | 600h |  |  |  | Rel-5 | Paolo |
| 1877 | 98.2 | **Enhanced Messaging Service (EMS) enhancements** | 191d | 2001-06-15 A | 2002-03-08 A |  | 100% | 2001-06-15 | 2002-03-08 | 191d |  | T2 | 3584h | 3584h | MESS5-EMS | Ericsson | Alan.Baldwin@EML.ERICSSON.SE | Rel-5 |  |
| 1878 | 98.2.1 | Definition of service requirements | 66d | 2001-06-15 A | 2001-09-14 A |  | 100% | 2001-06-15 | 2001-09-14 | 66d | finish no earlier than 2001-09-14 | S1 | 528h | 528h |  | Ericsson | Alan.Baldwin@EML.ERICSSON.SE | Rel-5 | Alain |
| 1879 | 98.2.2 | Technical realization | 191d | 2001-06-15 A | 2002-03-08 A |  | 100% | 2001-06-15 | 2002-03-08 | 191d | finish no earlier than 2002-03-08 | T2 | 1528h | 1528h |  | Ericsson | Alan.Baldwin@EML.ERICSSON.SE | Rel-5 |  |
| 1880 | 99 | **GERAN Inter BSC NACC improvements over the Gb Interface** | 215d | 2001-09-03 A | 2002-06-28 A |  | 100% | 2001-09-03 | 2002-06-28 | 215d |  | GP | 8200h | 8200h | GERNACC |  |  | Rel-5 | Paolo |
| 1881 | 99.1 | **Modification of core network protocols for GERAN Inter BSC NACC over Gb Interface** | 165d | 2001-09-03 A | 2002-04-19 A |  | 100% | 2001-09-03 | 2002-04-19 | 165d |  | N4,S2 | 4064h | 4064h | GERNACC-Cnmod |  |  | Rel-5 | Kimmo |
| 1882 | 99.1.1 | Stage 2 - Concept | 43d | 2001-09-03 A | 2001-10-31 A |  | 100% | 2001-09-03 | 2001-10-31 | 43d | finish no earlier than 2001-10-31 | N4,S2 | 344h | 344h |  |  |  | Rel-5 | Kimmo |
| 1883 | 99.1.2 | Stage 2 - 23.060 change - Definition of Inter BSC NACC | 165d | 2001-09-03 A | 2002-04-19 A |  | 100% | 2001-09-03 | 2002-04-19 | 165d | finish no earlier than 2002-04-19 | N4,S2 | 1320h | 1320h |  |  |  | Rel-5 | Kimmo |
| 1884 | 99.1.3 | Stage 3 (changes to TS 29.060) | 135d | 2001-09-03 A | 2002-03-08 A |  | 100% | 2001-09-03 | 2002-03-08 | 135d | finish no earlier than 2002-03-08 | N4 | 1080h | 1080h |  |  |  | Rel-5 | Kimmo |

Notes:
- 1859: SBC, Motorola, Nokia, Ericsson, Nortel
- 1860: -
- 1861: -
- 1862: -
- 1863: -
- 1864: Lucent, Ericsson, AWS, Nortel
- 1865: -
- 1866: -
- 1867: -
- 1868: - / Text3: 23.207
- 1869: [DAB - 30/07/02] - % complete to 95% (if we exclude Diffserv). Marked as closed 12/2008 (was marked 95% complete) / Text3: 29.208, 29.207, 27.060, 29.061, 24.008, 24.228, , 24.229, 29.060, 29.163
- 1870: - / Text3: 32-series
- 1871: support of UAProf, so this in my opinion is 100% complete
- 1872: -
- 1873: - / Text3: 22.140
- 1874: stage 3 MM7 is missing / Text3: 23.140
- 1875: Marked as closed 12/2008 (was marked 80% complete)
- 1876: - / Text3: 26.140
- 1877: - / Text3: 23.040
- 1878: -
- 1879: - / Text3: 23.040
- 1880: -
- 1881: -
- 1882: -
- 1883: -
- 1884: IP 30/11/01: Input awaited from GERAN2 to CN4 / 17 May Work complete 100%

| ID | WBS | Task | Duration | Start | Finish | Complete | Baseline start | Baseline finish | Baseline duration | Constraint | Resources | Work | Actual work | Text1 | Text6 | Text8 | Text12 | Text3 | Text4 | Text5 |
| --- | --- | --- | --- | --- | --- | --- | --- | --- | --- | --- | --- | --- | --- | --- | --- | --- | --- | --- | --- | --- |
| 1885 | 99.2 | **Modification of Gb protocols for GERAN Inter BSC NACC over Gb Interface** | 151d | 2001-11-30 A | 2002-06-28 A | 100% | 2001-11-30 | 2002-06-28 | 151d |  | GP | 2416h | 2416h | GERNACC-Gbmod | Rel-5 | Paolo |  |  |  |  |
| 1886 | 99.2.1 | Stage 3 (changes to TS 48.018) | 151d | 2001-11-30 A | 2002-06-28 A | 100% | 2001-11-30 | 2002-06-28 | 151d | finish no earlier than 2002-06-28 | GP | 1208h | 1208h |  | Rel-5 | Paolo |  |  |  |  |
| 1887 | 100 | **Enhanced Power Control** | 540d | 2001-11-26 A | 2003-12-19 A | 100% | 2001-11-26 | 2003-12-19 | 540d |  | GP | 12840h | 12840h | EPC | Rel-5 | Paolo |  |  |  |  |
| 1888 | 100.1 | Realization of Enhanced power control and signaling support | 5d | 2001-11-26 A | 2001-11-30 A | 100% | 2001-11-26 | 2001-11-30 | 5d | finish no earlier than 2001-11-30 | GP | 40h | 40h |  | Rel-5 | Paolo |  |  |  |  |
| 1889 | 100.2 | Deleted - GERAN MS Conformance test for Enhanced Power Control | 530d | 2001-12-10 A | 2003-12-19 A | 100% | 2001-12-10 | 2003-12-19 | 530d | finish no earlier than 2003-12-19 | GP | 4240h | 4240h |  | Rel-5 | Paolo | GP-17 |  |  |  |
| 1890 | 100.3 | Deleted - GERAN BTS Conformance test for Enhanced Power Control | 530d | 2001-12-10 A | 2003-12-19 A | 100% | 2001-12-10 | 2003-12-19 | 530d | finish no earlier than 2003-12-19 | GP | 4240h | 4240h |  | Rel-5 | Paolo | GP-17 |  |  |  |
| 1891 | 101 | **8PSK AMR HR** | 530d | 2001-12-10 A | 2003-12-19 A | 100% | 2001-12-10 | 2003-12-19 | 530d |  | GP | 21080h | 21080h | 8PSK-AH | Rel-5 | Paolo |  |  |  |  |
| 1892 | 101.1 | **Definition of channel coding, performance requirements and signaling support** | 145d | 2001-12-10 A | 2002-06-28 A | 100% | 2001-12-10 | 2002-06-28 | 145d |  | GP | 10440h | 10440h |  | Rel-5 | Paolo |  |  |  |  |
| 1893 | 101.1.1 | Concept | 145d | 2001-12-10 A | 2002-06-28 A | 100% | 2001-12-10 | 2002-06-28 | 145d | finish no earlier than 2002-06-28 | GP | 1160h | 1160h |  | Rel-5 | Paolo |  |  |  |  |
| 1894 | 101.1.2 | Changes to 44.018 | 145d | 2001-12-10 A | 2002-06-28 A | 100% | 2001-12-10 | 2002-06-28 | 145d | finish no earlier than 2002-06-28 | G2 | 1160h | 1160h |  | Rel-5 | Gert |  |  |  |  |
| 1895 | 101.1.3 | Changes to 45.001 | 145d | 2001-12-10 A | 2002-06-28 A | 100% | 2001-12-10 | 2002-06-28 | 145d | finish no earlier than 2002-06-28 | G1 | 1160h | 1160h |  | Rel-5 |  |  |  |  |  |
| 1896 | 101.1.4 | Changes to 45.002 | 145d | 2001-12-10 A | 2002-06-28 A | 100% | 2001-12-10 | 2002-06-28 | 145d | finish no earlier than 2002-06-28 | G1 | 1160h | 1160h |  | Rel-5 |  |  |  |  |  |
| 1897 | 101.1.5 | Changes to 45.003 | 145d | 2001-12-10 A | 2002-06-28 A | 100% | 2001-12-10 | 2002-06-28 | 145d | finish no earlier than 2002-06-28 | G1 | 1160h | 1160h |  | Rel-5 |  |  |  |  |  |
| 1898 | 101.1.6 | Changes to 45.005 | 145d | 2001-12-10 A | 2002-06-28 A | 100% | 2001-12-10 | 2002-06-28 | 145d | finish no earlier than 2002-06-28 | G1 | 1160h | 1160h |  | Rel-5 |  |  |  |  |  |
| 1899 | 101.1.7 | Changes to 24.008 | 145d | 2001-12-10 A | 2002-06-28 A | 100% | 2001-12-10 | 2002-06-28 | 145d | finish no earlier than 2002-06-28 | G2 | 1160h | 1160h |  | Rel-5 | Gert |  |  |  |  |
| 1900 | 101.1.8 | Changes to 48.058 | 145d | 2001-12-10 A | 2002-06-28 A | 100% | 2001-12-10 | 2002-06-28 | 145d | finish no earlier than 2002-06-28 | G2 | 1160h | 1160h |  | Rel-5 | Gert |  |  |  |  |
| 1901 | 101.2 | Deleted - GERAN MS Conformance test for 8PSK HR | 530d | 2001-12-10 A | 2003-12-19 A | 100% | 2001-12-10 | 2003-12-19 | 530d | finish no earlier than 2003-12-19 | GP | 4240h | 4240h |  | Rel-5 | Paolo |  |  |  |  |
| 1902 | 101.3 | GERAN BTS Conformance test for 8PSK HR | 270d | 2001-12-10 A | 2002-12-20 A | 100% | 2001-12-10 | 2002-12-20 | 270d | finish no earlier than 2002-12-20 | GP | 2160h | 2160h |  | Rel-5 | Paolo |  |  |  |  |
| 1903 | 102 | Service Change and UDI Fallback | 175d | 2001-10-08 A | 2002-06-07 A | 100% | 2001-10-08 | 2002-06-07 | 175d | finish no earlier than 2002-06-07 | N3 | 1400h | 1400h | SCUDIF | Rel-5 | Gwiho |  | 29.007, 27.001, 24.008 | Ericsson | Rune.Werner.Wiik@ericsson.no |
| 1904 | 103 | **Rel-5 USIM toolkit enhancements** | 865d | 2000-06-05 A | 2003-09-26 A | 100% | 2000-06-05 | 2003-09-26 | 865d |  | T3 | 24352h | 24352h | USAT1 | Rel-5 | Xavier |  |  |  |  |
| 1905 | 103.1 | Deleted - Test specification for USIM toolkit security mechanims | 349d | 2002-05-28 A | 2003-09-26 A | 100% | 2002-05-28 | 2003-09-26 | 349d | finish no earlier than 2003-09-26 | T3 | 2792h | 2792h |  | Rel-5 |  | TP-21 |  | Gemplus | Sophie Viallet |
| 1906 | 103.2 | **Protocol Standardisation of a SIM Toolkit Interpreter** | 688d | 2000-06-05 A | 2003-01-22 A | 100% | 2000-06-05 | 2003-01-22 | 688d |  | T3 | 12512h | 12512h | USAT1-Interpr | Rel-5 |  |  | 27.103 | G & D | Michael Meyer |
| 1907 | 103.2.1 | Stage 1 | 205d | 2000-06-05 A | 2001-03-16 A | 100% | 2000-06-05 | 2001-03-16 | 205d | finish no earlier than 2001-03-16 | T3 | 1640h | 1640h |  | Rel-5 |  |  |  |  |  |
| 1908 | 103.2.2 | Stage 2 and 3 | 308d | 2001-01-03 A | 2002-03-08 A | 100% | 2001-01-03 | 2002-03-08 | 308d | finish no earlier than 2002-03-08 | T3 | 2464h | 2464h |  | Rel-5 |  |  |  |  |  |
| 1909 | 103.2.3 | Test specification | 363d | 2001-09-03 A | 2003-01-22 A | 100% | 2001-09-03 | 2003-01-22 | 363d | finish no earlier than 2003-01-22 | T3 | 2904h | 2904h |  | Rel-5 |  |  |  | Gemplus | Gérald MAUNIER |

Notes:
- 1885: -
- 1886: -
- 1887: -
- 1888: Completed 11/2001
- 1889: Not started. Marked as stopped 12/2008
- 1890: Not started. Marked as stopped 12/2008
- 1891: Completed for Rel-5
- 1892: -
- 1893: -
- 1894: -
- 1895: -
- 1896: -
- 1897: -
- 1898: -
- 1899: -
- 1900: -
- 1901: Marked as stopped 12/2008
- 1902: -
- 1903: -
- 1904: -
- 1905: Marked as stopped 12/2008
- 1906: 28/5/2001: T3-19 proposed that since the stage 2 and 3 will not be presented to TP-12 for approval as expected, the WI will be moved to rel-5, with completion expected at TP-13.
- 1907: 5/10/2001: Stage one comepeted at TP-12.
- 1908: 5/10/2001: TS 31.112 and 31.113 approved at TP-13. TS 31.114 to be presented to TP-14.
- 1909: 5/10/2001: Work started on test specification. Marked as closed 12/2008 (was marked 12% complete)

| ID | WBS | Task | Duration | Start | Finish | Complete | Baseline start | Baseline finish | Baseline duration | Constraint | Resources | Work | Actual work | Text1 | Text6 | Text4 | Text5 | Text8 | Text12 |
| --- | --- | --- | --- | --- | --- | --- | --- | --- | --- | --- | --- | --- | --- | --- | --- | --- | --- | --- | --- |
| 1910 | 103.4 | **(U)SIM API** | 133d | 2002-03-20 A | 2002-09-20 A | 100% | 2002-03-20 | 2002-09-20 | 133d |  | T3 | 2128h | 2128h | USAT1-API | Rel-5 |  |  |  |  |
| 1911 | 103.4.1 | Java API Test specification | 133d | 2002-03-20 A | 2002-09-20 A | 100% | 2002-03-20 | 2002-09-20 | 133d | finish no earlier than 2002-09-20 | T3 | 1064h | 1064h |  | Rel-5 | Microelectrónica Española | Mario Pérez |  |  |
| 1912 | 104 | **small Technical Enhancements and Improvements for Rel5** | 2349d? | 2000-01-03 A | 2008-12-31 A | 100% | 2000-01-03 | 2008-12-31 | 2349d? |  | All | 18792h | 18792h | TEI5 | Rel-5 |  |  |  |  |
| 1913 | 482.1 | Small Technical Enhancements and Improvements for Rel-5 Conformance Testing | 2349d? | 2000-01-03 A | 2008-12-31 A | 100% | 2000-01-03 | 2008-12-31 | 2349d? | finish no earlier than 2008-12-31 | R5,T1 | 18792h | 18792h | TEI5_Test | Rel-5 |  |  | Ingbert |  |
| 1914 | 105 | Deleted - Technical Report on UE Functionality Split | 87d | 2000-01-03 A | 2000-05-01 A | 100% | 2000-01-03 | 2000-05-01 | 87d |  | S1 | 688h | 688h | UESPLIT | Rel-5 | Motorola | sanjay.gupta@motorola.com | Alain | SP-08 |
| 1915 | 106 | **User Equipment Management** | 267d | 2001-06-21 A | 2002-06-28 A | 100% | 2001-06-21 | 2002-06-28 | 267d |  | S5 | 3752h | 3752h | UEM | Rel-5 | Vodafone | john.mudge@vf.vodafone.co.uk | Dionisio |  |
| 1916 | 106.1 | FS on User Equipment (UE) Management | 267d | 2001-06-21 A | 2002-06-28 A | 100% | 2001-06-21 | 2002-06-28 | 267d | finish no earlier than 2002-06-28 | S5 | 2136h | 2136h | OAM-UEM | Rel-5 | Vodafone | john.mudge@vf.vodafone.co.uk | Dionisio |  |
| 1917 | 107 | **Flow control supporting an MS with multiple data flows with different QoS over the Gb interface** | 50d | 2002-06-24 A | 2002-08-30 A | 100% | 2002-06-24 | 2002-08-30 | 50d |  | GP | 1288h | 1288h | FlowCon | Rel-5 | Ericsson | ingemar.backlund@era.ericsson.se | Paolo |  |
| 1918 | 107.1 | **Update of stage 2 specifications** | 50d | 2002-06-24 A | 2002-08-30 A | 100% | 2002-06-24 | 2002-08-30 | 50d |  | GP | 808h | 808h |  | Rel-5 |  |  | Paolo |  |
| 1919 | 107.1.1 | Concept document 23.060 (changes to) | 46d | 2002-06-28 A | 2002-08-30 A | 100% | 2002-06-28 | 2002-08-30 | 46d | finish no earlier than 2002-08-30 | S2 | 368h | 368h |  | Rel-5 |  |  | Maurice |  |
| 1920 | 107.1.2 | Flow Control | 5d | 2002-06-24 A | 2002-06-28 A | 100% | 2002-06-24 | 2002-06-28 | 5d | finish no earlier than 2002-06-28 | GP | 40h | 40h |  | Rel-5 |  |  | Paolo |  |
| 1921 | 107.2 | **Modification of BSSGP protocol** | 5d | 2002-06-24 A | 2002-06-28 A | 100% | 2002-06-24 | 2002-06-28 | 5d |  | GP | 80h | 80h |  | Rel-5 | Ericsson | ingemar.backlund@era.ericsson.se | Paolo |  |
| 1922 | 107.2.1 | Stage 3 (changes to 48.018) | 5d | 2002-06-24 A | 2002-06-28 A | 100% | 2002-06-24 | 2002-06-28 | 5d | finish no earlier than 2002-06-28 | G2 | 40h | 40h |  | Rel-5 |  |  | Gert |  |
| 1923 | 108 | **Multiple TBF in A/Gb mode** | 421d | 2002-04-19 A | 2003-11-28 A | 100% | 2002-04-19 | 2003-11-28 | 421d |  | GP | 17480h | 17480h | MULTBF | Rel-5 | Ericsson | gunnar.mildh@era.ericsson.se | Paolo |  |
| 1924 | 108.1 | **Multiple TBF in A/Gb mode** | 351d | 2002-04-19 A | 2003-08-22 A | 100% | 2002-04-19 | 2003-08-22 | 351d |  | GP | 8112h | 8112h | MULTBF-Agbmode | Rel-5 |  |  | Paolo |  |
| 1925 | 108.1.1 | Multiple TBF Concept paper | 351d | 2002-04-19 A | 2003-08-22 A | 100% | 2002-04-19 | 2003-08-22 | 351d | finish no earlier than 2003-08-22 | GP | 2808h | 2808h |  | Rel-5 |  |  | Paolo |  |
| 1926 | 108.1.2 | Deleted - Multiple TBF Stage 2 (43.064) CRs | 156d | 2002-04-19 A | 2002-11-22 A | 100% | 2002-04-19 | 2002-11-22 | 156d | finish no earlier than 2002-11-22 | G1 | 1248h | 1248h |  | Rel-5 |  |  |  | GP-12 |
| 1927 | 108.1.3 | Deleted - Multiple TBF Stage 3 (44.060) CRs | 156d | 2002-04-19 A | 2002-11-22 A | 100% | 2002-04-19 | 2002-11-22 | 156d | finish no earlier than 2002-11-22 | G2 | 1248h | 1248h |  | Rel-5 |  |  | Gert | GP-12 |
| 1928 | 108.2 | **Deleted - Multiple TBF in A/Gb mode – MS testing** | 375d | 2002-06-24 A | 2003-11-28 A | 100% | 2002-06-24 | 2003-11-28 | 375d |  | GP | 6000h | 6000h |  | Rel-5 | Ericsson | ingemar.backlund@era.ericsson.se | Paolo | GP-17 |
| 1929 | 108.2.1 | Deleted - MS conformance tests | 375d | 2002-06-24 A | 2003-11-28 A | 100% | 2002-06-24 | 2003-11-28 | 375d | finish no earlier than 2003-11-28 | G4 | 3000h | 3000h |  | Rel-5 |  |  | Paolo | GP-17 |
| 1930 | 109 | **Alignment of 3G functional split and Iu** | 922d | 2000-06-08 A | 2003-12-19 A | 100% | 2000-06-08 | 2003-12-19 | 922d |  | GP | 126664h | 126664h | GER3GAL | Rel-5 | Ericsson | Frank Muller | Paolo |  |
| 1931 | 109.1 | **GERAN user / control plane** | 540d | 2000-08-07 A | 2002-08-30 A | 100% | 2000-08-07 | 2002-08-30 | 540d |  | GP | 36232h | 36232h | GER3GAL-GUCOPL | Rel-5 | Ericsson | Frank Muller | Paolo |  |
| 1932 | 109.1.1 | **Alignment with UMTS bearer concept** | 540d | 2000-08-07 A | 2002-08-30 A | 100% | 2000-08-07 | 2002-08-30 | 540d |  | GP | 24952h | 24952h |  | Rel-5 |  |  | Paolo |  |
| 1933 | 109.1.1.1 | Enhanced power control | 1d | 2001-08-31 A | 2001-08-31 A | 100% | 2001-08-31 | 2001-08-31 | 1d | finish no earlier than 2001-08-31 | GP | 8h | 8h |  | Rel-5 |  |  | Paolo |  |
| 1934 | 109.1.1.2 | Stage 2 | 235d | 2000-08-07 A | 2001-06-29 A | 100% | 2000-08-07 | 2001-06-29 | 235d | finish no earlier than 2001-06-29 | GP | 1880h | 1880h |  | Rel-5 |  |  | Paolo |  |
| 1935 | 109.1.1.3 | Adoption of the UTRAN PDCP | 295d | 2000-11-06 A | 2001-12-21 A | 100% | 2000-11-06 | 2001-12-21 | 295d | finish no earlier than 2001-12-21 | GP | 2360h | 2360h |  | Rel-5 |  |  | Paolo |  |
| 1936 | 109.1.1.4 | Development of RLC / MAC | 261d | 2001-08-31 A | 2002-08-30 A | 100% | 2001-08-31 | 2002-08-30 | 261d | finish no earlier than 2002-08-30 | GP | 2088h | 2088h |  | Rel-5 |  |  | Paolo |  |
| 1937 | 109.1.1.5 | Development of GERAN RRC | 266d | 2001-06-22 A | 2002-06-28 A | 100% | 2001-06-22 | 2002-06-28 | 266d | finish no earlier than 2002-06-28 | GP | 2128h | 2128h |  | Rel-5 |  |  | Paolo |  |
| 1938 | 109.1.1.6 | Ciphering and integrity protection concept paper | 166d | 2001-08-31 A | 2002-04-19 A | 100% | 2001-08-31 | 2002-04-19 | 166d | finish no earlier than 2002-04-19 | GP | 1328h | 1328h |  | Rel-5 |  |  | Paolo |  |
| 1939 | 109.1.1.7 | Multiple TBF or equivalent Concept paper | 116d | 2001-08-31 A | 2002-02-08 A | 100% | 2001-08-31 | 2002-02-08 | 116d | finish no earlier than 2002-02-08 | GP | 928h | 928h |  | Rel-5 |  |  | Paolo |  |
| 1940 | 109.1.1.8 | Paging concept | 166d | 2001-08-31 A | 2002-04-19 A | 100% | 2001-08-31 | 2002-04-19 | 166d | finish no earlier than 2002-04-19 | GP | 1328h | 1328h |  | Rel-5 |  |  | Paolo |  |
| 1941 | 109.1.1.9 | Dedicated Physical subchannels, includes traffic and control channels | 66d | 2001-08-31 A | 2001-11-30 A | 100% | 2001-08-31 | 2001-11-30 | 66d | finish no earlier than 2001-11-30 | GP | 528h | 528h |  | Rel-5 |  |  | Paolo |  |
| 1942 | 109.1.1.10 | Iu support and broadcast concept | 166d | 2001-08-31 A | 2002-04-19 A | 100% | 2001-08-31 | 2002-04-19 | 166d | finish no earlier than 2002-04-19 | GP | 1328h | 1328h |  | Rel-5 |  |  | Paolo |  |
| 1943 | 109.1.1.11 | Impact of using RLC instead of LAPDm concept | 116d | 2001-08-31 A | 2002-02-08 A | 100% | 2001-08-31 | 2002-02-08 | 116d | finish no earlier than 2002-02-08 | GP | 928h | 928h |  | Rel-5 |  |  | Paolo |  |
| 1944 | 109.1.1.12 | Contention resolution, mobile station identity, and access concept | 66d | 2001-08-31 A | 2001-11-30 A | 100% | 2001-08-31 | 2001-11-30 | 66d | finish no earlier than 2001-11-30 | GP | 528h | 528h |  | Rel-5 |  |  | Paolo |  |
| 1945 | 109.1.1.13 | PDCP concept | 166d | 2001-08-31 A | 2002-04-19 A | 100% | 2001-08-31 | 2002-04-19 | 166d | finish no earlier than 2002-04-19 | GP | 1328h | 1328h |  | Rel-5 |  |  | Paolo |  |
| 1946 | 109.1.1.14 | Downlink delayed TBF release | 261d | 2001-08-31 A | 2002-08-30 A | 100% | 2001-08-31 | 2002-08-30 | 261d | finish no earlier than 2002-08-30 | GP | 2088h | 2088h |  | Rel-5 |  |  | Paolo |  |
| 1947 | 109.1.1.15 | Add transparent RLC Concept | 116d | 2001-08-31 A | 2002-02-08 A | 100% | 2001-08-31 | 2002-02-08 | 116d | finish no earlier than 2002-02-08 | GP | 928h | 928h |  | Rel-5 |  |  | Paolo |  |
| 1948 | 109.1.1.16 | Handover concept | 116d | 2001-08-31 A | 2002-02-08 A | 100% | 2001-08-31 | 2002-02-08 | 116d | finish no earlier than 2002-02-08 | GP | 928h | 928h |  | Rel-5 |  |  | Paolo |  |

Notes:
- 1910: 8/3/2001: test spec is based on R99 core spec, so deleted from Workplan
- 1911: -
- 1912: "Joker" WI, to be used for a Rel 5 CR not related to any feature and with very limited impact on the system
- 1913: "Joker" WI, to be used for small modifications applicable to Rel 5 conformance testing. Moved in from Stoyan/testing WP. / Text3: 34.108, 34.109, 34.121-1, 34.121-2, 34.122, 34.123-1, 34.123-2, 34.123-3, 34.171, 34.229-1, 34.229-2, 34.229-3
- 1914: -
- 1915: - / Text3: 32.802
- 1916: - / Text3: 32.802
- 1917: 50101 -> 50201
- 1918: 50102 -> 50202
- 1919: -
- 1920: 50103 -> 50203
- 1921: -
- 1922: -
- 1923: -
- 1924: Marked as closed 12/2008 (was marked 26% complete)
- 1925: Marked as closed 12/2008 (was marked 50% complete)
- 1926: Marked as stopped 12/2008
- 1927: Marked as stopped 12/2008
- 1928: 08/08: duplicate UID_50106=-> 50206. Marked as stopped 12/2008
- 1929: Not started. Marked as stopped 12/2008
- 1930: AWS, Nokia, Ericsson, Nortel, Siemens, Vodafone
- 1931: AWS, Nokia, Ericsson, Nortel, Siemens, Vodafone
- 1932: -
- 1933: -
- 1934: -
- 1935: Responsible is GERAN; RAN WG2 help may be needed.
- 1936: -
- 1937: -
- 1938: -
- 1939: -
- 1940: -
- 1941: -
- 1942: -
- 1943: -
- 1944: -
- 1945: -
- 1946: -
- 1947: -
- 1948: -

| ID | WBS | Task | Duration | Start | Finish | Complete | Baseline start | Baseline finish | Baseline duration | Constraint | Resources | Work | Actual work | Text6 | Text8 | Text1 | Text4 | Text5 |
| --- | --- | --- | --- | --- | --- | --- | --- | --- | --- | --- | --- | --- | --- | --- | --- | --- | --- | --- |
| 1949 | 109.1.2 | **Physical layer alignment with UMTS bearer concept** | 280d | 2000-11-06 A | 2001-11-30 A | 100% | 2000-11-06 | 2001-11-30 | 280d |  | GP | 6960h | 6960h | Rel-5 | Paolo |  |  |  |
| 1950 | 109.1.2.1 | PDTCH/TCH in 45.003 | 155d | 2000-11-06 A | 2001-06-08 A | 100% | 2000-11-06 | 2001-06-08 | 155d | finish no earlier than 2001-06-08 | GP | 1240h | 1240h | Rel-5 | Paolo |  |  |  |
| 1951 | 109.1.2.2 | Control channels in 45.003 | 155d | 2000-11-06 A | 2001-06-08 A | 100% | 2000-11-06 | 2001-06-08 | 155d | finish no earlier than 2001-06-08 | GP | 1240h | 1240h | Rel-5 | Paolo |  |  |  |
| 1952 | 109.1.2.3 | Receiver performance in 45.005 for PDTCH/TCH and control channels | 280d | 2000-11-06 A | 2001-11-30 A | 100% | 2000-11-06 | 2001-11-30 | 280d | finish no earlier than 2001-11-30 | GP | 2240h | 2240h | Rel-5 | Paolo |  |  |  |
| 1953 | 109.2 | **Iu rg interface** | 430d | 2000-11-06 A | 2002-06-28 A | 100% | 2000-11-06 | 2002-06-28 | 430d |  | GP,RP | 39560h | 39560h | Rel-5 | Paolo | GER3GAL-Iurg | Ericsson | Frank Muller |
| 1954 | 109.2.1 | **Inter BSS interface** | 430d | 2000-11-06 A | 2002-06-28 A | 100% | 2000-11-06 | 2002-06-28 | 430d |  | GP,RP | 20640h | 20640h | Rel-5 | Paolo |  |  |  |
| 1955 | 109.2.1.1 | Identification of requirements | 430d | 2000-11-06 A | 2002-06-28 A | 100% | 2000-11-06 | 2002-06-28 | 430d | finish no earlier than 2002-06-28 | GP | 3440h | 3440h | Rel-5 | Paolo |  |  |  |
| 1956 | 109.2.1.2 | Stage 2 | 430d | 2000-11-06 A | 2002-06-28 A | 100% | 2000-11-06 | 2002-06-28 | 430d | finish no earlier than 2002-06-28 | GP | 3440h | 3440h | Rel-5 | Paolo |  |  |  |
| 1957 | 109.2.1.3 | Adoption of relevant parts from Iur | 430d | 2000-11-06 A | 2002-06-28 A | 100% | 2000-11-06 | 2002-06-28 | 430d | finish no earlier than 2002-06-28 | GP | 3440h | 3440h | Rel-5 | Paolo |  |  |  |
| 1958 | 109.2.1.4 | Complementation with GERAN specifics | 430d | 2000-11-06 A | 2002-06-28 A | 100% | 2000-11-06 | 2002-06-28 | 430d | finish no earlier than 2002-06-28 | GP | 3440h | 3440h | Rel-5 | Paolo |  |  |  |
| 1959 | 109.2.1.5 | Stage 3 | 430d | 2000-11-06 A | 2002-06-28 A | 100% | 2000-11-06 | 2002-06-28 | 430d | finish no earlier than 2002-06-28 | GP | 3440h | 3440h | Rel-5 | Paolo |  |  |  |
| 1960 | 109.2.2 | **Inter BSS-RNS interface** | 430d | 2000-11-06 A | 2002-06-28 A | 100% | 2000-11-06 | 2002-06-28 | 430d |  | GP,RP | 15480h | 15480h | Rel-5 | Paolo |  |  |  |
| 1961 | 109.2.2.1 | Identification of requirements | 430d | 2000-11-06 A | 2002-06-28 A | 100% | 2000-11-06 | 2002-06-28 | 430d | start no earlier than 2000-11-06 | GP,R3 | 3440h | 3440h | Rel-5 | Paolo |  |  |  |
| 1962 | 109.2.2.2 | Stage 2 | 430d | 2000-11-06 A | 2002-06-28 A | 100% | 2000-11-06 | 2002-06-28 | 430d | finish no earlier than 2002-06-28 | GP,R3 | 3440h | 3440h | Rel-5 | Paolo |  |  |  |
| 1963 | 109.2.2.3 | Adoption of relevant parts from Iur | 430d | 2000-11-06 A | 2002-06-28 A | 100% | 2000-11-06 | 2002-06-28 | 430d | finish no earlier than 2002-06-28 | GP,R3 | 3440h | 3440h | Rel-5 | Paolo |  |  |  |
| 1964 | 109.2.2.4 | Complementation with GERAN specifics | 107.5d | 2002-01-30 A | 2002-06-28 A | 100% | 2002-01-30 | 2002-06-28 | 107.5d | finish no earlier than 2002-06-28 | GP,R3 | 860h | 860h | Rel-5 | Paolo |  |  |  |
| 1965 | 109.2.2.5 | Stage 3 | 107.5d | 2002-01-30 A | 2002-06-28 A | 100% | 2002-01-30 | 2002-06-28 | 107.5d | finish no earlier than 2002-06-28 | GP,R3 | 860h | 860h | Rel-5 | Paolo |  |  |  |
| 1966 | 109.3 | **Voice over GERAN PS and CS concept** | 430d | 2000-11-06 A | 2002-06-28 A | 100% | 2000-11-06 | 2002-06-28 | 430d |  | GP,R3 | 18520h | 18520h | Rel-5 | Paolo |  |  |  |
| 1967 | 109.3.1 | Architecture for A, Iu cs and Iu ps | 430d | 2000-11-06 A | 2002-06-28 A | 100% | 2000-11-06 | 2002-06-28 | 430d | finish no earlier than 2002-06-28 | GP,R3 | 3440h | 3440h | Rel-5 | Paolo |  |  |  |
| 1968 | 109.3.2 | Transcoder position/operation | 115d | 2000-11-06 A | 2001-04-13 A | 100% | 2000-11-06 | 2001-04-13 | 115d | finish no earlier than 2001-04-13 | GP | 920h | 920h | Rel-5 | Paolo |  |  |  |
| 1969 | 109.3.3 | Handover | 430d | 2000-11-06 A | 2002-06-28 A | 100% | 2000-11-06 | 2002-06-28 | 430d | finish no earlier than 2002-06-28 | GP,R3 | 3440h | 3440h | Rel-5 | Paolo |  |  |  |
| 1970 | 109.3.4 | RTP payload | 430d | 2000-11-06 A | 2002-06-28 A | 100% | 2000-11-06 | 2002-06-28 | 430d | finish no earlier than 2002-06-28 | GP,R3 | 3440h | 3440h | Rel-5 | Paolo |  |  |  |
| 1971 | 109.3.5 | Codec renegotiation concept | 365d | 2000-11-06 A | 2002-03-29 A | 100% | 2000-11-06 | 2002-03-29 | 365d | finish no earlier than 2002-03-29 | GP,R3 | 2920h | 2920h | Rel-5 | Paolo |  |  |  |
| 1972 | 109.3.6 | LA | 115d | 2000-11-06 A | 2001-04-13 A | 100% | 2000-11-06 | 2001-04-13 | 115d | finish no earlier than 2001-04-13 | GP | 920h | 920h | Rel-5 | Paolo |  |  |  |

Notes:
- 1949: -
- 1950: -
- 1951: -
- 1952: -
- 1953: AWS, Nokia, Ericsson, Nortel, Siemens, Vodafone
- 1954: -
- 1955: -
- 1956: -
- 1957: -
- 1958: -
- 1959: -
- 1960: -
- 1961: -
- 1962: -
- 1963: -
- 1964: -
- 1965: -
- 1966: -
- 1967: -
- 1968: -
- 1969: -
- 1970: -
- 1971: -
- 1972: -

| ID | WBS | Task | Duration | Start | Finish | Complete | Baseline start | Baseline finish | Baseline duration | Total slack | Constraint | Resources | Work | Actual work | Text6 | Text8 | Text12 | Text1 | Text4 | Text5 |
| --- | --- | --- | --- | --- | --- | --- | --- | --- | --- | --- | --- | --- | --- | --- | --- | --- | --- | --- | --- | --- |
| 1973 | 109.4 | **Deleted - GERAN MS Conformance test for GERAN interface evolution** | 660d | 2001-06-11 A | 2003-12-19 A | 100% | 2001-06-11 | 2003-12-19 | 660d |  |  | GP | 10560h | 10560h | Rel-5 | Paolo | GP-17 |  |  |  |
| 1974 | 109.4.1 | Deleted - MS test | 660d | 2001-06-11 A | 2003-12-19 A | 100% | 2001-06-11 | 2003-12-19 | 660d |  | finish no earlier than 2003-12-19 | GP | 5280h | 5280h | Rel-5 | Paolo | GP-17 |  |  |  |
| 1975 | 109.5 | **GERAN BSS Conformance test for GERAN interface evolution** | 922d | 2000-06-08 A | 2003-12-19 A | 100% | 2000-06-08 | 2003-12-19 | 922d |  |  | GP | 14752h | 14752h | Rel-5 | Paolo |  |  |  |  |
| 1976 | 109.5.1 | Deleted - BSS test | 922d | 2000-06-08 A | 2003-12-19 A | 100% | 2000-06-08 | 2003-12-19 | 922d |  | finish no earlier than 2003-12-19 | GP | 7376h | 7376h | Rel-5 | Paolo | GP-17 |  |  |  |
| 1977 | 110 | **GERAN support for IMS** | 690d | 2000-05-01 A | 2002-12-20 A | 100% | 2000-05-01 | 2002-12-20 | 690d |  |  | GP | 39198.4h | 39198.4h | Rel-5 | Paolo |  | GERIMS | Nokia | Shkumbin Hamiti |
| 1978 | 110.1 | **GERAN Header adaptation** | 690d | 2000-05-01 A | 2002-12-20 A | 100% | 2000-05-01 | 2002-12-20 | 690d |  |  | GP,S2,RP | 12302.8h | 12302.8h | Rel-5 | Paolo |  | GERIMS-HEADAPT | Nokia | Shkumbin Hamiti |
| 1979 | 110.1.1 | Definition of compression and removal modes for PDCP protocol | 15.05d | 2000-05-01 A | 2000-06-09 A | 100% | 2000-05-01 | 2000-06-09 | 15.05d |  | finish no earlier than 2000-09-01 | GP,S2,RP | 120.4h | 120.4h | Rel-5 | Paolo |  |  |  |  |
| 1980 | 110.1.2 | Conceptual description in stage 2 | 393d | 2000-05-01 A | 2001-10-31 A | 100% | 2000-05-01 | 2001-10-31 | 393d |  | finish no earlier than 2001-10-31 | GP,S2,RP | 3144h | 3144h | Rel-5 | Paolo |  |  |  |  |
| 1981 | 110.1.3 | Necessary changes on stage 3 regarding header removal | 439.8d | 2000-11-06 A | 2002-12-20 A | 100% | 2000-11-06 | 2002-12-20 | 439.8d |  | finish no earlier than 2002-12-20 | GP,S2,RP | 3518.4h | 3518.4h | Rel-5 | Paolo |  |  |  |  |
| 1982 | 110.2 | **Deleted - GERAN Radio access bearer design for IMS** | 430d | 2000-11-06 A | 2002-06-28 A | 100% | 2000-11-06 | 2002-06-28 | 430d |  |  | GP,S2,RP | 9287.6h | 9287.6h | Rel-5 | Paolo | GP-10 | GERIMS-RABDES | Nokia | Shkumbin Hamiti |
| 1983 | 110.2.1 | **Deleted - MuM control signalling for conversational multimedia services** | 430d | 2000-11-06 A | 2002-06-28 A | 100% | 2000-11-06 | 2002-06-28 | 430d |  |  | GP,S2,RP | 5847.6h | 5847.6h | Rel-5 | Paolo | GP-10 |  |  |  |
| 1984 | 110.2.1.1 | Deleted - Identification of requirements | 330d | 2000-11-06 A | 2002-02-08 A | 100% | 2000-11-06 | 2002-02-08 | 330d |  | finish no earlier than 2002-02-08 | GP,S2,RP | 2640h | 2640h | Rel-5 | Paolo | GP-08 |  |  |  |
| 1985 | 110.2.1.2 | Deleted - Necessary modifications due to SIP | 40d | 2002-05-06 A | 2002-06-28 A | 100% | 2002-05-06 | 2002-06-28 | 40d |  | finish no earlier than 2002-06-28 | GP,S2,RP | 320h | 320h | Rel-5 | Paolo | GP-10 |  |  |  |
| 1986 | 110.3 | **Deleted - GERAN MS Conformance test for support of IMS** | 400d | 2001-06-11 A | 2002-12-20 A | 100% | 2001-06-11 | 2002-12-20 | 400d |  |  | GP | 6400h | 6400h | Rel-5 | Paolo | GP-12 | GERIMS-MSconf | Nokia | Shkumbin Hamiti |
| 1987 | 110.3.1 | Deleted - MS test | 400d | 2001-06-11 A | 2002-12-20 A | 100% | 2001-06-11 | 2002-12-20 | 400d |  | finish no earlier than 2002-12-20 | G4 | 3200h | 3200h | Rel-5 | Paolo | GP-12 |  |  |  |
| 1988 | 110.4 | **Deleted - GERAN BTS Conformance test for support of IMS** | 400d | 2001-06-11 A | 2002-12-20 A | 100% | 2001-06-11 | 2002-12-20 | 400d |  |  | GP | 6400h | 6400h | Rel-5 | Paolo | GP-12 | GERIMS-BTSconf | Nokia | Shkumbin Hamiti |
| 1989 | 110.4.1 | Deleted - BTS test | 400d | 2001-06-11 A | 2002-12-20 A | 100% | 2001-06-11 | 2002-12-20 | 400d |  | finish no earlier than 2002-12-20 | G3new | 3200h | 3200h | Rel-5 | Ingbert | GP-12 |  |  |  |
| 1990 | 489 | MS Conformance Testing of Dual Transfer Mode | 65d? | 2002-11-11 A | 2003-02-07 A | 100% | 2002-11-11 | 2003-02-07 | 65d? |  | finish no earlier than 2003-02-07 | G4,G5 | 520h | 520h | Rel-5 | Paolo |  | MSCTDTM | Vodafone | Dave Fox |
| 1991 | 490 | **Handling of early UEs** | 911d? | 2000-01-03 A | 2003-06-27 A | 100% | 2000-01-03 | 2003-06-27 | 911d? |  |  | S2 | 4480h | 4480h | Rel-5 | Maurice |  | LATE_UE |  |  |
| 1992 | 490.1 | Feasibility Study | 50d? | 2002-10-07 A | 2002-12-13 A | 100% | 2002-10-07 | 2002-12-13 | 50d? |  | finish no earlier than 2002-12-13 | S2 | 400h | 400h | Rel-5 | Maurice |  |  |  |  |
| 1993 | 490.2 | Stage 2 | 125d? | 2003-01-06 A | 2003-06-27 A | 100% | 2003-01-06 | 2003-06-27 | 125d? |  | start no earlier than 2003-01-06 | S2 | 1000h | 1000h | Rel-5 | Maurice |  |  |  |  |
| 1994 | 490.3 | FS for the Early Mobile Handling in UTRAN | 195d | 2002-09-09 A | 2003-06-06 A | 100% | 2002-09-09 | 2003-06-06 | 195d |  | finish no earlier than 2003-06-06 | R2 | 1560h | 1560h | Rel-5 | Joern |  | FSEarlyUE | Vodafone | Alan Law |
| 1995 | 490.4 | Note: Stage 3 RAN part not shown | 1d | 2000-01-03 A | 2000-01-03 A | 100% | 2000-01-03 | 2000-01-03 | 1d |  |  |  |  |  | Rel-5 |  |  |  |  |  |
| 1996 | 491 | Release 4 Features | 1d? | 2000-01-03 | 2000-01-03 |  | 2000-01-03 | 2000-01-03 | 1d? | 3317d |  | NP,GP, RP,SP,TP | 8h |  | Rel-4 |  |  |  |  |  |

Notes:
- 1973: Not started. Marked as stopped 12/2008
- 1974: Not started. Marked as stopped 12/2008
- 1975: Not started. Marked as stopped 12/2008
- 1976: Not started. Marked as stopped 12/2008
- 1977: AWS, Nokia, Ericsson, Nortel, Siemens, Motorola
- 1978: AWS, Nokia, Ericsson, Nortel, Siemens, Motorola
- 1979: -
- 1980: -
- 1981: -
- 1982: TERMINATED - NOT STANDARDIZED. Marked as stopped 12/2008
- 1983: TERMINATED - NOT STANDARDIZED. Marked as stopped 12/2008
- 1984: TERMINATED - NOT STANDARDIZED
- 1985: TERMINATED - NOT STANDARDIZED
- 1986: TERMINATED - NOT STANDARDIZED. Marked as stopped 12/2008
- 1987: TERMINATED - NOT STANDARDIZED. Marked as stopped 12/2008
- 1988: TERMINATED - NOT STANDARDIZED. Marked as stopped 12/2008
- 1989: TERMINATED - NOT STANDARDIZED. Marked as stopped 12/2008
- 1990: Needed to complete DTM (R99)
- 1991: -
- 1992: -
- 1993: -
- 1994: -
- 1995: -
- 1996: -

| ID | WBS | Task | Duration | Start | Finish | Predecessors | Complete | Baseline start | Baseline finish | Baseline duration | Constraint | Resources | Work | Actual work | Text1 | Text6 | Text8 | Text3 | Text12 | Text4 | Text5 |
| --- | --- | --- | --- | --- | --- | --- | --- | --- | --- | --- | --- | --- | --- | --- | --- | --- | --- | --- | --- | --- | --- |
| 1997 | 15 | **Miscelleneous UE Conformance Testing Activities** | 958d | 2001-04-02 A | 2004-12-01 A |  | 100% | 2001-04-02 | 2004-12-01 | 958d |  | T1 | 36360h | 36360h | MISTST1 | Rel-4 | Ingbert |  |  |  |  |
| 1998 | 15.1 | Optimisation of Test Time, RF Aspects (FDD) | 508d | 2001-09-24 A | 2003-09-03 A |  | 100% | 2001-09-24 | 2003-09-03 | 508d | finish no earlier than 2003-09-03 | T1 | 4064h | 4064h | MISTST1-OpFDD | Rel Indep | Ingbert | 34.121 |  |  |  |
| 1999 | 15.2 | Optimisation of Test Time, RF Aspects (TDD) | 508d | 2001-09-24 A | 2003-09-03 A |  | 100% | 2001-09-24 | 2003-09-03 | 508d | finish no earlier than 2003-09-03 | T1 | 4064h | 4064h | MISTST1-OpTDD | Rel Indep | Ingbert | 34.122 |  |  |  |
| 2000 | 15.3 | Extensions to R99 Test cases | 139.4w | 2001-04-02 A | 2003-12-02 A |  | 100% | 2001-04-02 | 2003-12-02 | 139.4w | finish no earlier than 2003-12-02 | T1 | 5576h | 5576h | MISTST1-Ext | Rel-4 | Ingbert | 34.123 p 1,2 |  |  |  |
| 2001 | 15.4 | Extension to R99 Test cases - TTCN | 439d | 2002-06-28 A | 2004-03-03 A |  | 100% | 2002-06-28 | 2004-03-03 | 439d | finish no earlier than 2004-03-03 | T1 | 3512h | 3512h |  | Rel-4 | Ingbert |  |  |  |  |
| 2002 | 15.5 | Creation of R99 TCs for TDD - prose | 719d | 2001-10-01 A | 2004-07-01 A |  | 100% | 2001-10-01 | 2004-07-01 | 719d | finish no earlier than 2004-07-01 | T1 | 5752h | 5752h | MISTST1-TDD | Rel-4 | Ingbert | 34.123-1 |  |  |  |
| 2003 | 15.6 | Deleted - Creation of R99 TCs for TDD - TTCN | 587d | 2002-09-03 A | 2004-12-01 A |  | 100% | 2002-09-03 | 2004-12-01 | 587d | finish no earlier than 2004-12-01 | T1 | 4696h | 4696h |  | Rel-4 | Ingbert |  | TP-26 |  |  |
| 2004 | 15.7 | Deleted - Review all other work items for impact on new or exiting 34 series specs. | 25.8w | 2002-07-02 A | 2002-12-27 A |  | 100% | 2002-07-02 | 2002-12-27 | 25.8w | finish no earlier than 2002-12-27 | T1 | 1032h | 1032h | MISTST1 | Rel-4 | Ingbert | 34.121,122,123,125 | TP-18 |  |  |
| 2005 | 46 | **Facsimile** | 89d | 2000-02-22 A | 2000-06-23 A |  | 100% | 2000-02-22 | 2000-06-23 | 89d |  | S1 | 4376h | 4376h | FAX | Rel-4 | Alain |  |  |  |  |
| 2006 | 46.1 | **Real Time Fax** | 89d | 2000-02-22 A | 2000-06-23 A |  | 100% | 2000-02-22 | 2000-06-23 | 89d |  | S2 | 3664h | 3664h | FAX-RT | Rel-4 | Maurice |  |  |  |  |
| 2007 | 46.1.1 | Terminal capabilities, AT commands | 89d | 2000-02-22 A | 2000-06-23 A |  | 100% | 2000-02-22 | 2000-06-23 | 89d | finish no earlier than 2000-06-23 | T2 | 712h | 712h |  | Rel-4 |  | 21.904, 27.007 |  |  |  |
| 2008 | 46.1.2 | Signalling aspects (e.g. ICM) | 89d | 2000-02-22 A | 2000-06-23 A |  | 100% | 2000-02-22 | 2000-06-23 | 89d | start no earlier than 2000-02-22 | N1 | 712h | 712h |  | Rel-4 | Frederic |  |  |  |  |
| 2009 | 46.1.3 | Service provision | 89d | 2000-02-22 A | 2000-06-23 A |  | 100% | 2000-02-22 | 2000-06-23 | 89d | finish no earlier than 2000-06-23 | N3 | 712h | 712h |  | Rel-4 | Gwiho | 23.146 |  |  |  |
| 2010 | 46.1.4 | Review whether service/stage 1 aspects need to be aligned | 51d | 2000-04-14 A | 2000-06-23 A |  | 100% | 2000-04-14 | 2000-06-23 | 51d | finish no earlier than 2000-12-14 | S1 | 408h | 408h |  | Rel-4 | Alain |  |  |  |  |
| 2011 | 46.1.5 | Review whether architecture/stage 2 aspects need to be aligned | 51d | 2000-04-14 A | 2000-06-23 A |  | 100% | 2000-04-14 | 2000-06-23 | 51d | finish no earlier than 2000-12-14 | S2 | 408h | 408h |  | Rel-4 | Maurice |  |  |  |  |
| 2012 | 47 | Transparent End-to-End PS mobile streaming application | 253d | 2000-04-03 A | 2001-03-21 A |  | 100% | 2000-04-03 | 2001-03-21 | 253d | finish no earlier than 2000-12-29 | S4 | 2024h | 2024h | PSTREAM | Rel-4 | Paolo | 26.233, 26.234 |  |  |  |
| 2013 | 48 | **Multimedia Messaging** | 277d | 2000-02-22 A | 2001-03-14 A |  | 100% | 2000-02-22 | 2001-03-14 | 277d |  | T2,S1 | 9992h | 9992h | MMS | Rel-4 | Kimmo | 22.140, 23.140 |  | Siemens | Josef.Laumen@SAL.SIEMENS.DE |
| 2014 | 48.1 | Definition of service requirements | 72d | 2000-02-22 A | 2000-05-31 A |  | 100% | 2000-02-22 | 2000-05-31 | 72d | start no earlier than 2000-02-22 | S1 | 576h | 576h | MMS | Rel-4 | Alain |  |  |  |  |
| 2015 | 48.2 | Review of definition of service requirements | 205d | 2000-06-01 A | 2001-03-14 A | 2014 | 100% | 2000-06-01 | 2001-03-14 | 205d | finish no earlier than 2000-09-08 | T2 | 1640h | 1640h | MMS | Rel-4 | Kimmo | 22.140, 23.140 |  | Siemens |  |
| 2016 | 48.3 | **Technical Realisation** | 243d | 2000-04-10 A | 2001-03-14 A |  | 100% | 2000-04-10 | 2001-03-14 | 243d |  | T2 | 7776h | 7776h | MMS | Rel-4 | Kimmo | 22.140, 23.140 |  | Siemens | Josef.Laumen@SAL.SIEMENS.DE |
| 2017 | 48.3.1 | Review of definition of reference Achitecture model | 243d | 2000-04-10 A | 2001-03-14 A |  | 100% | 2000-04-10 | 2001-03-14 | 243d | finish no earlier than 2001-03-14 | T2 | 1944h | 1944h | MMS | Rel-4 | Kimmo | 22.140, 23.140 |  | Siemens | Josef.Laumen@SAL.SIEMENS.DE |
| 2018 | 48.3.2 | "Fulfill Requirements of Stage 1" | 243d | 2000-04-10 A | 2001-03-14 A |  | 100% | 2000-04-10 | 2001-03-14 | 243d | finish no earlier than 2001-03-14 | T2 | 1944h | 1944h | MMS | Rel-4 | Kimmo | 22.140, 23.140 |  | Siemens | Josef.Laumen@SAL.SIEMENS.DE |
| 2019 | 48.3.3 | Definition of MMS primitives in Stage 2 | 243d | 2000-04-10 A | 2001-03-14 A |  | 100% | 2000-04-10 | 2001-03-14 | 243d | finish no earlier than 2001-03-14 | T2 | 1944h | 1944h | MMS | Rel-4 | Kimmo | 22.140, 23.140 |  | Siemens | Josef.Laumen@SAL.SIEMENS.DE |
| 2020 | 49 | **Transcoder-Free Operation** | 326d | 2000-01-03 A | 2001-03-30 A |  | 100% | 2000-01-03 | 2001-03-30 | 326d |  | N4,S2,N1 | 10448h | 10448h | TrFO | Rel-4 | Kimmo |  |  |  |  |
| 2021 | 49.1 | **Out-of-Band Transcoder Control solution** | 326d | 2000-01-03 A | 2001-03-30 A |  | 100% | 2000-01-03 | 2001-03-30 | 326d |  | N4 | 8448h | 8448h | TrFO-OoBTC | Rel-4 | Kimmo |  |  | NEC | Toshiyuki Tamura (tamurato@aj.jp.nec.com) |
| 2022 | 49.1.1 | implementation in UTRAN | 145d | 2000-09-11 A | 2001-03-30 A |  | 100% | 2000-09-11 | 2001-03-30 | 145d | finish no earlier than 2001-03-30 | R3 | 1160h | 1160h | TrFO-OoBTC-UTRAN | Rel-4 | Juha | 25.401, 25.410, 25.413, 25.415, 23.153 |  | Siemens | Alexander Vesely |
| 2023 | 49.1.2 | Impact on architecture, Principles and Terminology | 211d | 2000-01-03 A | 2000-10-20 A |  | 100% | 2000-01-03 | 2000-10-20 | 211d | finish no earlier than 2000-10-20 | S2 | 1680h | 1680h | TrFO-OoBTC | Rel-4 | Maurice |  |  |  |  |
| 2024 | 49.1.3 | Codec Negotiation between UE and MSC | 125d | 2000-08-14 A | 2001-02-02 A |  | 100% | 2000-08-14 | 2001-02-02 | 125d | finish no earlier than 2001-02-02 | N1 | 1000h | 1000h | TrFO-OoBTC | Rel-4 | Frederic | 24.008, 23.009, 23.108, (29.002) |  | Motorola | Andrew Howell |
| 2025 | 49.1.4 | Codec Negotiation inter MSC | 125d | 2000-07-03 A | 2000-12-22 A |  | 100% | 2000-07-03 | 2000-12-22 | 125d | finish no earlier than 2000-12-22 | N4 | 1000h | 1000h | TrFO-OoBTC | Rel-4 | Kimmo |  |  |  |  |
| 2026 | 49.1.5 | Bearer establishment inter MSC | 125d | 2000-07-03 A | 2000-12-22 A |  | 100% | 2000-07-03 | 2000-12-22 | 125d | finish no earlier than 2000-12-22 | N4 | 1000h | 1000h | TrFO-OoBTC | Rel-4 | Kimmo | 23.153 |  |  |  |

Notes:
- 1997: -
- 1998: It is believed that the current R99 test spec. can be optimised for faster overall test times. Marked as stopped 12/2008 (was 70% complete)
- 1999: It is believed that the current R99 test spec. can be optimised for faster overall test times
- 2000: Further test coverage of the R99 specification to cover supplementry services. Marked as stopped 12/2008 (was 70% complete)
- 2001: Marked as closed 12/2008 (was marked 50% complete)
- 2002: Marked as closed 12/2008 (was marked 50% complete)
- 2003: Marked as stopped 12/2008
- 2004: Marked as stopped 12/2008
- 2005: -
- 2006: postponed from R99 to R00, SP-000169
- 2007: -
- 2008: -
- 2009: -
- 2010: -
- 2011: -
- 2012: -
- 2013: -
- 2014: -
- 2015: -
- 2016: -
- 2017: -
- 2018: e.g. minimum set of media formats, media format conversion, personalization of MMS.
- 2019: -
- 2020: Lead given to CN4 from CN / [DAB 28/11/00]
- 2021: -
- 2022: moved according to NP-000575
- 2023: e.g. study cascading TrFO/TFO/TrFO
- 2024: the link to NP-000085has been deleted because refering to a R99 status sheet / One common set of codec negotiation procedures will be specified as in ID1656.
- 2025: Bearer establishment inter MSC. TS 23.153 R99 part complete. capabilities moved to annex + list of open issues
- 2026: Bearer establishment inter MSC. TS 23.153 R99 part complete. capabilities moved to annex. / See NP-000127 / Open issues: / Handling of Conference Calls; / Handling of Multi Party Supplementary Services; / Handling of Handover UMTS to GSM; / Handling of Sending a ...

| ID | WBS | Task | Duration | Start | Finish | Complete | Baseline start | Baseline finish | Baseline duration | Constraint | Resources | Work | Actual work | Text1 | Text6 | Text8 | Text4 | Text5 |
| --- | --- | --- | --- | --- | --- | --- | --- | --- | --- | --- | --- | --- | --- | --- | --- | --- | --- | --- |
| 2027 | 49.2 | **Speech Transcoder: Location and Control at the UMTS Core Network Border** | 125d | 2000-04-10 A | 2000-09-29 A | 100% | 2000-04-10 | 2000-09-29 | 125d |  | S2 | 2000h | 2000h | TrFO-STLC | Rel-4 | Maurice |  |  |
| 2028 | 49.2.1 | Transcoder at Edge | 125d | 2000-04-10 A | 2000-09-29 A | 100% | 2000-04-10 | 2000-09-29 | 125d | finish no earlier than 2000-09-29 | NP | 1000h | 1000h | TrFO-STLC | Rel-4 |  |  |  |
| 2029 | 50 | **GERAN improvements 1 (Gb over IP)** | 225d | 2000-05-09 A | 2001-03-19 A | 100% | 2000-05-09 | 2001-03-19 | 225d |  | GP | 6472h | 6472h | GEIMP1 | Rel-4 | Paolo |  |  |
| 2030 | 50.1 | **Gb over IP (Ip-fication of Gb)** | 225d | 2000-05-09 A | 2001-03-19 A | 100% | 2000-05-09 | 2001-03-19 | 225d |  | GP | 4672h | 4672h | GbIP | Rel-4 | Paolo |  |  |
| 2031 | 50.1.1 | Concept | 134d | 2000-05-09 A | 2000-11-10 A | 100% | 2000-05-09 | 2000-11-10 | 134d |  | GP | 1072h | 1072h |  | Rel-4 | Paolo |  |  |
| 2032 | 50.1.2 | Changes to 08.16, 08.18 | 225d | 2000-05-09 A | 2001-03-19 A | 100% | 2000-05-09 | 2001-03-19 | 225d |  | GP | 1800h | 1800h |  | Rel-4 | Paolo |  |  |
| 2033 | 51 | **GERAN improvements 2 (NACC)** | 677d | 2000-11-06 A | 2003-06-10 A | 100% | 2000-11-06 | 2003-06-10 | 677d |  | GP | 19224h | 19224h | GEIMP2 | Rel-4 | Paolo |  |  |
| 2034 | 51.1 | **Gb enhancements** | 155d | 2000-11-06 A | 2001-06-08 A | 100% | 2000-11-06 | 2001-06-08 | 155d |  | GP | 7440h | 7440h | Gben | Rel-4 | Paolo |  |  |
| 2035 | 51.1.1 | **Intra BSC NACC (Network Assisted Cell Change)** | 155d | 2000-11-06 A | 2001-06-08 A | 100% | 2000-11-06 | 2001-06-08 | 155d |  | GP | 6200h | 6200h |  | Rel-4 | Paolo |  |  |
| 2036 | 51.1.1.1 | Concept | 155d | 2000-11-06 A | 2001-06-08 A | 100% | 2000-11-06 | 2001-06-08 | 155d | finish no earlier than 2001-06-08 | GP | 1240h | 1240h |  | Rel-4 | Paolo |  |  |
| 2037 | 51.1.1.2 | Changes in 03.64 | 155d | 2000-11-06 A | 2001-06-08 A | 100% | 2000-11-06 | 2001-06-08 | 155d | finish no earlier than 2001-06-08 | GP | 1240h | 1240h |  | Rel-4 | Paolo |  |  |
| 2038 | 51.1.1.3 | Changes in 04.60 | 155d | 2000-11-06 A | 2001-06-08 A | 100% | 2000-11-06 | 2001-06-08 | 155d | finish no earlier than 2001-06-08 | GP | 1240h | 1240h |  | Rel-4 | Paolo |  |  |
| 2039 | 51.1.1.4 | Changes in 44.008 | 155d | 2000-11-06 A | 2001-06-08 A | 100% | 2000-11-06 | 2001-06-08 | 155d | finish no earlier than 2001-06-08 | GP | 1240h | 1240h |  | Rel-4 | Paolo |  |  |
| 2040 | 51.3 | **MS conformance test for Intra BSC NACC** | 398d | 2001-11-30 A | 2003-06-10 A | 100% | 2001-11-30 | 2003-06-10 | 398d |  | GP | 6368h | 6368h | GEIMP2-Msconf | Rel-4 | Paolo |  |  |
| 2041 | 51.3.1 | Changes in 51.010 | 398d | 2001-11-30 A | 2003-06-10 A | 100% | 2001-11-30 | 2003-06-10 | 398d | finish no earlier than 2003-12-19 | G5,G4 | 3184h | 3184h |  | Rel-4 | Paolo |  |  |
| 2042 | 52 | **GERAN improvements 4 (Delayed TBF)** | 105d | 2001-01-15 A | 2001-06-08 A | 100% | 2001-01-15 | 2001-06-08 | 105d |  | GP | 3960h | 3960h | GEIMP4 | Rel-4 | Paolo |  |  |
| 2043 | 52.1 | **Gb enhancements 2** | 105d | 2001-01-15 A | 2001-06-08 A | 100% | 2001-01-15 | 2001-06-08 | 105d |  | GP | 3120h | 3120h | GEIMP4-Gben2 | Rel-4 | Paolo |  |  |
| 2044 | 52.1.1 | stage 2 | 105d | 2001-01-15 A | 2001-06-08 A | 100% | 2001-01-15 | 2001-06-08 | 105d | finish no earlier than 2001-06-08 | GP | 840h | 840h |  | Rel-4 | Paolo |  |  |
| 2045 | 52.1.2 | **Stage 3 (changes in 44.060)** | 60d | 2001-01-15 A | 2001-04-06 A | 100% | 2001-01-15 | 2001-04-06 | 60d |  | G2 | 1440h | 1440h |  | Rel-4 | Gert |  |  |
| 2046 | 52.1.2.1 | Definition of enhanced countdown procedure | 60d | 2001-01-15 A | 2001-04-06 A | 100% | 2001-01-15 | 2001-04-06 | 60d | finish no earlier than 2001-04-06 | G2 | 480h | 480h |  | Rel-4 | Gert |  |  |
| 2047 | 52.1.2.2 | Definition of enhanced TBF release procedure | 60d | 2001-01-15 A | 2001-04-06 A | 100% | 2001-01-15 | 2001-04-06 | 60d | finish no earlier than 2001-04-06 | G2 | 480h | 480h |  | Rel-4 | Gert |  |  |
| 2048 | 52.1.2.3 | Definition of USF=FREE type polling mechanism on PDCH | 60d | 2001-01-15 A | 2001-04-06 A | 100% | 2001-01-15 | 2001-04-06 | 60d | finish no earlier than 2001-04-06 | G2 | 480h | 480h |  | Rel-4 | Gert |  |  |
| 2049 | 53 | **Low Chip Rate TDD option** | 880d | 2000-07-19 A | 2003-12-02 A | 100% | 2000-07-19 | 2003-12-02 | 880d |  | R1 | 25872h | 25872h | LCRTDD | Rel-4 | Patrick | CWTS | G. Yang |
| 2050 | 53.1 | Physical layer | 183d | 2000-07-19 A | 2001-03-30 A | 100% | 2000-07-19 | 2001-03-30 | 183d | finish no earlier than 2001-03-30 | R1 | 1464h | 1464h | LCRTDD-Phys | Rel-4 | Patrick | CWTS | G. Yang |
| 2051 | 53.2 | Layer 2 and layer 3 protocol aspects | 183d | 2000-07-19 A | 2001-03-30 A | 100% | 2000-07-19 | 2001-03-30 | 183d | finish no earlier than 2001-03-30 | R2 | 1464h | 1464h | LCRTDD-L23 | Rel-4 | Joern | CWTS | Y. Liu |
| 2052 | 53.3 | RF radio transmission/reception, system performance requirements and conformance testing | 165d | 2000-08-14 A | 2001-03-30 A | 100% | 2000-08-14 | 2001-03-30 | 165d | finish no earlier than 2001-03-30 | R4 | 1320h | 1320h | LCRTDD-RF | Rel-4 | Stefania | CWTS | D. Zhang |
| 2053 | 53.4 | UE radio access capability | 165d | 2000-08-14 A | 2001-03-30 A | 100% | 2000-08-14 | 2001-03-30 | 165d | finish no earlier than 2001-03-30 | R2 | 1320h | 1320h | LCRTDD-UErac | Rel-4 | Joern | CWTS | Y. Liu |
| 2054 | 53.5 | Iub/Iur protocol aspects | 165d | 2000-08-14 A | 2001-03-30 A | 100% | 2000-08-14 | 2001-03-30 | 165d | finish no earlier than 2001-03-30 | R3 | 1320h | 1320h | LCRTDD-IubIur | Rel-4 | Juha | CWTS | Y. Liu |

Notes:
- 2027: WI description and Tdoc S2-99352 / Speech Transcoder: Location and Control at the UMTS Core Network Border
- 2028: WI description and Tdoc S2-99352...
- 2029: -
- 2030: -
- 2031: -
- 2032: -
- 2033: -
- 2034: -
- 2035: -
- 2036: -
- 2037: -
- 2038: -
- 2039: -
- 2040: -
- 2041: az 05/08: duplicated UID_50099 => 50299. Marked as closed 12/2008 (was marked 50% complete)
- 2042: -
- 2043: -
- 2044: -
- 2045: -
- 2046: -
- 2047: -
- 2048: -
- 2049: -
- 2050: -
- 2051: -
- 2052: -
- 2053: -
- 2054: -

| ID | WBS | Task | Duration | Start | Finish | Predecessors | Complete | Baseline start | Baseline finish | Baseline duration | Constraint | Resources | Work | Actual work | Text6 | Text8 | Text3 | Text12 | Text1 | Text4 | Text5 |
| --- | --- | --- | --- | --- | --- | --- | --- | --- | --- | --- | --- | --- | --- | --- | --- | --- | --- | --- | --- | --- | --- |
| 2055 | 53.6 | **Low chiprate TDD interworking with GERAN** | 101d | 2000-09-01 A | 2001-01-19 A | 2054 | 100% | 2000-09-01 | 2001-01-19 | 101d |  |  |  |  | Rel-4 | Paolo |  |  |  |  |  |
| 2056 | 53.6.1 | Handover and Cell Selection / Reselection to UTRA 1.28 Mcps TDD | 101d | 2000-09-01 A | 2001-01-19 A |  | 100% | 2000-09-01 | 2001-01-19 | 101d | finish no earlier than 2001-01-19 |  |  |  | Rel-4 |  |  |  |  |  |  |
| 2057 | 53.8 | **Conformance Test Aspects - Low Chip Rate TDD** | 577d | 2001-09-17 A | 2003-12-02 A | 2055 | 100% | 2001-09-17 | 2003-12-02 | 577d |  | T1 | 12088h | 12088h | Rel-4 | Ingbert |  |  |  |  |  |
| 2058 | 53.8.1 | Testing Layer 2 and layer 3 protocol aspects | 468d | 2001-09-17 A | 2003-07-02 A |  | 100% | 2001-09-17 | 2003-07-02 | 468d | finish no earlier than 2003-07-02 | T1 | 3744h | 3744h | Rel-4 | Ingbert | 34.123-1, 34.123-2 |  |  |  |  |
| 2059 | 53.8.2 | Deleted - Testing Layer 2 and layer 3 protocol aspects - TTCN | 261d | 2002-12-03 A | 2003-12-02 A |  | 100% | 2002-12-03 | 2003-12-02 | 261d | finish no earlier than 2003-12-02 | T1 | 2088h | 2088h | Rel-4 | Ingbert | 34.123-3 | TP-22 |  |  |  |
| 2060 | 53.8.3 | Testing RF Radio Transmission and Reception | 205d | 2001-09-17 A | 2002-06-28 A |  | 100% | 2001-09-17 | 2002-06-28 | 205d | finish no earlier than 2002-06-28 | T1 | 1640h | 1640h | Rel-4 | Ingbert |  |  |  |  |  |
| 2061 | 54 | **Enable bearer independent CS architecture** | 566d | 2000-01-03 A | 2002-03-01 A |  | 100% | 2000-01-03 | 2002-03-01 | 566d |  | S2 | 20192h | 20192h | Rel-4 | Maurice |  |  | CSSPLIT | Siemens | Alexander Milinski |
| 2062 | 54.1 | **Enable bearer-independent call control** | 425d | 2000-01-03 A | 2001-08-16 A |  | 100% | 2000-01-03 | 2001-08-16 | 425d |  | N4 | 12344h | 12344h | Rel-4 | Kimmo |  |  |  | Ericsson | Heinz-Peter.Keutmann@eed.ericsson.se |
| 2063 | 54.1.1 | Architecture and Stage 2 description | 181d | 2000-01-03 A | 2000-09-08 A |  | 100% | 2000-01-03 | 2000-09-08 | 181d | finish no earlier than 2000-09-08 | S2 | 1440h | 1440h | Rel-4 | Maurice | 23.002 |  |  |  |  |
| 2064 | 54.1.2 | Standardisation of protocols (control & user planes) over Nb interface | 64d | 2001-01-02 A | 2001-03-30 A |  | 100% | 2001-01-02 | 2001-03-30 | 64d | finish no earlier than 2001-03-30 | N3 | 512h | 512h | Rel-4 | Gwiho |  |  |  |  |  |
| 2065 | 54.1.3 | Standardisation of protocols over reference points between MSC server and Gateway MSC server | 130d | 2000-09-25 A | 2001-03-23 A |  | 100% | 2000-09-25 | 2001-03-23 | 130d | finish no earlier than 2001-03-23 | N4 | 1040h | 1040h | Rel-4 | Kimmo |  |  |  |  |  |
| 2066 | 54.1.4 | Standardisation of detailed stage 2 description | 180d | 2000-07-17 A | 2001-03-23 A |  | 100% | 2000-07-17 | 2001-03-23 | 180d | finish no earlier than 2001-03-23 | N4 | 1440h | 1440h | Rel-4 | Kimmo |  |  |  |  |  |
| 2067 | 54.1.5 | **Bearer control between MSC server and MGW** | 250d | 2000-09-01 A | 2001-08-16 A |  | 100% | 2000-09-01 | 2001-08-16 | 250d |  | N4 | 4512h | 4512h | Rel-4 | Kimmo |  |  |  |  |  |
| 2068 | 54.1.5.1 | stage 3 - protocol issues | 250d | 2000-09-01 A | 2001-08-16 A |  | 100% | 2000-09-01 | 2001-08-16 | 250d | finish no earlier than 2001-08-16 | N4 | 2000h | 2000h | Rel-4 | Kimmo |  |  |  |  |  |
| 2069 | 54.1.5.2 | stage 3 - parameter value issues | 64d | 2001-01-02 A | 2001-03-30 A |  | 100% | 2001-01-02 | 2001-03-30 | 64d | finish no earlier than 2001-03-30 | N3 | 512h | 512h | Rel-4 | Gwiho |  |  |  |  |  |
| 2070 | 54.2 | Lawful interception | 155d | 2000-08-21 A | 2001-03-23 A |  | 100% | 2000-08-21 | 2001-03-23 | 155d | finish no earlier than 2001-03-23 | S3 | 1240h | 1240h | Rel-4 | Dionisio |  |  |  |  |  |
| 2071 | 54.4 | Deleted - Conformance Test Aspects - Enable bearer independent CS architecture | 260d | 2001-03-05 A | 2002-03-01 A |  | 100% | 2001-03-05 | 2002-03-01 | 260d |  | T1 | 2080h | 2080h | Rel-4 | Ingbert |  | TP-15 | CSSPLIT-TEST |  |  |
| 2072 | 55 | **MExE enhancements Rel-4** | 511d | 2000-01-03 A | 2001-12-14 A |  | 100% | 2000-01-03 | 2001-12-14 | 511d |  | T2 | 19032h | 19032h | Rel-4 | Kimmo |  |  | MEXE |  |  |
| 2073 | 55.1 | **MExE Security Analysis Activity** | 474d | 2000-02-22 A | 2001-12-14 A |  | 100% | 2000-02-22 | 2001-12-14 | 474d |  | S3 | 8464h | 8464h | Rel-4 | Dionisio |  |  | MEXE-SEC | BT | colin.blanchard@bt.com |
| 2074 | 55.1.1 | Stage 3 | 370d | 2000-07-17 A | 2001-12-14 A |  | 100% | 2000-07-17 | 2001-12-14 | 370d | finish no earlier than 2001-12-14 | S3 | 2960h | 2960h | Rel-4 | Dionisio |  |  | MEXE1-SEC |  |  |
| 2075 | 55.1.2 | Terminal aspects | 214d | 2000-02-22 A | 2000-12-15 A |  | 100% | 2000-02-22 | 2000-12-15 | 214d | finish no earlier than 2000-12-15 | T2 | 1712h | 1712h | Rel-4 |  |  |  |  |  |  |
| 2076 | 55.2 | **MExE Rel4 Improvements and Investigations** | 251d | 2000-01-03 A | 2000-12-15 A |  | 100% | 2000-01-03 | 2000-12-15 | 251d |  | T2 | 6480h | 6480h | Rel-4 |  | 22.057, 23.057 |  | MEXE-ENHANC | Motorola | Mark Cataldo |
| 2077 | 55.2.1 | 3rd MExE classmark | 251d | 2000-01-03 A | 2000-12-15 A |  | 100% | 2000-01-03 | 2000-12-15 | 251d | finish no earlier than 2000-12-15 | T2 | 2000h | 2000h | Rel-4 |  | 22.057, 23.057 |  |  | Motorola | Mark Cataldo |
| 2078 | 55.2.2 | FS on Secure download mechanism and capabilities to support SDR concepts | 225d | 2000-02-07 A | 2000-12-15 A |  | 100% | 2000-02-07 | 2000-12-15 | 225d | finish no earlier than 2000-12-15 | T2 | 1800h | 1800h | Rel-4 |  | 22.057, 23.057 |  |  | Motorola | Mark Cataldo |
| 2079 | 55.2.3 | FS on Support of MP3/MPEG4 content | 225d | 2000-02-07 A | 2000-12-15 A |  | 100% | 2000-02-07 | 2000-12-15 | 225d | finish no earlier than 2000-12-15 | T2 | 1800h | 1800h | Rel-4 |  | 22.057, 23.057 |  |  | Motorola | Mark Cataldo |

Notes:
- 2055: -
- 2056: -
- 2057: -
- 2058: Marked as closed 12/2008 (was marked 60% complete)
- 2059: Marked as stopped 12/2008
- 2060: duration set to 6 months (was 0), finish date set
- 2061: -
- 2062: DAB 12.12.01 should be 100% hence closed
- 2063: R00 stage 2 at least 80 % complete in TSGS #8 21.-23.6.2000
- 2064: -
- 2065: -
- 2066: -
- 2067: -
- 2068: -
- 2069: -
- 2070: Requirements capture: S3#14 (Aug 00), Feature specification: S3#15 (Sep 00), Definition of architecture. Should be included in general LI work mentioned above.
- 2071: Marked as stopped 12/2008
- 2072: -
- 2073: Presentation to S3 of threats and countermeasures analysis: S3#15, Feature specification: S3#16. S3#18: WID updated
- 2074: Analysis undertaken by T2. No additional analysis needed for Rel-4
- 2075: -
- 2076: -
- 2077: Additional features for MExE R2000
- 2078: -
- 2079: -

| ID | WBS | Task | Duration | Start | Finish | Complete | Baseline start | Baseline finish | Baseline duration | Constraint | Resources | Work | Actual work | Text1 | Text6 | Text8 | Text3 | Text4 | Text5 |
| --- | --- | --- | --- | --- | --- | --- | --- | --- | --- | --- | --- | --- | --- | --- | --- | --- | --- | --- | --- |
| 2080 | 56 | **Tandem Free aspects for 3G and between 2G and 3G systems** | 344d | 2000-02-22 A | 2001-06-15 A | 100% | 2000-02-22 | 2001-06-15 | 344d |  | S4 | 9696h | 9696h | TFO | Rel-4 | Paolo |  |  |  |
| 2081 | 56.1 | **Tandem Free AMR** | 344d | 2000-02-22 A | 2001-06-15 A | 100% | 2000-02-22 | 2001-06-15 | 344d |  | S4 | 6944h | 6944h | TFO-AMR | Rel-4 | Paolo |  |  |  |
| 2082 | 56.1.1 | Specification | 284d | 2000-02-22 A | 2001-03-23 A | 100% | 2000-02-22 | 2001-03-23 | 284d | start no earlier than 2000-02-22 | S4 | 2272h | 2272h |  | Rel-4 | Paolo | 28.062 |  |  |
| 2083 | 56.1.2 | **Impact on:** | 115d | 2001-01-08 A | 2001-06-15 A | 100% | 2001-01-08 | 2001-06-15 | 115d |  | NP | 1920h | 1920h |  | Rel-4 | Kimmo |  |  |  |
| 2084 | 56.1.2.1 | CN | 60d | 2001-03-26 A | 2001-06-15 A | 100% | 2001-03-26 | 2001-06-15 | 60d | finish no earlier than 2001-06-15 | NP | 480h | 480h |  | Rel-4 | Kimmo |  |  |  |
| 2085 | 56.1.2.2 | GERAN | 65d | 2001-01-08 A | 2001-04-06 A | 100% | 2001-01-08 | 2001-04-06 | 65d | finish no earlier than 2001-04-06 | GP | 520h | 520h |  | Rel-4 | Paolo |  |  |  |
| 2086 | 57 | **Advanced Speech Call Items enhancements_REL-4** | 334d | 2000-12-03 A | 2002-03-14 A | 100% | 2000-12-03 | 2002-03-14 | 334d |  | N1 | 5925.6h | 5925.6h | ASCI | Rel-4 | Frederic |  | Nortel | sonia.garapaty@nortelnetworks.com |
| 2087 | 57.1 | Stage 2 | 326.7d | 2000-12-03 A | 2002-03-14 A | 100% | 2000-12-03 | 2002-03-14 | 326.7d | finish no earlier than 2002-03-14 | N4 | 2613.6h | 2613.6h |  | Rel-4 | Kimmo | 23.067, 24.067 | Sagem | Vivien Perlic |
| 2088 | 57.2 | Stages 2 and 3 on A interface | 80d | 2000-12-03 A | 2001-03-23 A | 100% | 2000-12-03 | 2001-03-23 | 80d | finish no earlier than 2001-03-23 | N1 | 640h | 640h |  | Rel-4 | Frederic | 44.068, 44.069, 24.008 | Nortel | sonia.garapaty@nortelnetworks.com |
| 2089 | 58 | **700 MHz spectrum support** | 776d | 2000-01-03 A | 2002-12-20 A | 100% | 2000-01-03 | 2002-12-20 | 776d |  | GP | 25016h | 25016h | 700SS | Rel-4 | Paolo |  |  |  |
| 2090 | 58.1 | **GERAN support for the 700 MHz band** | 276d | 2000-01-03 A | 2001-01-19 A | 100% | 2000-01-03 | 2001-01-19 | 276d |  | GP | 8808h | 8808h |  | Rel-4 | Paolo |  |  |  |
| 2091 | 58.1.1 | Signalling support | 276d | 2000-01-03 A | 2001-01-19 A | 100% | 2000-01-03 | 2001-01-19 | 276d | finish no earlier than 2001-01-19 | GP | 2200h | 2200h |  | Rel-4 | Paolo |  |  |  |
| 2092 | 58.1.2 | Physical layer definitions | 276d | 2000-01-03 A | 2001-01-19 A | 100% | 2000-01-03 | 2001-01-19 | 276d | finish no earlier than 2001-01-19 | GP | 2200h | 2200h |  | Rel-4 | Paolo |  |  |  |
| 2093 | 58.1.3 | Receiver performance and RF budget | 276d | 2000-01-03 A | 2001-01-19 A | 100% | 2000-01-03 | 2001-01-19 | 276d | finish no earlier than 2001-01-19 | GP | 2200h | 2200h |  | Rel-4 | Paolo |  |  |  |
| 2094 | 58.2 | **GERAN MS Conformance test for 700 MHz band** | 175d | 2001-04-02 A | 2001-11-30 A | 100% | 2001-04-02 | 2001-11-30 | 175d |  | GP | 2800h | 2800h |  | Rel-4 | Paolo |  |  |  |
| 2095 | 58.2.1 | MS test | 175d | 2001-04-02 A | 2001-11-30 A | 100% | 2001-04-02 | 2001-11-30 | 175d | finish no earlier than 2001-11-30 | GP | 1400h | 1400h |  | Rel-4 | Paolo |  |  |  |
| 2096 | 58.3 | **GERAN BTS Conformance test for 700 MHz band** | 450d | 2001-04-02 A | 2002-12-20 A | 100% | 2001-04-02 | 2002-12-20 | 450d |  | GP | 7200h | 7200h |  | Rel-4 | Paolo |  |  |  |
| 2097 | 58.3.1 | BTS test | 450d | 2001-04-02 A | 2002-12-20 A | 100% | 2001-04-02 | 2002-12-20 | 450d | finish no earlier than 2002-12-20 | GP | 3600h | 3600h |  | Rel-4 | Paolo |  |  |  |
| 2098 | 59 | Operator Determined Barring for Packet Oriented Services | 208d | 2000-06-01 A | 2001-03-19 A | 100% | 2000-06-01 | 2001-03-19 | 208d | finish no earlier than 2001-03-19 | NP | 1664h | 1664h | ODB | Rel-4 |  |  | NEC | Toshiyuki Tamura (tamurato@aj.jp.nec.com) |
| 2099 | 60 | **UMTS QoS Architecture for PS Domain** | 759d | 2000-01-03 A | 2002-11-27 A | 100% | 2000-01-03 | 2002-11-27 | 759d |  | S2 | 41312h | 41312h | QoSPS | Rel-4 | Maurice |  | Ericsson | Ina.widegren@era.ericsson.se |
| 2100 | 60.1 | Architecture | 153d | 2000-06-05 A | 2001-01-03 A | 100% | 2000-06-05 | 2001-01-03 | 153d | finish no earlier than 2001-01-03 | S2 | 1224h | 1224h |  | Rel-4 | Maurice | 23.107 |  |  |
| 2101 | 60.2 | Charging and OAM&P for QoS Management | 201d | 2001-09-21 A | 2002-06-28 A | 100% | 2001-09-21 | 2002-06-28 | 201d | finish no earlier than 2002-06-28 | S5 | 1608h | 1608h | QoSPS-OAM | Rel-4 | Dionisio | 32-series | VoiceStream, Motorola |  |
| 2102 | 60.3 | **RAB Quality of Service (re)Negotiation over Iu** | 155d | 2000-08-21 A | 2001-03-23 A | 100% | 2000-08-21 | 2001-03-23 | 155d |  | R3 | 3648h | 3648h | QoSPS-MAPEND-RABQoS | Rel-4 | Juha | 25.413 | Ericsson | A. Molander |
| 2103 | 60.3.1 | RAB Quality of Service Negotiation over Iu | 155d | 2000-08-21 A | 2001-03-23 A | 100% | 2000-08-21 | 2001-03-23 | 155d | finish no earlier than 2001-03-23 | R3 | 1240h | 1240h | QoSPS-MAPEND-RABQoS-Negot | Rel-4 | Juha |  | Ericsson | A. Molander |
| 2104 | 60.3.2 | RAB Quality of Service Negotiation over Iu during relocation | 16d | 2001-03-02 A | 2001-03-23 A | 100% | 2001-03-02 | 2001-03-23 | 16d | start no earlier than 2001-03-02 | R3 | 128h | 128h | QoSPS-MAPEND-RABQoS-NegotReloc | Rel-4 | Juha |  |  |  |
| 2105 | 60.3.3 | RAB Quality of Service Re-Negotiation over Iu | 130d | 2000-09-25 A | 2001-03-23 A | 100% | 2000-09-25 | 2001-03-23 | 130d | finish no earlier than 2001-03-23 | R3 | 1040h | 1040h | QoSPS-MAPEND-RABQoS-ReNegot | Rel-4 | Juha |  | Motorola | S. Irwin |

Notes:
- 2080: RAN and CN to verify no problems for GSM terminals roaming in 3G R99
- 2081: RAN and CN to verify UMTS_AMR_2 support
- 2082: -
- 2083: "Implementation" changed to "Impact on:" by A. Sultan (for better wording)
- 2084: RAN and CN to verify UMTS_AMR_2 support
- 2085: End date Modified from June to March to have it in Rel4
- 2086: Approved at CN#10
- 2087: CN4#11 30/11/02: no inputs received in CN4
- 2088: -
- 2089: -
- 2090: -
- 2091: -
- 2092: -
- 2093: -
- 2094: -
- 2095: -
- 2096: -
- 2097: -
- 2098: Completed WI missing from the P-plan Added for tracking
- 2099: -
- 2100: -
- 2101: -
- 2102: -
- 2103: -
- 2104: -
- 2105: -

| ID | WBS | Task | Duration | Start | Finish | Complete | Baseline start | Baseline finish | Baseline duration | Constraint | Resources | Work | Actual work | Text1 | Text6 | Text8 | Text12 | Text4 | Text5 | Text3 |
| --- | --- | --- | --- | --- | --- | --- | --- | --- | --- | --- | --- | --- | --- | --- | --- | --- | --- | --- | --- | --- |
| 2106 | 60.4 | **GERAN QoS Aspects - Handovers: maintenance of real-time QoS while moving between cells in the PLMN including inter-SGSN and SRNS relocation or possibly other mechanisms** | 501d | 2000-01-03 A | 2001-11-30 A | 100% | 2000-01-03 | 2001-11-30 | 501d |  | GP | 14456h | 14456h | GERQoS | Rel-4 | Paolo |  |  |  |  |
| 2107 | 60.4.1 | **Handover Concept for the PS domain** | 501d | 2000-01-03 A | 2001-11-30 A | 100% | 2000-01-03 | 2001-11-30 | 501d |  | GP | 10448h | 10448h |  | Rel-4 | Paolo |  |  |  |  |
| 2108 | 60.4.1.1 | Stable RT handover report 25.936 including header removal | 14d | 2000-01-03 A | 2000-01-19 A | 100% | 2000-01-03 | 2000-01-19 | 14d | start no earlier than 2000-01-03 | GP [92.9%] | 104h | 104h |  | Rel-4 | Paolo |  |  |  |  |
| 2109 | 60.4.1.2 | Update of stage 2 | 293d | 2000-01-03 A | 2001-02-13 A | 100% | 2000-01-03 | 2001-02-13 | 293d | finish no earlier than 2001-02-13 | GP | 2336h | 2336h |  | Rel-4 | Paolo |  |  |  |  |
| 2110 | 60.4.1.3 | Update of relevant stage 3 specs -> RRC | 501d | 2000-01-03 A | 2001-11-30 A | 100% | 2000-01-03 | 2001-11-30 | 501d | finish no earlier than 2001-11-30 | G2 | 4000h | 4000h |  | Rel-4 | Gert |  |  |  |  |
| 2111 | 60.5 | **Deleted - GERAN MS Conformance test for inter-system and intra-system Packet data real-time Handover** | 324d | 2001-08-31 A | 2002-11-27 A | 100% | 2001-08-31 | 2002-11-27 | 324d |  | G4,R3 | 12960h | 12960h | GERQoS-Mstest | Rel-4 | Paolo | GP-12 |  |  |  |
| 2112 | 60.5.1 | **Deleted - Handover for the PS domain** | 324d | 2001-08-31 A | 2002-11-27 A | 100% | 2001-08-31 | 2002-11-27 | 324d |  | G4,R3 | 10368h | 10368h |  | Rel-4 | Paolo | GP-12 |  |  |  |
| 2113 | 60.5.1.1 | Deleted - Stable RT handover report 25.936 including header removal | 324d | 2001-08-31 A | 2002-11-27 A | 100% | 2001-08-31 | 2002-11-27 | 324d | finish no earlier than 2002-11-27 | G4,R3 | 2592h | 2592h |  | Rel-4 | Paolo | GP-12 |  |  |  |
| 2114 | 60.5.1.2 | Deleted - Update of stage 2 | 324d | 2001-08-31 A | 2002-11-27 A | 100% | 2001-08-31 | 2002-11-27 | 324d | finish no earlier than 2002-11-27 | G4,R3 | 2592h | 2592h |  | Rel-4 | Paolo | GP-12 |  |  |  |
| 2115 | 60.5.1.3 | Deleted - Update of relevant stage 3 specs | 324d | 2001-08-31 A | 2002-11-27 A | 100% | 2001-08-31 | 2002-11-27 | 324d | finish no earlier than 2002-11-27 | G4,R3 | 2592h | 2592h |  | Rel-4 | Paolo | GP-12 |  |  |  |
| 2116 | 60.6 | PS-domain handover for real-time services | 155d | 2000-08-28 A | 2001-03-30 A | 100% | 2000-08-28 | 2001-03-30 | 155d | finish no earlier than 2001-03-30 | R3 | 1240h | 1240h | QoSPS-PSdoRTS | Rel-4 | Juha |  | Nokia | A. Lansisalmi |  |
| 2117 | 60.7 | Deleted - RAB QoS Renegotiation at Relocation | 58d | 2001-01-03 A | 2001-03-23 A | 100% | 2001-01-03 | 2001-03-23 | 58d | finish no earlier than 2001-03-23 | R3 | 464h | 464h |  | Rel-4 | Juha | RP-11 |  |  | 25.851, 25.946 |
| 2118 | 61 | **small Technical Enhancements and Improvements for Rel4** | 2178d? | 2000-01-03 A | 2008-05-06 A | 100% | 2000-01-03 | 2008-05-06 | 2178d? |  | All | 17424h | 17424h | TEI4 | Rel-4 |  |  |  |  |  |
| 2119 | 508.1 | Small Technical Enhancements and Improvements for Rel-4 Conformance Testing | 2178d? | 2000-01-03 A | 2008-05-06 A | 100% | 2000-01-03 | 2008-05-06 | 2178d? | finish no earlier than 2008-12-31 | R5,T1 | 17424h | 17424h | TEI4_Test | Rel-4 | Ingbert |  |  |  |  |
| 2120 | 62 | **Rel-4 Evolutions of the transport in the UTRAN** | 525d | 2000-08-21 A | 2002-08-23 A | 100% | 2000-08-21 | 2002-08-23 | 525d |  | RP | 8600h | 8600h | ETRAN | Rel-4 | Stefania |  | Alcatel | Francois Courau |  |
| 2121 | 62.1 | QoS optimisation for AAL2 connections over Iub and Iur interfaces | 160d | 2000-08-21 A | 2001-03-30 A | 100% | 2000-08-21 | 2001-03-30 | 160d | finish no earlier than 2001-03-30 | R3 | 1280h | 1280h | ETRAN-QoSAAL2 | Rel-4 | Juha |  | Japan Telecom | T. Yoshimura |  |
| 2122 | 62.2 | Transport bearer modification procedure on Iub, Iur, and Iu | 130d | 2000-10-02 A | 2001-03-30 A | 100% | 2000-10-02 | 2001-03-30 | 130d | finish no earlier than 2001-03-30 | R3 | 1040h | 1040h | ETRAN-MigrMod | Rel-4 | Juha |  | Japan Telecom | T. Yoshimura |  |
| 2123 | 62.3 | **Deleted - Conformance Test Aspects of Rel-4 evolutions of the transport in UTRAN** | 130d | 2002-02-25 A | 2002-08-23 A | 100% | 2002-02-25 | 2002-08-23 | 130d |  | T1 | 2080h | 2080h |  | Rel-4 | Ingbert |  |  |  |  |
| 2124 | 62.3.1 | Deleted - Testing RAB support enhancements | 130d | 2002-02-25 A | 2002-08-23 A | 100% | 2002-02-25 | 2002-08-23 | 130d | finish no earlier than 2002-08-23 | T1 | 1040h | 1040h | CT-RABS? | Rel-4 | Ingbert |  |  |  | 34.108, 34. 121, 34.122, 34.123 p 1,2, 34.123 pt 3 |
| 2125 | 63 | **Rel-4 Evolutions of the transport in the CN** | 215d | 2000-05-29 A | 2001-03-23 A | 100% | 2000-05-29 | 2001-03-23 | 215d |  | N4,N1,N2,S2 | 7968h | 7968h | CNTRSP | Rel-4 | Kimmo |  |  |  |  |
| 2126 | 63.1 | **IP Transport of CN protocols (e.g., CAP, MAP)** | 77d | 2000-12-07 A | 2001-03-23 A | 100% | 2000-12-07 | 2001-03-23 | 77d |  | N4 | 2808h | 2808h | SS7IP | Rel-4 | Kimmo |  |  |  |  |
| 2127 | 63.1.1 | **Stage 3** | 77d | 2000-12-07 A | 2001-03-23 A | 100% | 2000-12-07 | 2001-03-23 | 77d |  | N4 | 2192h | 2192h |  | Rel-4 | Kimmo |  |  |  |  |
| 2128 | 63.1.1.1 | CAP | 77d | 2000-12-07 A | 2001-03-23 A | 100% | 2000-12-07 | 2001-03-23 | 77d | finish no earlier than 2001-03-23 | N2 | 616h | 616h |  | Rel-4 | Kimmo |  |  |  |  |
| 2129 | 63.1.1.2 | MAP | 77d | 2000-12-07 A | 2001-03-23 A | 100% | 2000-12-07 | 2001-03-23 | 77d | finish no earlier than 2001-03-23 | N4 | 616h | 616h |  | Rel-4 | Kimmo |  |  |  |  |
| 2130 | 63.1.1.3 | BSSAP+ | 43d | 2001-01-15 A | 2001-03-14 A | 100% | 2001-01-15 | 2001-03-14 | 43d | finish no earlier than 2001-03-14 | N1 | 344h | 344h | SS7IP-BSSAP+ | Rel-4 | Frederic |  |  |  |  |

Notes:
- 2106: -
- 2107: -
- 2108: -
- 2109: -
- 2110: -
- 2111: Still exist? To be clarified by GERAN4/5. Marked as stopped 12/2008
- 2112: Marked as stopped 12/2008
- 2113: Marked as stopped 12/2008
- 2114: Marked as stopped 12/2008
- 2115: Marked as stopped 12/2008
- 2116: -
- 2117: Marked as stopped 12/2008
- 2118: "Joker" WI, to be used for a Rel 4 CR not related to any feature and with very limited impact on the system
- 2119: "Joker" WI, to be used for small modifications applicable to Rel 4 conformance testing. Moved in from the Stoyan/Testing WP
- 2120: -
- 2121: -
- 2122: -
- 2123: Marked as stopped 12/2008
- 2124: Marked as stopped 12/2008
- 2125: -
- 2126: -
- 2127: -
- 2128: -
- 2129: -
- 2130: -

| ID | WBS | Task | Duration | Start | Finish | Complete | Baseline start | Baseline finish | Baseline duration | Constraint | Resources | Work | Actual work | Text4 | Text5 | Text6 | Text8 | Text1 | Text3 | Text12 |
| --- | --- | --- | --- | --- | --- | --- | --- | --- | --- | --- | --- | --- | --- | --- | --- | --- | --- | --- | --- | --- |
| 2131 | 63.2 | **FS on Transport and control separation in the PS CN domain** | 215d | 2000-05-29 A | 2001-03-23 A | 100% | 2000-05-29 | 2001-03-23 | 215d |  | S2 | 3440h | 3440h | Ericsson | Juan-Antonio.Ibanez@eed.ericsson.se | Rel-4 | Maurice |  |  |  |
| 2132 | 63.2.1 | Architectural impacts | 215d | 2000-05-29 A | 2001-03-23 A | 100% | 2000-05-29 | 2001-03-23 | 215d | finish no earlier than 2001-03-23 | S2 | 1720h | 1720h |  |  | Rel-4 | Maurice |  |  |  |
| 2133 | 64 | **Rel-4 Improvements of Radio Interface** | 700d | 2000-07-10 A | 2003-03-14 A | 100% | 2000-07-10 | 2003-03-14 | 700d |  | RP | 28624h | 28624h |  |  | Rel-4 | Stefania | RInImp |  |  |
| 2134 | 64.1 | UTRA repeater specification (master) | 183d | 2000-07-10 A | 2001-03-21 A | 100% | 2000-07-10 | 2001-03-21 | 183d | finish no earlier than 2001-03-21 | R4 | 1464h | 1464h | Mikom, Allgon | T. Kummetz, Mikom; Alf Ahlström, Allgon | Rel-4 | Stefania | RInImp-REP |  |  |
| 2135 | 64.2 | DSCH power control improvement in soft handover | 140d | 2000-09-11 A | 2001-03-23 A | 100% | 2000-09-11 | 2001-03-23 | 140d | finish no earlier than 2001-03-23 | R1 | 1120h | 1120h | Nokia | antti.toskala@nokia.com | Rel-4 | Patrick | RInImp-DSCHsho |  |  |
| 2136 | 64.3 | UMTS 1800 | 320d | 2000-09-25 A | 2001-12-14 A | 100% | 2000-09-25 | 2001-12-14 | 320d | finish no earlier than 2001-12-14 | R4 | 2560h | 2560h | Motorola | Howard Benn | Rel indep | Stefania | RInImp-UMTS18 |  |  |
| 2137 | 64.4 | UMTS 1900 | 195d | 2001-03-19 A | 2001-12-14 A | 100% | 2001-03-19 | 2001-12-14 | 195d | finish no earlier than 2001-12-14 | R4 | 1560h | 1560h | Motorola | Howard Benn | Rel indep | Stefania | RInImp-UMTS19 | 25.101 |  |
| 2138 | 64.5 | FS on High Speed downlink packet access | 155d | 2000-08-21 A | 2001-03-23 A | 100% | 2000-08-21 | 2001-03-23 | 155d | finish no earlier than 2001-03-23 | R2 | 1240h | 1240h | Motorola | A. Ghosh | Rel-4 | Joern | RInImp-HSDPA |  |  |
| 2139 | 64.6 | Deleted - FS on improved common DL channel for Cell-FACH state | 340d | 2000-09-11 A | 2001-12-28 A | 100% | 2000-09-11 | 2001-12-28 | 340d | finish no earlier than 2001-12-28 | R2 | 2720h | 2720h | GBT | J. Kwak | Rel-4 | Joern | RInImp-DLCFACH |  | RP-14 |
| 2140 | 64.7 | **Conformance Test Spec. Rel-4 improvements in Radio Interface** | 375d | 2001-10-08 A | 2003-03-14 A | 100% | 2001-10-08 | 2003-03-14 | 375d |  | T1 | 12360h | 12360h |  |  | Rel-4 | Ingbert |  |  |  |
| 2141 | 64.7.1 | Deleted - Testing Improved usage of downlink resource in FDD for CCTrCHs of dedicated type | 140d | 2002-02-18 A | 2002-08-30 A | 100% | 2002-02-18 | 2002-08-30 | 140d | finish no earlier than 2002-08-30 | T1 | 1120h | 1120h |  |  | Rel-4 | Ingbert |  |  | TP-17 |
| 2142 | 64.7.2 | Deleted - Testing Terminal Power saving features | 140d | 2002-02-18 A | 2002-08-30 A | 100% | 2002-02-18 | 2002-08-30 | 140d | finish no earlier than 2002-08-30 | T1 | 1120h | 1120h |  |  | Rel-4 | Ingbert |  |  | TP-17 |
| 2143 | 64.7.3 | Deleted - Testing DSCH power control improvement in soft handover | 140d | 2002-02-18 A | 2002-08-30 A | 100% | 2002-02-18 | 2002-08-30 | 140d | finish no earlier than 2002-08-30 | T1 | 1120h | 1120h |  |  | Rel-4 | Ingbert |  |  | TP-17 |
| 2144 | 64.7.4 | Testing UMTS 1800 | 180d | 2001-10-08 A | 2002-06-14 A | 100% | 2001-10-08 | 2002-06-14 | 180d | finish no earlier than 2002-06-14 | T1 | 1440h | 1440h |  |  | Rel indep | Ingbert |  | 34.108, 34,121, 34.122, 34.123-1 |  |
| 2145 | 64.7.5 | Testing UMTS 1900 | 180d | 2001-10-08 A | 2002-06-14 A | 100% | 2001-10-08 | 2002-06-14 | 180d | finish no earlier than 2002-06-14 | T1 | 1440h | 1440h |  |  | Rel indep | Ingbert |  | 34.108, 34,121, 34.122, 34.123-1 |  |
| 2146 | 64.7.6 | Testing UMTS 1800 - TTCN | 195d | 2002-06-17 A | 2003-03-14 A | 100% | 2002-06-17 | 2003-03-14 | 195d | finish no earlier than 2003-03-14 | T1 | 1560h | 1560h |  |  | Rel indep | Ingbert |  | 34.123-3 |  |
| 2147 | 64.7.7 | Testing UMTS 1900 - TTCN | 195d | 2002-06-17 A | 2003-03-14 A | 100% | 2002-06-17 | 2003-03-14 | 195d | finish no earlier than 2003-03-14 | T1 | 1560h | 1560h |  |  | Rel indep | Ingbert |  | 34.123-3 |  |
| 2148 | 65 | **Rel-4 RAN improvements** | 938d? | 2000-08-14 A | 2004-03-17 A | 100% | 2000-08-14 | 2004-03-17 | 938d? |  | RP | 29336h | 29336h |  |  | Rel-4 | Stefania | RANimp |  |  |
| 2149 | 65.1 | Node B synchronization for TDD | 160d | 2000-08-14 A | 2001-03-23 A | 100% | 2000-08-14 | 2001-03-23 | 160d | finish no earlier than 2001-03-23 | R1 | 1280h | 1280h | Siemens | S. Oestreich | Rel-4 | Patrick | RANimp-NBsync |  |  |
| 2150 | 65.2 | RAB support enhancement for Rel-4 | 155d | 2000-08-21 A | 2001-03-23 A | 100% | 2000-08-21 | 2001-03-23 | 155d | finish no earlier than 2001-03-23 | R2 | 1240h | 1240h | Ericsson | M. Israelsson, A. Krishnarajah | Rel-4 | Joern | RANimp-RABSE |  |  |
| 2151 | 65.4 | **Deleted - Conformance Test Aspects - Rel-4 RAN Improvements** | 577d? | 2002-01-01 A | 2004-03-17 A | 100% | 2002-01-01 | 2004-03-17 | 577d? |  | T1 | 19312h | 19312h |  |  | Rel-4 | Ingbert |  |  |  |
| 2152 | 65.4.1 | Deleted - Testing Radio access bearer support enhancments | 175d | 2002-01-01 A | 2002-09-02 A | 100% | 2002-01-01 | 2002-09-02 | 175d | finish no earlier than 2002-09-02 | T1 | 1400h | 1400h |  |  | Rel-4 | Ingbert |  |  | TP-17 |
| 2153 | 65.4.2 | Deleted - Testing RAB support enhancements-Robust Header Compression | 332d | 2002-05-28 A | 2003-09-03 A | 100% | 2002-05-28 | 2003-09-03 | 332d | finish no earlier than 2003-09-03 | T1 | 2656h | 2656h |  |  | Rel-4 | Ingbert | RABimp-RoCH | 34.123-1, -2 | TP-21 |
| 2154 | 65.4.3 | Deleted - Testing RAB support enhancements-Robust Header Compression - TTCN | 472d | 2002-05-28 A | 2004-03-17 A | 100% | 2002-05-28 | 2004-03-17 | 472d | finish no earlier than 2004-03-17 | T1 | 3776h | 3776h |  |  | Rel-4 | Ingbert |  | 34.123-3 | TP-23 |
| 2155 | 65.4.4 | Testing of Extended Robut Header Compression | 270d | 2002-09-18 A | 2003-09-30 A | 100% | 2002-09-18 | 2003-09-30 | 270d | finish no earlier than 2003-09-30 | T1 | 2160h | 2160h |  |  | Rel-4 | Ingbert | Ext-RoHC | 34.123-1, -2 |  |
| 2156 | 65.4.5 | Deleted - Testing of Extended Robut Header Compression - TTCN | 325d | 2002-09-18 A | 2003-12-16 A | 100% | 2002-09-18 | 2003-12-16 | 325d | finish no earlier than 2003-12-16 | T1 | 2600h | 2600h |  |  | Rel-4 | Ingbert |  | 34.123-3 | TP-22 |
| 2157 | 512.3.6 | Deleted - General changes to TS34.121 corresponding to release 4 | 263d? | 2003-03-03 A | 2004-03-03 A | 100% | 2003-03-03 | 2004-03-03 | 263d? | finish no earlier than 2004-03-03 | T1 | 2104h | 2104h |  |  | Rel-4 | Ingbert | RANimp-test | 34.108, 34.121 | TP-23 |

Notes:
- 2131: -
- 2132: -
- 2133: -
- 2134: -
- 2135: -
- 2136: -
- 2137: -
- 2138: -
- 2139: Stopped at RP#14
- 2140: -
- 2141: Marked as stopped 12/2008
- 2142: Marked as stopped 12/2008
- 2143: Marked as stopped 12/2008
- 2144: -
- 2145: -
- 2146: -
- 2147: -
- 2148: -
- 2149: -
- 2150: 29 Nov 2000: split into ROHC and non-ROHC part; 5 Mar 2001: splitting off of ROHC for Rel-4 agreed by R2
- 2151: Marked as stopped 12/2008
- 2152: Marked as stopped 12/2008
- 2153: UID changed. Marked as stopped 12/2008
- 2154: UID changed. Marked as stopped 12/2008
- 2155: Marked as closed 12/2008 (was marked 15% complete)
- 2156: Marked as stopped 12/2008
- 2157: Marked as stopped 12/2008

| ID | WBS | Task | Duration | Start | Finish | Complete | Baseline start | Baseline finish | Baseline duration | Constraint | Resources | Work | Actual work | Text1 | Text4 | Text6 | Text8 | Text12 | Text3 | Text5 |
| --- | --- | --- | --- | --- | --- | --- | --- | --- | --- | --- | --- | --- | --- | --- | --- | --- | --- | --- | --- | --- |
| 2158 | 66 | **Rel-4 Emergency call enhancements** | 628d | 2000-01-03 A | 2002-05-28 A | 100% | 2000-01-03 | 2002-05-28 | 628d |  | N1,S1,T1 | 3600h | 3600h | EMC1 | Ericsson | Rel-4 | Frederic |  |  |  |
| 2159 | 66.1 | **For CS based calls** | 628d | 2000-01-03 A | 2002-05-28 A | 100% | 2000-01-03 | 2002-05-28 | 628d |  | N1 | 3600h | 3600h | EMC1-CS | Ericsson | Rel-4 | Frederic |  |  |  |
| 2160 | 66.1.1 | Distinction in CS domain of emergency call types to different emergency services | 40d | 2000-05-01 A | 2000-06-23 A | 100% | 2000-05-01 | 2000-06-23 | 40d | finish no earlier than 2000-06-23 | S1 | 320h | 320h | EMC1-CS |  | Rel-4 | Alain |  |  |  |
| 2161 | 66.1.2 | Distinction in CS domain of emergency calls to different emergency types | 22d | 2000-08-24 A | 2000-09-22 A | 100% | 2000-08-24 | 2000-09-22 | 22d | finish no earlier than 2000-09-22 | N1 | 176h | 176h | EMC1-CS |  | Rel-4 | Frederic |  |  |  |
| 2162 | 66.1.3 | Deleted - Conformance Test Aspects - Emergency call enhancements | 151d | 2000-01-03 A | 2000-07-28 A | 100% | 2000-01-03 | 2000-07-28 | 151d |  | T1 | 1200h | 1200h | EMC1-CS |  | Rel-4 | Ingbert | TP-08 |  |  |
| 2163 | 66.1.4 | Testing CS based emergency calls | 67d | 2002-02-25 A | 2002-05-28 A | 100% | 2002-02-25 | 2002-05-28 | 67d | finish no earlier than 2002-05-28 | T1 | 536h | 536h | EMC1-CS |  | Rel-4 | Ingbert |  | 34.123-1 |  |
| 2164 | 66.1.5 | Testing CS based emergency calls - TTCN | 134d | 2001-11-22 A | 2002-05-28 A | 100% | 2001-11-22 | 2002-05-28 | 134d | finish no earlier than 2002-05-28 | T1 | 1072h | 1072h | EMC1-CS |  | Rel-4 | Ingbert |  | 34.123-3 |  |
| 2165 | 67 | **Rel-4 Terminal interfaces** | 315d | 2000-01-03 A | 2001-03-15 A | 100% | 2000-01-03 | 2001-03-15 | 315d |  | T2 | 14296h | 14296h | TI |  | Rel-4 | Kimmo |  |  |  |
| 2166 | 67.1 | **AT commands enhancements** | 314d | 2000-01-03 A | 2001-03-14 A | 100% | 2000-01-03 | 2001-03-14 | 314d |  | T2 | 5016h | 5016h | TI-ATC |  | Rel-4 |  |  | 27.007 |  |
| 2167 | 67.1.1 | Specification of AT commands for new services | 314d | 2000-01-03 A | 2001-03-14 A | 100% | 2000-01-03 | 2001-03-14 | 314d | finish no earlier than 2001-03-14 | T2 | 2504h | 2504h |  |  | Rel-4 |  |  | 27.007 |  |
| 2168 | 67.2 | **Wide Area Data Synchronization** | 314d | 2000-01-03 A | 2001-03-14 A | 100% | 2000-01-03 | 2001-03-14 | 314d |  | T2 | 5016h | 5016h | TI-WADS |  | Rel-4 |  |  |  |  |
| 2169 | 67.2.1 | Continues evolution of Synchronization protocol | 314d | 2000-01-03 A | 2001-03-14 A | 100% | 2000-01-03 | 2001-03-14 | 314d | finish no earlier than 2001-03-14 | T2 | 2504h | 2504h | TI-SYNC-EVOL |  | Rel-4 |  |  | 27.903, 27.103 |  |
| 2170 | 67.3 | Terminal local model | 218d | 2000-05-16 A | 2001-03-15 A | 100% | 2000-05-16 | 2001-03-15 | 218d | finish no earlier than 2001-03-15 | T2 | 1744h | 1744h | TLM | Ericsson | Rel-4 |  |  | 23.227 | Olga.Tome@ECS.ERICSSON.SE |
| 2171 | 68 | **Rel-4 Location Services enhancements** | 455d | 2000-04-03 A | 2001-12-28 A | 100% | 2000-04-03 | 2001-12-28 | 455d |  | S2 | 26799.2h | 26799.2h | LCS1 | Nokia | Rel-4 | Maurice |  |  | Jan Kall |
| 2172 | 68.1 | CBS interactions | 455d | 2000-04-03 A | 2001-12-28 A | 100% | 2000-04-03 | 2001-12-28 | 455d | finish no earlier than 2001-12-28 | T2 | 3640h | 3640h | LCS1-CBS |  | Rel-4 |  |  | 23.041 |  |
| 2173 | 68.2 | LCS support in the CS domain | 180d | 2000-05-15 A | 2001-01-19 A | 100% | 2000-05-15 | 2001-01-19 | 180d | finish no earlier than 2001-01-19 | S2 | 1440h | 1440h | LCS1-CS |  | Rel-4 | Maurice |  |  |  |
| 2174 | 68.3 | **LCS support in the PS domain** | 435d | 2000-05-01 A | 2001-12-28 A | 100% | 2000-05-01 | 2001-12-28 | 435d |  | S2 | 13560h | 13560h | LCS1-PS |  | Rel-4 | Maurice |  |  |  |
| 2175 | 68.3.1 | Stage 1 | 40d | 2000-07-03 A | 2000-08-25 A | 100% | 2000-07-03 | 2000-08-25 | 40d | start no earlier than 2000-07-03 | S1 | 320h | 320h |  | Pacific Bell Wireless | Rel-4 | Alain |  | 22.071 | Randolph Wohlert (rwohlert@tri.sbc.com) |
| 2176 | 68.3.2 | Stage 2 | 190d | 2000-05-01 A | 2001-01-19 A | 100% | 2000-05-01 | 2001-01-19 | 190d | finish no earlier than 2001-01-19 | S2 | 1520h | 1520h |  |  | Rel-4 | Maurice |  | 23.271 |  |
| 2177 | 68.3.3 | **Stage 3** | 355d | 2000-08-21 A | 2001-12-28 A | 100% | 2000-08-21 | 2001-12-28 | 355d |  | N1 | 8240h | 8240h |  |  | Rel-4 | Frederic |  |  |  |
| 2178 | 68.3.3.1 | Layer 3 LCS signaling UE (MS) -SGSN (UMTS PS and and GSM-GPRS) | 355d | 2000-08-21 A | 2001-12-28 A | 100% | 2000-08-21 | 2001-12-28 | 355d | finish no earlier than 2001-12-28 | N1 | 2840h | 2840h |  | Nokia | Rel-4 | Frederic |  |  | Janne Muhonen |
| 2179 | 68.3.3.2 | MAP impacts of LCS | 160d | 2000-08-21 A | 2001-03-30 A | 100% | 2000-08-21 | 2001-03-30 | 160d | finish no earlier than 2001-03-30 | N4 | 1280h | 1280h |  |  | Rel-4 | Kimmo |  |  |  |
| 2180 | 68.3.3.3 | GTP signaling for LCS | 160d | 2000-08-21 A | 2001-03-30 A | 100% | 2000-08-21 | 2001-03-30 | 160d | finish no earlier than 2001-03-30 | N4 | 1280h | 1280h |  |  | Rel-4 | Kimmo |  |  |  |
| 2181 | 68.4 | **UE positioning Rel-4** | 260d | 2000-04-03 A | 2001-03-30 A | 100% | 2000-04-03 | 2001-03-30 | 260d |  | RP | 4591.2h | 4591.2h | LCS1-UEpos |  | Rel-4 | Stefania |  |  |  |
| 2182 | 68.4.1 | Iub/Iur interfaces for methods Rel 99 | 233.9d | 2000-04-03 A | 2001-03-30 A | 100% | 2000-04-03 | 2001-03-30 | 233.9d | finish no earlier than 2001-03-30 | R3 | 1871.2h | 1871.2h | LCS1-UEpos-IubIur | Ericsson | Rel-4 | Juha |  |  | Yun-Chao Hu |
| 2183 | 68.4.2 | UE positioning enhancements - IPDL for TDD | 150d | 2000-08-28 A | 2001-03-23 A | 100% | 2000-08-28 | 2001-03-23 | 150d | finish no earlier than 2001-03-23 | R2 | 1200h | 1200h | LCS1-UEpos-enh | Siemens | Rel-4 | Joern |  |  | M. Beckmann |

Notes:
- 2158: -
- 2159: WI approved in TSG_10
- 2160: -
- 2161: Calls to different emergency services such as ambulance, fire brigade, police, etc. can be routed to respective different emergency centres. / NP-000447 is the stage 3 changes for CS call control protocol.
- 2162: UID changed. Marked as stopped 12/2008
- 2163: -
- 2164: -
- 2165: -
- 2166: -
- 2167: goal not completely achieved because of missing input
- 2168: AS: Rel5 changed to Rel4 according to SP#10 decision, milestone on testing added
- 2169: -
- 2170: -
- 2171: -
- 2172: -
- 2173: Only MAP impact foreseen so far. To be further split if needed.
- 2174: -
- 2175: To be also considered: External LCS client identity, and Privacy options when PDP-context and when no PDP-context is established
- 2176: AS: 23.271 completed at SP#10
- 2177: -
- 2178: -
- 2179: Missing work task
- 2180: -
- 2181: UID changed
- 2182: 27/11: WG corrected; rapporteur corrected
- 2183: 5 Mar 2001: splitting off of IPDL for TDD for Rel-4 agreed by R2

| ID | WBS | Task | Duration | Start | Finish | Complete | Baseline start | Baseline finish | Baseline duration | Constraint | Resources | Work | Actual work | Text1 | Text6 | Text8 | Text3 | Text4 | Text5 | Text12 |
| --- | --- | --- | --- | --- | --- | --- | --- | --- | --- | --- | --- | --- | --- | --- | --- | --- | --- | --- | --- | --- |
| 2184 | 69 | **Rel-4 UICC/(U)SIM enhancements and interworking** | 175d | 2000-07-24 A | 2001-03-23 A | 100% | 2000-07-24 | 2001-03-23 | 175d |  | T3 | 2800h | 2800h | UICC1 | Rel-4 | Xavier |  |  |  |  |
| 2185 | 69.1 | Common PCN Handset Specification (CPHS) | 175d | 2000-07-24 A | 2001-03-23 A | 100% | 2000-07-24 | 2001-03-23 | 175d | finish no earlier than 2001-03-23 | T3 | 1400h | 1400h | UICC1-CPHS | Rel-4 |  | 27.103 | One2One |  |  |
| 2186 | 70 | **Rel-4 (U)SIM toolkit enhancements** | 210d | 2000-06-05 A | 2001-03-23 A | 100% | 2000-06-05 | 2001-03-23 | 210d |  | T3 | 3360h | 3360h | USAT1 | Rel-4 | Xavier |  |  |  |  |
| 2187 | 70.1 | USAT local link | 210d | 2000-06-05 A | 2001-03-23 A | 100% | 2000-06-05 | 2001-03-23 | 210d | finish no earlier than 2001-03-23 | T3 | 1680h | 1680h | USAT1-LocLnk | Rel-4 |  |  | Gemplus | Jean-Francois Rubon |  |
| 2188 | 71 | **Rel-4 Security enhancements** | 576d | 2000-01-03 A | 2002-03-15 A | 100% | 2000-01-03 | 2002-03-15 | 576d |  | S3 | 24152h | 24152h | SEC1 | Rel-4 | Dionisio |  | Vodafone | Peter.Howard@vodafone.com |  |
| 2189 | 71.1 | Evolution of GSM CS algorithms (e.g. A5/3 development and deployment) | 272d | 2000-01-03 A | 2001-01-15 A | 100% | 2000-01-03 | 2001-01-15 | 272d | finish no earlier than 2001-01-15 | S3 | 2168h | 2168h | SEC1-CSALGO1 | Rel-4 | Dionisio |  |  |  |  |
| 2190 | 71.2 | **Evolution of GSM PS algorithms (e.g. GEA 2 deployment)** | 219d | 2000-02-22 A | 2000-12-22 A | 100% | 2000-02-22 | 2000-12-22 | 219d |  | S3 | 6024h | 6024h | SEC1-PSALGO1 | Rel-4 | Dionisio |  |  |  |  |
| 2191 | 71.2.1 | Main aspects | 199d | 2000-02-22 A | 2000-11-24 A | 100% | 2000-02-22 | 2000-11-24 | 199d | finish no earlier than 2000-11-24 | S3 | 1592h | 1592h |  | Rel-4 | Dionisio |  |  |  |  |
| 2192 | 71.2.2 | Impact on GTP | 200d | 2000-03-20 A | 2000-12-22 A | 100% | 2000-03-20 | 2000-12-22 | 200d | finish no earlier than 2000-12-22 | N4 | 1600h | 1600h |  | Rel-4 | Kimmo |  |  |  |  |
| 2193 | 71.2.3 | GEA capability indication in MS CM | 135d | 2000-06-19 A | 2000-12-22 A | 100% | 2000-06-19 | 2000-12-22 | 135d | finish no earlier than 2000-12-22 | N1 | 1080h | 1080h | SEC1-PSALGO1-GEACAP | Rel-4 | Frederic |  | Vodafone Airtouch | Duncan Mills |  |
| 2194 | 71.3 | **Deleted - MAP application layer security** | 576d | 2000-01-03 A | 2002-03-15 A | 100% | 2000-01-03 | 2002-03-15 | 576d |  | S3 | 11352h | 11352h | SEC1-MAPAL | Rel-4 | Dionisio |  |  |  | SP-15 |
| 2195 | 71.3.1 | Deleted - Main aspects | 199d | 2000-02-21 A | 2001-03-29 A | 100% | 2000-02-21 | 2001-03-29 | 199d | start no earlier than 2000-02-21 | S3 | 1592h | 1592h |  | Rel-4 | Dionisio |  |  |  | SP-11 |
| 2196 | 71.3.2 | Deleted - Other stage 3 aspects | 199d | 2000-02-22 A | 2000-11-24 A | 100% | 2000-02-22 | 2000-11-24 | 199d | finish no earlier than 2000-11-24 | N4 | 1592h | 1592h |  | Rel-4 | Kimmo |  |  |  | CP-10 |
| 2197 | 71.3.3 | Deleted - CHECK STATUS - Visibility and Configurability of security | 576d | 2000-01-03 A | 2002-03-15 A | 100% | 2000-01-03 | 2002-03-15 | 576d | finish no earlier than 2002-03-15 | S3 | 4600h | 4600h | SEC1-VCS | Rel-4 | Dionisio |  | France Telecom | Sebastien.nguyenngoc@rd.francetelecom.com | SP-15 |
| 2198 | 72 | **Rel-4 Charging and OAM&P** | 221d | 2000-12-01 A | 2001-10-05 A | 100% | 2000-12-01 | 2001-10-05 | 221d |  | S5 | 10472h | 10472h | OAM | Rel-4 | Dionisio |  | VoiceStream, Motorola |  |  |
| 2199 | 72.1 | Rel4 Principles, high level Requirements and Architecture | 145d | 2000-12-01 A | 2001-06-21 A | 100% | 2000-12-01 | 2001-06-21 | 145d | finish no earlier than 2001-06-21 | S5 | 1160h | 1160h | OAM-AR/PR | Rel-4 | Dionisio | 32.101, 32.102 | Motorola, Telia | Michael.Truss@MOTOROLA.COM; Tommy.R.Berggren@TELIA.SE |  |
| 2200 | 72.2 | Rel4 Performance Management | 216d | 2000-12-01 A | 2001-09-28 A | 100% | 2000-12-01 | 2001-09-28 | 216d | finish no earlier than 2001-06-21 | S5 | 1728h | 1728h |  | Rel-4 | Dionisio | 32.4xy, 52.402 | T-Mobile | karl-heinz.nenner@t-mobile.de |  |
| 2201 | 72.3 | Fault Management | 221d | 2000-12-01 A | 2001-10-05 A | 100% | 2000-12-01 | 2001-10-05 | 221d | finish no earlier than 2001-06-21 | S5 | 1768h | 1768h |  | Rel-4 | Dionisio | 32.111-1/4 | Lucent |  |  |
| 2202 | 72.4 | Configuration Management | 145d | 2000-12-01 A | 2001-06-21 A | 100% | 2000-12-01 | 2001-06-21 | 145d | finish no earlier than 2001-06-21 | S5 | 1160h | 1160h | OAM-CM | Rel-4 | Dionisio | 32.106-1/8 | Ericsson | thomas.tovinger@ericsson.com |  |
| 2203 | 72.5 | Rel4 Charging Management | 216d | 2000-12-01 A | 2001-09-28 A | 100% | 2000-12-01 | 2001-09-28 | 216d | finish no earlier than 2001-06-21 | S5 | 1728h | 1728h | OAM-CH | Rel-4 | Dionisio | 32.200, 32.205, 32.215, 32.235 | T-Mobile | karl-heinz.nenner@t-mobile.de |  |
| 2204 | 72.6 | UTRAN Operations and Maintenance procedures | 145d | 2000-12-01 A | 2001-06-21 A | 100% | 2000-12-01 | 2001-06-21 | 145d | finish no earlier than 2001-06-21 | S5 | 1160h | 1160h | UOAM | Rel-4 | Dionisio | 32.800 | Mannesmann Mobilfunk | bert.boden@d2mannesmann.de |  |
| 2205 | 73 | **Global Text Telephony** | 2537d? | 2000-01-03 A | 2009-09-18 A | 100% | 2000-01-03 | 2009-09-18 | 2537d? |  | S1,S2,S4,T1,R5 | 44928h | 44928h | GTT | Rel Indep | Maurice |  | Ericsson | gunnar.hellstrom@omnitor.se |  |
| 2206 | 73.1 | Stage 1 | 188d | 2000-04-05 A | 2000-12-22 A | 100% | 2000-04-05 | 2000-12-22 | 188d | finish no earlier than 2000-12-22 | S1 | 1504h | 1504h | GTT | Rel Indep | Alain | 22.976, 22.226 |  |  |  |
| 2207 | 73.2 | Stage 2 | 206d | 2000-01-03 A | 2000-10-13 A | 100% | 2000-01-03 | 2000-10-13 | 206d |  | S2 | 1640h | 1640h | GTT | Rel Indep | Maurice | 23.226 |  |  |  |

Notes:
- 2184: -
- 2185: 28/5/2001: CRs approved at TP-11. WI complete.
- 2186: -
- 2187: 25/5/2001:CR was approved at TP-11. WI is complete
- 2188: Added BB UE authentication and rapporteur added. TO BE DELETED
- 2189: Algorithm development go-ahead at SA3#21. Scheduled for completion in August 2002?. Approved SP#17. DELETE ENTRY FROM REL-4?
- 2190: A5/3 development will consider new GEA algorithm based on Kasumi.
- 2191: Complete TSG#09 (09/2000). S3#17: Proposed for deletion. TO BE DELETED
- 2192: -
- 2193: -
- 2194: TO DELETE: REPLACED BY NDS-MAP and NDS-IP. TO BE DELETED, but replacement NDS-MAP was missing. Completed Auto Key Management -> Rel-6. Marked as stopped 12/2008
- 2195: UID changed. Marked as stopped 12/2008
- 2196: UID changed. Marked as stopped 12/2008
- 2197: CR approved at SA3#21 awaiting comments from CN1. Marked as stopped 12/2008
- 2198: SP#13 approved WID
- 2199: -
- 2200: -
- 2201: -
- 2202: -
- 2203: -
- 2204: -
- 2205: SP#12 updated WID SP-000162=>SP-010340
- 2206: -
- 2207: -

| ID | WBS | Task | Type | Duration | Start | Finish | Complete | Baseline start | Baseline finish | Baseline duration | Total slack | Constraint | Resources | Work | Actual work | Text1 | Text6 | Text8 | Text9 | Text12 |
| --- | --- | --- | --- | --- | --- | --- | --- | --- | --- | --- | --- | --- | --- | --- | --- | --- | --- | --- | --- | --- |
| 2208 | 73.3 | **Specification of Cellular Text telephone Modem** |  | 136d | 2000-09-11 A | 2001-03-19 A | 100% | 2000-09-11 | 2001-03-19 | 136d |  |  | S4 | 2704h | 2704h | GTT-CTM | Rel Indep | Paolo |  |  |
| 2209 | 73.3.1 | General description and C-code |  | 66d | 2000-09-11 A | 2000-12-11 A | 100% | 2000-09-11 | 2000-12-11 | 66d |  | finish no earlier than 2000-12-11 | S4 | 528h | 528h | GTT-CTM | Rel Indep | Paolo |  |  |
| 2210 | 73.3.2 | Minimum Performance requirements |  | 136d | 2000-09-11 A | 2001-03-19 A | 100% | 2000-09-11 | 2001-03-19 | 136d |  | finish no earlier than 2001-03-19 | S4 | 1088h | 1088h | GTT-CTM | Rel Indep | Paolo |  |  |
| 2211 | 73.5 | Deleted - Conformance Test Aspects - Global Text Telephony |  | 2348d? | 2000-09-21 A | 2009-09-18 A | 100% | 2000-09-21 | 2009-09-18 | 2348d? |  | finish no earlier than 2009-09-18 | R5,T1 | 18784h | 18784h | GTT_Test | Rel Indep | Ingbert | PCG-23 | RP-45 |
| 2212 | 521 | Release 1999 Features | milestone | 0d? | 2000-01-01 | 2000-01-01 |  | 2000-01-01 | 2000-01-01 | 0d? | 3318d |  | NP,SP,TP,SMG |  |  |  | R99 |  |  |  |
| 2213 | 522 | **UMTS Features** |  | 261d? | 1999-01-01 A | 1999-12-31 A | 100% | 1999-01-01 | 1999-12-31 | 261d? |  |  | S1,S2,S4,SMG,N3,N4,RP | 25056h | 25056h |  | R99 |  |  |  |
| 2214 | 522.1 | UMTS_SERVICES |  | 261d? | 1999-01-01 A | 1999-12-31 A | 100% | 1999-01-01 | 1999-12-31 | 261d? |  | start no earlier than 1999-01-01 | S1 | 2088h | 2088h | UMTS_SERVICES | R99 |  |  |  |
| 2215 | 522.2 | UMTS phase 1 |  | 261d? | 1999-01-01 A | 1999-12-31 A | 100% | 1999-01-01 | 1999-12-31 | 261d? |  | start no earlier than 1999-01-01 | S1 | 2088h | 2088h | UMTS1 | R99 |  |  |  |
| 2216 | 522.3 | UMTS Capabilities |  | 261d? | 1999-01-01 A | 1999-12-31 A | 100% | 1999-01-01 | 1999-12-31 | 261d? |  | start no earlier than 1999-01-01 | S1 | 2088h | 2088h | UMTS_Capabil | R99 |  |  |  |
| 2217 | 522.4 | Architecture of the GSM-UMTS platform |  | 261d? | 1999-01-01 A | 1999-12-31 A | 100% | 1999-01-01 | 1999-12-31 | 261d? |  | start no earlier than 1999-01-01 | S2,N4 | 2088h | 2088h |  | R99 |  |  |  |
| 2218 | 522.5 | UMTS Terrestrial Radio Access Network |  | 261d? | 1999-01-01 A | 1999-12-31 A | 100% | 1999-01-01 | 1999-12-31 | 261d? |  | start no earlier than 1999-01-01 | RP | 2088h | 2088h | UTRAN | R99 |  |  |  |
| 2219 | 522.6 | UMTS 1800, UMTS 1900 |  | 261d? | 1999-01-01 A | 1999-12-31 A | 100% | 1999-01-01 | 1999-12-31 | 261d? |  | start no earlier than 1999-01-01 | R2 | 2088h | 2088h | Rlnlmp19, Rlnlmp18 | R99 |  |  |  |
| 2220 | 522.7 | Mandatory speech codec for narrowband telephony service |  | 261d? | 1999-01-01 A | 1999-12-31 A | 100% | 1999-01-01 | 1999-12-31 | 261d? |  | start no earlier than 1999-01-01 | S4 | 2088h | 2088h | Mandatory_Speech_Codec, AMR-NB, AMR | R99 | Paolo |  |  |
| 2221 | 522.8 | Codec for low bitrate multimedia telephony service |  | 261d? | 1999-01-01 A | 1999-12-31 A | 100% | 1999-01-01 | 1999-12-31 | 261d? |  | start no earlier than 1999-01-01 | S4 | 2088h | 2088h | Low_bit_rate_codec_for_MM_Tel., H.324M | R99 | Paolo |  |  |
| 2222 | 522.9 | 3G Audio-Visual Terminal characteristics |  | 261d? | 1999-01-01 A | 1999-12-31 A | 100% | 1999-01-01 | 1999-12-31 | 261d? |  | start no earlier than 1999-01-01 | S4 | 2088h | 2088h | WI5TAC, 3G-AVT, Terminal_Acoustic_Characteristics | R99 |  |  |  |
| 2223 | 522.10 | Updates_for_UMTS |  | 261d? | 1999-01-01 A | 1999-12-31 A | 100% | 1999-01-01 | 1999-12-31 | 261d? |  | start no earlier than 1999-01-01 | N3 | 2088h | 2088h | Updates_for_UMTS | R99 |  |  |  |
| 2224 | 522.11 | UMTS |  | 261d? | 1999-01-01 A | 1999-12-31 A | 100% | 1999-01-01 | 1999-12-31 | 261d? |  | start no earlier than 1999-01-01 | N3 | 2088h | 2088h | UMTS | R99 |  |  |  |
| 2225 | 523 | **UMTS and GSM Features** |  | 261d? | 1999-01-01 A | 1999-12-31 A | 100% | 1999-01-01 | 1999-12-31 | 261d? |  |  | S1,S2,SMG,T2,N1,N2,N3,N4,R2,R3 | 114840h | 114840h |  | R99 |  |  |  |
| 2226 | 523.1 | Multimedia Messaging Service |  | 261d? | 1999-01-01 A | 1999-12-31 A | 100% | 1999-01-01 | 1999-12-31 | 261d? |  | start no earlier than 1999-01-01 | T2 | 2088h | 2088h | MMS | R99 |  |  |  |
| 2227 | 523.2 | Location Services |  | 261d? | 1999-01-01 A | 1999-12-31 A | 100% | 1999-01-01 | 1999-12-31 | 261d? |  | start no earlier than 1999-01-01 | S1,S2,S3,SMG1,SMG2,SMG12,N1,N2,N4,R2,R3 | 2088h | 2088h | LCS | R99 |  |  |  |
| 2228 | 523.3 | **Customised Application for Mobile network Enhanced Logic Phase 3** |  | 261d? | 1999-01-01 A | 1999-12-31 A | 100% | 1999-01-01 | 1999-12-31 | 261d? |  |  | S1,S2,N2,N4 | 6264h | 6264h | CAMEL3 | R99 |  |  |  |
| 2229 | 523.3.1 | Global view |  | 261d? | 1999-01-01 A | 1999-12-31 A | 100% | 1999-01-01 | 1999-12-31 | 261d? |  | start no earlier than 1999-01-01 | S1,S2,N2,N4 | 2088h | 2088h | CAMEL3 | R99 |  |  |  |
| 2230 | 523.3.2 | Multiple Subscriber Profile (MSP) based on CAMEL phase 3 |  | 261d? | 1999-01-01 A | 1999-12-31 A | 100% | 1999-01-01 | 1999-12-31 | 261d? |  | start no earlier than 1999-01-01 | S1 | 2088h | 2088h | CAMEL3 | R99 |  |  |  |
| 2231 | 523.4 | Short Message Service enhancements / Enhanced Messaging Service (EMS) |  | 261d? | 1999-01-01 A | 1999-12-31 A | 100% | 1999-01-01 | 1999-12-31 | 261d? |  | start no earlier than 1999-01-01 | T2 | 2088h | 2088h | EMS | R99 |  |  |  |
| 2232 | 523.5 | Mobile Station Execution Environment |  | 261d? | 1999-01-01 A | 1999-12-31 A | 100% | 1999-01-01 | 1999-12-31 | 261d? |  | start no earlier than 1999-01-01 | S1,SMG1,T2 | 2088h | 2088h | MExE | R99 |  |  |  |
| 2233 | 523.6 | MS_Classmark |  | 261d? | 1999-01-01 A | 1999-12-31 A | 100% | 1999-01-01 | 1999-12-31 | 261d? |  | start no earlier than 1999-01-01 | N1 | 2088h | 2088h | MS_Classmark | R99 |  |  |  |

Notes:
- 2208: -
- 2209: - / Text3: 26.226, 26.230
- 2210: - / Text3: 26.231
- 2211: RP#45 work item abandoned/closed (it was never really started)
- 2212: -
- 2213: -
- 2214: - / Text3: 22.101
- 2215: - / Text3: 22.100
- 2216: Requirement for high quality speech in UMTS Phase 1 but not in R99 / Text3: 22.105
- 2217: wid Architecture overview of the GSM-UMTS System, Architecture the GSM-UMTS Platform and New Access Network to Core Network (BSS-NSS) interface / Text3: 23.002, 23.008, 23.060, 23.101, 23.110
- 2218: - / Text3: 22.011, 22.038, 22.060, 22.078, 22.100, 22.101, 22.105, 22.115, 22.129, 23.002, 23.060, 24.007, 24.008, 25.101, 25.102, 25.104, 25.105, 25.113, 25.123, 25.133, 25.141, 25.142, 25.201, 25.211, 25.212, 25.213, 25.214, 25.215, 25.221, 25.222, 25.223, 25.224,
- 2219: - / Text3: 25.307 CR#0002, 0003 Inclusion of release independent RF related information
- 2220: Define the default speech codec for UMTS (both for FDD and TDD). Definition limited to selection of one codec among several existing ones/proposed codecs: GSM AMR, IS127 EVRC, ITU G.729 and MPEG-4 speech codec. / Text3: 04.08, 05.01, 05.02, 05.03, 05.05, 05.08, 05.09, 05.09, 05.50, 08.60, 08.61, 11.21, 26.071, 26.073, 26.074, 26.090, 26.091, 26.092, 26.093, 26.094, 26.101, 26.102, 26.103, 26.104, 26.975
- 2221: - / Text3: 26.104, 26.110, 26.111, 26.911, 26.912, 26.915
- 2222: - / Text3: 26.131, 26.132
- 2223: - / Text3: 24.022, 27.001, 29.007
- 2224: - / Text3: 27.060, 29.061
- 2225: -
- 2226: MMS allows users to send/receive messages e.g. almost unlimited text length, images, audio and video clips and new content types. R99 only includes the concept. MMS stage 3 is not included in 23.140. Rel-4 adds detailed architecture and protocols. / Text3: 22.140, 23.040, 23.140
- 2227: LCS provide ability to localize a terminal. Location data is used to provide services to end-user (e.g. local map indicating closest restaurants), for emergency services or for a UMTS network entity (RNC to direct beam when space diversity is used) / Text3: 02.07, 03.71, 04.31, 04.35, 04.71, 05.05, 08.08, 08.31, 08.71, 09.31, 22.071, 23.002, 23.003, 23.007, 23.008, 23.016, 23.018, 23.032, 23.171, 24.007, 24.008, 24.030, 24.080, 25.305, 25.306, 25.331, 25.413, 25.423, 29.002, 29.010
- 2228: CAMEL is a network feature providing mechanisms to support services of operators which are not covered by standardised services, even when roaming outside the HPLMN. / Text3: 22.101, 23.008, 23.012, 23.016, 23.018, 23.060, 23.072, 23.078, 23.079, 23.082, 23.093, 29.002, 29.078
- 2229: - / Text3: 22.078, 23.078, 29.078
- 2230: MSP is an optional service enabling mobile subscribers to have several profiles associated with a single IMSI, with each profile being a subscription option. Each profile may be used for mobile originated and mobile terminated calls. / Text3: 22.097 (Advanced Addressing)
- 2231: SMS for 3G terminals compatible with GSM SMS. Added Enhanced Messaging Service (EMS) allowing small pictures, sounds, animations to be transferred via SMS. / Text3: 23.038, 23.039, 23.040, 23.042
- 2232: MExE provides a standardized MS execution environment and ability to negotiate its supported capabilities with a MExE SP. R99 enhances SIM MExE certificate management, security clarifications, QoS and defines two MExE classmarks WAP/Personal-Java based. / Text3: 02.57, 22.057, 22.101, 23.057
- 2233: MExE classmark identifies a category of MExE UE supporting MExE functionality with a minimum level of processing, memory, display, and interactive capabilities. Several MExE classmarks may be defined. / Text3: 24.008

| ID | WBS | Task | Duration | Start | Finish | Complete | Baseline start | Baseline finish | Baseline duration | Constraint | Resources | Work | Actual work | Text1 | Text6 |
| --- | --- | --- | --- | --- | --- | --- | --- | --- | --- | --- | --- | --- | --- | --- | --- |
| 2234 | 523.7 | **MultiCall** | 261d? | 1999-01-01 A | 1999-12-31 A | 100% | 1999-01-01 | 1999-12-31 | 261d? |  | S1,N1,N2,N4 | 4176h | 4176h | Multicall | R99 |
| 2235 | 523.7.1 | Multicall | 261d? | 1999-01-01 A | 1999-12-31 A | 100% | 1999-01-01 | 1999-12-31 | 261d? | start no earlier than 1999-01-01 | S1 | 2088h | 2088h | Multicall | R99 |
| 2236 | 523.8 | Virtual Home Environment | 261d? | 1999-01-01 A | 1999-12-31 A | 100% | 1999-01-01 | 1999-12-31 | 261d? | start no earlier than 1999-01-01 | S1,SMG1,S2 | 2088h | 2088h | VHE | R99 |
| 2237 | 523.9 | Open Service Access | 261d? | 1999-01-01 A | 1999-12-31 A | 100% | 1999-01-01 | 1999-12-31 | 261d? | start no earlier than 1999-01-01 | S1,S2,N5 | 2088h | 2088h | OSA | R99 |
| 2238 | 523.10 | Super Charger mechanism for signalling traffic associated with mobility | 261d? | 1999-01-01 A | 1999-12-31 A | 100% | 1999-01-01 | 1999-12-31 | 261d? | start no earlier than 1999-01-01 | N2,N4 | 2088h | 2088h | Super_Charger | R99 |
| 2239 | 523.11 | Follow_Me service | 261d? | 1999-01-01 A | 1999-12-31 A | 100% | 1999-01-01 | 1999-12-31 | 261d? | start no earlier than 1999-01-01 | S1,N2,N4 | 2088h | 2088h | Follow_Me | R99 |
| 2240 | 523.12 | Wide area network Synchronization and object exchange | 261d? | 1999-01-01 A | 1999-12-31 A | 100% | 1999-01-01 | 1999-12-31 | 261d? | start no earlier than 1999-01-01 | T2 | 2088h | 2088h | SYNC | R99 |
| 2241 | 523.13 | **Terminal Interfaces** | 261d? | 1999-01-01 A | 1999-12-31 A | 100% | 1999-01-01 | 1999-12-31 | 261d? |  | T2 | 8352h | 8352h |  | R99 |
| 2242 | 523.13.1 | AT commands for 3GPP | 261d? | 1999-01-01 A | 1999-12-31 A | 100% | 1999-01-01 | 1999-12-31 | 261d? | start no earlier than 1999-01-01 | T2 | 2088h | 2088h |  | R99 |
| 2243 | 523.13.2 | Physical interfaces | 261d? | 1999-01-01 A | 1999-12-31 A | 100% | 1999-01-01 | 1999-12-31 | 261d? | start no earlier than 1999-01-01 | T2 | 2088h | 2088h |  | R99 |
| 2244 | 523.13.3 | Multiplexer | 261d? | 1999-01-01 A | 1999-12-31 A | 100% | 1999-01-01 | 1999-12-31 | 261d? | start no earlier than 1999-01-01 | T2 | 2088h | 2088h | MUX MS-TE | R99 |
| 2245 | 523.14 | **Bearer Services** | 261d? | 1999-01-01 A | 1999-12-31 A | 100% | 1999-01-01 | 1999-12-31 | 261d? |  | S1,T2,N1,N3 | 27144h | 27144h |  | R99 |
| 2246 | 523.14.1 | **Circuit Switched Bearer Services** | 261d? | 1999-01-01 A | 1999-12-31 A | 100% | 1999-01-01 | 1999-12-31 | 261d? |  | S1,N3 | 14616h | 14616h | Circuit_switched_Bearer_Services | R99 |
| 2247 | 523.14.1.1 | Circuit Switched Bearer Services | 261d? | 1999-01-01 A | 1999-12-31 A | 100% | 1999-01-01 | 1999-12-31 | 261d? | start no earlier than 1999-01-01 | S1,N3 | 2088h | 2088h | CS_Bearerss_in_UMTS | R99 |
| 2248 | 523.14.1.2 | CS_Bearers | 261d? | 1999-01-01 A | 1999-12-31 A | 100% | 1999-01-01 | 1999-12-31 | 261d? | start no earlier than 1999-01-01 | N3 | 2088h | 2088h | CS_Bearers | R99 |
| 2249 | 523.14.1.3 | CS_Bearerss | 261d? | 1999-01-01 A | 1999-12-31 A | 100% | 1999-01-01 | 1999-12-31 | 261d? | start no earlier than 1999-01-01 | N3 | 2088h | 2088h | CS_Bearerss | R99 |
| 2250 | 523.14.1.4 | CS_Data | 261d? | 1999-01-01 A | 1999-12-31 A | 100% | 1999-01-01 | 1999-12-31 | 261d? | start no earlier than 1999-01-01 | N3 | 2088h | 2088h | CS_Data | R99 |
| 2251 | 523.14.1.5 | CS_Data_Bearers | 261d? | 1999-01-01 A | 1999-12-31 A | 100% | 1999-01-01 | 1999-12-31 | 261d? | start no earlier than 1999-01-01 | N3 | 2088h | 2088h | CS_Data_Bearers | R99 |
| 2252 | 523.14.1.6 | Deleted - Circuit Switched Bearer Services | 261d? | 1999-01-01 A | 1999-12-31 A | 100% | 1999-01-01 | 1999-12-31 | 261d? | start no earlier than 1999-01-01 | N3 | 2088h | 2088h | CSBS | R99 |
| 2253 | 523.14.2 | Frame Tunnelling Mode | 261d? | 1999-01-01 A | 1999-12-31 A | 100% | 1999-01-01 | 1999-12-31 | 261d? | start no earlier than 1999-01-01 | T2,N1,N3 | 2088h | 2088h | FTM | R99 |
| 2254 | 523.14.3 | Access to ISPs and Intranets – Wireless/Remote access to LANs | 261d? | 1999-01-01 A | 1999-12-31 A | 100% | 1999-01-01 | 1999-12-31 | 261d? | start no earlier than 1999-01-01 | N3 | 2088h | 2088h | Interworking with PDN (DHCP) | R99 |
| 2255 | 523.14.4 | **PHS Internet Access Forum Specification** | 261d? | 1999-01-01 A | 1999-12-31 A | 100% | 1999-01-01 | 1999-12-31 | 261d? |  | S1,N3 | 6264h | 6264h | PIAFS | R99 |
| 2256 | 523.14.4.1 | Personal Handyphone System Internet Access Forum Standard (PIAFS) | 261d? | 1999-01-01 A | 1999-12-31 A | 100% | 1999-01-01 | 1999-12-31 | 261d? | start no earlier than 1999-01-01 | S1 | 2088h | 2088h | PIAFS | R99 |
| 2257 | 523.14.4.2 | Support_of_PIAFS_in_UMTS | 261d? | 1999-01-01 A | 1999-12-31 A | 100% | 1999-01-01 | 1999-12-31 | 261d? | start no earlier than 1999-01-01 | N3 | 2088h | 2088h | Support_of_PIAFS_in_UMTS | R99 |

Notes:
- 2234: Multicall allows several simultaneous CS calls with dedicated bearers of independent traffic and performance characteristics. R99 Multicall was defined as a supplementary service limited to one CS bearer to be used for speech at any time. / Text3: 22.030, 22.083, 22.087, 23.008, 23.009, 23.016, 23.018, 23.108, 23.135, 24.008, 24.080, 24.135, 29.002, 29.010
- 2235: - / Text3: 22.030, 22.083, 22.087
- 2236: Information exists in SP#5-8 reports & in SP-99416,SP-000095,SP 000155. OSA allows service development by operators and 3rd parties by making use of network functionality through open, standardised, secure, extensible and scalable interfaces. / Text3: 02.01, 22.105, 22.121,23.127
- 2237: Open Service Architecture became in later Releases Open Service Access. Produced by Parlay, ETSI SPAN (TISPAN), 3GPP SA1 (Stage 1), SA2 (Stage 2) and CN5 (Stage 3), resulting in a single set of standard OSA APIs for the whole development community. / Text3: 22.121, 23.127, 29.198, 29.998
- 2238: Super Charger reduces mobility management cost by reducing the volume of location update signalling. It changes subscriber data management associated with inter-VLR and SGSN location updates. It also applies to packet services (SGSN replaces VLR and … / Text3: 21.905, 23.007, 23.008, 23.012, 23.016, 23.018, 23.040, 23.060, 23.116, 23.912, 29.002
- 2239: Follow Me enables a mobile subscriber A to manipulate the Follow Me data of a party B in such a way that - under certain conditions - subsequent calls directed to party B will be forwarded to subscriber A. It is PLMN-specific and control based on USSD / Text3: 21.905, 22.004, 22.030, 22.082, 22.090, 22.094, 23.090, 24.090, 22.094, 23.011, 23.015, 23.082, 29.002
- 2240: Allows data stored in ME/USIM to be synchronized with the outside world. TS 27.103 defines protocols based upon IrMC level 4 and will evaluate new technologies (XML) for inclusion. From Rel-4 IrMC was replaced by SyncML in 27.103. / Text3: 27.103, 27.903
- 2241: -
- 2242: AT commands to control a 3G ME via an external Terminal Equipment (TE), fully compatible with GSM AT commands. R99 adds new AT commands e.g. to control Advanced Speech Call Items (ASCI) services. / Text3: 27.005, 27.007
- 2243: Conclusion: 3GPP should not produce any technical specification for terminal interfaces other than radio interface and USIM interface. SDOs could develop own optional physical connector specification based on market requirements / Text3: 27.901
- 2244: Multiplexing protocol allowing a number of simultaneous sessions between a MS and a terminal; used to send any data (voice, SMS, USSD, fax etc.). 27.010 describes the protocol, but not the commands or data transported with it. / Text3: 27.010
- 2245: -
- 2246: CS and real-time data services provided for interworking with PSTN/ISDN so that user is unaware of access network used (UMTS, GSM or handover between ANs). Transparent(constant delay) & non-transparent(zero error with flow control) services are supported / Text3: 22.002, 23.910, 27.001, 29.007
- 2247: CS and real-time data services provided for interworking with PSTN/ISDN so that user is unaware of access network used (UMTS, GSM or handover between ANs). Transparent(constant delay) & non-transparent(zero error with flow control) services are supported / Text3: 22.002, 23.910, 27.001, 29.007
- 2248: - / Text3: 29.007
- 2249: - / Text3: 04.21, 23.910, 27.001, 29.007
- 2250: - / Text3: 27.001, 27.002, 27.003, 29.007
- 2251: - / Text3: 23.910, 27.001, 29.007
- 2252: No CR or new TS/TR approved under this WI / Text3: 29.007
- 2253: FTM is a type of async non-transparent CS bearer service (22.002). Generic term for HDLC and HDLC-related transmission protocols. Converts async non-transp data stream towards mobile side & sync data stream using X.31 flag stuffing on fixed network side. / Text3: 22.002, 27.001, 27.007, 29.007
- 2254: Access to an Intranet or ISP by running DHCP between the TE and a server in the Intranet/ISP domain. / Text3: 29.061
- 2255: PIAFS is one type of CS bearer data service (22.002). It refers to async CS tx protocol over ISDN 64 kbit/s unrestricted digital line. Facilitates interworking between PHS-MS and UMTS-UE & UMTS-UE and existing PIAFS TA (Terminal Adapter). / Text3: 22.002, 27.001, 27.007, 29.007
- 2256: PIAFS was originally standardised by the PHS Internet Access Forum in Japan. More information can be found at: http://www.infopro.or.jp/piaf / Text3: 22.002
- 2257: - / Text3: 27.001, 27.007, 29.007

| ID | WBS | Task | Duration | Start | Finish | Complete | Baseline start | Baseline finish | Baseline duration | Constraint | Resources | Work | Actual work | Text1 | Text6 |
| --- | --- | --- | --- | --- | --- | --- | --- | --- | --- | --- | --- | --- | --- | --- | --- |
| 2258 | 523.15 | **Universal Integrated Circuit Card (UICC) and Universal Subscriber Identity Module (USIM)** | 261d? | 1999-01-01 A | 1999-12-31 A | 100% | 1999-01-01 | 1999-12-31 | 261d? |  | T3 | 27144h | 27144h | UICC, USIM | R99 |
| 2259 | 523.15.1 | UICC / Terminal interface; Physical and logical characteristics | 261d? | 1999-01-01 A | 1999-12-31 A | 100% | 1999-01-01 | 1999-12-31 | 261d? | start no earlier than 1999-01-01 | T3 | 2088h | 2088h | UICC | R99 |
| 2260 | 523.15.2 | UICC/(U)SIM enhancements and interworking | 261d? | 1999-01-01 A | 1999-12-31 A | 100% | 1999-01-01 | 1999-12-31 | 261d? | start no earlier than 1999-01-01 | T3 | 2088h | 2088h | UICC1 | R99 |
| 2261 | 523.15.3 | Characteristics of the USIM application | 261d? | 1999-01-01 A | 1999-12-31 A | 100% | 1999-01-01 | 1999-12-31 | 261d? | start no earlier than 1999-01-01 | T3 | 2088h | 2088h | USIM | R99 |
| 2262 | 523.15.4 | UICC Application Identifiers | 261d? | 1999-01-01 A | 1999-12-31 A | 100% | 1999-01-01 | 1999-12-31 | 261d? | start no earlier than 1999-01-01 | T3 | 2088h | 2088h | AID, Application_Identifiers | R99 |
| 2263 | 523.15.5 | SIM Application Toolkit | 261d? | 1999-01-01 A | 1999-12-31 A | 100% | 1999-01-01 | 1999-12-31 | 261d? | start no earlier than 1999-01-01 | S1,T3 | 2088h | 2088h | SAT | R99 |
| 2264 | 523.15.6 | USIM Application Toolkit | 261d? | 1999-01-01 A | 1999-12-31 A | 100% | 1999-01-01 | 1999-12-31 | 261d? | start no earlier than 1999-01-01 | T3 | 2088h | 2088h | USAT, USAT1 | R99 |
| 2265 | 523.15.7 | Bearer Independent Protocol for SAT applications to exchange data over the GSM network | 261d? | 1999-01-01 A | 1999-12-31 A | 100% | 1999-01-01 | 1999-12-31 | 261d? | start no earlier than 1999-01-01 | T3 | 2088h | 2088h | BIP | R99 |
| 2266 | 523.15.8 | Administrative commands and functions for IC cards | 261d? | 1999-01-01 A | 1999-12-31 A | 100% | 1999-01-01 | 1999-12-31 | 261d? | start no earlier than 1999-01-01 | T3 | 2088h | 2088h |  | R99 |
| 2267 | 523.15.9 | USIM and UICC requirements | 261d? | 1999-01-01 A | 1999-12-31 A | 100% | 1999-01-01 | 1999-12-31 | 261d? | start no earlier than 1999-01-01 | T3 | 2088h | 2088h |  | R99 |
| 2268 | 523.15.10 | SIM_API | 261d? | 1999-01-01 A | 1999-12-31 A | 100% | 1999-01-01 | 1999-12-31 | 261d? | start no earlier than 1999-01-01 | T3 | 2088h | 2088h | SIM_API | R99 |
| 2269 | 523.15.11 | SIM_toolkit_API | 261d? | 1999-01-01 A | 1999-12-31 A | 100% | 1999-01-01 | 1999-12-31 | 261d? | start no earlier than 1999-01-01 | SMG9,T3 | 2088h | 2088h | SIM_toolkit | R99 |
| 2270 | 523.15.12 | Deleted - 1.8 Volt SIM ME interface | 261d? | 1999-01-01 A | 1999-12-31 A | 100% | 1999-01-01 | 1999-12-31 | 261d? | start no earlier than 1999-01-01 | SMG9 | 2088h | 2088h | SMIME_1.8V | R99 |
| 2271 | 523.16 | **USIM/UICC Testing** | 261d? | 1999-01-01 A | 1999-12-31 A | 100% | 1999-01-01 | 1999-12-31 | 261d? |  | T3 | 10440h | 10440h |  | R99 |
| 2272 | 523.16.1 | Terminal tests for the UICC Interface | 261d? | 1999-01-01 A | 1999-12-31 A | 100% | 1999-01-01 | 1999-12-31 | 261d? | start no earlier than 1999-01-01 | T3 | 2088h | 2088h |  | R99 |
| 2273 | 523.16.2 | USIM application test specification | 261d? | 1999-01-01 A | 1999-12-31 A | 100% | 1999-01-01 | 1999-12-31 | 261d? | start no earlier than 1999-01-01 | T3 | 2088h | 2088h |  | R99 |
| 2274 | 523.16.3 | USIM conformance test specification | 261d? | 1999-01-01 A | 1999-12-31 A | 100% | 1999-01-01 | 1999-12-31 | 261d? | start no earlier than 1999-01-01 | T3 | 2088h | 2088h |  | R99 |
| 2275 | 523.16.4 | SIM toolkit test specification | 261d? | 1999-01-01 A | 1999-12-31 A | 100% | 1999-01-01 | 1999-12-31 | 261d? | start no earlier than 1999-01-01 | T3 | 2088h | 2088h |  | R99 |
| 2276 | 523.17 | **Security** | 261d? | 1999-01-01 A | 1999-12-31 A | 100% | 1999-01-01 | 1999-12-31 | 261d? |  | S3,N2,N4 | 8352h | 8352h | Security | R99 |
| 2277 | 523.17.1 | Fraud Information Gathering Service (for connection-orientated services) | 261d? | 1999-01-01 A | 1999-12-31 A | 100% | 1999-01-01 | 1999-12-31 | 261d? | start no earlier than 1999-01-01 | S3 | 2088h | 2088h | FIGS | R99 |
| 2278 | 523.17.2 | Immediate Service Termination / SECurity Immediate Service Termination | 261d? | 1999-01-01 A | 1999-12-31 A | 100% | 1999-01-01 | 1999-12-31 | 261d? | start no earlier than 1999-01-01 | S3,N2,N4 | 2088h | 2088h | IST, SECIST | R99 |
| 2279 | 523.17.3 | Core_Network_Security | 261d? | 1999-01-01 A | 1999-12-31 A | 100% | 1999-01-01 | 1999-12-31 | 261d? | start no earlier than 1999-01-01 | N4 | 2088h | 2088h | Core_Network_Security | R99 |
| 2280 | 524 | **GSM Features** | 261d? | 1999-01-01 A | 1999-12-31 A | 100% | 1999-01-01 | 1999-12-31 | 261d? |  | S1,S2,SMG,T2,N1,N2,N3,N4 | 50112h | 50112h |  | R99 |
| 2281 | 524.1 | **Dual Transfer Mode within GSM and GPRS** | 261d? | 1999-01-01 A | 1999-12-31 A | 100% | 1999-01-01 | 1999-12-31 | 261d? |  | SMG,N1 | 6264h | 6264h | DTM | R99 |
| 2282 | 524.1.1 | Class A Dual Transfer Mode | 261d? | 1999-01-01 A | 1999-12-31 A | 100% | 1999-01-01 | 1999-12-31 | 261d? | start no earlier than 1999-01-01 | SMG | 2088h | 2088h | Class_A_Dual_Transfer_Mode_(DTM) | R99 |
| 2283 | 524.1.2 | Dual Transfer Mode | 261d? | 1999-01-01 A | 1999-12-31 A | 100% | 1999-01-01 | 1999-12-31 | 261d? | start no earlier than 1999-01-01 | SMG,N1 | 2088h | 2088h | DTM | R99 |

Notes:
- 2258: For 3G, GSM 11.11 was divided into two parts: a platform comprised of basic physical, electrical and logical specification (31.101) and an application specification (31.102)
- 2259: Defines a generic Terminal/Integrated Circuit Card (ICC) interface. Is independent of 3G USIM application => platform for any IC card application. Ensures interoperability between ICC and terminal independently of manufacturer, card issuer or operator. / Text3: 31.101 (Since 10/2000, ETSI EP SCP is responsible for the generic Terminal/Integrated Circuit Card (ICC) interface TS 102 221)
- 2260: - / Text3: 31.102, 31.900
- 2261: Defines Universal Subscriber Identity Module (USIM) application for 3G telecom network operation & resides on UICC, an IC card specified in 31.101. UICC can be used as a multi-application card: several USIMs and/or other applications can co-exist / Text3: 31.102
- 2262: Defines and administers Application IDentifiers (AID) for UICC. AID is used to address an application in the card. Consists of Registered application provider ID (RID) & Proprietary application ID eXtension (PIX - according to ISO/IEC 7816-5). / Text3: 21.111, 31.110
- 2263: - / Text3: 11.14, 22.030, 22.100, 22.101
- 2264: Defines UICC - ME interface, and mandatory ME procedures for USAT. Based on GSM 11.14 (SIM Application Toolkit). Commands and procedures defined in USIM and 3G Terminal for using USAT. Service and security requirements defined in 22.100 and 22.101. / Text3: 31.111
- 2265: Defines at SIM-ME interface a basic protocol allowing SIM Toolkit applications to determine available bearers and to exchange data by selecting using the most appropriate bearer available (CS data, GPRS, SMS, Unstructured Supplementary Service Data (USSD) / Text3: 03.48, 11.10, 11.14
- 2266: Defines function and syntax of administrative commands for telecommunication IC Card used during installation, activation and de-activation of applications. Compliant to ISO/IEC 7816 series. Handed over to ETSI Project Smart Card Platform (SCP) in 2000. / Text3: ETSI TS 102 222
- 2267: High level requirements for 3GPP IC card and its interface to 3GPP terminal (USIM&UICC reqs). Service&security reqs in 322.01,22.00. USIM is a 3GPP application on an IC card. Inter-operates with 3GPP terminals and provides access to 3GPP services / Text3: 21.111
- 2268: - / Text3: 03.19
- 2269: - / Text3: 03.48, 11.11, 11.14
- 2270: No CR or new TS/TR approved under this WI / Text3: 11.18
- 2271: -
- 2272: Test spec for the interface between UICC and terminal (originally based GSM 11.10-1 clause 27). Ensures UICC - terminal interoperability independently of manufacturer, card issuer or operator. Tests for applications residing on UICC are in 31.121 / Text3: 31.120
- 2273: Application test spec originally based on GSM 11.17. Aspects related to UICC administrative management phase are not defined. Any internal technical realisation of either UICC or terminal is only specified where these are reflected over the interface. / Text3: 31.121
- 2274: Conformance Test specification for UICC defined in 31.101 with USIM defined in 31.102. / Text3: 31.122
- 2275: SIM Application Toolkit (SAT) has major impact on ME design and enhances SIM/ME interface. Contains tests for SIM/ME interface optional features (no network related signalling issues involved). Doesn't form basis for any type approval or regulatory tests. / Text3: 11.10-4
- 2276: - / Text3: 02.09, 03.20, 21.133, 22.022, 23.003, 23.007, 23.008, 23.012, 23.018, 24.007, 24.008, 24.010, 24.011, 29.002, 29.060, 33.102, 33.103, 33.105, 33.107, 35.201
- 2277: HPLMN can monitor its subscribers in VPLMN, which collects info on a defined set of monitored subscribers activities & sends it to HPLMN, which can perform service limitation control eg Operator Determined Barring (ODB) and IST to limit financial exposure / Text3: 22.031, 23.031
- 2278: HPLMN can terminate all activities of its subscriber in VPLMN, if decides (based on info via eg FIGS) that a roaming subscriber is behaving in fraudulent/suspicious way. HPLMN can terminate all subscriber activities including calls in progress. / Text3: 03.35, 22.032, 23.008, 23.016, 23.035, 29.002
- 2279: - / Text3: 29.002
- 2280: -
- 2281: WID on BSS co-ordination of Radio Resource allocation for class A GPRS services - GSM Radio Access (R99) / Text3: 03.55, 03.64, 04.18, 04.60, 05.01, 05.02, 05.08, 08.08, 23.060, 24.007, 24.008
- 2282: - / Text3: 05.10
- 2283: - / Text3: 03.55, 03.64, 04.18, 05.01, 05.02, 05.08, 24.008

| ID | WBS | Task | Duration | Start | Finish | Complete | Baseline start | Baseline finish | Baseline duration | Constraint | Resources | Work | Actual work | Text1 | Text6 |
| --- | --- | --- | --- | --- | --- | --- | --- | --- | --- | --- | --- | --- | --- | --- | --- |
| 2284 | 524.2 | **General Packet Radio Service enahancements** | 261d? | 1999-01-01 A | 1999-12-31 A | 100% | 1999-01-01 | 1999-12-31 | 261d? |  | S1,S2,SMG1,SMG2,SMG7,N1,N2,N3,N4,T2 | 8352h | 8352h | GPRS enhancements | R99 |
| 2285 | 524.2.1 | General Packet Radio Service | 261d? | 1999-01-01 A | 1999-12-31 A | 100% | 1999-01-01 | 1999-12-31 | 261d? | start no earlier than 1999-01-01 | S1,S2,SMG1,SMG2,SMG7,N1,N2,N3,N4,T2 | 2088h | 2088h | GPRS | R99 |
| 2286 | 524.2.2 | GPRS2 | 261d? | 1999-01-01 A | 1999-12-31 A | 100% | 1999-01-01 | 1999-12-31 | 261d? | start no earlier than 1999-01-01 | SMG1,N2 | 2088h | 2088h | GPRS2 | R99 |
| 2287 | 524.2.3 | GPRS Tunnelling Protocol enhancement | 261d? | 1999-01-01 A | 1999-12-31 A | 100% | 1999-01-01 | 1999-12-31 | 261d? | start no earlier than 1999-01-01 | N4,N2 | 2088h | 2088h | GTP_enhancement | R99 |
| 2288 | 524.3 | **Enhanced Data rates for GSM Evolution - Phase 1** | 261d? | 1999-01-01 A | 1999-12-31 A | 100% | 1999-01-01 | 1999-12-31 | 261d? |  | SMG2,SMG1,SMG3,SMG4,SMG7,SMG9,SMG10,N1,N3,T2 | 25056h | 25056h | EDGE - Phase 1 | R99 |
| 2289 | 524.3.1 | Enhanced Data rates for GSM Evolution | 261d? | 1999-01-01 A | 1999-12-31 A | 100% | 1999-01-01 | 1999-12-31 | 261d? | start no earlier than 1999-01-01 | SMG2,SMG1,SMG3,SMG4,SMG7,SMG9,SMG10,N1,N3,T2 | 2088h | 2088h | EDGE | R99 |
| 2290 | 524.3.2 | EDGE-Layer1 | 261d? | 1999-01-01 A | 1999-12-31 A | 100% | 1999-01-01 | 1999-12-31 | 261d? | start no earlier than 1999-01-01 | SMG2 | 2088h | 2088h | EDGE-Layer1 | R99 |
| 2291 | 524.3.3 | High Speed Circuit Switched Data | 261d? | 1999-01-01 A | 1999-12-31 A | 100% | 1999-01-01 | 1999-12-31 | 261d? | start no earlier than 1999-01-01 | SMG1,SMG2,SMG7 | 2088h | 2088h | HSCSD | R99 |
| 2292 | 524.3.4 | Enhanced Circuit Switched Data - Phase 1 | 261d? | 1999-01-01 A | 1999-12-31 A | 100% | 1999-01-01 | 1999-12-31 | 261d? | start no earlier than 1999-01-01 | S1,SMG | 2088h | 2088h | ECSD | R99 |
| 2293 | 524.3.5 | EDGE-Enhanced Circuit Switched Data | 261d? | 1999-01-01 A | 1999-12-31 A | 100% | 1999-01-01 | 1999-12-31 | 261d? | start no earlier than 1999-01-01 | SMG2 | 2088h | 2088h | EDGE-ECSD | R99 |
| 2294 | 524.3.6 | Enhanced GPRS - Phase 1 | 261d? | 1999-01-01 A | 1999-12-31 A | 100% | 1999-01-01 | 1999-12-31 | 261d? | start no earlier than 1999-01-01 | SMG,N1 | 2088h | 2088h | EGPRS | R99 |
| 2295 | 524.3.7 | EDGE-EGPRS | 261d? | 1999-01-01 A | 1999-12-31 A | 100% | 1999-01-01 | 1999-12-31 | 261d? | start no earlier than 1999-01-01 | SMG2 | 2088h | 2088h | EDGE-EGPRS | R99 |
| 2296 | 524.3.8 | Packet Flow Context (PFC) | 261d? | 1999-01-01 A | 1999-12-31 A | 100% | 1999-01-01 | 1999-12-31 | 261d? | start no earlier than 1999-01-01 | SMG2 | 2088h | 2088h | PFC | R99 |
| 2297 | 524.3.9 | Support for EGPRS in ANSI-136 networks and EDGE COMPACT | 261d? | 1999-01-01 A | 1999-12-31 A | 100% | 1999-01-01 | 1999-12-31 | 261d? | start no earlier than 1999-01-01 | SMG | 2088h | 2088h | EDGE-Compact | R99 |
| 2298 | 524.3.10 | EGPRS COMPACT | 261d? | 1999-01-01 A | 1999-12-31 A | 100% | 1999-01-01 | 1999-12-31 | 261d? | start no earlier than 1999-01-01 | SMG | 2088h | 2088h | EGPRS-Compact | R99 |
| 2299 | 524.3.11 | COMPACT | 261d? | 1999-01-01 A | 1999-12-31 A | 100% | 1999-01-01 | 1999-12-31 | 261d? | start no earlier than 1999-01-01 | SMG,N1 | 2088h | 2088h | COMPACT | R99 |
| 2300 | 524.4 | GSM_400 | 261d? | 1999-01-01 A | 1999-12-31 A | 100% | 1999-01-01 | 1999-12-31 | 261d? | start no earlier than 1999-01-01 | SMG2,SMG7,T2 | 2088h | 2088h | GSM_400 | R99 |
| 2301 | 524.5 | GSM_450 | 261d? | 1999-01-01 A | 1999-12-31 A | 100% | 1999-01-01 | 1999-12-31 | 261d? | start no earlier than 1999-01-01 | SMG2 | 2088h | 2088h | GSM_450 | R99 |
| 2302 | 524.6 | GSM_700 | 261d? | 1999-01-01 A | 1999-12-31 A | 100% | 1999-01-01 | 1999-12-31 | 261d? | start no earlier than 1999-01-01 | SMG2 | 2088h | 2088h | GSM_700 | R99 |
| 2303 | 524.7 | Deleted - GERAN | 261d? | 1999-01-01 A | 1999-12-31 A | 100% | 1999-01-01 | 1999-12-31 | 261d? | start no earlier than 1999-01-01 | SMG2,S2 | 2088h | 2088h | GERAN | R99 |
| 2304 | 525 | **GSM Features transposed to UMTS** | 261d? | 1999-01-01 A | 1999-12-31 A | 100% | 1999-01-01 | 1999-12-31 | 261d? |  | S1,S3,T2,N2,N4 | 16704h | 16704h |  | R99 |
| 2305 | 525.1 | Cell Broadcast Service | 261d? | 1999-01-01 A | 1999-12-31 A | 100% | 1999-01-01 | 1999-12-31 | 261d? | start no earlier than 1999-01-01 | T2 | 2088h | 2088h | CBS | R99 |
| 2306 | 525.2 | **GSM mobile number portability euro MNP / North American MNP** | 261d? | 1999-01-01 A | 1999-12-31 A | 100% | 1999-01-01 | 1999-12-31 | 261d? |  | S1,N2,N4 | 4176h | 4176h | MNP | R99 |
| 2307 | 525.2.1 | Mobile Number Portability | 261d? | 1999-01-01 A | 1999-12-31 A | 100% | 1999-01-01 | 1999-12-31 | 261d? | start no earlier than 1999-01-01 | N2,N4 | 2088h | 2088h | MNP | R99 |
| 2308 | 525.3 | Automatic establishment of roaming relations | 261d? | 1999-01-01 A | 1999-12-31 A | 100% | 1999-01-01 | 1999-12-31 | 261d? | start no earlier than 1999-01-01 | S1 | 2088h | 2088h |  | R99 |
| 2309 | 525.4 | Advanced addressing | 261d? | 1999-01-01 A | 1999-12-31 A | 100% | 1999-01-01 | 1999-12-31 | 261d? | start no earlier than 1999-01-01 | S1 | 2088h | 2088h |  | R99 |
| 2310 | 525.5 | UMTS numbering, addressing and identities | 261d? | 1999-01-01 A | 1999-12-31 A | 100% | 1999-01-01 | 1999-12-31 | 261d? | start no earlier than 1999-01-01 | S1 | 2088h | 2088h |  | R99 |
| 2311 | 525.6 | Lawful Interception | 261d? | 1999-01-01 A | 1999-12-31 A | 100% | 1999-01-01 | 1999-12-31 | 261d? | start no earlier than 1999-01-01 | S3 | 2088h | 2088h | LI | R99 |

Notes:
- 2284: GPRS was introduced in Release 97. Release 99 brings a number of essential corrections e.g. on Downlink Power Control, Timing Advance procedure, Cell reselection delay time, PBCCH scheduling, PTCCH mapping, etc. / Text3: 05.02, 05.05, 05.08, 05.10, 05.50, 11.21, 23.064, 24.008, 24.060
- 2285: - / Text3: 02.60, 03.22, 03.64, 04.18, 04.60, 04.64, 04.65, 05.01, 05.02, 05.05, 05.08, 05.10, 08.08, 08.18, 11.10-1, 11.21, 22.041, 22.060, 23.003, 23.007, 23.060, 23.107, 23.122, 24.007, 24.008, 27.007, 27.060, 29.002, 29.016, 29.018, 29.060, 29.061
- 2286: Introduction of EGPRS (S1) + Introduction of Reserved Service Labels in the APN (N2) / Text3: 02.60, 23.003
- 2287: - / Text3: 23.003, 23.008, 29.060
- 2288: EDGE is independent of the frequency bands, so it can be deployed e.g. in 900 and 1900 MHz bands. The new physical layer based on 8-PSK modulation is introduced and EGPRS and ECSD facilitate the new modulation in single and multi slot constellation. / Text3: 10.59, 02.34, 02.60, 03.30, 05.10, 05.50, 11.26
- 2289: - / Text3: 02.34, 03.10, 03.20, 03.64, 04.03, 04.04, 04.06, 04.08, 04.18, 04.21, 04.22, 04.60, 04.64, 05.01, 05.02, 05.03, 05.04, 05.05, 05.08, 05.10, 05.50, 07.01, 07.02, 07.03, 08.08, 08.20, 08.58, 08.60, 09.07, 09.18, 11.10-1, 11.11, 11.21, 11.26, 23.034, 24.008,
- 2290: - / Text3: 05.05, 05.10, 05.50
- 2291: No additional features for R99. / Text3: 02.34, 04.18, 11.10-1
- 2292: ECSD supports both transparent and non-transparent services, up to 64 kbit/s and 57.6 kbit/s respectively. See Tdoc SMG2 670/99 ECSD Concept Evaluation for more info / Text3: 05.02, 08.58, 22.034
- 2293: - / Text3: 05.03
- 2294: - / Text3: 02.07, 03.64, 04.14, 04.18, 04.60, 05.05, 05.08, 24.008
- 2295: - / Text3: 05.03, 05.05, 05.08
- 2296: - / Text3: 04.18
- 2297: Support for EGPRS in ANSI-136 networks and EDGE Compact (for ANSI-136 networks only). COMPACT = Deployment of services in spectrum below 1 MHz / Text3: 03.22, 03.30, 03.64, 05.01, 05.02, 05.03, 05.05, 05.08, 05.10
- 2298: COMPACT = Deployment of services in spectrum below 1 MHz / Text3: 04.18, 05.02
- 2299: COMPACT = Deployment of services in spectrum below 1 MHz / Text3: 03.22, 04.18, 04.60, 05.08, 23.122, 24.008
- 2300: - / Text3: 02.17, 03.22, 03.30, 04.04, 04.18, 04.60, 05.01, 05.02, 05.05, 05.08, 05.10, 05.50, 08.18, 08.58, 11.21, 24.008, 27.007 / Text8: GSM in the 400 MHz bands allows to deploy GSM within frequency bands in the range 450 to 500 MHz, previously used for analogue cellular systems. See Tdoc SMG2 190/99 and 595/99 for further info.
- 2301: - / Text3: 03.22, 03.30, 05.01, 05.05, 05.08
- 2302: - / Text3: 05.05
- 2303: No CR or new TS/TR approved under this WI / Text3: G2: 04.18 CR#A248 , 04.60 CR#B090
- 2304: -
- 2305: Moved to CT1 at TSG-T closure. Applicability of the Cell Broadcast Service (as defined for GSM network) to 3G networks / Text3: 23.041
- 2306: R98 MNP: mobile subscriber ability to change PLMN operator within the same country whilst retaining its original MS ISDN number (MSISDN). IMSI is changed, only MSISDN is kept. R99 adds requirements for North American Service Provider Number Portability. / Text3: 22.066
- 2307: - / Text3: 23.018, 23.066, 29.002
- 2308: framework for commercial and technical interworking between UMTS Home Environments and Serving Networks who have no direct prior commercial agreements with each other. / Text3: 22.101, 22.971
- 2309: - / Text3: 22.101, 22.75U, 22.975
- 2310: Also new requirements for Single and Multiple Numbering scheme was added (CR#20 and 21). Deleted the term International Mobile User Identifier (IMUI) and changed IMSI (International Mobile Station Identifier=>International Mobile Subscriber Identity. / Text3: 22.101
- 2311: Defines an interception system in UMTS that supports a number of regional interception regulations. Regional interception requirements shall be met in using specific (regional) mediation functions allowing only required information to be transported. / Text3: 33.106, 33.107

| ID | WBS | Task | Duration | Start | Finish | Complete | Baseline start | Baseline finish | Baseline duration | Constraint | Resources | Work | Actual work | Text1 | Text6 |
| --- | --- | --- | --- | --- | --- | --- | --- | --- | --- | --- | --- | --- | --- | --- | --- |
| 2312 | 526 | **Charging** | 261d? | 1999-01-01 A | 1999-12-31 A | 100% | 1999-01-01 | 1999-12-31 | 261d? |  | S1,S5 | 6264h | 6264h | CH | R99 |
| 2313 | 526.1 | Charging | 261d? | 1999-01-01 A | 1999-12-31 A | 100% | 1999-01-01 | 1999-12-31 | 261d? | start no earlier than 1999-01-01 | S1 | 2088h | 2088h | Charging | R99 |
| 2314 | 526.2 | OAM Charging Management | 261d? | 1999-01-01 A | 1999-12-31 A | 100% | 1999-01-01 | 1999-12-31 | 261d? | start no earlier than 1999-01-01 | S5 | 2088h | 2088h | OAMCH, CH | R99 |
| 2315 | 527 | **Operations, Administration, Maintenance and Provisioning (OAM&P)** | 261d? | 1999-01-01 A | 1999-12-31 A | 100% | 1999-01-01 | 1999-12-31 | 261d? |  | S5 | 12528h | 12528h | OAM | R99 |
| 2316 | 527.1 | OAM Principles and High-level Requirements | 261d? | 1999-01-01 A | 1999-12-31 A | 100% | 1999-01-01 | 1999-12-31 | 261d? | start no earlier than 1999-01-01 | S5 | 2088h | 2088h | PR, Princs_&_Reqs_(PR) | R99 |
| 2317 | 527.2 | OAM Architecture | 261d? | 1999-01-01 A | 1999-12-31 A | 100% | 1999-01-01 | 1999-12-31 | 261d? | start no earlier than 1999-01-01 | S5 | 2088h | 2088h | OAMAR, AR, Telecom_Management_Arch_(AR) | R99 |
| 2318 | 527.3 | OAM Configuration Management | 261d? | 1999-01-01 A | 1999-12-31 A | 100% | 1999-01-01 | 1999-12-31 | 261d? | start no earlier than 1999-01-01 | S5 | 2088h | 2088h | OAMCM, CM | R99 |
| 2319 | 527.4 | OAM Fault Management | 261d? | 1999-01-01 A | 1999-12-31 A | 100% | 1999-01-01 | 1999-12-31 | 261d? | start no earlier than 1999-01-01 | S5 | 2088h | 2088h | OAMFM | R99 |
| 2320 | 527.5 | OAM Performance Management | 261d? | 1999-01-01 A | 1999-12-31 A | 100% | 1999-01-01 | 1999-12-31 | 261d? | start no earlier than 1999-01-01 | S5 | 2088h | 2088h | OAMPM, PM | R99 |
| 2321 | 528 | Vocabulary | 261d? | 1999-01-01 A | 1999-12-31 A | 100% | 1999-01-01 | 1999-12-31 | 261d? | start no earlier than 1999-01-01 | S1 | 2088h | 2088h | Vocabulary | R99 |
| 2322 | 529 | Emergency | 261d? | 1999-01-01 A | 1999-12-31 A | 100% | 1999-01-01 | 1999-12-31 | 261d? | start no earlier than 1999-01-01 | S1 | 2088h | 2088h | Emergency | R99 |
| 2323 | 530 | GSM General Bearer Services (GBS) and interworking scenarios support in UMTS | 261d? | 1999-01-01 A | 1999-12-31 A | 100% | 1999-01-01 | 1999-12-31 | 261d? | start no earlier than 1999-01-01 | S1 | 2088h | 2088h | GSM_to_UMTS_Evol | R99 |
| 2324 | 531 | GPRS_Mobile_IP_interworking | 261d? | 1999-01-01 A | 1999-12-31 A | 100% | 1999-01-01 | 1999-12-31 | 261d? | start no earlier than 1999-01-01 | N3 | 2088h | 2088h | GPRS_Mobile_IP_interworking | R99 |
| 2325 | 532 | GSM/UMTS interworking | 261d? | 1999-01-01 A | 1999-12-31 A | 100% | 1999-01-01 | 1999-12-31 | 261d? | start no earlier than 1999-01-01 | N1,N2,N4,R3,S1,SMG | 2088h | 2088h | 2G3Ginterworking | R99 |
| 2326 | 533 | Handover | 261d? | 1999-01-01 A | 1999-12-31 A | 100% | 1999-01-01 | 1999-12-31 | 261d? | start no earlier than 1999-01-01 | S1,SMG2,N1,N2,N4 | 2088h | 2088h | Handover | R99 |
| 2327 | 534 | 2G3Ghandover | 261d? | 1999-01-01 A | 1999-12-31 A | 100% | 1999-01-01 | 1999-12-31 | 261d? | start no earlier than 1999-01-01 | SMG2 | 2088h | 2088h | 2G3Ghandover | R99 |
| 2328 | 535 | Service Provider Name Indication | 261d? | 1999-01-01 A | 1999-12-31 A | 100% | 1999-01-01 | 1999-12-31 | 261d? | start no earlier than 1999-01-01 | S1 | 2088h | 2088h | SPANME | R99 |
| 2329 | 536 | Data & Data_CleanUp | 261d? | 1999-01-01 A | 1999-12-31 A | 100% | 1999-01-01 | 1999-12-31 | 261d? | start no earlier than 1999-01-01 | SMG1 | 2088h | 2088h | Data, Data_CleanUp | R99 |
| 2330 | 537 | Unstructured Supplementary Service Data | 261d? | 1999-01-01 A | 1999-12-31 A | 100% | 1999-01-01 | 1999-12-31 | 261d? | start no earlier than 1999-01-01 | SMG1,N4 | 2088h | 2088h | USSD | R99 |
| 2331 | 538 | Man-Machine Interface (MMI) of the User Equipment (UE) | 261d? | 1999-01-01 A | 1999-12-31 A | 100% | 1999-01-01 | 1999-12-31 | 261d? | start no earlier than 1999-01-01 | S1 | 2088h | 2088h | MMI | R99 |
| 2332 | 539 | Network Identity and Timezone (NITZ) | 261d? | 1999-01-01 A | 1999-12-31 A | 100% | 1999-01-01 | 1999-12-31 | 261d? | start no earlier than 1999-01-01 | SMG1,SMG3 | 2088h | 2088h | NITZ | R99 |
| 2333 | 540 | Operator Determined Barring for Packet Oriented Services | 261d? | 1999-01-01 A | 1999-12-31 A | 100% | 1999-01-01 | 1999-12-31 | 261d? | start no earlier than 1999-01-01 | S1 | 2088h | 2088h | ODB_Enh. | R99 |
| 2334 | 541 | Packet Flow Management | 261d? | 1999-01-01 A | 1999-12-31 A | 100% | 1999-01-01 | 1999-12-31 | 261d? | start no earlier than 1999-01-01 | SMG2 | 2088h | 2088h | Packet_Flow_Management | R99 |
| 2335 | 542 | GPRS_Point-To-Multipoint Group call | 261d? | 1999-01-01 A | 1999-12-31 A | 100% | 1999-01-01 | 1999-12-31 | 261d? | start no earlier than 1999-01-01 | SMG1 | 2088h | 2088h | GPRS_PTMG | R99 |

Notes:
- 2312: -
- 2313: WID SP-99271 Charging and accounting / Text3: 22.115, 23.121
- 2314: WID SP-99581 SA5 Year 2000 Work plan / Text3: 32.005, 32.015
- 2315: WID SP-99581 SA5 Year 2000 Work plan
- 2316: WID SP-99581 SA5 Year 2000 Work plan / Text3: 32.101
- 2317: WID SP-99581 SA5 Year 2000 Work plan / Text3: 32.101, 32.102
- 2318: WID SP-99273 Configuration management / Text3: 32.106, 32.106-1, 32.106-2, 32.106-3, 32.106-4, 32.106-5, 32.106-6, 32.106-7, 32.106-8
- 2319: WID SP-99272 Fault management / Text3: 32.111, 32.111-1, 32.111-2, 32.111-3, 32.111-4
- 2320: WID SP-99274 Performance management / Text3: 12.04, 32.104
- 2321: - / Text3: 21.905
- 2322: - / Text3: 22.101
- 2323: UMTS shall support GSM General Bearer Services (GBS) and interworking scenarios as specified in 02.02 / Text3: 22.105
- 2324: - / Text3: 29.061
- 2325: - / Text3: 03.22, 04.18, 04.60, 05.02, 05.08, 05.10, 08.08, 08.18, 08.58, 09.08, 22.011, 23.003, 23.009, 23.014, 23.034, 23.122, 24.007, 24.008, 24.011, 24.080, 29.108
- 2326: - / Text3: 04.18, 08.08, 08.58, 22.129, 23.009, 29.002, 29.010
- 2327: - / Text3: 04.18, 04.60, 05.02, 05.08, 05.10, 08.08, 29.010
- 2328: Service Provider Name Indication included in R98 (02.07) was not carried into R99 (22.101), but is in the SIM/USIM specification for R99 / Text3: 22.101
- 2329: - / Text3: 02.01, 02.02, 02.04, 02.34
- 2330: No additional features for R99. / Text3: 02.04, 02.90, 23.090, 29.002
- 2331: Data services streamlining + Support for Anonymous Call Rejection / Text3: 22.030
- 2332: - / Text3: 02.42, 04.08
- 2333: Remove ODB for Packet Oriented Services from R99 / Text3: 22.041
- 2334: - / Text3: 08.18
- 2335: - / Text3: 02.60

| ID | WBS | Task | Duration | Start | Finish | Complete | Baseline start | Baseline finish | Baseline duration | Constraint | Resources | Work | Actual work | Text6 | Text8 |
| --- | --- | --- | --- | --- | --- | --- | --- | --- | --- | --- | --- | --- | --- | --- | --- |
| 2336 | 543 | **Call Forwarding** | 261d? | 1999-01-01 A | 1999-12-31 A | 100% | 1999-01-01 | 1999-12-31 | 261d? |  | SMG1,N2,N4 | 8352h | 8352h | R99 |  |
| 2337 | 543.1 | Call Forwarding enhancements | 261d? | 1999-01-01 A | 1999-12-31 A | 100% | 1999-01-01 | 1999-12-31 | 261d? | start no earlier than 1999-01-01 | N4,N2 | 2088h | 2088h | R99 |  |
| 2338 | 543.2 | Call_Forwarding | 261d? | 1999-01-01 A | 1999-12-31 A | 100% | 1999-01-01 | 1999-12-31 | 261d? | start no earlier than 1999-01-01 | SMG1,N2 | 2088h | 2088h | R99 |  |
| 2339 | 543.3 | Call_Forwarding_Enhancements | 261d? | 1999-01-01 A | 1999-12-31 A | 100% | 1999-01-01 | 1999-12-31 | 261d? | start no earlier than 1999-01-01 | N4 | 2088h | 2088h | R99 |  |
| 2340 | 544 | **Quality of Service** | 261d? | 1999-01-01 A | 1999-12-31 A | 100% | 1999-01-01 | 1999-12-31 | 261d? |  | S2,T2,N1,N2,N4 | 10440h | 10440h | R99 |  |
| 2341 | 544.1 | End-to-end UMTS Quality of Service management | 261d? | 1999-01-01 A | 1999-12-31 A | 100% | 1999-01-01 | 1999-12-31 | 261d? | start no earlier than 1999-01-01 | S2,T2,N1,N2,N4 | 2088h | 2088h | R99 |  |
| 2342 | 544.2 | End-to-end QoS for PS Domain including IMS | 261d? | 1999-01-01 A | 1999-12-31 A | 100% | 1999-01-01 | 1999-12-31 | 261d? | start no earlier than 1999-01-01 | S2 | 2088h | 2088h | R99 |  |
| 2343 | 544.3 | GPRS-enhanced_QoS | 261d? | 1999-01-01 A | 1999-12-31 A | 100% | 1999-01-01 | 1999-12-31 | 261d? | start no earlier than 1999-01-01 | T2 | 2088h | 2088h | R99 |  |
| 2344 | 544.4 | QoS_enhancements | 261d? | 1999-01-01 A | 1999-12-31 A | 100% | 1999-01-01 | 1999-12-31 | 261d? | start no earlier than 1999-01-01 | N2,N1,N4 | 2088h | 2088h | R99 |  |
| 2345 | 545 | Support of Localised Service Area | 261d? | 1999-01-01 A | 1999-12-31 A | 100% | 1999-01-01 | 1999-12-31 | 261d? | start no earlier than 1999-01-01 | SMG2,SMG3,SMG7,N2 | 2088h | 2088h | R99 |  |
| 2346 | 546 | Transcoder_location | 261d? | 1999-01-01 A | 1999-12-31 A | 100% | 1999-01-01 | 1999-12-31 | 261d? | start no earlier than 1999-01-01 | S2 | 2088h | 2088h | R99 |  |
| 2347 | 547 | Antenna_test_methods | 261d? | 1999-01-01 A | 1999-12-31 A | 100% | 1999-01-01 | 1999-12-31 | 261d? | start no earlier than 1999-01-01 | SMG2 | 2088h | 2088h | R99 |  |
| 2348 | 548 | WBAMR / high quality speech in UMTS Phase 1 but not in R99 | 261d? | 1999-01-01 A | 1999-12-31 A | 100% | 1999-01-01 | 1999-12-31 | 261d? | start no earlier than 1999-01-01 | S1 | 2088h | 2088h | R99 |  |
| 2349 | 549 | **Codec** | 261d? | 1999-01-01 A | 1999-12-31 A | 100% | 1999-01-01 | 1999-12-31 | 261d? |  | S4 | 14616h | 14616h | R99 | Paolo |
| 2350 | 549.1 | Codec(s)_for_Multimedia_Telephony_Service | 261d? | 1999-01-01 A | 1999-12-31 A | 100% | 1999-01-01 | 1999-12-31 | 261d? | start no earlier than 1999-01-01 | S4 | 2088h | 2088h | R99 | Paolo |
| 2351 | 549.2 | QoS for Speech and Multimedia Codec | 261d? | 1999-01-01 A | 1999-12-31 A | 100% | 1999-01-01 | 1999-12-31 | 261d? | start no earlier than 1999-01-01 | S4 | 2088h | 2088h | R99 | Paolo |
| 2352 | 549.3 | Tandem Free Operation - Adaptive Multi-Rate codec types | 261d? | 1999-01-01 A | 1999-12-31 A | 100% | 1999-01-01 | 1999-12-31 | 261d? | start no earlier than 1999-01-01 | S4 | 2088h | 2088h | R99 | Paolo |
| 2353 | 549.4 | Noise Suppression for AMR | 261d? | 1999-01-01 A | 1999-12-31 A | 100% | 1999-01-01 | 1999-12-31 | 261d? | start no earlier than 1999-01-01 | S4 | 2088h | 2088h | R99 | Paolo |
| 2354 | 549.5 | Out-of-Band Transcoder | 261d? | 1999-01-01 A | 1999-12-31 A | 100% | 1999-01-01 | 1999-12-31 | 261d? | start no earlier than 1999-01-01 | N1 | 2088h | 2088h | R99 |  |
| 2355 | 549.6 | Out-of-Band Transcoder Control | 261d? | 1999-01-01 A | 1999-12-31 A | 100% | 1999-01-01 | 1999-12-31 | 261d? | start no earlier than 1999-01-01 | N1 | 2088h | 2088h | R99 |  |
| 2356 | 550 | Advanced Speech Call Items enhancements | 261d? | 1999-01-01 A | 1999-12-31 A | 100% | 1999-01-01 | 1999-12-31 | 261d? | start no earlier than 1999-01-01 | SMG1,SMG2,SMG3,SMG7,SMG9,N1,C1,N4,S1,T2 | 2088h | 2088h | R99 |  |
| 2357 | 551 | Call Control improvements | 261d? | 1999-01-01 A | 1999-12-31 A | 100% | 1999-01-01 | 1999-12-31 | 261d? | start no earlier than 1999-01-01 | N1 | 2088h | 2088h | R99 |  |
| 2358 | 552 | Multimedia | 261d? | 1999-01-01 A | 1999-12-31 A | 100% | 1999-01-01 | 1999-12-31 | 261d? | start no earlier than 1999-01-01 | N1,N3 | 2088h | 2088h | R99 |  |
| 2359 | 553 | Sub-System Number allocation for RANAP, RNSAP | 261d? | 1999-01-01 A | 1999-12-31 A | 100% | 1999-01-01 | 1999-12-31 | 261d? | start no earlier than 1999-01-01 | N2 | 2088h | 2088h | R99 |  |
| 2360 | 554 | Intranet / ISP access with DHCP end-to-end | 261d? | 1999-01-01 A | 1999-12-31 A | 100% | 1999-01-01 | 1999-12-31 | 261d? | start no earlier than 1999-01-01 | N3 | 2088h | 2088h | R99 |  |
| 2361 | 555 | Point_to_Multipoint_Services | 261d? | 1999-01-01 A | 1999-12-31 A | 100% | 1999-01-01 | 1999-12-31 | 261d? | start no earlier than 1999-01-01 | N3 | 2088h | 2088h | R99 |  |
| 2362 | 556 | Facsimile | 261d? | 1999-01-01 A | 1999-12-31 A | 100% | 1999-01-01 | 1999-12-31 | 261d? | start no earlier than 1999-01-01 | S1 | 2088h | 2088h | R99 |  |
| 2363 | 557 | Realtime_NT_FAX_in_UMTS | 261d? | 1999-01-01 A | 1999-12-31 A | 100% | 1999-01-01 | 1999-12-31 | 261d? | start no earlier than 1999-01-01 | N3 | 2088h | 2088h | R99 |  |
| 2364 | 558 | Gateway Location Register (GLR) - Mobile Application Part (MAP) specification | 261d? | 1999-01-01 A | 1999-12-31 A | 100% | 1999-01-01 | 1999-12-31 | 261d? | start no earlier than 1999-01-01 | N4 | 2088h | 2088h | R99 |  |
| 2365 | 559 | Multiple Subscriber Profile phase 2 | 261d? | 1999-01-01 A | 1999-12-31 A | 100% | 1999-01-01 | 1999-12-31 | 261d? | start no earlier than 1999-01-01 | S1,N4 | 2088h | 2088h | R99 |  |
| 2366 | 560 | Prepaging | 261d? | 1999-01-01 A | 1999-12-31 A | 100% | 1999-01-01 | 1999-12-31 | 261d? | start no earlier than 1999-01-01 | N2,N4 | 2088h | 2088h | R99 |  |
| 2367 | 561 | Downlink Advanced Receiver Performance | 261d? | 1999-01-01 A | 1999-12-31 A | 100% | 1999-01-01 | 1999-12-31 | 261d? | start no earlier than 1999-01-01 | SMG | 2088h | 2088h | R99 |  |
| 2368 | 562 | Harmonized Standard | 261d? | 1999-01-01 A | 1999-12-31 A | 100% | 1999-01-01 | 1999-12-31 | 261d? | start no earlier than 1999-01-01 | SMG2 | 2088h | 2088h | R99 |  |
| 2369 | 563 | Streamlining of specifications | 261d? | 1999-01-01 A | 1999-12-31 A | 100% | 1999-01-01 | 1999-12-31 | 261d? | start no earlier than 1999-01-01 | N3 | 2088h | 2088h | R99 |  |
| 2370 | 564 | R99_Service_Clean_up | 261d? | 1999-01-01 A | 1999-12-31 A | 100% | 1999-01-01 | 1999-12-31 | 261d? | start no earlier than 1999-01-01 | N3 | 2088h | 2088h | R99 |  |

Notes:
- 2336: -
- 2337: No additional features for R99. / Text1: CF_enhancements / Text3: 23.078, 23.079, 23.082, 29.002, 29.078
- 2338: - / Text1: Call_Forwarding / Text3: 02.82, 29.002
- 2339: - / Text1: Call_Forwarding_Enhancements / Text3: 23.082
- 2340: WID SMG 98-0781 End To End UMTS QoS Management
- 2341: WID SMG 98-0781 End To End UMTS QoS Management / Text1: QoS / Text3: 23.107, 23.907, 24.008
- 2342: - / Text1: E2EQoS / Text3: 23.060, 23.170
- 2343: AT-commands for Enhanced QoS Support management / Text1: GPRS-enhanced_QoS / Text3: 27.007
- 2344: - / Text1: QoS_enhancements / Text3: 23.008, 23.016, 24.008, 29.002, 29.060
- 2345: Mechanism which can be used as a platform for providing special tariffs and/or special set of service features for certain subscribers within a regionally restricted area or areas. No additional features for R99. / Text1: SoLSA / Text3: 04.08, 04.18, 08.08, 11.10-1, 29.002
- 2346: UE location identification: background information and associated primitives 2. Transcoder location at the core network and source depending coding belonging to the non-access stratum. / Text1: Transcoder_location / Text3: 23.110
- 2347: - / Text1: Antenna_test_methods / Text3: 03.30
- 2348: Add requirement for high quality speech in UMTS Phase 1 but not in R99 / Text1: WBAMR / Text3: 22.105
- 2349: -
- 2350: - / Text1: Multimedia_Codec, CSM, WI2MMC, Codec(s)_for_CS_MM_Tel._Serv, Codec(s)_for_MM_Tel_Service, Codec_for_Multimedia_Telephony / Text3: 26.911, 26.104, 26.111
- 2351: - / Text1: QoS_for_Speech_&_MM_Codecs_/_AMR / Text3: 26.102, 26.912
- 2352: UMTS_AMR2 is default Codec Type in R99 dual_mode terminals / Text1: TFOAMR / Text3: 26.103
- 2353: Combination of the AMR speech codec and the Noise Suppression function. TS 06.77 and TR 06.78 only apply to GSM. They apply to UMTS from Rel-4 onwards, when they were converted to TS 26.077 and TR 26.078. / Text1: AMRNS / Text3: 06.77, 06.78
- 2354: Transcoder handling in the CN at inter-system handover and relocation + Introduction of UMTS AMR / Text1: OoBT / Text3: 23.009, 24.008
- 2355: 24.008 CR#0572 in NP-020220 was approved under this WI / Text1: OoBTC / Text3: 24.008 CR#0572 in NP-020220
- 2356: - / Text1: ASCI / Text3: 02.30, 02.68, 03.68, 03.69, 04.18, 08.08, 11.10-1, 11.11, 23.067, 23.094, 24.008, 24.067, 27.007, 29.002
- 2357: Minor improvements to 24.007 and 24.008 to increase the number of simultaneous calls/sessions from the present 7: the TI value is increased (NP-99441). / Text1: CC_Related_items / Text3: 24.007, 24.008
- 2358: - / Text1: Multimedia / Text3: 24.008, 27.001, 29.007
- 2359: Sub-System Number allocation for Radio Access Network Application Part, Radio Network Subsystem Application Part / Text1: SSN_allocation / Text3: 23.003
- 2360: Access to an Intranet/ISP with DHCP end to end / Text1: ISPaccess / Text3: 29.061
- 2361: Support for the IP-Multicast protocol / Text1: Point_to_Multipoint_Services / Text3: 29.061
- 2362: - / Text1: FAX / Text3: 22.003, 22.100
- 2363: Asynchronous Interface for real-time NT Fax + Introduction of Asynchronous interface for Real-time non-transparent FAX / Text1: Realtime_NT_FAX_in_UMTS / Text3: 27.001, 27.003
- 2364: - / Text1: GLR / Text3: 29.120
- 2365: - / Text1: MSP2 / Text3: 22.097, 23.072, 23.083, 23.084, 23.091, 23.093, 23.097
- 2366: - / Text1: Prepaging / Text3: 23.018, 23.082, 29.002
- 2367: Re-definition of channel quality measure used for AMR link adaptation for DARP MS / Text1: DARP / Text3: 05.09
- 2368: - / Text1: HS / Text3: 13.21
- 2369: - / Text1: Streamlining / Text3: 27.060, 29.061
- 2370: - / Text1: R99_Service_Clean_up / Text3: 03.10, 27.001, 27.002, 27.003, 27.060, 29.007, 29.061

| ID | WBS | Task | Type | Duration | Start | Finish | Complete | Baseline start | Baseline finish | Baseline duration | Total slack | Constraint | Resources | Work | Actual work | Text1 | Text6 | Text3 |
| --- | --- | --- | --- | --- | --- | --- | --- | --- | --- | --- | --- | --- | --- | --- | --- | --- | --- | --- |
| 2371 | 565 | **small Technical Enhancements and Improvements for R99** |  | 261d? | 1999-01-01 A | 1999-12-31 A | 100% | 1999-01-01 | 1999-12-31 | 261d? |  |  | N3 | 6264h | 6264h | TEI | R99 |  |
| 2372 | 565.1 | TEI_[CS_Data] |  | 261d? | 1999-01-01 A | 1999-12-31 A | 100% | 1999-01-01 | 1999-12-31 | 261d? |  | start no earlier than 1999-01-01 | N3 | 2088h | 2088h | TEI_[CS_Data] | R99 |  |
| 2373 | 565.2 | TEI_[GPRS] |  | 261d? | 1999-01-01 A | 1999-12-31 A | 100% | 1999-01-01 | 1999-12-31 | 261d? |  | start no earlier than 1999-01-01 | N3 | 2088h | 2088h | TEI_[GPRS] | R99 |  |
| 2374 | 566 | **R99 UE Conformance Testing** |  | 261d? | 1999-01-01 A | 1999-12-31 A | 100% | 1999-01-01 | 1999-12-31 | 261d? |  |  | R5,T1 | 4176h | 4176h | TEI_Test | R99 | 34.108, 34.121, 34.122, 34.123-1, 34.123-2, 34.123-3 |
| 2375 | 566.1 | Deleted - RTEI |  | 261d? | 1999-01-01 A | 1999-12-31 A | 100% | 1999-01-01 | 1999-12-31 | 261d? |  | start no earlier than 1999-01-01 | T1 | 2088h | 2088h | RTEI | R99 | 34.123-1 CR#0650, 0651, 34.123-3 CR#0148, 0149, 0150 |
| 2376 | 566.2 | Common test environments for User Equipment (UE); Conformance testing | milestone | 0d? | 1999-01-01 A | 1999-01-01 A | 100% | 1999-01-01 | 1999-01-01 | 0d? |  | start no earlier than 1999-01-01 | R5,T1 |  |  | TEI_Test | R99 | 34.108 |
| 2377 | 566.3 | Terminal conformance specification, Radio transmission and reception (FDD) | milestone | 0d? | 1999-01-01 A | 1999-01-01 A | 100% | 1999-01-01 | 1999-01-01 | 0d? |  | start no earlier than 1999-01-01 | R5,T1 |  |  | TEI_Test | R99 | 34.121 |
| 2378 | 566.4 | Terminal conformance specification, Radio transmission and reception (TDD) | milestone | 0d? | 1999-01-01 A | 1999-01-01 A | 100% | 1999-01-01 | 1999-01-01 | 0d? |  | start no earlier than 1999-01-01 | R5,T1 |  |  | TEI_Test | R99 | 34.122 |
| 2379 | 566.5 | UE conformance specification; Part 1: Protocol conformance specification | milestone | 0d? | 1999-01-01 A | 1999-01-01 A | 100% | 1999-01-01 | 1999-01-01 | 0d? |  | start no earlier than 1999-01-01 | R5,T1 |  |  | TEI_Test | R99 | 34.123-1 |
| 2380 | 566.6 | UE conformance specification; Part 2: Implementation Conformance Statement (ICS) specification | milestone | 0d? | 1999-01-01 A | 1999-01-01 A | 100% | 1999-01-01 | 1999-01-01 | 0d? |  | start no earlier than 1999-01-01 | R5,T1 |  |  | TEI_Test | R99 | 34.123-2 |
| 2381 | 566.7 | UE conformance specification; Part 3: Abstract test suites (ATSs) | milestone | 0d? | 1999-01-01 A | 1999-01-01 A | 100% | 1999-01-01 | 1999-01-01 | 0d? |  | start no earlier than 1999-01-01 | R5,T1 |  |  | TEI_Test | R99 | 34.123-3 |
| 2382 | 567 | Deleted - Dual Tone Multi-Frequency signalling : Support in the whole 3GPP system |  | 261d? | 1999-01-01 A | 1999-12-31 A | 100% | 1999-01-01 | 1999-12-31 | 261d? |  | start no earlier than 1999-01-01 | N1 | 2088h | 2088h | DTMF | R99 | 23.014 CR#0004 |
| 2383 | 568 | Deleted - Intersystem_Change |  | 261d? | 1999-01-01 A | 1999-12-31 A | 100% | 1999-01-01 | 1999-12-31 | 261d? |  | start no earlier than 1999-01-01 | G3new | 2088h | 2088h | Intersystem_Change | R99 | 04.18 CR#A243 |
| 2384 | 569 | Deleted - Long_Forwardedto_Numbers |  | 261d? | 1999-01-01 A | 1999-12-31 A | 100% | 1999-01-01 | 1999-12-31 | 261d? |  | start no earlier than 1999-01-01 | N2 | 2088h | 2088h | Long_Forwardedto_Numbers | R99 | 29.002 |
| 2385 | 570 | Deleted - RANimp-FSEarlyUE |  | 261d? | 1999-01-01 A | 1999-12-31 A | 100% | 1999-01-01 | 1999-12-31 | 261d? |  | start no earlier than 1999-01-01 | R3 | 2088h | 2088h | RANimp-FSEarlyUE | R99 | 25.413 CR#0520, 0538, 0565, 0563, 0541, 0540, 0539, 0547 |
| 2386 | 571 | Release 1999 Studies |  | 1d? | 2000-01-03 | 2000-01-03 |  | 2000-01-03 | 2000-01-03 | 1d? | 3317d |  | S1,T2 | 8h |  |  | R99 |  |
| 2387 | 572 | Advanced Addressing/Numbering |  | 261d? | 1999-01-01 A | 1999-12-31 A | 100% | 1999-01-01 | 1999-12-31 | 261d? |  | start no earlier than 1999-01-01 | S1 | 2088h | 2088h | Numbering | R99 | 22.975 |
| 2388 | 573 | Combined GSM and Mobile IP mobility handling in UMTS IP CN |  | 261d? | 1999-01-01 A | 1999-12-31 A | 100% | 1999-01-01 | 1999-12-31 | 261d? |  | start no earlier than 1999-01-01 | S2 | 2088h | 2088h |  | R99 | 23.923 |
| 2389 | 574 | UE Capabilities Requirements |  | 261d? | 1999-01-01 A | 1999-12-31 A | 100% | 1999-01-01 | 1999-12-31 | 261d? |  | start no earlier than 1999-01-01 | T2 | 2088h | 2088h | UCR | R99 | 21.904 |
| 2390 | 575 | Electrical safety requirements and regulations |  | 261d? | 1999-01-01 A | 1999-12-31 A | 100% | 1999-01-01 | 1999-12-31 | 261d? |  | start no earlier than 1999-01-01 | T2 | 2088h | 2088h |  | R99 | 34.907 |
| 2391 | 576 | Specific Absorbtion Rate (SAR) requirements and regulations in different regions |  | 261d? | 1999-01-01 A | 1999-12-31 A | 100% | 1999-01-01 | 1999-12-31 | 261d? |  | start no earlier than 1999-01-01 | T2 | 2088h | 2088h |  | R99 | 34.925 |
| 2392 | 577 | Multi-mode UE issues |  | 261d? | 1999-01-01 A | 1999-12-31 A | 100% | 1999-01-01 | 1999-12-31 | 261d? |  | start no earlier than 1999-01-01 | T2 | 2088h | 2088h |  | R99 | 21.810, 21.910 |
| 2393 | 578 | Provision of fax service in GSM and UMTS |  | 261d? | 1999-01-01 A | 1999-12-31 A | 100% | 1999-01-01 | 1999-12-31 | 261d? |  | start no earlier than 1999-01-01 | T2 | 2088h | 2088h |  | R99 | 22.945 |
| 2394 | 579 | Separating Radio Resources and Mobility Management specific parts of the MS Classmark |  | 261d? | 1999-01-01 A | 1999-12-31 A | 100% | 1999-01-01 | 1999-12-31 | 261d? |  | start no earlier than 1999-01-01 | T2 | 2088h | 2088h |  | R99 | 23.814 |

Notes:
- 2371: -
- 2372: -
- 2373: -
- 2374: Specifies Conformance Tests for a 3G UE to be recognised as 3GPP-standard compliant. A 3GPP-external body, GCF (Global Certification Forum), delivers certificates to prove that a UE has correctly passed tests and is then conform to the 3GPP standard.
- 2375: No CR or new TS/TR approved under this WI
- 2376: -
- 2377: measurement procedures for the conformance test of the UE that contain transmitting characteristics, receiving characteristics and performance requirements in addition to requirements for support of RRM (Radio Resource Management) in FDD mode.
- 2378: measurement procedures for the conformance test of the UE that contain transmitting characteristics, receiving characteristics and performance requirements in addition to requirements for support of RRM (Radio Resource Management) in TDD mode.
- 2379: TS 34.123, composed of three parts, actually specifies the protocol conformance testing for the 3G UE. Part 1 describes the overall test structure.
- 2380: Part 2 contains the applicability of each test case defined as the Implementation Conformance Statement (ICS) proforma, in compliance with the relevant requirements, and in accordance with the relevant guidance given in ISO/IEC 9646-7 and ETS 300 406.
- 2381: Part 3 specifies the protocol conformance testing in TTCN for the 3G UE at the Uu interface. It defines the TTCN test specification and design considerations in Abstract Test Suites based on the test cases specified in prose in part 1.
- 2382: No CR or new TS/TR approved under this WI
- 2383: No CR or new TS/TR approved under this WI
- 2384: -
- 2385: No CR or new TS/TR approved under this WI
- 2386: -
- 2387: Study on requirements for numbering and addressing for UMTS
- 2388: -
- 2389: Moved to CT1 at TSG-T closure
- 2390: Moved to RAN4 at TSG-T closure. TR summarizes differences between international and national standards relevant to IEC60950 and refers to regulations for conformity assessment due to different regulatory environments in different countries / regions.
- 2391: Moved to RAN4 at TSG-T closure.
- 2392: Moved to CT1 at TSG-T closure. Consequences on roaming capabilities and service availability (e.g. handover) of multi-mode UEs while roaming in various regions with various network configurations. Case studies for each of the possible scenarios in specs
- 2393: CP#27: Moved to C1 on closure of T2; see TP-050062. CP#28: C1->C3
- 2394: CP#27: change of WG as a result of closure of CN and T.
